# 3GPP_Release-2000

Schedule from MS Project, 1998-12-07 to 2011-09-16, A marks actual dates.

## Calendars

- Standard: Mon-Fri 08:00-12:00, 13:00-17:00; Sat-Sun off. Exceptions (off unless hours are given): 2000-01-15 08:00-12:00, 13:00-17:00, 2009-05-30 08:00-12:00, 13:00-17:00.

## Resources

| Resource |
| --- |
| NP |
| N1 |
| N2 |
| N3 |
| N4 |
| N5 |
| TP |
| T1 |
| T2 |
| T3 |
| RP |
| R1 |
| R2 |
| R3 |
| R4 |
| SP |
| S1 |
| S2 |
| S3 |
| S4 |
| S5 |
| PCG |
| GP |
| No |
| CN4 |
| ? |
| WG G2 |
| G2 |
| G1 |
| G4 |
| G3 |
| All |
| Generic |
| MLST |
| G5 |
| S3, G2 |
| WG T2 |
| GP,G1 |
| G4,G5 |
| OMA |
| GP-G2 |
| Yes |
| GP, |
| N4, |
| GP, N1 |
| CT5 |
| C5 |
| C1 |
| C4 |
| C3 |
| C6 |
| G1, |
| 4 |
| ct |
| c,s,r |
| CT,RAN,SA |
| G2, |
| G1, G3 |
| CT6 |
| CT1 |
| CT1, CT3, CT4 |
| C1, C3, C4 |
| CP |
| R5 |
| C |
| Rel-8 |
| GP, G2 |
| R1,R4 |
| S5,C1 |
| CT,RAN,SA,GERAN |
| S3,C1,C4 |
| 5 |
| S1,C1,C3,C4,S5 |
| S1,C1,C3,C5 |
| S1,C1,C3,C4 |
| S1,S5 |
| S2,S3 |
| RAN,SA |
| RP,S5 |
| S2,CT |
| S1,CT |
| S1,CT,GERAN |
| S1,C5 |
| S3,CT |
| S4,CT |
| C1,SA |
| S1,S2 |
| S1,S4 |
| S2,S2,S3,CT |
| S2,S3,CT |
| S1,CT,GX |
| S1,S4,CT |
| S2,S2,S3,S5,CT |
| S1,S2,CT |
| S1,S2,S3,CT |
| S1,S2,S3,S5CT |
| S1,S2,S3,S5,CT |
| S2,S5,CT |
| S4,S3 |
| S1,C1 |
| CP,C1 |
| C1,C3 |
| C1,C3,C4 |
| S1,S5,CT |
| C4,C3 |
| CP,RAN,SA,GERAN |
| S1,S2,S3,S5,CP |
| S2,S3,CP |
| S2,CP |
| S1,CP,GX |
| S1,CP |
| S1,S4,CP |
| S1,S2,CP |
| S1,S2,S3,CP |
| S2,S5,CP |
| S3,CP |
| S1,S5,CP |
| RAN,SA,GERAN |
| S1,S2,S3,S5,C1,C3,C4,C6 |
| S2,S3,C1,C3,C4 |
| S2,C4 |
| S2,C1,C3,C4 |
| S2,C1,C4 |
| S2,S3,C1,C4 |
| S1,C1,C4,G2 |
| C1,C4 |
| S1,C1,C3 |
| S1,S4,C1,C3,C4 |
| S1,S2,S3,C1,C3,C4 |
| S2,S5,C3 |
| S1,S2,C1,C4 |
| S2,C1 |
| S2,C1,C3 |
| S3,C1,C3,C4 |
| S1,S5,C1,C3,C4 |
| S2,C3,C4 |
| C3,C1 |
| R2,R4 |
| R2,R5 |
| RP,R5 |
| RP,S5,R5 |
| R1,R5 |
| S1,C1,R5 |
| S1,C1,S4,R5 |
| GERAN |
| G3new |
| G1, G3new |
| C4,C1,C3 |
| R1.R4 |
| R1, R4 |
| R2,R3 |
| C3,C4 |
| S4,C3 |
| S4,C3,C1,C4 |
| S1,S2,C1 |
| S1,S2<C1,C3,C4 |
| S1,S2,C1,C3,C4 |
| S5,C1,C3,C4 |
| GP,C4 |
| C4,C1 |
| S2,S1 |
| RP,SP,GP |
| RP,SP,CP,GP |
| CP,GP,RP,SP |
| GP,C4,S4 |
| S1,C1,C4 |
| S1,S2,C3,C1 |
| R2,R4,R3 |
| CP,GP, RP,SP |
| S2,S1,C1,S5 |
| S2,S1,C1 |
| S1,C1,S4 |
| S1,S2,GP,C4,R2 |
| S1,GP,R2 |
| S1,C6 |
| S1,S2,C1,S4 |
| S2,S3,S5,C1,C3,C4 |
| S2,S5,C1 |
| S2,S3,S5 |
| CP,GP, RP,SP,TP |
| S2,C4,C1 |
| S1,C1,C4,S3 |
| S2,S5 |
| S3,C1 |
| S3,C4 |
| S1,C4 |
| S2,S5,C3,C1 |
| S2,S1,S5,C1,C4 |
| S1,R1,C3 |
| S1,C1,R2 |
| S2,S1,C1,C4 |
| S1,C1,C6 |
| GP,S4,C4,C1,C3 |
| C3,C1,C4 |
| S1,C4,C1 |
| S1,S3 |
| S1,S2,S5,C3,C4 |
| R4,G1 |
| G1,R4 |
| RP,GP |
| R4,GP |
| R3,R2 |
| C6,RP,SP |
| R5,C6 |
| CP,RP,SP |
| RP,SP,CP |
| R3,S5 |
| S1,S2,RP |
| S1,S2,S5,RP |
| S2,S1,RP |
| Rel-9 |
| S3,C6 |
| S1,S2,S3,S5,RP |
| S2,S1,S3 |
| S1,S2,S3 |
| S1,S2,S3,S5 |
| C6,R5 |
| S1,S2,RP,GP |
| S1,S2,S4,S5,RP,GP |
| GP,G2 |
| GP,GP, N1 |
| GP,S2,G1,G2 |
| GP,R2,R3,S2,G1,G2 |
| GP,S2,S5,R2,R3,G2,G1 |
| GP,R3 |
| N4,S2 |
| GP,RP |
| GP,S2,RP |
| G5,G4 |
| G4,R3 |
| S2,R2,R4 |
| S1,S2,R2,R4 |
| GP,S5 |
| S1,S2,S5 |
| R4,R5 |
| R4,R2,R3,R5 |
| S2,S5,N4,RP |
| S1,S2,S3,S5,NP |
| S2,S4,S5 |
| T2,S1,S4,S5 |
| SP,RP |
| S2,RP |
| S1,S2,CP,G2 |
| CP,SP |
| S1,G2 |
| SP,CP |
| S1,S2,S5,C3 |
| S1,C1,S3 |
| G1,G3new |
| C4, C3, C1C4 |
| C4,C3,C1 |
| S1,S2,S3,S5,R2,R3,R4 |
| S1,S2,S3,R2 |
| S2,S3,S5,C4,R2 |
| S1,S5,C1 |
| S1,S2,S3,C1,C3,C4,R2 |
| Ggp |
| S3,S2,C1,C4,G2 G3new |
| R1,R2,R3,R4 |
| R4,R1,R2,R3 |
| R4,R2,R3 |
| S1,C1,C4,R2 |
| R4,R2 |
| S2,C4,R2,R4 |
| S2,C4,R2 |
| S2,S3,S5,C3,C4,R2 |
| S1,S2,S4,T2 |
| S1,S2,S4 |
| S1,S2,S4,R5 |
| S3,S2,C1,C4,G2,G3new |
| GP,C1 |
| S1,S5,C4 |
| S1,S2,S3,S5,R2,R3,R4,GP |
| GP,C4,C3,C1 |
| SMG9 |
| SMG1 |
| SMG2 |
| N3,R5 |
| N1, N2, N4, G1, G2, R3, S1, SMG2 |
| S1,SMG1 |
| SMG1,N4 |
| N1,C1,N4,S1,T2,G2,SMG1,SMG2,SMG3,SMG7,SMG9 |
| SMG1,N2 |
| S1,S2,N2,N4 |
| N4,N2 |
| G1,G2 |
| G1,G2,C1 |
| G1,G2,N1 |
| SMG2, SMG1, SMG3, SMG4, SMG7, SMG9, SMG10, G1, G2, G3, N1, N3, T2 |
| SMG2,G1 |
| S1,G1,G2 |
| SMG1,N1,G1,G2 |
| G2,G1 |
| G1,G2,G3,S1,S2,SMG1,SMG2,SMG7,N1,N2,N3,N4,T2 |
| 23.003, 23.008, 29.060 |
| S1, S2, SMG1, SMG2, SMG12, G2, N1, N2, N4 |
| S1,S2,SMG1,SMG2,SMG12,G2,N1,N2,N4 |
| S1,SMG2,N1,N2,N4 |
| SMG1,T2 |
| S1,N1,N2,N4 |
| S1,S2,N5 |
| SMG2,SMG7,G2,T2 |
| S3,N1,N2,N3 |
| S3,N1,N2,N4 |
| SMG9,T3 |
| SMG2,SMG3,SMG7,G2,N2 |
| SMG2,N1,G1,G2 |
| S1,N2 |
| N1,N3 |
| S2,N1 |
| N1,N2,N4 |
| N2,N1,N4 |
| N2,N4 |
| S1,T3 |
| T2,N3 |
| S3,N2 |
| T2,S1 |
| S1,N4 |
| SMG1,SMG2,SMG7 |
| N1,S1,T1 |
| SMG1,SMG3 |
| N4,S2,N1 |
| S1,S2,SMG1,SMG2,SMG7,G1,G2,G3,N1,N2,N3,N4,T2 |
| SMG1,N3 |
| S1,N3 |
| CP,SP,SMG |
| CP,SP,TP,GP,SMG |
| NP,SP,TP,GP,SMG |
| NP,GP, RP,SP,TP |
| SMG2,SMG1,SMG3,SMG4,SMG7,SMG9,SMG10,G1,G2,G3,N1,N3,T2 |
| S1,N2,N4 |
| S1,S2,S3,C1,C3,C4,R2,R3 |
| R2,R3,R1,R4 |
| R2,R3,R4 |
| R2,R1,R3,R4 |
| S2,C4,R2,R3,R4 |
| S2,C4,R2,R1,R3,R4 |
| S2,S3,S5,C3,C4,R2,R3,R4 |
| R1,R2,R4 |
| R3,R1,R4 |
| S2, |
| S2,G2, |
| S1,S2,G2, |
| S1,S2,G2,R2,R3, |
| S1,S2,C4,G2,R2,R3 |
| S1,S2,N4,G2,R2,R3 |
| S1,S2,SMG1,SMG2,SMG12,G2,N1,N2,N4,R2,R3 |
| S1,SMG1,T2 |
| S1,SMG1,S2 |
| S1,N4,N2 |
| T2,N1,N3 |
| S3,N2,N4 |
| SMG1,SMG2,SMG3,SMG7,SMG9,N1,C1,N4,S1,T2,G2 |
| SMG1,N2,N4 |
| S2,T2,N1,N2,N4 |
| S1,T2 |
| S1,S2,C4 |
| S1,S2,N4,RP |
| S2,N4 |
| S1,S2,N3,N4,RP |
| S1,S2,SMG1,SMG2,SMG12,T2,G2,N1,N2,N4,R2,R3 |
| S1,T2,N1,N3 |
| S1,S2,SMG1,SMG2,SMG12,T2,G2,N1,N2,N3,N4,R2,R3 |
| S1,S2,S3,SMG1,SMG2,SMG12,G2,N1,N2,N4,R2,R3 |
| S1,S2,SMG,G1,G2,G3,N1,N2,N3,N4,T2 |
| S1,S2,SMG,T2,G2,N1,N2,N3,N4,R2,R3 |
| S1,S3,SMG,G1,G2,G3,N1,N2,N3,N4,T2 |
| S1,S3,T2,N2,N4 |
| S1,S2,SMG,T2,G1,G2,G3,N1,N2,N3,N4 |
| G2,S2 |
| T1,R5 |
| R5,T1 |
| S1,S2,S4,T1,R5 |
| S1,S2,S4,S5,T1,RP,GP |
| S1,S2,S3,S5,R2,R3,R4,GP,C1 |
| S1,S2,S3,SMG1,SMG2,SMG12,N1,N2,N4,R2,R3 |
| S1,S2,SMG,T2,N1,N2,N3,N4,R2,R3 |
| NP,SP,TP,SMG |
| S1,S2,SMG,T2,N1,N2,N3,N4 |
| SMG,N1 |
| SMG |
| S1,S2,SMG1,SMG2,SMG7,N1,N2,N3,N4,T2 |
| SMG2,SMG1,SMG3,SMG4,SMG7,SMG9,SMG10,N1,N3,T2 |
| S1,SMG |
| SMG2,SMG7,T2 |
| SMG2,S2 |
| N1,N2,N4,R3,S1,SMG |
| SMG2,SMG3,SMG7,N2 |
| SMG1,SMG2,SMG3,SMG7,SMG9,N1,C1,N4,S1,T2 |
| S1,S2,SMG,N3,N4,RP |
| S1,S2,S4,SMG,N3,N4,RP |
| S2,C1,C4,R2,R1,R3,R4 |
| R2,S2,S4 |
| G3new,R5 |
| GP,R4 |
| S2,S4,R2 |
| SP,GP |
| RP,SP |
| S2,S1,S3,S5 |
| S3,S1 |
| N4,N1,N2,S2 |
| S2,G1,G2,R2,R3 |
| S2,G1,G2 |
| G1,G2,R2,R3 |
| N4,T3 |
| S3,S2,N1,N4,T3,OMA |
| T2,S1,S4,S5,OMA |
| S2,N3 |
| S4,S1 |
| N4,N3,S1 |
| R5,G3new |
| R4,R2,R1 |
| S2,R2 |
| C3, C4,C1 |
| S3,C1,C4,C3 |
| C1,C4,C3 |
| S2,C1,C4,C3 |
| R3,R5 |
| S1,S2,C3 |
| R1,R2 |
| S3,C1,C4,G2,G3new |
| R1,R3 |
| GP,N1 |
| R1,R2,R3 |
| R3,R2,R4 |
| R4,R3 |
| S1,S2,R2,R3 |
| S1,S2,S3,C1,C3,C4,R2,R3,R5 |
| S2,S1,S5 |

## Schedule

| ID | WBS | Task | Type | Duration | Start | Finish | Complete | Remaining | Baseline start | Baseline finish | Baseline duration | Total slack | Constraint | Resources | Work | Actual work | Text6 | Text1 | Text2 | Text4 | Text5 | Text7 | Text8 | Text9 | Text12 |
| --- | --- | --- | --- | --- | --- | --- | --- | --- | --- | --- | --- | --- | --- | --- | --- | --- | --- | --- | --- | --- | --- | --- | --- | --- | --- |
| 1 | 1 | Version 2010 Mar 24 |  | 3318d? | 1998-12-07 | 2011-08-22 |  |  | 1998-12-07 | 2011-08-22 | 3318d? | 19d | start no earlier than 1998-12-07 |  |  |  |  |  |  |  |  |  |  |  |  |
| 2 | 2 | 2 SA1 Rel-10 exceptions to 06/2010 (TEI10: UDC Data Model, Access Control for CSFB) | milestone | 0d? | 1998-12-07 | 1998-12-07 |  |  | 1998-12-07 | 1998-12-07 | 0d? | 3337d | finish no earlier than 1998-12-07 |  |  |  |  |  |  |  |  |  |  |  |  |
| 3 | 3 | 4 old (GERAN) + 1 RAN + 5 SA5 Rel-9 exceptions to 06/2010 | milestone | 0d | 1998-12-07 | 1998-12-07 |  |  | 1998-12-07 | 1998-12-07 | 0d | 3337d | finish no earlier than 1998-12-07 |  |  |  |  |  |  |  |  |  |  |  |  |
| 4 | 4 | "CTRL + a" to display all the 3GPP fields | milestone | 0d | 1998-12-07 | 1998-12-07 |  |  | 1998-12-07 | 1998-12-07 | 0d | 3337d | finish no earlier than 1998-12-07 |  |  |  |  |  |  |  |  |  |  |  |  |
| 5 | 5 | Gantt: dark blue=done; light blue=to be done; grey: previous values; black=summary | milestone | 0d? | 1998-12-07 | 1998-12-07 |  |  | 1998-12-07 | 1998-12-07 | 0d? | 3337d | finish no earlier than 1998-12-07 |  |  |  |  |  |  |  |  |  |  |  |  |
| 6 | 6 | Release 11 Features | milestone | 0d? | 2000-01-01 | 2000-01-01 |  |  | 2000-01-01 | 2000-01-01 | 0d? | 3057d |  | SP |  |  | Rel-11 |  |  |  |  |  |  |  |  |
| 7 | 7 | **Advanced IP Interconnection of Services** |  | 187d | 2010-03-25 | 2010-12-10 |  |  | 2010-03-25 | 2010-12-10 | 187d | 200d |  | S1 | 2992h |  | Rel-11 | IPXS | PCG-24 | Telefónica | Chris Friel | SP-47 | Alain |  |  |
| 8 | 7.1 | Stage 1 for IPXS |  | 187d | 2010-03-25 | 2010-12-10 |  |  | 2010-03-25 | 2010-12-10 | 187d | 200d | finish no earlier than 2010-12-10 | S1 | 1496h |  | Rel-11 | IPXS | PCG-24 | Telefónica | Chris Friel | SP-47 | Alain |  |  |
| 9 | 8 | Release 11 Studies | milestone | 0d? | 2000-01-01 | 2000-01-01 |  |  | 2000-01-01 | 2000-01-01 | 0d? | 3057d | start no earlier than 2000-01-01 | SP |  |  | Rel-11 |  |  |  |  |  |  |  |  |
| 10 | 9 | Study on IMS based Peer-to-Peer Content Distribution Services |  | 196d? | 2009-05-12 A | 2010-06-24 | 70% | 58.8d? | 2009-05-12 | 2010-06-24 | 196d? | 321d | finish no earlier than 2010-06-24 | S1 | 1568h | 1097.6h | Rel-11 | FS_IMS_P2P | PCG-23 | China Mobile | Li Gang (ligangyf@chinamobile.com) | SP-45 | Alain |  |  |
| 11 | 10 | Study on Non Voice Emergency Services |  | 206d? | 2009-12-10 A | 2010-09-23 | 10% | 185.4d? | 2009-12-10 | 2010-09-23 | 206d? | 256d | start no earlier than 2009-12-10 | S1 | 1648h | 164.8h | Rel-11 | FS_NOVES | PCG-24 | Qualcomm | dwilliams@qualcomm.com | SP-46 | Alain |  |  |
| 12 | 11 | Study on UICC/USIM enhancements |  | 206d? | 2009-12-10 A | 2010-09-23 | 5% | 195.7d? | 2009-12-10 | 2010-09-23 | 206d? | 256d | start no earlier than 2009-12-10 | S1 | 1648h | 82.4h | Rel-11 | FS_U2e | PCG-24 | Giesecke & Devrient | Ilario Macchi | SP-46 | Alain |  |  |
| 13 | 12 | Study on Alternatives to E.164 for Machine-Type Communications |  | 191d? | 2010-03-25 | 2010-12-16 |  |  | 2010-03-25 | 2010-12-16 | 191d? | 196d | finish no earlier than 2010-12-16 | S1 | 1528h |  | Rel-11 | FS_AMTC | PCG-24 | T-Mobile USA | gary.jones@T-Mobile.com | SP-47 | Alain |  |  |
| 14 | 13 | Release 10 Features | milestone | 0d? | 2000-01-01 | 2000-01-01 |  |  | 2000-01-01 | 2000-01-01 | 0d? | 3057d |  | CP,RP,SP |  |  | Rel-10 |  |  |  |  |  |  |  |  |
| 15 | 14 | **Extended H(e)NB features** |  | 337d? | 2008-12-11 A | 2010-03-25 A | 100% |  | 2008-12-11 | 2010-03-25 | 337d? |  |  | S1,S2 | 6432h | 6432h | Rel-10 | EHNBF | PCG-23 | NEC | joerg.swetina@nw.neclab.eu | SP-45 | Alain |  |  |
| 16 | 14.1 | Stage 1 of Extended H(e)NB features |  | 131d? | 2009-09-24 A | 2010-03-25 A | 100% |  | 2009-09-24 | 2010-03-25 | 131d? |  | finish no earlier than 2010-03-25 | S1 | 1048h | 1048h | Rel-10 | EHNBF | PCG-23 | NEC | joerg.swetina@nw.neclab.eu | SP-45 | Alain |  |  |
| 17 | 14.2 | IMS aspects of Architecture for Home NodeB |  | 336d? | 2008-12-11 A | 2010-03-25 A | 100% |  | 2008-12-11 | 2010-03-25 | 336d? |  | finish no earlier than 2010-03-25 | S2 | 2688h | 2688h | Rel-10 | EHNB-IMS | PCG-22 | Alcatel-Lucent | Nicolas Drevon | SP-42 | Maurice |  |  |
| 18 | 15 | **Network Improvements for Machine-Type Communications** |  | 658d? | 2008-09-18 A | 2011-03-25 | 47% | 346.3d? | 2008-09-18 | 2011-03-25 | 658d? | 125d |  | S1,S2,S3 | 13121.2h | 6215.69h | Rel-10 | NIMTC | PCG-21 | KPN | Toon Norp (toon.norp AT tno.nl) | SP-41 | Alain |  |  |
| 19 | 15.1 | Stage 1 for NIMTC |  | 397d? | 2008-09-18 A | 2010-03-25 A | 100% |  | 2008-09-18 | 2010-03-25 | 397d? |  | finish no earlier than 2009-12-10 | S1 | 3176h | 3176h | Rel-10 | NIMTC | PCG-21 | KPN | Toon Norp (toon.norp AT tno.nl) | SP-41 | Alain |  |  |
| 20 | 15.2 | Stage 2 for NIMTC |  | 392d? | 2009-09-24 A | 2011-03-25 | 15% | 333.2d? | 2009-09-24 | 2011-03-25 | 392d? | 125d | finish no earlier than 2011-03-25 | S2 | 3136h | 470.4h | Rel-10 | NIMTC | PCG-23 | Samsung | Erik Guttman (erik.guttman@partner.samsung.com) | SP-45 | Maurice |  |  |
| 21 | 15.3 | Security for NIMTC |  | 193.15d? | 2009-12-10 A | 2010-09-23 | 5% | 183.69d? | 2009-12-10 | 2010-09-23 | 193.15d? | 256d | finish no earlier than 2010-09-23 | S3 | 1545.2h | 75.66h | Rel-10 | NIMTC | PCG-24 | Samsung | Rajavelsamy R (rajvel@samsung.com) | SP-46 | Dionisio |  |  |
| 22 | 16 | **Deleted - GTP-based S8 chaining** |  | 337d? | 2008-12-11 A | 2010-03-25 A | 100% |  | 2008-12-11 | 2010-03-25 | 337d? |  |  | S2 | 5392h | 5392h | Rel-10 | GTPchaining | PCG-22 | Huawei | Haining Wang (wanghaining@huawei.com) | SP-42 | Maurice | PCG-24 | SP-47 |
| 23 | 16.1 | Deleted - Stage 2 for GTPchaining |  | 337d? | 2008-12-11 A | 2010-03-25 A | 100% |  | 2008-12-11 | 2010-03-25 | 337d? |  | finish no earlier than 2010-03-25 | S2 | 2696h | 2696h | Rel-10 | GTPchaining | PCG-22 | Huawei | Haining Wang (wanghaining@huawei.com) | SP-42 | Maurice | PCG-24 | SP-47 |
| 24 | 17 | Multi Access PDN Connectivity |  | 401d? | 2009-03-13 A | 2010-09-23 | 75% | 99.5d? | 2009-03-13 | 2010-09-23 | 401d? | 256d | finish no earlier than 2010-09-23 | S2 | 3208h | 2412h | Rel-10 | MAPCON | PCG-22 | Telecom Italia | ivano.guardini@telecomitalia.it | SP-43 | Maurice |  |  |

Notes:
- 1: -
- 2: -
- 3: -
- 4: -
- 5: -
- 6: -
- 7: Triggered by Rel-10 TR 22.893 UID_380083 Study on advanced requirements for IP interconnect (FS_IPXS)
- 8: - / Text3: 22.101, 22.228
- 9: -
- 10: SP#47 TR 22.906 v100 for Information / Text3: 22.906
- 11: - / Text3: 22.8xy
- 12: Triggered by GSMA Smart SIM and 3GNBK projects, and to evolve from traditional USAT to multimedia USIM toolkit support, particularly to Smart Card Web Server / Text3: 22.8xy
- 13: Determine an alternative to E.164 for identifying individual devices and route messages between those devices / Text3: 22.9xy
- 14: -
- 15: SP#47 Stage 1/2 completed. Items beyond Rel-9 UID_400035 Enhanced Home NodeB / eNodeB (EHNB)
- 16: SP#47 completed / Text3: 22.220
- 17: SP#47 completed. TR concluded (chosen solution has no normative impacts) / Text3: new 23.832
- 18: SP#47 Stage 1 completed. Triggered by Rel-8 UID_7027 Study on Facilitating Machine to Machine Communication in GSM and UMTS (FS_M2M) TR 22.868
- 19: SA#47 completed / Text3: new 22.368
- 20: SP#47 completion 09/10=>03/11 / Text3: new 23.888 (Architectural Enhancements for machine-type communications)
- 21: SP#46 updated WID SP-090658=>SP-090832 (added SA3 part) / Text3: new 33.868
- 22: SP#47 work stopped (depending on ongoing related CT4 work). Stage 1 in UID_320022 Rel-8 Requirements for evolution of the 3GPP system architecture (AIPN-SAE): 22.278, 22.011, 22.246
- 23: SP#47 work stopped / Text3: 23.402
- 24: SP#47 completion 03/10=>09/10. Triggered by TR 23.861 UID_410043 FS_MAPIM. Stage 1 in Rel-9 22.278 (6.2 - IP session control) / Text3: 23.401, 23.402, 23.237

| ID | WBS | Task | Duration | Start | Finish | Complete | Remaining | Baseline start | Baseline finish | Baseline duration | Total slack | Constraint | Resources | Work | Actual work | Text1 | Text2 | Text4 | Text6 | Text7 | Text8 |
| --- | --- | --- | --- | --- | --- | --- | --- | --- | --- | --- | --- | --- | --- | --- | --- | --- | --- | --- | --- | --- | --- |
| 25 | 18 | **IMS Service Continuity – Inter Device Transfer enhancements** | 467d? | 2009-06-04 A | 2011-03-18 | 47% | 249.11d? | 2009-06-04 | 2011-03-18 | 467d? | 130d |  | S1,S2,C1 | 9600h | 4424h | IMS_SC_eIDT | PCG-23 | Huawei | Rel-10 | SP-44 | Alain |
| 26 | 18.1 | Stage 1 - IMS Service Continuity – Inter Device Transfer enhancements | 211d? | 2009-06-04 A | 2010-03-25 A | 100% |  | 2009-06-04 | 2010-03-25 | 211d? |  | finish no earlier than 2010-03-25 | S1 | 1688h | 1688h | IMS_SC_eIDT | PCG-23 | Huawei | Rel-10 | SP-44 | Alain |
| 27 | 18.2 | Stage 2 - IMS Inter-UE Transfer enhancements | 261d? | 2009-09-24 A | 2010-09-23 | 50% | 130d? | 2009-09-24 | 2010-09-23 | 261d? | 256d | finish no earlier than 2010-09-23 | S2 | 2088h | 1048h | IMS_SC_eIDT | PCG-23 | Huawei | Rel-10 | SP-45 | Maurice |
| 28 | 18.3 | Stage 3 - IMS Inter-UE Transfer enhancements | 261d? | 2010-03-19 | 2011-03-18 |  |  | 2010-03-19 | 2011-03-18 | 261d? | 130d | start no earlier than 2010-03-19 | C1 | 2088h |  | IMS_SC_eIDT | PCG-24 | Huawei | Rel-10 | CP-47 | Frederic |
| 29 | 19 | **IP-Short-Message-Gateway enhancements for CPM-SMS Interworking** | 182d? | 2009-09-24 A | 2010-06-04 | 88% | 21.28d? | 2009-09-24 | 2010-06-04 | 182d? | 335d |  | S1,S2,C3 | 4592.8h | 3128.4h | CPM-SMS | PCG-23 | China Mobile | Rel-10 | SP-45 | Alain |
| 30 | 19.1 | Stage 1 for CPM-SMS | 131d? | 2009-09-24 A | 2010-03-25 A | 100% |  | 2009-09-24 | 2010-03-25 | 131d? |  | finish no earlier than 2010-03-25 | S1 | 1048h | 1048h | CPM-SMS | PCG-23 | China Mobile | Rel-10 | SP-45 | Alain |
| 31 | 19.2 | Stage 2 for CPM-SMS | 130.1d? | 2009-09-24 A | 2010-03-25 A | 100% |  | 2009-09-24 | 2010-03-25 | 130.1d? |  | finish no earlier than 2010-03-25 | S2 | 1040.8h | 1040.8h | CPM-SMS | PCG-23 | Orange | Rel-10 | SP-45 | Maurice |
| 32 | 19.3 | Stage 3 for CPM-SMS | 131d? | 2009-12-04 A | 2010-06-04 | 65% | 45.85d? | 2009-12-04 | 2010-06-04 | 131d? | 335d | finish no earlier than 2010-06-04 | C3 | 1048h | 681.2h | CPM-SMS | PCG-24 | Ericsson | Rel-10 | CP-46 | Gwiho |
| 33 | 20 | **Completion of Communications on Not Logged-in** | 252d? | 2009-09-24 A | 2010-09-10 | 1% | 250.02d? | 2009-09-24 | 2010-09-10 | 252d? | 265d |  | S1,C1 | 3032h | 16h | CCNL | PCG-23 | Deutsche Telekom | Rel-10 | SP-45 | Alain |
| 34 | 20.1 | Stage 1 for CCNL | 1d? | 2009-09-24 A | 2009-09-24 A | 100% |  | 2009-09-24 | 2009-09-24 | 1d? |  | start no earlier than 2009-09-24 | S1 | 8h | 8h | CCNL | PCG-23 | Deutsche Telekom | Rel-10 | SP-45 | Alain |
| 35 | 20.2 | Stage 3 for CCNL | 126d? | 2010-03-19 | 2010-09-10 |  |  | 2010-03-19 | 2010-09-10 | 126d? | 265d | finish no earlier than 2010-09-10 | C1 | 1008h |  | CCNL | PCG-24 | Deutsche Telekom | Rel-10 | CP-47 | Frederic |
| 36 | 21 | **Local IP Access and Selected Internet IP Traffic Offload** | 321d? | 2009-09-24 A | 2010-12-16 | 22% | 250.63d? | 2009-09-24 | 2010-12-16 | 321d? | 196d |  | S2,S1,S3,S5 | 14016h | 2509.6h | LIPA_SIPTO | PCG-23 | Huawei, China Mobile | Rel-10 | SP-45 | Maurice |
| 37 | 21.1 | TR on LIPA_SIPTO | 261d? | 2009-09-24 A | 2010-09-23 | 60% | 104.4d? | 2009-09-24 | 2010-09-23 | 261d? | 256d | finish no earlier than 2010-09-23 | S2 | 2088h | 1252.8h | LIPA_SIPTO | PCG-23 | Huawei, China Mobile | Rel-10 | SP-45 | Maurice |
| 38 | 21.2 | Stage 1 for LIPA_SIPTO | 131d? | 2009-09-24 A | 2010-03-25 A | 100% |  | 2009-09-24 | 2010-03-25 | 131d? |  | finish no earlier than 2010-03-25 | S1 | 1048h | 1048h | LIPA_SIPTO | PCG-23 | Huawei, China Mobile | Rel-10 | SP-45 | Alain |
| 39 | 21.3 | Stage 2 for LIPA_SIPTO | 261d? | 2009-09-24 | 2010-09-23 |  |  | 2009-09-24 | 2010-09-23 | 261d? | 256d | finish no earlier than 2010-09-23 | S2 | 2088h |  | LIPA_SIPTO | PCG-23 | Huawei, China Mobile | Rel-10 | SP-45 | Maurice |
| 40 | 21.4 | Security for LIPA_SIPTO | 256d? | 2009-09-24 A | 2010-09-16 | 5% | 243.2d? | 2009-09-24 | 2010-09-16 | 256d? | 261d | finish no earlier than 2010-09-16 | S3 | 2048h | 102.4h | LIPA_SIPTO | PCG-23 | Huawei, Qualcomm | Rel-10 | SP-45 | Dionisio |
| 41 | 21.5 | OAM&P for LIPA_SIPTO | 256d? | 2009-09-24 | 2010-09-16 |  |  | 2009-09-24 | 2010-09-16 | 256d? | 261d | finish no earlier than 2010-09-16 | S5 | 2048h |  | LIPA_SIPTO | PCG-23 | Huawei, China Mobile | Rel-10 | SP-45 | Dionisio |
| 42 | 21.6 | Charging for LIPA_SIPTO | 266d? | 2009-12-10 A | 2010-12-16 | 5% | 252.7d? | 2009-12-10 | 2010-12-16 | 266d? | 196d | finish no earlier than 2010-12-16 | S5 | 2128h | 106.4h | LIPA_SIPTO | PCG-24 | Huawei, China Mobile | Rel-10 | SP-46 | Dionisio |
| 43 | 22 | **IP Flow Mobility and seamless WLAN offload** | 386d? | 2009-09-24 A | 2011-03-17 | 39% | 233.99d? | 2009-09-24 | 2011-03-17 | 386d? | 131d |  | S2,S1,S5 | 7672h | 2253.2h | IFOM | PCG-23 | Qualcomm | Rel-10 | SP-45 | Maurice |
| 44 | 22.1 | Stage 1 for IFOM | 56d? | 2009-09-24 A | 2009-12-10 A | 100% |  | 2009-09-24 | 2009-12-10 | 56d? |  | finish no earlier than 2009-12-10 | S1 | 448h | 448h | IFOM | PCG-23 | Qualcomm | Rel-10 | SP-45 | Alain |
| 45 | 22.2 | Stage 2 for IFOM | 261d? | 2009-09-24 A | 2010-09-23 | 65% | 91.35d? | 2009-09-24 | 2010-09-23 | 261d? | 256d | finish no earlier than 2010-09-23 | S2 | 2088h | 1357.2h | IFOM | PCG-23 | Qualcomm | Rel-10 | SP-45 | Maurice |
| 46 | 22.3 | Charging for IFOM | 256d? | 2010-03-25 | 2011-03-17 |  |  | 2010-03-25 | 2011-03-17 | 256d? | 131d | finish no earlier than 2011-03-17 | S5 | 2048h |  | IFOM | PCG-24 | Alcatel-Lucent | Rel-10 | SP-47 | Dionisio |
| 47 | 23 | **Enabling Coder Selection and Rate Adaptation for UTRAN and E-UTRAN for Load Adaptive Applications** | 257d? | 2009-09-24 A | 2010-09-17 | 30% | 179.9d? | 2009-09-24 | 2010-09-17 | 257d? | 260d |  | S2,S4,R2 | 6168h | 1850.4h | ECSRA_LAA | PCG-23 | Qualcomm | Rel-10 | SP-45 | Maurice |
| 48 | 23.1 | TR on ECSRA_LAA | 257d? | 2009-09-24 A | 2010-09-17 | 60% | 102.8d? | 2009-09-24 | 2010-09-17 | 257d? | 260d | finish no earlier than 2010-09-17 | S2,S4,R2 | 2056h | 1233.6h | ECSRA_LAA | PCG-23 | Qualcomm | Rel-10 | SP-45 | Maurice |
| 49 | 23.2 | Stage 2 for ECSRA_LAA | 257d? | 2009-09-24 | 2010-09-17 |  |  | 2009-09-24 | 2010-09-17 | 257d? | 260d | finish no earlier than 2010-09-17 | S2 | 2056h |  | ECSRA_LAA | PCG-23 | Qualcomm | Rel-10 | SP-45 | Maurice |

Notes:
- 25: SP#47 Stage 1 completed. Rel-9 set Inter-Device Transfer requirements UID_410033 (IMS_SCC-IDT). Adding additional scenarios and requirements for IDT. / Text5: Amar Deol (adeol@huawei.com)
- 26: SA#47 completed / Text3: 22.228 / Text5: Amar Deol (adeol@huawei.com)
- 27: SP#47 completion 06/10=>09/10, WID updated SP-090613=>??? / Text3: 23.237, 23.292, new 23.831 / Text5: Lee Valerius (lvalerius@huawei.com)
- 28: - / Text3: 24.216, 24.229, 24.237 / Text5: georg.mayer@huawei.com
- 29: SP#47 Stage 1 completed. IP-SM-GW enhancements for interworking with OMA CPM / Text5: Qing Huang
- 30: SA#47 completed. External requirements (Stage 1 in OMA-RD-CPM-V1_0-20090310-C) / Text3: 22.340 / Text5: Qing Huang
- 31: SP#47 completed / Text3: 23.204, new TR 23.824 / Text5: Antoine Mouquet
- 32: Linked to Rel-8 UID_340031 Service-Level Interworking for Messaging Services (MESSIW) 23.204 / Text3: 29.311 / Text5: Jan Holm
- 33: SP#45 Stage 1 completed / Text5: Kurt Bischinger
- 34: SP#45 Stage 1 completed / Text3: 22.173 CR#0056r1 Call Completion on Not Logged in (CCNL) / Text5: Kurt Bischinger
- 35: - / Text3: 24.173, 24.642 / Text5: martin.huelsemann@telekom.de
- 36: SP#47 Stage 1 completed. UID_400035 Enhanced Home NodeB/eNodeB (EHNB) formerly covered Local IP Access to Internet and Local access to Home Network from the Home NodeB/eNodeB Features now covered by this WI / Text5: patrice.hede@huawei.com, Tao Sun (suntao@chinamobile.com)
- 37: SP#47 completion 06/10=090/10 / Text3: new 23.829 / Text5: patrice.hede@huawei.com, Tao Sun (suntao@chinamobile.com)
- 38: SA#47 completed / Text3: 22.101, 22.220 / Text5: Amar Deol (adeolf@huawei.com), Gang Li (ligangyf@chinamobile.com)
- 39: SP#46 completion 06/10=>09/10 / Text3: 23.060, 23.203, 23.401 / Text5: patrice.hede@huawei.com, Tao Sun (suntao@chinamobile.com)
- 40: - / Text3: 33.102, 33.107, 33.108, 33.320, 33.401 / Text5: Marcus Wong (mwong@huawei.com), Brian Rosenberg (bmr@qualcomm.com)
- 41: SP#46 updated WID SP-090618=>SP-090761 (added SA5 aspects) / Text3: 32.101, 32.102, 32.405, 32.425, 32.452, 32.453, 32.581, 32.582, 32.583, 32.584, 32.591, 32.592, 32.593, 32.594, 32.64x, 32.76x / Text5: Zou Lan (zlan@huawei.com), Chen Gang (chengang@chinamobile.com)
- 42: SP#46 updated WID SP-090618=>SP-090761 (added SA5 aspects) / Text3: 32.240, 32.251, 32.298, 32.299 / Text5: shan.mingjun@huawei.com, Ai Chen (chenai@chinamobile.com)
- 43: SP#47 WID updated SP-090804=>SP-100089 (Added SA5 Charging). Triggered by Rel-10 TR 23.861 (UID_410043 Study on Multi Access PDN connectivity and IP flow mobility - MAPIM) / Text5: Gerardo Giaretta (gerardo@qualcomm.com)
- 44: SP#46 Stage 1 completed / Text3: 22.278 / Text5: David Williams (dwilliam@qualcomm.com)
- 45: SP#47 completion 06/10=>09/10 / Text3: 23.203, 23.402, new TS 23.261 / Text5: Gerardo Giaretta (gerardo@qualcomm.com)
- 46: - / Text3: 32.240, 32.251, 32.252, 32.298, 32.299 / Text5: maryse.gardella@alcatel-lucent.com
- 47: Triggered by Rel-9 UID_440013 Vocoder rate adaptation for LTE / Text5: AC Mahendran (ac@qualcomm.com)
- 48: SP#47 completion 06/10=>09/10 / Text3: new 23.860 / Text5: AC Mahendran (ac@qualcomm.com)
- 49: SP#46 completion 06/10=>09/10 / Text3: 23.060, 23.203, 23.228, 23.401 / Text5: AC Mahendran (ac@qualcomm.com)

| ID | WBS | Task | Duration | Start | Finish | Complete | Remaining | Baseline start | Baseline finish | Baseline duration | Total slack | Constraint | Resources | Work | Actual work | Text1 | Text2 | Text4 | Text6 | Text7 | Text8 | Text5 |
| --- | --- | --- | --- | --- | --- | --- | --- | --- | --- | --- | --- | --- | --- | --- | --- | --- | --- | --- | --- | --- | --- | --- |
| 50 | 24 | **Support BroadBand Forum (BBF) Accesses Interworking** | 331d? | 2009-12-10 A | 2011-03-17 | 11% | 295.72d? | 2009-12-10 | 2011-03-17 | 331d? | 131d |  | S2,S1 | 8352h | 890.25h | BBAI | PCG-24 | Ericsson | Rel-10 | SP-46 | Alain |  |
| 51 | 24.1 | Stage 1 for BBAI | 76d? | 2009-12-10 A | 2010-03-25 A | 100% |  | 2009-12-10 | 2010-03-25 | 76d? |  | start no earlier than 2009-12-10 | S1 | 608h | 608h | BBAI | PCG-24 | Ericsson | Rel-10 | SP-46 | Alain | Peter Bleckert |
| 52 | 24.2 | TR on Stage 2 for BBAI | 255d? | 2010-03-26 | 2011-03-17 |  |  | 2010-03-26 | 2011-03-17 | 255d? | 131d | finish no earlier than 2011-03-17 | S2 | 2040h |  | BBAI | PCG-24 | Ericsson, Huawei | Rel-10 | SP-47 | Maurice | Stefan Rommer, Marco Spini |
| 53 | 24.3 | Stage 2 Building Block I | 130d? | 2010-03-26 | 2010-09-23 |  |  | 2010-03-26 | 2010-09-23 | 130d? | 256d | finish no earlier than 2010-09-23 | S2 | 1040h |  | BBAI | PCG-24 | Ericsson | Rel-10 | SP-47 | Maurice | Stefan Rommer |
| 54 | 24.4 | Stage 2 Building Block II | 126d? | 2010-09-23 | 2011-03-17 |  |  | 2010-09-23 | 2011-03-17 | 126d? | 131d | start no earlier than 2010-09-23 | S2 | 1008h |  | BBAI | PCG-24 | Ericsson | Rel-10 | SP-47 | Maurice | Stefan Rommer |
| 55 | 24.5 | Stage 2 Building Block III | 126d? | 2010-09-23 | 2011-03-17 |  |  | 2010-09-23 | 2011-03-17 | 126d? | 131d | start no earlier than 2010-09-23 | S2 | 1008h |  | BBAI | PCG-24 | Huawei | Rel-10 | SP-47 | Maurice | Marco Spini |
| 56 | 25 | Optimal Media Routeing | 76d? | 2009-12-10 A | 2010-03-25 A | 100% |  | 2009-12-10 | 2010-03-25 | 76d? |  |  | S2 | 608h | 608h | OMR | PCG-24 | Alcatel-Lucent | Rel-10 | SP-46 | Maurice | andy.bennett@alcatel-lucent.com |
| 57 | 26 | Enhancedments for Multimedia Priority Service | 131d? | 2009-12-10 A | 2010-06-10 | 15% | 111.35d? | 2009-12-10 | 2010-06-10 | 131d? | 331d | finish no earlier than 2010-06-10 | S2 | 1048h | 157.2h | eMPS | PCG-24 | Telcordia, NTT DoCoMo | Rel-10 | SP-46 | Maurice | Vijay Varma, Katsutoshi Nishida |
| 58 | 27 | **IMS Emergency Session Enhancements** | 56d? | 2010-03-25 A | 2010-06-10 | 2% | 55.02d? | 2010-03-25 | 2010-06-10 | 56d? | 331d |  | S2,S1 | 904h | 15.86h | IESE | PCG-24 | Deutsche Telekom, T-Mobile | Rel-10 | SP-47 | Maurice | Michele Zarri |
| 59 | 27.1 | IMS Emergency Session Enhancements | 1d? | 2010-03-25 A | 2010-03-25 A | 100% |  | 2010-03-25 | 2010-03-25 | 1d? |  | start no earlier than 2010-03-25 | S1 | 8h | 8h | IESE | PCG-24 | Deutsche Telekom, T-Mobile | Rel-10 | SP-47 | Alain | Kurt Bischinger |
| 60 | 27.2 | IMS Emergency Session Enhancements | 56d? | 2010-03-25 | 2010-06-10 |  |  | 2010-03-25 | 2010-06-10 | 56d? | 331d | finish no earlier than 2010-06-10 | S2 | 448h |  | IESE | PCG-24 | Deutsche Telekom, T-Mobile | Rel-10 | SP-47 | Maurice | Michele Zarri |
| 61 | 28 | EEA3 and EIA3 (new Encryption & Integrity EPS security algorithms) | 401d? | 2009-06-04 A | 2010-12-16 | 10% | 360.9d? | 2009-06-04 | 2010-12-16 | 401d? | 196d | finish no earlier than 2010-12-16 | S3 | 3208h | 320.8h | EEA3_EIA3 | PCG-23 | CATR | Rel-10 | SP-44 | Dionisio | Yuan Qi, yuanqi@mail.ritt.com.cn |
| 62 | 29 | Lawful Interception in the 3GPP Rel-10 | 191d? | 2010-03-25 | 2010-12-16 |  |  | 2010-03-25 | 2010-12-16 | 191d? | 196d | start no earlier than 2010-03-25 | S3 | 1528h |  | LI10 | PCG-24 | PIDS, Nortel | Rel-10 | SP-47 | Dionisio | Koen Jaspers, Ronald Ryan |
| 63 | 30 | **Codec for Enhanced Voice Services** | 261d? | 2010-03-25 A | 2011-03-24 |  | 260d? | 2010-03-25 | 2011-03-24 | 261d? | 126d |  | S4,S1 | 4184h | 15.97h | EVS_codec | PCG-24 | Huawei | Rel-10 | SP-47 | Paolo | anisse.taleb@huawei.com |
| 64 | 30.1 | Stage 1 for EVS_codec | 1d? | 2010-03-25 A | 2010-03-25 A | 100% |  | 2010-03-25 | 2010-03-25 | 1d? |  | start no earlier than 2010-03-25 | S1 | 8h | 8h | EVS_codec | PCG-24 | Huawei | Rel-10 | SP-47 | Paolo | anisse.taleb@huawei.com |
| 65 | 30.2 | Codec for Enhanced Voice Services | 261d? | 2010-03-25 | 2011-03-24 |  |  | 2010-03-25 | 2011-03-24 | 261d? | 126d | finish no earlier than 2011-03-24 | S4 | 2088h |  | EVS_codec | PCG-24 | Huawei | Rel-10 | SP-47 | Paolo | anisse.taleb@huawei.com |
| 66 | 31 | Optimization of IMS based PSS and MBMS User Service | 191d? | 2010-03-25 | 2010-12-16 |  |  | 2010-03-25 | 2010-12-16 | 191d? | 196d | start no earlier than 2010-03-25 | S4 | 1528h |  | OPT_IMS_PSS_MBMS_US | PCG-24 | Ericsson | Rel-10 | SP-47 | Paolo | markus.kampmann@ericsson.com |
| 67 | 32 | HTTP-based Streaming and Download Services | 191d? | 2010-03-25 | 2010-12-16 |  |  | 2010-03-25 | 2010-12-16 | 191d? | 196d | start no earlier than 2010-03-25 | S4 | 1528h |  | HTTP_SDS | PCG-24 | Qualcomm | Rel-10 | SP-47 | Paolo | Thomas Stockhammer (c_tstock@qualcomm.com) |
| 68 | 33 | **OAM&P 10** | 332d? | 2009-12-10 A | 2011-03-18 | 3% | 320.63d? | 2009-12-10 | 2011-03-18 | 332d? | 130d |  | S5 | 30216h | 1084.7h | OAM10 | PCG-24 |  | Rel-10 | SP-46 | Dionisio |  |
| 69 | 33.1 | **Network Infrastructure Management** | 332d? | 2009-12-10 A | 2011-03-18 | 5% | 316.56d? | 2009-12-10 | 2011-03-18 | 332d? | 130d |  | S5 | 8368h | 389.1h | OAM10-NIM | PCG-24 |  | Rel-10 | SP-46 | Dionisio |  |
| 70 | 33.1.1 | Common RAT Network Resource Model (NRM) | 332d? | 2009-12-10 A | 2011-03-18 | 10% | 298.8d? | 2009-12-10 | 2011-03-18 | 332d? | 130d | finish no earlier than 2011-03-18 | S5 | 2656h | 265.6h | RAT_NRM_common | PCG-24 | Ericsson | Rel-10 | SP-46 | Dionisio | Robert Petersen |
| 71 | 33.1.2 | IRP Solution Set specification organisation improvements | 191d? | 2010-03-25 | 2010-12-16 |  |  | 2010-03-25 | 2010-12-16 | 191d? | 196d | finish no earlier than 2010-12-16 | S5 | 1528h |  | OAM-IRP-SS | PCG-24 | Nokia Siemens Networks, Huawei | Rel-10 | SP-47 | Dionisio | Jörg Schmidt (joerg@cox.net), Lan Zou (zlan@huawei.com) |
| 72 | 33.1.3 | Service Oriented Architecture (SOA) for IRP continuation from Rel-9 | 191d? | 2010-03-25 | 2010-12-16 |  |  | 2010-03-25 | 2010-12-16 | 191d? | 196d | finish no earlier than 2010-12-16 | S5 | 1528h |  | OAM-SOA-IRP | PCG-24 | Nokia Siemens Networks, Ericsson | Rel-10 | SP-47 | Dionisio | Jörg Schmidt (joerg@cox.net), edwin.tse@ericsson.com |
| 73 | 33.2 | **Self-Organizing Networks (SON) - OAM aspects** | 332d? | 2009-12-10 A | 2011-03-18 | 7% | 309.61d? | 2009-12-10 | 2011-03-18 | 332d? | 130d |  | S5 | 8968h | 604.68h | OAM10-SON | PCG-24 |  | Rel-10 | SP-46 | Dionisio |  |
| 74 | 33.2.1 | SON Self-optimization management continuation | 266d? | 2009-12-10 | 2010-12-16 |  |  | 2009-12-10 | 2010-12-16 | 266d? | 196d | finish no earlier than 2010-12-16 | S5 | 2128h |  | LTE-SON-OAM_SO | PCG-24 | Huawei | Rel-10 | SP-46 | Dionisio | Lan Zou (zlan@huawei.com) |
| 75 | 33.2.2 | SON Self-healing management | 266d? | 2009-12-10 A | 2010-12-16 | 20% | 212.8d? | 2009-12-10 | 2010-12-16 | 266d? | 196d | finish no earlier than 2010-12-16 | S5 | 2128h | 425.6h | LTE-SON-OAM_SH | PCG-24 | ZTE | Rel-10 | SP-46 | Dionisio | zhu.weihong@zte.com.cn |
| 76 | 33.2.3 | OAM aspects of Energy Saving in Radio Networks | 257d? | 2010-03-25 | 2011-03-18 |  |  | 2010-03-25 | 2011-03-18 | 257d? | 130d | finish no earlier than 2011-03-18 | S5 | 2056h |  | OAM-ES | PCG-24 | Nokia Siemens Networks | Rel-10 | SP-47 | Dionisio | clemens.suerbaum@nsn.com |
| 77 | 33.3 | Subscription Management (SuM) evolution | 191d? | 2010-03-25 | 2010-12-16 |  |  | 2010-03-25 | 2010-12-16 | 191d? | 196d | finish no earlier than 2010-12-16 | S5 | 1528h |  | OAM10-SuM | PCG-24 | Ericsson | Rel-10 | SP-47 | Dionisio | leo.yang@ericsson.com |

Notes:
- 50: SP#47 Stage 1 completed. Triggered by BBF WT 203. Interworking between the 3GPP EPS and the fixed broadband accesses as defined by BBF
- 51: SP#47 completed / Text3: 22.278
- 52: TR structure to follow the structure of the Building Blocks. Once a BB is completed, TR to be sent for SA Information. When all the BBs are completed, TR to be sent for SA approval. / Text3: TR 23.8xx (Technical Report on Support for BBF Accesses Interworking)
- 53: - / Text3: 23.203, 23.401, 23.402
- 54: - / Text3: 23.203, 23.401, 23.402
- 55: - / Text3: 23.203, 23.401, 23.402
- 56: SP#47 completed. Triggered by TR 23.894 (UID_370050 Study on System enhancements for the use of IMS services in local breakout) / Text3: 23.228 (IMS Stage 2)
- 57: SP#47 updated WID => / Text3: 23.203, 23.272, 23.401, new TR 23.854 (Enhancements for Multimedia Priority Service)
- 58: SP#47 SP#47 Stage 1 completed. Source of external requirements: ETSI TISPAN TS 181.019 (Business Communication Requirements)
- 59: SP#47 completed / Text3: 22.101 CR#0343
- 60: - / Text3: 23.167
- 61: develop new EPS algorithms acceptable to regions such as China / Text3: 35.xxx (EEA3 & EIA3 Algorithm Specification, Implementers’ test data, Design and evaluation report, Final project report), 33.401 (SAE Security Architecture)
- 62: LI for CAT & CRS, VCC, IMS Media security, H(e)NB also with LIPA-SIPTO, eMBMS, LCLS, IMS/EPS enhancements / Text3: 33.106 (LI requirements), 33.107 (LI architecture and functions), 33.108 (Handover interface for LI)
- 63: SP#47 Stage 1 completed. Develop EVS codec for EPS based on TR 22.813 recommendations. Triggered by UID_370045 Study on enhanced voice service requirements for EPS (TR 22.813)
- 64: SP#47 completed / Text3: 22.173
- 65: - / Text3: 26.xyz, 26.xyz, 26.xyz, 26.xyz, 26.xyz, 26.xyz, 26.xyz, 26.xyz, 26.xyz, 26.xyz, 26.9yz, 26.xyz
- 66: Work to enhance UID_430046 Rel-9 IMS_PSS_MBMS_US_EXT / Text3: 26.237
- 67: Work to enhance UID_430038 Rel-9 PSS and MBMS extensions / Text3: 26.234, 26.244, 26.346, new TS 26.xxx (HTTP-based Streaming and Download (HSD) Services)
- 68: umbrella Feature
- 69: umbrella BB
- 70: To reduce costs, some equipment can be shared between several RATs, e.g. RET, TMA and repeaters. With existing modelling it is very difficult for an operator to see that several cells are affected when an antenna tilt is changed etc / Text3: new (TR 32.9xx, TSs 32.7x1, 32.7x2, 32.7x3, 32.7x5), 32.615, 32.642, 32.643, 32.645, 32.652, 32.653, 32.655, 32.762, 32.763, 32.765
- 71: Stage 3 / Text3: 32.153, new (32.111-6,32.126,32.306,32.316,32.326,32.336,32.346,32.356,32.366,32.386,32.396,32.416,32.446,32.506,32.536,32.606,32.616,32.626,32.636,32.646,32.656,32.666,32.676,32.696,32.716,32.726,32.736,32.746,32.756,32.766,32.776,32.786)
- 72: Continuation of Rel-9 UID_440065 SOA for IRP (covering SOA Architecture & SOA-supporting Solution Set) to address SOA conforming Registration & Discovery capabilities / Text3: 32.101, 32.150
- 73: umbrella BB
- 74: Continuation of Rel-9 work UID_390007 SON self-optimization management / Text3: 32.425, 32.521, 32.522, 32.752, 32.753, 32.755, 32.762, 32.763, 32.765
- 75: Work moved to Rel-10 after split of the Rel-9 UID_390007 SON self-optimization (removed Self-Healing handling) / Text3: new TS (32.541, 32.542, 32.543), 32.752, 32.753, 32.755, 32.762, 32.763, 32.765
- 76: Stage 3. Triggered by Rel-10 TR 32.826 Study on Telecommunication Management; Energy Savings Management (FS_OAM_ESM) UID_430044 / Text3: 32.425, 32.762, 32.763, 32.765, 32.767 or new 32.es1, 32.es2
- 77: Stage 3 / Text3: 32.172, 32.175

| ID | WBS | Task | Duration | Start | Finish | Complete | Remaining | Baseline start | Baseline finish | Baseline duration | Total slack | Constraint | Resources | Work | Actual work | Text1 | Text2 | Text6 | Text7 | Text8 | Text4 | Text11 | Text9 | Text12 |
| --- | --- | --- | --- | --- | --- | --- | --- | --- | --- | --- | --- | --- | --- | --- | --- | --- | --- | --- | --- | --- | --- | --- | --- | --- |
| 78 | 33.4 | **Performance Management** | 257d? | 2010-03-25 | 2011-03-18 |  |  | 2010-03-25 | 2011-03-18 | 257d? | 130d |  | S5 | 8696h |  | OAM10-PM | PCG-24 | Rel-10 | SP-47 | Dionisio |  |  |  |  |
| 79 | 33.4.1 | Key Performance Indicators (KPIs) for IMS | 191d? | 2010-03-25 | 2010-12-16 |  |  | 2010-03-25 | 2010-12-16 | 191d? | 196d | finish no earlier than 2010-12-16 | S5 | 1528h |  | OAM-PM-KPI_IMS | PCG-24 | Rel-10 | SP-47 | Dionisio | China Mobile |  |  |  |
| 80 | 33.4.2 | Key Performance Indicators (KPIs) for EPC | 191d? | 2010-03-25 | 2010-12-16 |  |  | 2010-03-25 | 2010-12-16 | 191d? | 196d | finish no earlier than 2010-12-16 | S5 | 1528h |  | OAM-PM-KPI_EPC | PCG-24 | Rel-10 | SP-47 | Dionisio | China Mobile |  |  |  |
| 81 | 33.4.3 | Management of UE based network performance measurements | 257d? | 2010-03-25 | 2011-03-18 |  |  | 2010-03-25 | 2011-03-18 | 257d? | 130d | finish no earlier than 2011-03-18 | S5 | 2056h |  | OAM-PM-UE | PCG-24 | Rel-10 | SP-47 | Dionisio | Huawei, Nokia Siemens Networks, Ericsson |  |  |  |
| 82 | 33.4.4 | 3G HNB and LTE HeNB Subsystem performance measurement | 191d? | 2010-03-25 | 2010-12-16 |  |  | 2010-03-25 | 2010-12-16 | 191d? | 196d | finish no earlier than 2010-12-16 | S5 | 1528h |  | OAM-PM-HeNS | PCG-24 | Rel-10 | SP-47 | Dionisio | China Mobile |  |  |  |
| 83 | 34 | **Charging Management small Enhancements** | 466d? | 2009-06-04 A | 2011-03-17 | 16% | 390.81d? | 2009-06-04 | 2011-03-17 | 466d? | 131d |  | S5 | 9504h | 1533.54h | CH10 | PCG-24 | Rel-10 | SP-47 | Dionisio |  |  |  |  |
| 84 | 34.1 | IWLAN mobility charging | 466d? | 2009-06-04 A | 2011-03-17 | 25% | 349.5d? | 2009-06-04 | 2011-03-17 | 466d? | 131d | finish no earlier than 2011-03-17 | S5 | 3728h | 932h | eIWLAN_Mob | PCG-23 | Rel-10 | SP-44 | Dionisio | Orange |  |  |  |
| 85 | 34.2 | Add solutions for Rc - reference point within the Online Charging System (OCS) | 256d? | 2010-03-25 | 2011-03-17 |  |  | 2010-03-25 | 2011-03-17 | 256d? | 131d | finish no earlier than 2011-03-17 | S5 | 2048h |  | CH-Rc | PCG-24 | Rel-10 | SP-47 | Dionisio | Huawei |  |  |  |
| 86 | 35 | **Advice of Charge (AoC) service support enhancements** | 256d? | 2010-03-25 | 2011-03-17 |  |  | 2010-03-25 | 2011-03-17 | 256d? | 131d |  | S5 | 4096h |  | eAoC | PCG-24 | Rel-10 | SP-47 | Dionisio | Deutsche Telekom |  |  |  |
| 87 | 35.1 | SA5 part - AoC enhancements | 256d? | 2010-03-25 | 2011-03-17 |  |  | 2010-03-25 | 2011-03-17 | 256d? | 131d | start no earlier than 2010-03-25 | S5 | 2048h |  | eAoC | PCG-24 | Rel-10 | SP-47 | Dionisio | Deutsche Telekom |  |  |  |
| 88 | 36 | IMS Stage 3 - IETF Protocol Alignment | 261d? | 2010-03-19 | 2011-03-18 |  |  | 2010-03-19 | 2011-03-18 | 261d? | 130d | finish no earlier than 2011-03-18 | C1 | 2088h |  | IMSProtoc4 | PCG-24 | Rel-10 | CP-47 | Frederic | Alcatel-Lucent |  |  |  |
| 89 | 37 | **UMTS/LTE 3500 MHz** | 792d? | 2007-11-30 A | 2010-12-10 | 24% | 605.88d? | 2007-11-30 | 2010-12-10 | 792d? | 200d |  | R4,R2,R3,R5 | 16994h | 3993.63h | RInImp8-UMTSLTE3500 | PCG-21 | Rel-10 | RP-38 | Issam | Ericsson |  |  |  |
| 90 | 37.1 | UMTS/LTE 3500 MHz | 645d? | 2007-11-30 A | 2010-06-04 | 57% | 277.35d? | 2007-11-30 | 2010-06-04 | 645d? | 335d | finish no earlier than 2010-06-04 | R4,R2,R3 | 5160h | 2941.2h | RInImp8-UMTSLTE3500 | PCG-21 | Rel-10 | RP-38 | Issam | Ericsson | RP-100050 |  |  |
| 91 | 37.2 | Conformance Test Aspects – LTE 3500 | 527d? | 2008-12-05 A | 2010-12-10 | 3% | 511.19d? | 2008-12-05 | 2010-12-10 | 527d? | 200d | finish no earlier than 2010-12-10 | R5 | 4216h | 126.48h | LTE-UEConTest_LTE3500 | PCG-22 | Rel-10 | RP-42 | Ingbert | Ericsson | RP-100062 |  |  |
| 92 | 37.3 | Conformance Test Aspects – UMTS 3500 | 527d? | 2008-12-05 A | 2010-12-10 | 3% | 511.19d? | 2008-12-05 | 2010-12-10 | 527d? | 200d | finish no earlier than 2010-12-10 | R5 | 4216h | 126.48h | RInImp-UEConTest_UMTS3500 | PCG-22 | Rel-10 | RP-42 | Ingbert | Nokia | RP-100063 |  |  |
| 93 | 38 | 1.28 Mcps TDD Repeater | 599d? | 2007-12-04 A | 2010-03-19 A | 100% |  | 2007-12-04 | 2010-03-19 | 599d? |  | finish no earlier than 2010-03-19 | R4 | 4792h | 4792h | RANimp-Repeaters1.28TDD | PCG-21 | Rel-10 | RP-38 | Issam | RITT | RP-100039 |  |  |
| 94 | 39 | 1.28 Mcps TDD Multi-carrier HSUPA | 321d? | 2009-09-18 A | 2010-12-10 | 15% | 272.85d? | 2009-09-18 | 2010-12-10 | 321d? | 200d | finish no earlier than 2010-12-10 | R1,R2,R3,R4 | 2568h | 385.2h | TDD_MC_HSUPA | PCG-23 | Rel-10 | RP-45 | Patrick | CATR | RP-100042 |  |  |
| 95 | 40 | **1.28 Mcps TDD Home NodeB RF requirements** | 266d? | 2009-12-04 A | 2010-12-10 | 28% | 192.85d? | 2009-12-04 | 2010-12-10 | 266d? | 200d |  | R4 | 6384h | 1755.6h | HNB_LCRTDD_RF | PCG-24 | Rel-10 | RP-46 | Issam | TD Tech |  |  |  |
| 96 | 40.1 | Core - 1.28 Mcps TDD Home NodeB RF requirements | 266d? | 2009-12-04 A | 2010-12-10 | 35% | 172.9d? | 2009-12-04 | 2010-12-10 | 266d? | 200d | finish no earlier than 2010-12-10 | R4 | 2128h | 744.8h | HNB_LCRTDD_RF-Core | PCG-24 | Rel-10 | RP-46 | Issam | TD Tech | RP-100350 |  |  |
| 97 | 40.2 | Perf - 1.28 Mcps TDD Home NodeB RF requirements | 266d? | 2009-12-04 A | 2010-12-10 | 20% | 212.8d? | 2009-12-04 | 2010-12-10 | 266d? | 200d | finish no earlier than 2010-12-10 | R4 | 2128h | 425.6h | HNB_LCRTDD_RF-Perf | PCG-24 | Rel-10 | RP-46 | Issam | TD Tech | RP-100351 |  |  |
| 98 | 41 | Network-Based Positioning Support in LTE | 461d? | 2009-03-09 A | 2010-12-10 | 30% | 322.7d? | 2009-03-09 | 2010-12-10 | 461d? | 200d | finish no earlier than 2010-12-10 | R2,R3,R4 | 3688h | 1106.4h | LCS_LTE-NBPS | PCG-22 | Rel-10 | RP-43 | Joern | TruePosition | RP-100032 |  |  |
| 99 | 42 | Deleted - UTRAN 2 ms TTI uplink range improvement | 272d? | 2009-03-06 A | 2010-03-19 A | 100% |  | 2009-03-06 | 2010-03-19 | 272d? |  | finish no earlier than 2010-03-19 | R1,R2,R3,R4 | 2176h | 2176h | RANimp-2mTTI_ULimp | PCG-22 | Rel-10 | RP-43 | Patrick | Nokia Siemens Networks | RP-100040 | PCG-24 | RP-47 |
| 100 | 43 | A-GNSS Minimum Performance for UTRAN | 261d? | 2009-09-18 A | 2010-09-17 | 40% | 156.6d? | 2009-09-18 | 2010-09-17 | 261d? | 260d | finish no earlier than 2010-09-17 | R4 | 2088h | 835.2h | AGNSSPerf_UTRAN | PCG-23 | Rel-10 | RP-45 | Issam | Thales | RP-100041 |  |  |
| 101 | 44 | UE Over The Air (Antenna) conformance testing methodology - Laptop mounted equipment Free Space test | 521d? | 2009-09-18 A | 2011-09-16 | 25% | 390.75d? | 2009-09-18 | 2011-09-16 | 521d? | 0d | finish no earlier than 2011-09-16 | R4 | 4168h | 1042h | UEAnt_FSTest | PCG-23 | Rel-10 | RP-45 | Issam | CATR | RP-100043 |  |  |

Notes:
- 78: umbrella BB
- 79: Stage 3 / Text3: new 32.4xy / Text5: lijian@chinamobile.com, liangshuangchun@cmdi.chinamobile.com
- 80: Stage 3 / Text3: new 32.4xy / Text5: lijian@chinamobile.com, liangshuangchun@cmdi.chinamobile.com
- 81: Stage 2/3. Linked to UID_460003 Minimization of drive tests for E-UTRAN and UTRAN (MDT_UMTSLTE) / Text3: 32.405, 32.421, 32.422, 32.423, 32.425, 32.441, 32.442, 32.443, 32.445, new 32.XX1/2 (Management of UE based network performance measurements Requirements/Stage 2) / Text5: Zou Lan (zlan@huawei.com), gyula.bodog@nsn.com, ulf.hubinette@ericsson.com
- 82: Stage 3 / Text3: 32.582, 32.592, new 32.452, 32.453 / Text5: Chen Gang (chengang@chinamobile.com)
- 83: umbrella Feature
- 84: SP#47 moved to Rel-10. WID updated SP-090312=>SP-100090. RAT differentiation for charging. Completes Rel-8 Feature IWLAN_Mob UID_370049 Mobility between 3GPP-WLAN Interworking and 3GPP Systems / Text3: 32.240, 32.252, 32.298, 32.299 / Text5: Jean-Luc Garcia
- 85: Stage 3 (Stage 1 in 22.115). Triggered by Rel-10 TR 32.825 SA5 Study on Rc Reference Point Functionalities and Message Flows (FS_OAM_Rc) UID_10044 / Text3: 32.296, 32.299 / Text5: shan.mingjun@huawei.com
- 86: Continuation of UID_80042 Rel-8 BB: Advice of Charge (AoC) support in IMS Charging (IMSTSS). Stage 2/3 work. SA5, CT1, CT3 and possibly CT4 coordination needed. / Text5: matthias.seibel@telekom.de
- 87: - / Text3: 32.275, 32.280, 32.298, 32.299 / Text5: matthias.seibel@telekom.de
- 88: Ensure protocol alignment between 3GPP Stage 3 IMS work and IETF. Review capabilities provided in SIP by IETF and document whether these capabilities are supported in the IM CN Subsystem or not / Text3: 23.218, 24.229, 24.930 / Text5: keith.drage@alcatel-lucent.com
- 89: RP#46 moved to Rel-10. WID updated RP-081096=>RP-091380 / Text5: Jjohan.skold@ericsson.com
- 90: RP#46 moved to Rel-10. WID updated RP-081096=>RP-091380 / Text3: 25.101, 25.104, 25.113, 25.133, 25.141, 25.307, 25.307, 25.331, 25.461, 25.463, 34.124, 36.101, 36.104, 36.113, 36.141, 36.331 / Text5: Jjohan.skold@ericsson.com
- 91: RP#47 completion 06/10=>12/10 / Text3: 36.508, 36.521-1, 36.521-2, 36.521-3 / Text5: fredrik.sundstrom@ericsson.com
- 92: RP#47 completion 06/10=>12/10 / Text3: 34.108, 34.121-1, 34.121-2 / Text5: jukka.vikstedt@nokia.com
- 93: RP#47 completed / Text3: 25.113, new 25.116, 25.153 (testing) / Text5: qinyan@chinattl.com
- 94: - / Text3: 25.102, 25.105, 25.123, 25.221, 25.222, 25.223, 25.224, 25.225, 25.306, 25.319, 25.321, 25.331, 25.423, 25.427, 25.433 / Text5: Aihui Song (songaihui@mail.ritt.com.cn)
- 95: Triggered by FS_RAN-HNBLCRTDD UID_410016 Study on 1.28 Mcps TDD Home NodeB (TR 25.866) / Text5: Li Rong (lirong@td-tech.com)
- 96: RP#47 completion 06/10=>12/10 / Text3: 25.105 / Text5: Li Rong (lirong@td-tech.com)
- 97: - / Text3: 25.142 / Text5: Li Rong (lirong@td-tech.com)
- 98: RP#47 completion 03/10=>12/10. Moved to Rel-10 / Text3: 36.300, 36.331, 36.355, 36.413, new R4 36.xxx (Performance Requirements for LMU) / Text5: terri.brooks@trueposition.com
- 99: RP#47 work stopped/abandoned (no CR approved). Cell sets the TTI (Transmission Time Interval) to 2 ms / Text3: 25.133, 25.212, 25.214, 25.321, 25.331 / Text5: Karri Ranta-aho (karri.ranta-aho@nsn.com)
- 100: RP#47 updated WID RP-090951=>RP-100363. Triggered by Rel-7 UID_20050 (GNSS in UTRAN) and Rel-8 UID_400051 (Support for Additional NSS). Linked to GERAN Rel-9 UID_38002 (A-GNSS Performances and Testing Procedures) / Text3: new 25.172 / Text5: Michel.monnerat@thalesaleniaspace.com
- 101: - / Text3: 25.144, 25.914, 34.114 / Text5: Guo Lin (guolin@emcite.com)

| ID | WBS | Task | Duration | Start | Finish | Complete | Remaining | Baseline start | Baseline finish | Baseline duration | Total slack | Constraint | Resources | Work | Actual work | Text1 | Text2 | Text4 | Text5 | Text6 | Text7 | Text8 | Text11 |
| --- | --- | --- | --- | --- | --- | --- | --- | --- | --- | --- | --- | --- | --- | --- | --- | --- | --- | --- | --- | --- | --- | --- | --- |
| 102 | 45 | **Inclusion of RF Pattern Matching Technologies as positioning method in the UTRAN** | 141d? | 2009-12-04 | 2010-06-18 |  |  | 2009-12-04 | 2010-06-18 | 141d? | 325d |  | R2,R3 | 2256h |  | LCS_UMTS_RFPMT | PCG-24 | Polaris Wireless | Norman Shaw | Rel-10 | RP-46 | Joern |  |
| 103 | 45.1 | Core - Inclusion of RF Pattern Matching Technologies as positioning method in the UTRAN | 141d? | 2009-12-04 | 2010-06-18 |  |  | 2009-12-04 | 2010-06-18 | 141d? | 325d | finish no earlier than 2010-06-18 | R2,R3 | 1128h |  | LCS_UMTS_RFPMT | PCG-24 | Polaris Wireless | Norman Shaw | Rel-10 | RP-46 | Joern | RP-100134 |
| 104 | 46 | **Minimization of Drive Tests for E-UTRAN and UTRAN** | 266d? | 2009-12-04 A | 2010-12-10 | 20% | 212.8d? | 2009-12-04 | 2010-12-10 | 266d? | 200d |  | R2,R4,R3 | 4256h | 851.2h | MDT_UMTSLTE | PCG-24 | Nokia Siemens Networks | Malgorzata Tomala | Rel-10 | RP-46 | Joern |  |
| 105 | 46.1 | Core - MDT for E-UTRAN and UTRAN | 266d? | 2009-12-04 A | 2010-12-10 | 20% | 212.8d? | 2009-12-04 | 2010-12-10 | 266d? | 200d | finish no earlier than 2010-12-10 | R2,R4,R3 | 2128h | 425.6h | MDT_UMTSLTE-Core | PCG-24 | Nokia Siemens Networks | Malgorzata Tomala | Rel-10 | RP-46 | Joern | RP-100051 |
| 106 | 47 | **Fixed Wireless Customer-Premises Equipment (CPE) RF Requirements** | 270d? | 2009-12-04 A | 2010-12-16 | 2% | 264.08d? | 2009-12-04 | 2010-12-16 | 270d? | 196d |  | R4,R5 | 6008h | 131.78h | FW_CPE_RF | PCG-24 | Verizon Wireless | zheng.zhao@verizonwireless.com | Rel-10 | RP-46 | Issam |  |
| 107 | 47.1 | Core - Fixed Wireless CPE RF Requirements | 211d? | 2009-12-04 A | 2010-09-24 | 5% | 200.45d? | 2009-12-04 | 2010-09-24 | 211d? | 255d | finish no earlier than 2010-09-24 | R4 | 1688h | 84.4h | FW_CPE_RF-Core | PCG-24 | Verizon Wireless | zheng.zhao@verizonwireless.com | Rel-10 | RP-46 | Issam | RP-100049 |
| 108 | 47.2 | Test - Fixed Wireless CPE RF Requirements | 270d? | 2009-12-04 | 2010-12-16 |  |  | 2009-12-04 | 2010-12-16 | 270d? | 196d | finish no earlier than 2010-12-16 | R5 | 2160h |  | FW_CPE_RF-UEConTest | PCG-24 | Verizon Wireless | zheng.zhao@verizonwireless.com | Rel-10 | RP-46 | Ingbert | RP-100079 |
| 109 | 48 | **Four carrier HSDPA** | 400d? | 2009-12-04 A | 2011-06-16 | 10% | 360.06d? | 2009-12-04 | 2011-06-16 | 400d? | 66d |  | R1,R2,R3,R4 | 8528h | 851.52h | 4C_HSDPA | PCG-24 | Qualcomm | Arjun Bharadwaj (arjunb@qualcomm.com) | Rel-10 | RP-46 | Patrick |  |
| 110 | 48.1 | Core - Four carrier HSDPA | 266d? | 2009-12-04 A | 2010-12-10 | 25% | 199.5d? | 2009-12-04 | 2010-12-10 | 266d? | 200d | finish no earlier than 2010-12-10 | R1,R2,R3,R4 | 2128h | 532h | 4C_HSDPA-Core | PCG-24 | Qualcomm | Arjun Bharadwaj (arjunb@qualcomm.com) | Rel-10 | RP-46 | Patrick | RP-100046 |
| 111 | 48.2 | Perf - Four carrier HSDPA | 400d? | 2009-12-04 | 2011-06-16 |  |  | 2009-12-04 | 2011-06-16 | 400d? | 66d | finish no earlier than 2011-06-16 | R4 | 3200h |  | 4C_HSDPA-Perf | PCG-24 | Qualcomm | Arjun Bharadwaj (arjunb@qualcomm.com) | Rel-10 | RP-46 | Issam | RP-100047 |
| 112 | 49 | **Carrier Aggregation for LTE** | 400d? | 2009-12-04 A | 2011-06-16 | 8% | 368.05d? | 2009-12-04 | 2011-06-16 | 400d? | 66d |  | R1,R2,R3,R4 | 8528h | 681.22h | LTE_CA | PCG-24 | Nokia | Asbjørn Grøvlen | Rel-10 | RP-46 | Patrick |  |
| 113 | 49.1 | Core - Carrier Aggregation for LTE | 266d? | 2009-12-04 A | 2010-12-10 | 20% | 212.8d? | 2009-12-04 | 2010-12-10 | 266d? | 200d | finish no earlier than 2010-12-10 | R1,R2,R3,R4 | 2128h | 425.6h | LTE_CA-Core | PCG-24 | Nokia | Asbjørn Grøvlen | Rel-10 | RP-46 | Patrick | RP-100056 |
| 114 | 49.2 | Perf - Carrier Aggregation for LTE | 400d? | 2009-12-04 | 2011-06-16 |  |  | 2009-12-04 | 2011-06-16 | 400d? | 66d | finish no earlier than 2011-06-16 | R4 | 3200h |  | LTE_CA-Perf | PCG-24 | Nokia | Asbjørn Grøvlen | Rel-10 | RP-46 | Issam | RP-100057 |
| 115 | 50 | **Enhanced Downlink Multiple Antenna Transmission for LTE** | 400d? | 2009-12-04 A | 2011-06-16 | 8% | 368.05d? | 2009-12-04 | 2011-06-16 | 400d? | 66d |  | R1,R2,R4 | 8528h | 681.22h | LTE_eDL_MIMO | PCG-24 | NTT DoCoMo | Hidekazu Taoka | Rel-10 | RP-46 | Patrick |  |
| 116 | 50.1 | Core - Enhanced Downlink Multiple Antenna Transmission for LTE | 266d? | 2009-12-04 A | 2010-12-10 | 20% | 212.8d? | 2009-12-04 | 2010-12-10 | 266d? | 200d | finish no earlier than 2010-12-10 | R1,R2,R4 | 2128h | 425.6h | LTE_eDL_MIMO-Core | PCG-24 | NTT DoCoMo | Hidekazu Taoka | Rel-10 | RP-46 | Patrick | RP-100052 |
| 117 | 50.2 | Perf - Enhanced Downlink Multiple Antenna Transmission for LTE | 400d? | 2009-12-04 | 2011-06-16 |  |  | 2009-12-04 | 2011-06-16 | 400d? | 66d | finish no earlier than 2011-06-16 | R4 | 3200h |  | LTE_eDL_MIMO-Perf | PCG-24 | NTT DoCoMo | Hidekazu Taoka | Rel-10 | RP-46 | Issam | RP-100053 |
| 118 | 51 | **Uplink Multiple Antenna Transmission for LTE** | 400d? | 2009-12-04 A | 2011-06-16 | 16% | 336.1d? | 2009-12-04 | 2011-06-16 | 400d? | 66d |  | R1,R2,R4 | 8528h | 1362.43h | LTE_UL_MIMO | PCG-24 | Huawei | Mattias Wennström | Rel-10 | RP-46 | Patrick |  |
| 119 | 51.1 | Core - UL Multiple Antenna Transmission for LTE | 266d? | 2009-12-04 A | 2010-12-10 | 40% | 159.6d? | 2009-12-04 | 2010-12-10 | 266d? | 200d | finish no earlier than 2010-12-10 | R1,R2,R4 | 2128h | 851.2h | LTE_UL_MIMO-Core | PCG-24 | Huawei | Mattias Wennström | Rel-10 | RP-46 | Patrick | RP-100328 |
| 120 | 51.2 | Perf - UL Multiple Antenna Transmission for LTE | 400d? | 2009-12-04 | 2011-06-16 |  |  | 2009-12-04 | 2011-06-16 | 400d? | 66d | finish no earlier than 2011-06-16 | R4 | 3200h |  | LTE_UL_MIMO-Perf | PCG-24 | Huawei | Mattias Wennström | Rel-10 | RP-46 | Issam | RP-100055 |
| 121 | 52 | **Latency reductions for LTE** | 266d? | 2009-12-04 A | 2010-12-10 | 20% | 212.8d? | 2009-12-04 | 2010-12-10 | 266d? | 200d |  | R1,R2 | 4256h | 851.2h | LTE_LATRED | PCG-24 | Ericsson | Henrik Enbuske | Rel-10 | RP-46 | Patrick |  |
| 122 | 52.1 | Core - Latency reductions for LTE | 266d? | 2009-12-04 A | 2010-12-10 | 20% | 212.8d? | 2009-12-04 | 2010-12-10 | 266d? | 200d | finish no earlier than 2010-12-10 | R1,R2 | 2128h | 425.6h | LTE_LATRED-Core | PCG-24 | Ericsson | Henrik Enbuske | Rel-10 | RP-46 | Patrick | RP-100060 |
| 123 | 53 | **Relays for LTE** | 336d? | 2009-12-04 A | 2011-03-18 | 2% | 328.58d? | 2009-12-04 | 2011-03-18 | 336d? | 130d |  | R1,R2,R4 | 7504h | 165.78h | LTE_Relay | PCG-24 | Ericsson | Christian Hoymann | Rel-10 | RP-46 | Patrick |  |
| 124 | 53.1 | Core - Relays for LTE | 266d? | 2009-12-04 A | 2010-12-10 | 5% | 252.7d? | 2009-12-04 | 2010-12-10 | 266d? | 200d | finish no earlier than 2010-12-10 | R1,R2,R4 | 2128h | 106.4h | LTE_Relay-Core | PCG-24 | Ericsson | Christian Hoymann | Rel-10 | RP-46 | Patrick | RP-100058 |
| 125 | 53.2 | Perf - Relays for LTE | 336d? | 2009-12-04 | 2011-03-18 |  |  | 2009-12-04 | 2011-03-18 | 336d? | 130d | finish no earlier than 2011-03-18 | R4 | 2688h |  | LTE_Relay-Perf | PCG-24 | Ericsson | Christian Hoymann | Rel-10 | RP-46 | Issam | RP-100059 |

Notes:
- 102: Triggered by Study UID_380079 Evaluation of the inclusion of Path Loss Based Technology in the UTRAN (25.907)
- 103: - / Text3: 25.305, 25.453
- 104: RP#47 updated WID RP-091423=>RP-100360. Triggered by UID_430021 TR 36.805 (Study on Minimization of drive-tests in NGN)
- 105: RP#47 updated WID RP-091423=>RP-100360 / Text3: 25.133, 25.215, 25.304, 25.331, 25.423, 36.133, 36.214, 36.300, 36.304, 36.331, 36.413, 36.423, new 37.320
- 106: Add new power classes in E-UTRAN UL to allow CPE type applications to be operated at higher max output power
- 107: - / Text3: 36.101
- 108: - / Text3: 36.521-1
- 109: -
- 110: - / Text3: 25.101, 25.104, 25.133, 25.211, 25.212, 25.213, 25.214, 25.215, 25.308, 25.331, 25.423, 25.433, 26.306
- 111: - / Text3: 25.101, 25.104, 25.133, 25.141
- 112: Triggered by FS_RAN_LTEA (Study on LTE-Advanced) 36.912, 36. 814
- 113: - / Text3: 36.101, 36.104, 36.133, 36.211, 36.212, 36.213, 36.300, 36.302, 36.306, 36.321, 36.331, 36.413, 36.423
- 114: - / Text3: 36.101, 36.104, 36.133, 36.141, 36.211, 36.212, 36.213, 36.300, 36.302, 36.306, 36.321, 36.331, 36.413, 36.423
- 115: Triggered by FS_RAN_LTEA (Study on LTE-Advanced) 36.912, 36. 814
- 116: RP#47 updated WID RP-091429=>RP-100196 / Text3: 36.101, 36.104, 36.133, 36.201, 36.211, 36.212, 36.213, 36.300, 36.306, 36.321, 36.331
- 117: - / Text3: 36.101, 36.104, 36.133, 36.141
- 118: Triggered by FS_RAN_LTEA (Study on LTE-Advanced) 36.912, 36. 814
- 119: - / Text3: 36.101, 36.104, 36.133, 36.201, 36.211, 36.212, 36.213, 36.300, 36.306, 36.321, 36.331
- 120: - / Text3: 36.101, 36.104, 36.133, 36.141
- 121: Triggered by FS_RAN_LTEA (Study on LTE-Advanced) 36.912, 36. 814
- 122: - / Text3: 36.213, 36.300, 36.306, 36.321, 36.331
- 123: Triggered by FS_RAN_LTEA (Study on LTE-Advanced) 36.912, 36. 814
- 124: - / Text3: 36.133, 36.201, 36.211, 36.212, 36.213, 36.300, 36.321, 36.323, 36.331
- 125: - / Text3: 36.133

| ID | WBS | Task | Duration | Start | Finish | Baseline start | Baseline finish | Baseline duration | Total slack | Constraint | Resources | Work | Text1 | Text2 | Text4 | Text5 | Text6 | Text7 | Text8 | Text12 |
| --- | --- | --- | --- | --- | --- | --- | --- | --- | --- | --- | --- | --- | --- | --- | --- | --- | --- | --- | --- | --- |
| 126 | 54 | **HNB and HeNB Mobility Enhancements** | 191d? | 2010-03-19 | 2010-12-10 | 2010-03-19 | 2010-12-10 | 191d? | 200d |  | R3,R2 | 3056h | HNB_HENB_mob_enh | PCG-24 | Alcatel-Lucent | Martin,Warner@alcatel-lucent.com | Rel-10 | RP-47 | Juha |  |
| 127 | 54.1 | HNB and HeNB Mobility Enhancements | 191d? | 2010-03-19 | 2010-12-10 | 2010-03-19 | 2010-12-10 | 191d? | 200d | start no earlier than 2010-03-19 | R3,R2 | 1528h | HNB_HENB_mob_enh-Core | PCG-24 | Alcatel-Lucent | Martin,Warner@alcatel-lucent.com | Rel-10 | RP-47 | Juha |  |
| 128 | 55 | **Enhanced Interference Management for Home NodeBs** | 261d? | 2010-03-19 | 2011-03-18 | 2010-03-19 | 2011-03-18 | 261d? | 130d |  | R3 | 4176h | HNB_IM | PCG-24 | Qualcomm | Andrei Radulescu (aradules@qualcomm.com) | Rel-10 | RP-47 | Juha |  |
| 129 | 55.1 | Enhanced Interference Management for Home NodeBs | 261d? | 2010-03-19 | 2011-03-18 | 2010-03-19 | 2011-03-18 | 261d? | 130d | finish no earlier than 2011-03-18 | R3 | 2088h | HNB_IM-Core | PCG-24 | Qualcomm | Andrei Radulescu (aradules@qualcomm.com) | Rel-10 | RP-47 | Juha |  |
| 130 | 56 | **Enhanced ICIC for non-CA based deployments of heterogeneous networks for LTE** | 326d? | 2010-03-19 | 2011-06-17 | 2010-03-19 | 2011-06-17 | 326d? | 65d |  | R1,R2,R3,R4 | 6744h | ECIC_LTE | PCG-24 | China Mobile | Xiaodong XU (xuxiaodong@chinamobile.com) | Rel-10 | RP-47 | Patrick |  |
| 131 | 56.1 | Core - Enhanced ICIC for non-CA based deployments of heterogeneous networks for LTE | 191d? | 2010-03-19 | 2010-12-10 | 2010-03-19 | 2010-12-10 | 191d? | 200d | finish no earlier than 2010-12-10 | R1,R2,R3,R4 | 1528h | ECIC_LTE-Core | PCG-24 | China Mobile | Xiaodong XU (xuxiaodong@chinamobile.com) | Rel-10 | RP-47 | Patrick |  |
| 132 | 56.2 | Perf - Enhanced ICIC for non-CA based deployments of heterogeneous networks for LTE | 326d? | 2010-03-19 | 2011-06-17 | 2010-03-19 | 2011-06-17 | 326d? | 65d | finish no earlier than 2011-06-17 | R4 | 2608h | ECIC_LTE-Perf | PCG-24 | China Mobile | Xiaodong XU (xuxiaodong@chinamobile.com) | Rel-10 | RP-47 | Issam |  |
| 133 | 57 | **LTE TDD in 2600MHz for USA (Region 2)** | 191d? | 2010-03-19 | 2010-12-10 | 2010-03-19 | 2010-12-10 | 191d? | 200d |  | R4,R2,R3 | 4584h | LTE_TDD_2600_US | PCG-24 | Clearwire | michael.hart@clearwire.com | Rel-10 | RP-47 | Issam |  |
| 134 | 57.1 | Core - LTE TDD in 2600MHz for USA (Region 2) | 191d? | 2010-03-19 | 2010-12-10 | 2010-03-19 | 2010-12-10 | 191d? | 200d | finish no earlier than 2010-12-10 | R4,R2,R3 | 1528h | LTE_TDD_2600_US-Core | PCG-24 | Clearwire | michael.hart@clearwire.com | Rel-10 | RP-47 | Issam |  |
| 135 | 57.2 | Perf - LTE TDD in 2600MHz for USA (Region 2) | 191d? | 2010-03-19 | 2010-12-10 | 2010-03-19 | 2010-12-10 | 191d? | 200d | finish no earlier than 2010-12-10 | R4 | 1528h | LTE_TDD_2600_US-Perf | PCG-24 | Clearwire | michael.hart@clearwire.com | Rel-10 | RP-47 | Issam |  |
| 136 | 58 | **Add 2 GHz band LTE for ATC of MSS in North America** | 326d? | 2010-03-19 | 2011-06-17 | 2010-03-19 | 2011-06-17 | 326d? | 65d |  | R4,R2 | 6744h | 2GHz-ATC-MSS | PCG-24 | TerreStar | Eric.Jacks@skyterra.com, Maqbool.Aliani@skyterra.com | Rel-10 | RP-47 | Issam | 470010 |
| 137 | 58.1 | Core - Add 2 GHz band LTE for ATC of MSS in North America | 191d? | 2010-03-19 | 2010-12-10 | 2010-03-19 | 2010-12-10 | 191d? | 200d | finish no earlier than 2010-12-10 | R4,R2 | 1528h | 2GHz-ATC-MSS-core | PCG-24 | TerreStar | Rhys.Robinson@terrestar.com | Rel-10 | RP-47 | Issam | 470110 |
| 138 | 58.2 | Perf - Add 2 GHz band LTE for ATC of MSS in North America | 326d? | 2010-03-19 | 2011-06-17 | 2010-03-19 | 2011-06-17 | 326d? | 65d | finish no earlier than 2011-06-17 | R4 | 2608h | 2GHz-ATC-MSS-perf | PCG-24 | TerreStar | Rhys.Robinson@terrestar.com | Rel-10 | RP-47 | Issam | 470210 |
| 139 | 59 | **Add L-Band LTE for ATC of MSS in North America** | 326d? | 2010-03-19 | 2011-06-17 | 2010-03-19 | 2011-06-17 | 326d? | 65d |  | R4,R2 | 6744h | LTE, L-Band-ATC-MSS | PCG-24 | Skyterra | Eric.Jacks@skyterra.com, Maqbool.Aliani@skyterra.com | Rel-10 | RP-47 | Issam | 470009 |
| 140 | 59.1 | Core - Add L-Band LTE for ATC of MSS in North America | 191d? | 2010-03-19 | 2010-12-10 | 2010-03-19 | 2010-12-10 | 191d? | 200d | finish no earlier than 2010-12-10 | R4,R2 | 1528h | LTE, L-Band-ATC-MSS | PCG-24 | Skyterra | Eric.Jacks@skyterra.com, Maqbool.Aliani@skyterra.com | Rel-10 | RP-47 | Issam | 470109 |
| 141 | 59.2 | Perf - Add L-Band LTE for ATC of MSS in North America | 326d? | 2010-03-19 | 2011-06-17 | 2010-03-19 | 2011-06-17 | 326d? | 65d | finish no earlier than 2011-06-17 | R4 | 2608h | LTE, L-Band-ATC-MSS | PCG-24 | Skyterra | Eric.Jacks@skyterra.com, Maqbool.Aliani@skyterra.com | Rel-10 | RP-47 | Issam | 470209 |
| 142 | 60 | **LTE Self Optimizing Networks (SON) enhancements** | 191d? | 2010-03-19 | 2010-12-10 | 2010-03-19 | 2010-12-10 | 191d? | 200d |  | R3,R2,R4 | 3056h | SONenh_LTE | PCG-24 | Nokia Siemens Networks | krzysztof.kordybach@nsn.com | Rel-10 | RP-47 | Juha |  |
| 143 | 60.1 | Core - LTE Self Optimizing Networks (SON) enhancements | 191d? | 2010-03-19 | 2010-12-10 | 2010-03-19 | 2010-12-10 | 191d? | 200d | finish no earlier than 2010-12-10 | R3,R2,R4 | 1528h | SONenh_LTE-Core | PCG-24 | Nokia Siemens Networks | krzysztof.kordybach@nsn.com | Rel-10 | RP-47 | Juha |  |
| 144 | 61 | **MU-MIMO for 1.28Mcps TDD** | 260d? | 2010-03-19 | 2011-03-17 | 2010-03-19 | 2011-03-17 | 260d? | 131d |  | R1,R2,R3,R4 | 5688h | MUMIMO_LCR_TDD | PCG-24 | CATT | Yanping Xing (xingyanping@datangmobile.cn) | Rel-10 | RP-47 | Patrick |  |
| 145 | 61.1 | Core - MU-MIMO for 1.28Mcps TDD | 191d? | 2010-03-19 | 2010-12-10 | 2010-03-19 | 2010-12-10 | 191d? | 200d | finish no earlier than 2010-12-10 | R1,R2,R3 | 1528h | MUMIMO_LCR_TDD-Core | PCG-24 | CATT | Yanping Xing (xingyanping@datangmobile.cn) | Rel-10 | RP-47 | Patrick |  |
| 146 | 61.2 | Perf - MU-MIMO for 1.28Mcps TDD | 260d? | 2010-03-19 | 2011-03-17 | 2010-03-19 | 2011-03-17 | 260d? | 131d | finish no earlier than 2011-03-17 | R4 | 2080h | MUMIMO_LCR_TDD-Perf | PCG-24 | CATT | Sanjun Feng (fengsanjun@datangmobile.cn) | Rel-10 | RP-47 | Issam |  |
| 147 | 62 | **Performance Requirements for two-antenna 1.28Mcps TDD Type 1 and Type 2 UE receiver** | 191d? | 2010-03-19 | 2010-12-10 | 2010-03-19 | 2010-12-10 | 191d? | 200d |  | R4 | 3504h | 2ant_UE_LCR_TDD | PCG-24 | TD Tech | Dafei Wang | Rel-10 | RP-47 | Issam |  |
| 148 | 62.1 | Core - Performance Requirements for two-antenna 1.28Mcps TDD Type 1 and Type 2 UE receiver | 56d? | 2010-03-19 | 2010-06-04 | 2010-03-19 | 2010-06-04 | 56d? | 335d | finish no earlier than 2010-06-04 | R4 | 448h | 2ant_UE_LCR_TDD-Core | PCG-24 | TD Tech | Dafei Wang | Rel-10 | RP-47 | Issam |  |
| 149 | 62.2 | Perf - Performance Requirements for two-antenna 1.28Mcps TDD Type 1 and Type 2 UE receiver | 191d? | 2010-03-19 | 2010-12-10 | 2010-03-19 | 2010-12-10 | 191d? | 200d | finish no earlier than 2010-12-10 | R4 | 1528h | 2ant_UE_LCR_TDD-Perf | PCG-24 | TD Tech | Dafei Wang | Rel-10 | RP-47 | Issam |  |
| 150 | 63 | (Small) Technical Enhancements and Improvements for Rel-10 | 136d? | 2009-06-04 | 2009-12-10 | 2009-06-04 | 2009-12-10 | 136d? | 461d | finish no earlier than 2009-12-10 | All | 1088h | TEI10 | PCG-23 |  |  | Rel-10 | SP-44 |  |  |

Notes:
- 126: common UTRA and E-UTRA Work Item to ensure that divergence between the systems is minimized
- 127: common UTRA and E-UTRA Work Item to ensure that divergence between the systems is minimized / Text3: 25.413, 25.467, 25.468, 25.469, 36.300, 36.401, 36.413, 36.423
- 128: Ensure that Enhanced Interference Management methods identified in Rel-9 for HNBs do not fail in deployments with a large penetration of CSG-aware UEs
- 129: Ensure that Enhanced Interference Management methods identified in Rel-9 for HNBs do not fail in deployments with a large penetration of CSG-aware UEs / Text3: 25.413, 25.467, 25.469
- 130: Stage 3 Triggered by FS_RAN_LTEA (Study on LTE-Advanced) 36.912, 36. 814
- 131: - / Text3: 36.101, 36.133, 36.201, 36.211, 36.212, 36.213, 36.214, 36.300, 36.321, 36.331, 36.413, 36.423, new TR 36.8xy
- 132: - / Text3: 36.101, 36.133
- 133: Stage 3
- 134: - / Text3: 36.101, 36.104, 36.113, 36.124, 36.133, 36.141, 36.307, 36.331, 25.461, 25.466, new TR 36.8yy LTE-TDD 2600MHz in US Work Item Technical report
- 135: - / Text3: 36.101, 36.104, 36.133, 36.141, 36.307
- 136: Stage 3 , ATC=Ancillary Terrestrial Component, MSS=Mobile Satellite Service
- 137: - / Text3: 25.461, 25.466, 36.101, 36.104, 36.113, 36.124, 36.133, new TR xx.xxx LTE in 2 GHz Technical Report
- 138: - / Text3: 36.101, 36.104, 36.113, 36.124, 36.133, 36.141
- 139: Stage 3 , ATC=Ancillary Terrestrial Component, MSS=Mobile Satellite Service
- 140: - / Text3: 25.461, 25.466, 34.124, 36.101, 36.104, 36.113, 36.124, 36.133, new TR xx.xxx LTE L-Band Technical Report
- 141: - / Text3: 34.124, 36.101, 36.104, 36.113, 36.124, 36.133, 36.141
- 142: Stage 1,2,3
- 143: - / Text3: 36.300, 36.413, 36.423, 36.902
- 144: -
- 145: - / Text3: 25.221, 25.222, 25.224, 25.306, 25.308, 25.319, 25.331, 25.423, 25.425, 25.433, 25.435
- 146: - / Text3: 25.102, 25.105, 25.142
- 147: Stage 3
- 148: - / Text3: 25.102
- 149: - / Text3: 25.102
- 150: -

| ID | WBS | Task | Type | Duration | Start | Finish | Complete | Remaining | Baseline start | Baseline finish | Baseline duration | Total slack | Constraint | Resources | Work | Actual work | Text1 | Text2 | Text4 | Text6 | Text7 | Text8 | Text9 | Text12 | Text3 | Text11 |
| --- | --- | --- | --- | --- | --- | --- | --- | --- | --- | --- | --- | --- | --- | --- | --- | --- | --- | --- | --- | --- | --- | --- | --- | --- | --- | --- |
| 151 | 64 | **Deleted - Network Selection for non-3GPP Access** |  | 471d? | 2007-12-07 A | 2009-09-24 A | 100% |  | 2007-12-07 | 2009-09-24 | 471d? |  |  | S1,C6 | 10452.8h | 10452.8h | N3GtoNSP | PCG-21 | Telefonica O2 | Rel-10 | SP-38 | Alain | PCG-23 | SP-45 |  |  |
| 152 | 64.1 | Deleted - Stage 1 for N3GtoNSP |  | 471d? | 2007-12-07 A | 2009-09-24 A | 100% |  | 2007-12-07 | 2009-09-24 | 471d? |  | finish no earlier than 2009-12-10 | S1 | 3768h | 3768h | N3GtoNSP | PCG-21 | Telefonica O2 | Rel-10 | SP-38 | Alain | PCG-23 | SP-45 | 22.011 |  |
| 153 | 64.2 | Deleted - CT6 issues for N3GtoNSP |  | 471d? | 2007-12-07 A | 2009-09-24 A | 100% |  | 2007-12-07 | 2009-09-24 | 471d? |  | finish no earlier than 2009-12-04 | C6 | 3768h | 3768h | N3GtoNSP | PCG-21 | Telefonica O2 | Rel-10 | CP-38 | Xavier | PCG-23 | CP-45 | 36.300 |  |
| 154 | 65 | **Deleted - Registration in Densely-populated area (RED)** |  | 665d? | 2007-03-12 A | 2009-09-24 A | 100% |  | 2007-03-12 | 2009-09-24 | 665d? |  |  | S1 | 9544h | 9544h | RED |  | NTT DoCoMo | Rel-10 | SP-35 | Alain | PCG-24 | SP-46 | WID identifies also impacted CT1 24.008, RAN2 25.331 |  |
| 155 | 65.1 | Deleted - Stage 1 for RED |  | 4d? | 2007-03-12 A | 2007-03-15 A | 100% |  | 2007-03-12 | 2007-03-15 | 4d? |  | start no earlier than 2007-03-12 | S1 | 32h | 32h | RED |  | NTT DoCoMo | Rel-10 | SP-35 | Alain | PCG-24 | SP-46 | 22.101 CR#0207 |  |
| 156 | 65.2 | Deleted - Stage 2 for RED |  | 524d? | 2007-09-25 A | 2009-09-24 A | 100% |  | 2007-09-25 | 2009-09-24 | 524d? |  | finish no earlier than 2009-09-24 | S2 | 4192h | 4192h | RED |  | NTT DoCoMo | Rel-10 | SP-37 | Maurice | PCG-23 | SP-45 | draft TR 23.880 withdrawn, 23.002, 23.060, 23.221, 23.236 |  |
| 157 | 66 | Deleted - Enhanced Home NodeB / eNodeB continuation of Rel-9 |  | 337d? | 2008-12-11 A | 2010-03-25 A | 100% |  | 2008-12-11 | 2010-03-25 | 337d? |  |  | S2 | 2696h | 2696h | eEHNB | PCG-23 | Alcatel-Lucent | Rel-10 | SP-44 | Maurice | PCG-24 | SP-47 |  |  |
| 158 | 67 | Release 10 Studies | milestone | 0d? | 2000-01-01 | 2000-01-01 |  |  | 2000-01-01 | 2000-01-01 | 0d? | 3057d | start no earlier than 2000-01-01 | CP,GP,RP,SP |  |  |  |  |  | Rel-10 |  |  |  |  |  |  |
| 159 | 68 | **Study on enhanced voice service requirements for the Evolved Packet System (EPS)** |  | 670d? | 2007-09-03 A | 2010-03-25 A | 100% |  | 2007-09-03 | 2010-03-25 | 670d? |  |  | S1,S4 | 13384h | 13384h | FS_EV_EPS |  | Orange | Rel-10 | SP-37 | Alain |  |  | 22.813 |  |
| 160 | 68.1 | Use cases definition and service and system requirements |  | 334d? | 2007-09-03 A | 2008-12-11 A | 100% |  | 2007-09-03 | 2008-12-11 | 334d? |  | finish no earlier than 2008-12-11 | S1 | 2672h | 2672h | FS_EV_EPS-S1 |  | Orange | Rel-10 | SP-37 | Alain |  |  | 22.813 |  |
| 161 | 68.2 | Codec specific part of FS_EV_EPS |  | 669d? | 2007-09-03 A | 2010-03-25 A | 100% |  | 2007-09-03 | 2010-03-25 | 669d? |  | finish no earlier than 2010-03-25 | S4 | 5352h | 5352h | FS_EV_EPS-S4 |  | Ericsson | Rel-10 | SP-37 | Paolo |  |  | 22.813 |  |
| 162 | 69 | Study on advanced requirements for IP interconnect |  | 528d? | 2007-12-04 A | 2009-12-10 A | 100% |  | 2007-12-04 | 2009-12-10 | 528d? |  | finish no earlier than 2009-12-10 | S1 | 4224h | 4224h | FS_IPXS | PCG-21 | Telefonica O2 | Rel-10 | SP-38 | Alain |  |  | 22.893 |  |
| 163 | 70 | Deleted - Study on Unauthenticated PS Emergency Calls |  | 471d? | 2008-06-05 A | 2010-03-25 A | 100% |  | 2008-06-05 | 2010-03-25 | 471d? |  | finish no earlier than 2010-03-25 | S1 | 3768h | 3768h | FS_UAPSEC | PCG-21 | Nokia Siemens Networks | Rel-10 | SP-40 | Alain | PCG-24 | SP-47 | 22.984 |  |
| 164 | 71 | Study on Personal Broadcast Service |  | 397d? | 2008-09-18 A | 2010-03-25 A | 100% |  | 2008-09-18 | 2010-03-25 | 397d? |  | finish no earlier than 2010-03-25 | S1 | 3168h | 3168h | FS_PBS | PCG-21 | ETRI | Rel-10 | SP-41 | Alain |  |  | 22.947 |  |
| 165 | 72 | Study on LCS support in SAE for non-3GPP accesses |  | 397d? | 2008-09-18 A | 2010-03-25 A | 100% |  | 2008-09-18 | 2010-03-25 | 397d? |  | finish no earlier than 2010-03-25 | S1 | 3168h | 3168h | FS_LCS_n3GPP | PCG-21 | SK Telecom | Rel-10 | SP-41 | Alain |  |  | 22.913 |  |
| 166 | 73 | Study on Haptic Services |  | 272d? | 2009-03-12 A | 2010-03-25 A | 100% |  | 2009-03-12 | 2010-03-25 | 272d? |  | finish no earlier than 2010-03-25 | S1 | 2168h | 2168h | FS_Haptics | PCG-22 | SK Telecom | Rel-10 | SP-43 | Alain |  |  | 22.987 |  |
| 167 | 74 | Study on System enhancements for the use of IMS services in Local BreakOut and Optimal Routing of Media |  | 575d? | 2007-10-01 A | 2009-12-10 A | 100% |  | 2007-10-01 | 2009-12-10 | 575d? |  | finish no earlier than 2009-12-10 | S2 | 4600h | 4600h | FS_IMS_LBO_ORM |  | Telecom Italia, BT | Rel-10 | SP-37 | Maurice |  |  | 23.894 |  |
| 168 | 75 | Study on Intra Domain Connection of RAN Nodes to Multiple CN Nodes |  | 533d? | 2008-03-12 A | 2010-03-25 A | 100% |  | 2008-03-12 | 2010-03-25 | 533d? |  | finish no earlier than 2010-03-25 | S2 | 4264h | 4264h | FS_IDC | PCG-21 | China Mobile | Rel-10 | SP-39 | Maurice |  |  | 23.924 (was 23.823) |  |
| 169 | 76 | Study on IMS Evolution |  | 527d? | 2008-09-18 A | 2010-09-23 | 75% | 131d? | 2008-09-18 | 2010-09-23 | 527d? | 256d | finish no earlier than 2010-09-23 | S2 | 4216h | 3168h | FS_eIMS | PCG-21 | China Mobile | Rel-10 | SP-41 | Maurice |  |  | 23.812 |  |
| 170 | 77 | Study on enhancements to IMS border functions for IMS Interconnection of services |  | 527d? | 2008-09-18 A | 2010-09-23 | 35% | 342.2d? | 2008-09-18 | 2010-09-23 | 527d? | 256d | finish no earlier than 2010-09-23 | S2 | 4216h | 1478.4h | FS_eIMS_IBCF | PCG-21 | Starent Networks | Rel-10 | SP-41 | Maurice |  |  | 23.848 |  |
| 171 | 78 | Study on Multi Access PDN connectivity and IP flow Mobility |  | 452d? | 2008-09-18 A | 2010-06-10 | 75% | 113d? | 2008-09-18 | 2010-06-10 | 452d? | 331d | finish no earlier than 2010-06-10 | S2,S1 | 3616h | 2712h | FS_MAPIM | PCG-21 | Qualcomm | Rel-10 | SP-41 | Maurice |  |  | 23.861 |  |
| 172 | 79 | Study on Policy solutions and enhancements |  | 401d? | 2009-06-04 A | 2010-12-16 | 35% | 260.65d? | 2009-06-04 | 2010-12-16 | 401d? | 196d | finish no earlier than 2010-12-16 | S2,S1 | 3208h | 1122.8h | FS_PP | PCG-23 | AT&T | Rel-10 | SP-44 | Maurice |  |  | 23.813 |  |
| 173 | 80 | Study on IPv6 Migration |  | 266d? | 2009-06-04 A | 2010-06-10 | 70% | 79.8d? | 2009-06-04 | 2010-06-10 | 266d? | 331d | finish no earlier than 2010-06-10 | S2 | 2128h | 1489.6h | FS_IP6M | PCG-23 | China Mobile | Rel-10 | SP-44 | Maurice |  |  | 23.975 |  |
| 174 | 81 | Study on Single Radio Video Call Continuity enhancements |  | 341d? | 2009-06-04 A | 2010-09-23 | 60% | 136.4d? | 2009-06-04 | 2010-09-23 | 341d? | 256d | finish no earlier than 2010-09-23 | S2 | 2728h | 1636.8h | FS_eSRVCC | PCG-23 | China Mobile | Rel-10 | SP-44 | Maurice |  |  | 23.856 |  |
| 175 | 82 | Study on Single Radio Video Call Continuity from UTRAN/GERAN to E-UTRAN/HSPA |  | 206d? | 2009-12-10 A | 2010-09-23 | 20% | 164.8d? | 2009-12-10 | 2010-09-23 | 206d? | 256d | finish no earlier than 2010-09-23 | S2 | 1648h | 329.6h | FS_rSRVCC | PCG-24 | Orange | Rel-10 | SP-46 | Maurice |  |  | 23.885 |  |
| 176 | 83 | Study on Single Radio Video Call Continuity for 3G-CS |  | 131d? | 2010-03-25 | 2010-09-23 |  |  | 2010-03-25 | 2010-09-23 | 131d? | 256d | finish no earlier than 2010-09-23 | S2 | 1048h |  | FS_vSRVCC | PCG-24 | Samsung | Rel-10 | SP-47 | Maurice |  |  | 23.8yz |  |
| 177 | 84 | Study on S2b Mobility based on GTP |  | 131d? | 2010-03-25 | 2010-09-23 |  |  | 2010-03-25 | 2010-09-23 | 131d? | 256d | finish no earlier than 2010-09-23 | S2 | 1048h |  | FS_SMOG | PCG-24 | Alcatel-Lucent | Rel-10 | SP-47 | Maurice |  |  | 23.8yz |  |
| 178 | 85 | Study on UTRAN key management enhancements |  | 782d? | 2007-12-20 A | 2010-12-16 | 50% | 391d? | 2007-12-20 | 2010-12-16 | 782d? | 196d | finish no earlier than 2010-12-16 | S3 | 6256h | 3128h | FS_UKM | PCG-21 | Ericsson | Rel-10 | SP-38 | Dionisio |  |  | 33.8xy |  |
| 179 | 86 | Study on Surround Sound codec extension for PSS and MBMS |  | 326d? | 2009-03-12 A | 2010-06-10 | 60% | 130.4d? | 2009-03-12 | 2010-06-10 | 326d? | 331d | finish no earlier than 2010-06-10 | S4 | 2608h | 1564.8h | FS_SS_PSS_MBMS | PCG-22 | Fraunhofer Gesellschaft | Rel-10 | SP-43 | Paolo |  |  | 26.950 |  |
| 180 | 87 | Study on Rc Reference Point Functionalities and Message Flows |  | 397d? | 2008-09-18 A | 2010-03-25 A | 100% |  | 2008-09-18 | 2010-03-25 | 397d? |  | finish no earlier than 2010-03-23 | S5 | 3170.08h | 3170.08h | FS_OAM_Rc | PCG-21 | Huawei | Rel-10 | SP-41 | Dionisio |  |  | 32.825 |  |
| 181 | 88 | Study on Telecommunication Management; Energy Savings Management |  | 271d? | 2009-03-12 A | 2010-03-25 A | 100% |  | 2009-03-12 | 2010-03-25 | 271d? |  | finish no earlier than 2010-03-25 | S5 | 2168h | 2168h | FS_OAM_ESM | PCG-22 | Orange, Vodafone | Rel-10 | SP-43 | Dionisio |  |  | 32.826 |  |
| 182 | 89 | Study on Integration of Device Management Information with Itf-N |  | 211d? | 2009-06-04 A | 2010-03-25 A | 100% |  | 2009-06-04 | 2010-03-25 | 211d? |  | finish no earlier than 2010-03-25 | S5 | 1688h | 1688h | FS_IDMI_Itf-N | PCG-23 | Motorola | Rel-10 | SP-44 | Dionisio |  |  | 32.827 |  |
| 183 | 90 | Deleted - Study on EPC Charging enhancement |  | 211d? | 2009-06-04 A | 2010-03-25 A | 100% |  | 2009-06-04 | 2010-03-25 | 211d? |  | finish no earlier than 2010-03-25 | S5 | 1688h | 1688h | FS_EPCcharg | PCG-23 | Nokia Siemens Networks | Rel-10 | SP-44 | Dionisio | PCG-24 | SP-47 |  |  |
| 184 | 91 | Study on Alignment of 3GPP Generic NRM IRP and TMF Shared Information Data (SID) model |  | 131d? | 2009-12-10 A | 2010-06-10 | 20% | 104.8d? | 2009-12-10 | 2010-06-10 | 131d? | 331d |  | S5 | 1048h | 209.6h | FS_3GNRM_TMFSID | PCG-24 | Nokia Siemens Networks | Rel-10 | SP-46 | Dionisio |  |  | 32.8xy |  |
| 185 | 92 | Study on Harmonization of 3GPP Alarm IRP and TMF Interface Program (TIP) Fault Management |  | 131d? | 2009-12-10 A | 2010-06-10 | 30% | 91.7d? | 2009-12-10 | 2010-06-10 | 131d? | 331d | finish no earlier than 2010-06-10 | S5 | 1048h | 314.4h | FS_3G_TMF_FM | PCG-24 | Nokia Siemens Networks, Alcatel-Lucent | Rel-10 | SP-46 | Dionisio |  |  | 32.8xy |  |
| 186 | 93 | Study on version handling |  | 131d? | 2010-03-25 | 2010-09-23 |  |  | 2010-03-25 | 2010-09-23 | 131d? | 256d | finish no earlier than 2010-09-23 | S5 | 1048h |  | FS_OAM_VH | PCG-24 | Ericsson | Rel-10 | SP-47 | Dionisio |  |  | 32.8xx |  |
| 187 | 94 | Study on Interworking Proxy between GTP based and PMIP based interfaces |  | 186d? | 2009-09-18 A | 2010-06-04 | 80% | 37.2d? | 2009-09-18 | 2010-06-04 | 186d? | 335d | finish no earlier than 2010-06-04 | C4 | 1488h | 1190.4h | FS_GTP-MIP-IW | PCG-23 | NTT DoCoMo | Rel-10 | CP-45 | Kimmo |  |  | 29.875 |  |
| 188 | 95 | Study on Policy and Charging Rules Function (PCRF) failure and restoration |  | 186d? | 2009-08-18 A | 2010-06-04 | 70% | 55.8d? | 2009-08-18 | 2010-06-04 | 186d? | 335d | finish no earlier than 2010-06-04 | C3 | 1488h | 1041.6h | FS_PCRF-FR | PCG-23 | NEC | Rel-10 | CP-45 | Gwiho |  |  | 29.816 |  |
| 189 | 96 | Study on Measurement of Radiated Performance for MIMO and multi-antenna reception for HSPA and LTE terminals |  | 256.8d? | 2009-03-06 A | 2010-06-04 | 55% | 115.56d? | 2009-03-06 | 2010-06-04 | 256.8d? | 335d | finish no earlier than 2010-06-04 | R4 | 2054.4h | 1129.92h | FS_HSPA_LTE_measRP_MIMO_multi-antenna | PCG-22 | Vodafone | Rel-10 | RP-43 | Issam |  |  | TR (25/36) | RP-100081 |
| 190 | 97 | Study on Extending 850 MHz |  | 266d? | 2009-05-30 A | 2010-06-04 | 10% | 239.4d? | 2009-05-30 | 2010-06-04 | 266d? | 335d | finish no earlier than 2010-06-04 | R4 | 2128h | 212.8h | FS_e850 | PCG-23 | Ericsson | Rel-10 | RP-44 | Issam |  |  | TR xx.yyy | RP-100082 |
| 191 | 98 | Study on Uplink Tx Diversity for HSPA |  | 208.4d? | 2009-08-18 A | 2010-06-04 | 38% | 129.21d? | 2009-08-18 | 2010-06-04 | 208.4d? | 335d | finish no earlier than 2010-06-04 | R4 | 1667.2h | 633.53h | FS_UL-TxDiv-HSPA | PCG-23 | Qualcomm | Rel-10 | RP-45 | Issam |  |  | 25.8xx | RP-100083 |
| 192 | 99 | Study on RAN improvements for Machine-Type Communications |  | 321d? | 2009-09-18 A | 2010-12-10 | 10% | 288.9d? | 2009-09-18 | 2010-12-10 | 321d? | 200d | finish no earlier than 2010-12-10 | R2,R1,R3,R4 | 2568h | 256.8h | FS_NIMTC_RAN | PCG-23 | Huawei | Rel-10 | RP-45 | Joern |  |  | 37.868 | RP-100084 |
| 193 | 100 | Study on GERAN improvements for Machine-Type Communications |  | 206d? | 2009-11-20 | 2010-09-03 |  |  | 2009-11-20 | 2010-09-03 | 206d? | 270d | finish no earlier than 2010-09-03 | GP | 1648h |  | FS_NIMTC_GERAN | PCG-24 | Ericsson | Rel-10 | GP-44 | Paolo |  |  | 45.8/9xy |  |
| 194 | 101 | Study on Solutions for energy saving within UTRA Node B |  | 141d? | 2009-12-04 A | 2010-06-18 | 10% | 126.9d? | 2009-12-04 | 2010-06-18 | 141d? | 325d | finish no earlier than 2010-06-18 | R1,R3 | 1128h | 112.8h | FS_Energy_UMTS | PCG-24 | Vodafone | Rel-10 | RP-46 | Patrick |  |  | 25.927 | RP-100085 |
| 195 | 102 | Study on Coordinated Multi-Point operation for LTE |  | 270d? | 2010-06-04 | 2011-06-16 |  |  | 2010-06-04 | 2011-06-16 | 270d? | 66d | start no earlier than 2010-06-04 | R1 | 2160h |  | FS_COMP_LTE | PCG-24 | Samsung | Rel-10 | RP-47 | Patrick |  |  | 36.8xx |  |
| 196 | 103 | Study on Network Energy Saving for E-UTRAN |  | 131d? | 2010-03-19 | 2010-09-17 |  |  | 2010-03-19 | 2010-09-17 | 131d? | 260d | finish no earlier than 2010-09-17 | R3 | 1048h |  | FS_Energy_LTE | PCG-24 | China Mobile | Rel-10 | RP-47 | Juha |  |  | 36.8xx (Potential solutions for energy saving for E-UTRAN) |  |
| 197 | 104 | Study on Improvements of distributed antenna for 1.28Mcps TDD |  | 191d? | 2010-03-19 | 2010-12-10 |  |  | 2010-03-19 | 2010-12-10 | 191d? | 200d | finish no earlier than 2010-12-10 | R1 | 1528h |  | FS_distr_ant_LCR_TDD | PCG-24 | ZTE | Rel-10 | RP-47 | Patrick |  |  | 25.8xy |  |
| 198 | 105 | Release 9 Features | milestone | 0d? | 2000-01-01 | 2000-01-01 |  |  | 2000-01-01 | 2000-01-01 | 0d? | 3057d |  | CP,GP,RP,SP |  |  |  |  |  | Rel-9 |  |  |  |  |  |  |

Notes:
- 151: SP#45 work stopped/abandoned / Text5: chris.friel@O2.com
- 152: SP#45 work stopped/abandoned / Text5: chris.friel@O2.com
- 153: SP#45 work stopped/abandoned / Text5: chris.friel@O2.com
- 154: SP#35 Stage 1 completed. SP#45 Stage 2 work stopped. SP#46 work stopped/abandoned / Text5: tanakai@nttdocomo.co.jp
- 155: SP#35 completed. SP#46 work stopped/abandoned / Text5: takakurat@s1.nttdocomo.co.jp
- 156: SP#45 Stage 2 work stopped / Text5: tanakai@nttdocomo.co.jp
- 157: SP#47 deleted (SA2 work moved under SA1 UID_450053). SP#44 Umbrella Feature created to host WIs moved out of Rel-9 (SA2 UID_420034 on IMS aspects of Architecture for Home NodeB) / Text5: Nicolas Drevon
- 158: -
- 159: SP#47 completed. TR 22.813-100 for Approval / Text5: tim.haysom@orange-ftgroup.com
- 160: SP#47 completed. TR 22.813-100 for Approval / Text5: tim.haysom@orange-ftgroup.com
- 161: SP#47 completed. TR 22.813-100 for Approval / Text5: stefan.bruhn@ericson.com
- 162: SP#46 completed. Linked to Rel-8 Feature UID_380060 IP Interconnection of Services (IPinterc) / Text5: chris.friel@O2.com
- 163: SP#47 work stopped/abandoned / Text5: Juergen Merkel
- 164: SP#47 completed / Text5: Jaihyung Cho
- 165: SP#47 completed / Text5: Donghee Shim
- 166: SP#47 completed. Covers Mobile/Fixed/Cordless/etc terminals. Haptic (human-machine tactile communication) extend service offering & richness of user experience beyond current visual & auditory senses / Text5: Jinhan Song
- 167: SP#46 completed. Spin-off Feature UID_460028 Optimal Media Routeing (OMR). Linked to Study on Multimedia Session Continuity UID_350051, Study on Centralized IMS Service Control UID_330012, IMS inter-operator service interconnection interface UID_360011 / Text5: mario.madella@telecomitalia.it, victor.kueh@bt.com
- 168: SP#47 completed. Concluded no further normative work expected. Linked to 23.236 / Text5: LIU HONG (liuhongyfw@chinamobile.com)
- 169: SP#47 completion 03/10=>09/10. TR 23.812 v100 for Information / Text5: Li Gang (ligangyf@chinamobile.com), Yu Qing (yuqing@chinamobile.com)
- 170: SP#47 completion 06/10=>09/10 / Text5: Rajat Ghai (rghai@starentnetworks.com)
- 171: SP#47 completion 03/10=>06/10 (No consensus on starting normative work for network-based mobility (PMIP) option. Note: DSMIPv6-based option already pursued in 23.261). Spin-off UID_430035 MAPCON and UID_450041 IFOM / Text5: Gerardo Giaretta (gerardog@qualcomm.com)
- 172: SP#46 updated WID SP-090361=>SP-090805. Study an evolved policy solution through enhancement of 3GPP policy framework (Stage 2). Consider aspects such as DPI, traffic steering, enhancing service policies / Text5: farooq.bari@att.com
- 173: Study how to migrate from IPv4 to IPv6-only with the help of transition mechanisms defined in IETF, and how to handle scenarios where not all services are provided via IPv6. Some of these solutions may have impacts on 3GPP network elements and terminals. / Text5: Li Lianyuan (lilianyuan@chinamobile.com), Liu Hong (liuhongyfw@chinamobile.com)
- 174: SP#47 TR 23.856-100 for Information. Analyze current performance of SR-VCC solution in Rel-8 from E-UTRAN/HSPA to UTRAN/GERAN, and then evaluate additional mechanisms to improve user experience. Study if SR-VCC performance needs to be enhanced. / Text5: Hou zhiqiang (houzhiqiang@chinamobile.com), Jiang Yi (jiangyi@chinamobile.com)
- 175: SP#47 completion 06/10=>09/10. Study on "reverse direction" from UTRAN/GERAN to E-UTRAN/HSPA (Rel-8 SRVCC was in the other direction E-UTRAN/HSPA to GERAN/UTRAN) / Text5: delphin.barankanira@orange-ftgroup.com
- 176: Related to Rel-8 UID_350030 Single Radio Voice Call Continuity for 3GPP (SAES-SRVCC). Study how to provide Video Call seamless service continuity for 3G/LTE terminal user / Text5: Haris Zisimopoulos (haris.z@samsung.com)
- 177: SP#47 No completion date proveded.Triggered by Rel-8 UID_350027 SAE for support for non-3GPP accesses. Nature of relationship: S2b one of the interfaces defined for non-3GPP accesses support in EPS. Stage 1 in Rel-8 UID_320022 (AIPN-SAE) 22.278,22.101 / Text5: bruno.landais@alcatel-lucent.com
- 178: SP#44 SID updated SP-070782=>SP-090283 (removed UTRAN/E-UTRAN IRAT signalling cases from Study scope (while IRAT handling is left as specified by 33.401). Study also focuses on support for a key hierarchy locally in UTRAN and intra-UTRAN mobility cases.) / Text5: Karl Norrman
- 179: SP#47 TR 26.950-100 for Information. Work to extend Rel-8 UID_34043 PSS_MBMS_OMTV (Extending PSS and MBMS User Services for optimized Mobile TV) / Text5: jan.plogsties@iis.franhofer.de
- 180: SP#47 completed / Text5: shan.mingjun@huawei.com
- 181: SP#47 completed. Study result might impact Feature UID_420011 Self Organising Networks (SON) / Text5: Jean-Michel Cornilly (Orange)
- 182: SP#47 completed. TR 32.827 v100 for Information + Approval. WID updated SP-090462=>SP-100088. Study the missing Itf-N part in the Framework. Study changes to Itf-N to utilize UE based measurements / Text5: Yizhi Yao (yzyao@motorola.com)
- 183: SP#47 work stopped. Issue covered by Rel-10 UID_460039 Charging for LIPA_SIPTO and UID_4700xy Charging for IFOM / Text5: Gerald.Goermer@nsn.com
- 184: - / Text5: Olaf Pollakowski
- 185: - / Text5: Olaf Pollakowski, Padma Sudarsan
- 186: - / Text5: thomas.tovinger@ericsson.com
- 187: CP#47 completion 03/10=>06/10. Moved to Rel-10 / Text5: takaaki.matsuura.sp@s1.nttdocomo.com
- 188: CP#47 TR 29.816 v100 for Information / Text5: gottfried.punz@nw.neclab.eu
- 189: - / Text5: soonleh.ling@vodafone.com
- 190: RP#46 completion 12/09=>06/10 / Text5: Christian Bergljung (christian.bergljung@stericsson.com)
- 191: - / Text5: Heechoon Lee (heechoon@qualcomm.com)
- 192: RP#47 updated WID RP-09099=>RP-100330. Completion 06/10=>12/10. Triggered by UID_7027 Study on Facilitating Machine to Machine Communication in GSM and UMTS (M2M) TR 22.868 and Rel-10 UID_410030 Network Improvements for Machine-Type Communications (NIMTC) / Text5: arnaud.meylan@huawei.com
- 193: SA1 TS 22.36 (Stage 1) to be approved before GERAN work starts / Text5: Paul Schliwa-Bertling
- 194: Based on ETSI EE TS 102 706 and Linked to SA5 Rel-9 UID_430044 TR 32.826 (Study on Telecommunication Management; Energy Savings Management) / Text5: Prakash Bhat
- 195: - / Text5: bruno.clerckx@samsung.com
- 196: - / Text5: Yang Ning (yangning@chinamobile.com)
- 197: - / Text5: huang.he4@zte.com.cn
- 198: -

| ID | WBS | Task | Duration | Start | Finish | Complete | Remaining | Baseline start | Baseline finish | Baseline duration | Total slack | Constraint | Resources | Work | Actual work | Text1 | Text2 | Text4 | Text5 | Text6 | Text7 | Text8 | Text11 |
| --- | --- | --- | --- | --- | --- | --- | --- | --- | --- | --- | --- | --- | --- | --- | --- | --- | --- | --- | --- | --- | --- | --- | --- |
| 199 | 106 | **Enhanced Home NodeB / eNodeB** | 523d? | 2008-06-05 A | 2010-06-04 | 96% | 20.57d? | 2008-06-05 | 2010-06-04 | 523d? | 335d |  | S1,S2,S3,S5,R2,R3,R4,GP,C1 | 30416h | 29219.4h | EHNB | PCG-21 | T-Mobile | michael.kurz@t-mobile.at | Rel-9 | SP-40 | Alain |  |
| 200 | 106.1 | Stage 1 for EHNB | 261d? | 2008-06-05 A | 2009-06-04 A | 100% |  | 2008-06-05 | 2009-06-04 | 261d? |  | finish no earlier than 2009-06-04 | S1 | 2088h | 2088h | EHNB | PCG-21 | T-Mobile | michael.kurz@t-mobile.at | Rel-9 | SP-40 | Alain |  |
| 201 | 106.2 | Architecture aspects of EHNB | 266d? | 2008-09-18 A | 2009-09-24 A | 100% |  | 2008-09-18 | 2009-09-24 | 266d? |  | finish no earlier than 2009-09-22 | S2 | 2128h | 2128h | EHNB | PCG-21 | T-Mobile | Sebastian Speicher | Rel-9 | SP-41 | Maurice |  |
| 202 | 106.3 | Security aspects of Enhanced Home NodeB / eNodeB | 262d? | 2008-12-11 A | 2009-12-10 A | 100% |  | 2008-12-11 | 2009-12-10 | 262d? |  | finish no earlier than 2009-12-10 | S3 | 2096h | 2096h | EHNB-Sec | PCG-22 | Huawei | Marcus Wong (mwong@huawei.com) | Rel-9 | SP-42 | Dionisio |  |
| 203 | 106.4 | CT1 aspects - Support of Home NB and Home eNB enhancements | 186d? | 2009-09-18 A | 2010-06-04 | 95% | 9.3d? | 2009-09-18 | 2010-06-04 | 186d? | 335d | finish no earlier than 2010-06-04 | C1 | 1488h | 1413.6h | EHNB-CT1 | PCG-23 | Qualcomm | Ramachandran Subramanian (rsubrama@qualcomm.com) | Rel-9 | CP-45 | Frederic |  |
| 204 | 106.5 | CT6 aspects - Support of Home NB and Home eNB enhancements | 131d? | 2009-09-18 A | 2010-03-19 A | 100% |  | 2009-09-18 | 2010-03-19 | 131d? |  | finish no earlier than 2010-03-19 | C6 | 1048h | 1048h | EHNB-CT6 | PCG-23 | Qualcomm | Alfredo Ruvacalba | Rel-9 | CP-45 | Xavier |  |
| 205 | 106.6 | 3G HNB Gateway and LTE HeNB Gateway OAM&P | 336d? | 2008-12-11 A | 2010-03-25 A | 100% |  | 2008-12-11 | 2010-03-25 | 336d? |  | finish no earlier than 2010-03-25 | S5 | 2688h | 2688h | HNB-OAM_GW | PCG-22 | China Mobile | GangChen (chengang@chinamobile.com) | Rel-9 | SP-42 | Dionisio |  |
| 206 | 106.7 | 3G HNB and LTE HeNB OAM&P Type 1 Interface | 272d? | 2009-03-12 A | 2010-03-25 A | 100% |  | 2009-03-12 | 2010-03-25 | 272d? |  | finish no earlier than 2010-03-25 | S5 | 2168h | 2168h | HNB_eHNB-OAM_Type1 | PCG-22 | Huawei | Zou Lan (zlan@huawei.com) | Rel-9 | SP-43 | Dionisio |  |
| 207 | 106.8 | 3G HNB and LTE HeNB OAM&P Type 2 Interface | 225d? | 2009-05-15 A | 2010-03-25 A | 100% |  | 2009-05-15 | 2010-03-25 | 225d? |  | finish no earlier than 2010-03-25 | S5 | 1800h | 1800h | HNB_eHNB-OAM_Type2 | PCG-23 | Ericsson | edwin.tse@ericsson.com | Rel-9 | SP-44 | Dionisio |  |
| 208 | 106.9 | LTE FDD Home eNodeB RF Requirements | 336d? | 2008-12-05 A | 2010-03-19 A | 100% |  | 2008-12-05 | 2010-03-19 | 336d? |  | finish no earlier than 2010-03-19 | R4 | 2688h | 2688h | HeNB-RF_FDD | PCG-22 | Motorola | Ying Cai (yingcai@motorola.com) | Rel-9 | RP-42 | Issam | RP-100035 |
| 209 | 106.10 | LTE TDD Home eNodeB RF Requirements | 271d? | 2009-03-06 A | 2010-03-19 A | 100% |  | 2009-03-06 | 2010-03-19 | 271d? |  | finish no earlier than 2010-03-19 | R4 | 2168h | 2168h | HeNB-RF_TDD | PCG-22 | China Mobile | Nan Li (linan@chinamobile.com) | Rel-9 | RP-43 | Issam | RP-100036 |
| 210 | 106.11 | Home NB and Home eNB enhancements - RAN3 aspects | 197d? | 2009-03-06 A | 2009-12-04 A | 100% |  | 2009-03-06 | 2009-12-04 | 197d? |  | finish no earlier than 2009-12-04 | R3 | 1576h | 1576h | EHNB-RAN3 | PCG-22 | Alcatel-Lucent | Martin Warner (mw15@alcatel-lucent.com) | Rel-9 | RP-43 | Juha | RP-091050 |
| 211 | 106.12 | Home NB and Home eNB enhancements - RAN2 aspects | 271d? | 2009-03-06 A | 2010-03-19 A | 100% |  | 2009-03-06 | 2010-03-19 | 271d? |  | finish no earlier than 2010-03-19 | R2 | 2168h | 2168h | EHNB-RAN2 | PCG-22 | Huawei | Yang Xudong (yangxudong@huawei.com) | Rel-9 | RP-43 | Joern | RP-100037 |
| 212 | 106.13 | Home NB and Home eNB enhancements - GERAN aspects | 266d? | 2009-05-18 A | 2010-05-21 | 55% | 119.7d? | 2009-05-18 | 2010-05-21 | 266d? | 345d | finish no earlier than 2010-05-21 | GP | 2128h | 1170.4h | EHNB-GERAN | PCG-23 | Nokia Siemens Networks | Leonardo Provvedi | Rel-9 | GP-42 | Paolo |  |
| 213 | 107 | **Services Alignment and Migration** | 467d? | 2006-12-06 A | 2008-09-18 A | 100% |  | 2006-12-06 | 2008-09-18 | 467d? |  |  | S1 | 7472h | 7472h | ServAl |  | China Mobile | fenglingjuan@chinamobile.com | Rel-9 | SP-33 | Alain |  |
| 214 | 107.1 | Stage 1 for ServAl | 467d? | 2006-12-06 A | 2008-09-18 A | 100% |  | 2006-12-06 | 2008-09-18 | 467d? |  | finish no earlier than 2008-12-11 | S1 | 3736h | 3736h | ServAl | PCG-21 | China Mobile | fenglingjuan@chinamobile.com | Rel-9 | SP-33 | Alain |  |
| 215 | 108 | **Value-Added Services for Short Message Service** | 586d? | 2007-09-10 A | 2009-12-04 A | 100% |  | 2007-09-10 | 2009-12-04 | 586d? |  |  | S1,C4,C1 | 10888h | 10888h | VAS4SMS |  | China Mobile | Wu Bin (wubin@chinamobile.com) | Rel-9 | SP-37 | Alain |  |
| 216 | 108.1 | Stage 1 for VAS4SMS | 133d? | 2007-09-10 A | 2008-03-12 A | 100% |  | 2007-09-10 | 2008-03-12 | 133d? |  | finish no earlier than 2008-03-21 | S1 | 1064h | 1064h | VAS4SMS |  | China Mobile | Wu Bin (wubin@chinamobile.com) | Rel-9 | SP-37 | Alain |  |
| 217 | 108.2 | VAS4SMS Interface and Signalling Flow - CT4 aspects | 322d? | 2008-09-12 A | 2009-12-04 A | 100% |  | 2008-09-12 | 2009-12-04 | 322d? |  | finish no earlier than 2009-12-04 | C4 | 2568h | 2568h | VAS4SMS | PCG-21 | China Mobile | Wu Bin (wubin@chinamobile.com) | Rel-9 | CP-41 | Kimmo |  |
| 218 | 108.3 | VAS4SMS Interface and Signalling Flow - CT1 aspects | 321d? | 2008-09-09 A | 2009-12-04 A | 100% |  | 2008-09-09 | 2009-12-04 | 321d? |  | finish no earlier than 2009-12-04 | C1 | 2568h | 2568h | VAS4SMS | PCG-21 | China Mobile | Wu Bin (wubin@chinamobile.com) | Rel-9 | CP-41 | Frederic |  |
| 219 | 109 | **End-User Identity** | 334d? | 2007-09-03 A | 2008-12-11 A | 100% |  | 2007-09-03 | 2008-12-11 | 334d? |  |  | S1 | 5344h | 5344h | EUI |  | Nokia Siemens Networks | Juergen.Merkel@NSN.com | Rel-9 | SP-38 | Alain |  |
| 220 | 109.1 | Definition of EUI | 334d? | 2007-09-03 A | 2008-12-11 A | 100% |  | 2007-09-03 | 2008-12-11 | 334d? |  | finish no earlier than 2008-12-11 | S1 | 2672h | 2672h | EUI | PCG-21 | Nokia Siemens Networks | Juergen.Merkel@NSN.com | Rel-9 | SP-38 | Alain |  |
| 221 | 110 | **Customized Ringing Signal** | 653d? | 2007-12-06 A | 2010-06-04 | 98% | 14.48d? | 2007-12-06 | 2010-06-04 | 653d? | 335d |  | S1,C1 | 8168h | 5072h | CRS | PCG-21 | SK Telecom, China Mobile | Donghee Shim (SK Telecom), Jianping Zheng (China Mobile) | Rel-9 | SP-38 | Alain |  |
| 222 | 110.1 | Stage 1 for CRS | 266d? | 2007-12-06 A | 2008-12-11 A | 100% |  | 2007-12-06 | 2008-12-11 | 266d? |  | finish no earlier than 2008-12-11 | S1 | 2128h | 2128h | CRS | PCG-21 | SK Telecom, China Mobile | Donghee Shim (SK Telecom), Jianping Zheng (China Mobile) | Rel-9 | SP-38 | Alain |  |
| 223 | 110.2 | Stage 3 for IMS CRS Service | 212d? | 2009-05-29 A | 2010-06-04 | 95% | 10.6d? | 2009-05-29 | 2010-06-04 | 212d? | 335d | finish no earlier than 2010-06-04 | C1 | 816h | 816h | CRS | PCG-23 | China Mobile | wangzhao | Rel-9 | CP-44 | Frederic | CP-090868 |

Notes:
- 199: SP#43 WID updated SP-080791=>SP-090197 to include RAN items/BBs
- 200: SP#44 completed / Text3: 22.220, 22.011
- 201: SP#45 completed / Text3: 23.401, 23.402, 23.060, new 23.830
- 202: SP#46 completed / Text3: new 33.320
- 203: CP#47 completion 03/10=>06/90 (need to complete new Req from SA1). Roaming aspects for manual CSG selection, Support of temporary users and CSG membership changes, Support of user controlled and operator controlled lists / Text3: 23.122, 24.008, 24.285, 24.301
- 204: CP#47 completed. Storing of CSG related data items on the USIM / Text3: 31.102
- 205: SP#47 completed. WID updated SP-090305=>SP-100087 / Text3: 32.632, 32.633, 32.635, new (32.771, 32.772, 32.773, 32.775, 32.781, 32.782, 32.783, 32.785)
- 206: SP#47 completed / Text3: 32.581, 32.582, 32.583, 32.584, new (32.591, 32.592, 32.593, 32.594)
- 207: SP#47 completed / Text3: new 32.571, 32.572
- 208: RP#47 completed / Text3: new TR 36.921, 36.104, 36.141
- 209: RP#47 completed / Text3: new TR 36.922, 36.104, 36.141, 36.300, 36.331, 36.413
- 210: RP#46 completed (based on high priority items specified in RP-090995) / Text3: 25.413, 25.467, 25.467, 25.468, 25.469, 25.469, 36.401, 36.413, new 25.444
- 211: RP#47 completed / Text3: 25.304, 25.331, 25.367, 36.300, 36.304, 36.331
- 212: GP#44 exception to 05/10 in GP-092474. GP#42 WID approved / Text3: 43.055, 43.129, 44.018, 44.060, 45.008, 48.008, 48.018
- 213: SP#41 Stage 1 completed. Triggered by Study UID_370086 (FSServAl).
- 214: SP#41 completed / Text3: 22.182
- 215: CP#46 completed. SP#43 Feature moved to Rel-9. Stage 1 TS 22.142 promoted to Rel-9 and dismissed the Rel-8 version.
- 216: SP#39 completed. SP#43 Feature moved to Rel-9. Stage 1 TS 22.142 promoted to Rel-9 and dismissed the Rel-8 version. / Text3: 22.142
- 217: CP#46 completed. WID updated CP-090021=>CP-090813 / Text3: new 23.142
- 218: CP#46 completed. WID updated CP-090021=>CP-090813 / Text3: 23.040
- 219: SP#42 completed. SP#44 WID updated SP-070651=>SP-090380 (reduced scope of the work)
- 220: SP#42 completed. SP#44 WID updated SP-070651=>SP-090380 (reduced scope of the work) / Text3: 21.905
- 221: SP#42 Stage 1 completed (need for Input in SA2). SP#41 WID updated SP-070875=>SP-080502
- 222: SP#42 completed. / Text3: 22.183, 22.173
- 223: CP#46 exception to 03/10 in CP-090868 / Text3: 24.173, new 24.183

| ID | WBS | Task | Type | Duration | Start | Finish | Complete | Remaining | Baseline start | Baseline finish | Baseline duration | Total slack | Constraint | Resources | Work | Actual work | Text1 | Text2 | Text4 | Text6 | Text7 | Text8 | Text3 | Text11 |
| --- | --- | --- | --- | --- | --- | --- | --- | --- | --- | --- | --- | --- | --- | --- | --- | --- | --- | --- | --- | --- | --- | --- | --- | --- |
| 224 | 111 | **Public Warning System** |  | 523d? | 2007-12-06 A | 2009-12-04 A | 100% |  | 2007-12-06 | 2009-12-04 | 523d? |  |  | S1,C1,C4,R2 | 10232h | 10232h | PWS | PCG-21 | T-Mobile | Rel-9 | SP-38 | Alain |  |  |
| 225 | 111.1 | Stage 1 for PWS |  | 266d? | 2007-12-06 A | 2008-12-11 A | 100% |  | 2007-12-06 | 2008-12-11 | 266d? |  | finish no earlier than 2008-12-11 | S1 | 2128h | 2128h | PWS | PCG-21 | T-Mobile | Rel-9 | SP-38 | Alain | 22.268 |  |
| 226 | 111.2 | **Stage 3 for PWS** |  | 137d? | 2009-05-29 A | 2009-12-04 A | 100% |  | 2009-05-29 | 2009-12-04 | 137d? |  |  | C1,C4 | 3272h | 3272h | PWS-St3 | PCG-23 | Qualcomm | Rel-9 | CP-44 | Frederic |  |  |
| 227 | 111.2.1 | CT1 aspects of PWS-St3 |  | 137d? | 2009-05-29 A | 2009-12-04 A | 100% |  | 2009-05-29 | 2009-12-04 | 137d? |  | finish no earlier than 2009-12-04 | C1 | 1088h | 1088h | PWS-St3 | PCG-23 | Qualcomm | Rel-9 | CP-44 | Frederic | 23.041 |  |
| 228 | 111.2.2 | CT4 aspects of PWS-St3 |  | 136d? | 2009-05-30 A | 2009-12-04 A | 100% |  | 2009-05-30 | 2009-12-04 | 136d? |  | finish no earlier than 2009-12-04 | C4 | 1088h | 1088h | PWS-St3 | PCG-23 | Qualcomm | Rel-9 | CP-44 | Kimmo | 29.168 |  |
| 229 | 111.3 | Public Warning System (PWS) – RAN aspects |  | 81d? | 2009-05-30 A | 2009-12-04 A | 100% |  | 2009-05-30 | 2009-12-04 | 81d? |  | finish no earlier than 2009-12-04 | R2,R3 | 648h | 648h | PWS-RAN | PCG-23 | AT&T | Rel-9 | RP-44 | Joern | 36.300, 36.302, 36.331, 36.413 | RP-091052 |
| 230 | 112 | **Enhancements to Multimedia Priority Service** |  | 584d? | 2006-03-13 A | 2008-06-05 A | 100% |  | 2006-03-13 | 2008-06-05 | 584d? |  |  | S1 | 4672h | 4672h | ePRIOR | PCG-21 | Telcordia | Rel-9 | SP-39 | Alain |  |  |
| 231 | 112.1 | Stage 1 for ePRIOR |  | 584d? | 2006-03-13 A | 2008-06-05 A | 100% |  | 2006-03-13 | 2008-06-05 | 584d? |  | start no earlier than 2006-03-12 | S1 | 4672h | 4672h | ePRIOR | PCG-21 | Telcordia | Rel-9 | SP-39 | Alain | 22.153, 22.278 |  |
| 232 | 113 | **Support of Personal Area Networks and Enhancements to Personal Network Management** |  | 523d? | 2008-06-05 A | 2010-06-04 | 97% | 16.33d? | 2008-06-05 | 2010-06-04 | 523d? | 335d |  | S1,C1 | 8360h | 8098.95h | PAN_EPNM | PCG-21 | Vodafone | Rel-9 | SP-40 | Alain |  |  |
| 233 | 113.1 | Stage 1 for PAN_EPNM | milestone | 0d? | 2008-06-05 A | 2008-06-05 A | 100% |  | 2008-06-05 | 2008-06-05 | 0d? |  | finish no earlier than 2008-06-05 | S1 |  |  | PAN_EPNM | PCG-21 | Vodafone | Rel-9 | SP-40 | Alain | 22.259 |  |
| 234 | 113.2 | Stage 2 for PAN_EPNM |  | 196d? | 2009-03-06 A | 2009-12-04 A | 100% |  | 2009-03-06 | 2009-12-04 | 196d? |  | finish no earlier than 2009-12-04 | C1 | 1568h | 1568h | PAN_EPNM | PCG-22 | Huawei | Rel-9 | CP-43 | Frederic | 23.259 |  |
| 235 | 113.3 | Stage 3 for PAN_EPNM |  | 326d? | 2009-03-09 A | 2010-06-04 | 95% | 16.3d? | 2009-03-09 | 2010-06-04 | 326d? | 335d | finish no earlier than 2010-06-04 | C1 | 2608h | 2477.6h | PAN_EPNM | PCG-22 | Huawei | Rel-9 | CP-43 | Frederic | 24.259 | CP-090879 |
| 236 | 114 | **Multi-Media Telephony Service enhancements** |  | 472d? | 2008-06-05 A | 2010-03-25 A | 100% |  | 2008-06-05 | 2010-03-25 | 472d? |  |  | S1,S5,C1 | 10288h | 10288h | eMMTel | PCG-21 | France Telecom | Rel-9 | SP-40 | Alain |  |  |
| 237 | 114.1 | Stage 1 for eMMTel |  | 136d? | 2008-06-05 A | 2008-12-11 A | 100% |  | 2008-06-05 | 2008-12-11 | 136d? |  | start no earlier than 2008-06-05 | S1 | 1088h | 1088h | eMMTel | PCG-21 | France Telecom | Rel-9 | SP-40 | Alain | 22.173 |  |
| 238 | 114.2 | Multimedia Telephony (MMTel) Service and Supplementary Services - Online Charging and completion for Offline Charging (all supplementary services) |  | 272d? | 2009-03-12 A | 2010-03-25 A | 100% |  | 2009-03-12 | 2010-03-25 | 272d? |  | finish no earlier than 2010-03-25 | S5 | 2168h | 2168h | eMMTel-SS-CH | PCG-22 | Alcatel-Lucent | Rel-9 | SP-43 | Dionisio | 32.275, 32.298, 32.299 | SP-090753 |
| 239 | 114.3 | Support of Real-time Transfer of Tariff Information (RTTI) in IMS charging |  | 271d? | 2009-03-12 A | 2010-03-25 A | 100% |  | 2009-03-12 | 2010-03-25 | 271d? |  | finish no earlier than 2010-03-25 | S5 | 2168h | 2168h | IMSTSS-RTTI-CH | PCG-22 | Orange | Rel-9 | SP-43 | Dionisio | 32.27x, 32.240, 32.280, 32.298, 32.299 | SP-090754 |
| 240 | 114.4 | Stage 3 - Enhancements for Completion of Communications Supplementary service |  | 136d? | 2009-05-30 A | 2009-12-04 A | 100% |  | 2009-05-30 | 2009-12-04 | 136d? |  | finish no earlier than 2009-12-04 | C1 | 1088h | 1088h | eMMTel-CC | PCG-23 | France Telecom | Rel-9 | CP-44 | Frederic | 24.642 |  |
| 241 | 115 | **User Data Convergence** |  | 527d? | 2008-06-05 A | 2010-06-10 | 95% | 27.65d? | 2008-06-05 | 2010-06-10 | 527d? | 331d |  | S1,S5,C4 | 14456h | 13571.9h | UDC | PCG-21 | China Mobile | Rel-9 | SP-40 | Alain |  |  |
| 242 | 115.1 | Stage 1 for UDC |  | 136d? | 2008-06-05 A | 2008-12-11 A | 100% |  | 2008-06-05 | 2008-12-11 | 136d? |  | start no earlier than 2008-06-05 | S1 | 1088h | 1088h | UDC | PCG-21 | China Mobile | Rel-9 | SP-40 | Alain | 22.985, 22.101 |  |
| 243 | 115.2 | UDC Technical Realization (Stage 2) |  | 271d? | 2009-03-06 A | 2010-03-19 A | 100% |  | 2009-03-06 | 2010-03-19 | 271d? |  | finish no earlier than 2010-03-19 | C4 | 2168h | 2168h | UDC-CN | PCG-22 | Ericsson | Rel-9 | CP-43 | Kimmo | new 23.335 |  |
| 244 | 115.3 | UDC Protocol Description |  | 130d? | 2009-09-18 A | 2010-03-19 A | 100% |  | 2009-09-18 | 2010-03-19 | 130d? |  | finish no earlier than 2010-03-19 | C4 | 1040h | 1040h | UDC-CN | PCG-23 | China Mobile, Ericsson | Rel-9 | CP-45 | Kimmo | new 29.335 |  |
| 245 | 115.4 | **User Data Convergence - Modelling and Management** |  | 266d? | 2009-06-04 A | 2010-06-10 | 89% | 29.67d? | 2009-06-04 | 2010-06-10 | 266d? | 331d |  | S5 | 5944h | 5281.06h | UDC-MMAN | PCG-23 | T-Mobile, China Mobile, Ericsson | Rel-9 | SP-44 | Dionisio |  |  |
| 246 | 115.4.1 | UDC – Framework for Model Handling and Management |  | 266d? | 2009-06-04 A | 2010-06-10 | 80% | 53.2d? | 2009-06-04 | 2010-06-10 | 266d? | 331d | finish no earlier than 2010-06-10 | S5 | 2128h | 1702.4h | UDC-MMAN-MFRM | PCG-23 | T-Mobile | Rel-9 | SP-44 | Dionisio | 32.172, new 32.181 | SP-100074 |
| 247 | 115.4.2 | UDC – Common Baseline Information Model |  | 211d? | 2009-06-04 A | 2010-03-25 A | 100% |  | 2009-06-04 | 2010-03-25 | 211d? |  | finish no earlier than 2010-03-25 | S5 | 1688h | 1688h | UDC-MMAN-CBIM | PCG-23 | China Mobile, Ericsson | Rel-9 | SP-44 | Dionisio | 32.172, new 32.182 |  |

Notes:
- 224: TSG#46 completed. Larger scope than Rel-8 Feature UID_370051 (ETWS). Triggered by TR 22.968 Study UID_320025 (FS_PWS) / Text5: Mark.Younge@t-mobile.com
- 225: SP#42 completed / Text5: Mark.Younge@t-mobile.com
- 226: RP#46 completed / Text5: Ramachandran Subramanian (rsubrama@qualcomm.com)
- 227: CP#46 completed / Text5: Ramachandran Subramanian (rsubrama@qualcomm.com)
- 228: CP#46 completed / Text5: Ramachandran Subramanian (rsubrama@qualcomm.com)
- 229: RP#46 completed / Text5: don.zelmer@att.com
- 230: SP#40 Stage 1 completed. Continuation of Rel-8 Feature PRIOR UID_340044. / Text5: jgarraha@telcordia.com
- 231: SP#40 completed / Text5: jgarraha@telcordia.com
- 232: SP#40 WID approved & Stage 1 completed / Text5: armin.toepfer@vodafone.com
- 233: SP#40 Stage 1 completed / Text5: armin.toepfer@vodafone.com
- 234: CP#46 completed. CP#44 WID updated CP-090113=>CP-090435 Removed: Mechanism for a PNE without a (U)SIM capable of discovering PNEs with a (U)SIM in its proximity / Text5: Lili Yang (kadyyang@huawei.com)
- 235: CP#46 exception to 03/10 in CP-090879 / Text5: Lili Yang (kadyyang@huawei.com)
- 236: SP#42 Stage 1 completed. SP#41 WID updated SP-080324=>SP-080503 / Text5: Philippe Lottin
- 237: SP#42 completed. SP#41 WID updated SP-080324=>SP-080503 / Text5: Philippe Lottin
- 238: SA#47 completed / Text5: Maryse.Gardella@alcatel-lucent.fr
- 239: SA#47 completed. Linked to SA5 Rel-8 UID_380042 AoC support in IMS Charging (IMSTSS) / Text5: Jean-Luc Garcia (jl.garcia@orange-ftgroup.com)
- 240: CP#46 completed / Text5: Youssef.chadli@orange-ftgroup.com
- 241: SP#42 Stage 1 completed. CP#47 completed CT4 / Text5: lansizhong@chinamobile.com
- 242: SP#42 completed / Text5: lansizhong@chinamobile.com
- 243: CP#47 completed / Text5: Emiliano Merino (emiliano.merino@ericsson.com)
- 244: CP#47 completed / Text5: Lan Si Zhong (lansizhong@chinamobile.com), emiliano.merino@ericsson.com
- 245: SP#47 exception to 06/10 in SP-100074 / Text5: Istvan Aba, Lan Si Zhong, Miguel Garcia
- 246: SP#47 exception to 06/10 in SP-100074. TS 32.181 v100 for information / Text5: istvan.aba@t-mobile.at
- 247: SP#47 completed / Text5: Lan Si Zhong, Miguel Garcia

| ID | WBS | Task | Duration | Start | Finish | Complete | Remaining | Baseline start | Baseline finish | Baseline duration | Total slack | Constraint | Resources | Work | Actual work | Text1 | Text2 | Text4 | Text5 | Text6 | Text7 | Text8 | Text11 |
| --- | --- | --- | --- | --- | --- | --- | --- | --- | --- | --- | --- | --- | --- | --- | --- | --- | --- | --- | --- | --- | --- | --- | --- |
| 248 | 116 | **IMS Services Centralization and Continuity** | 393d? | 2008-09-18 A | 2010-03-19 A | 100% |  | 2008-09-18 | 2010-03-19 | 393d? |  |  | S1,S2,C1 | 12160h | 12160h | IMS_SCC | PCG-21 | NEC | Joerg Swetina (joerg.swetina@nw.neclab.eu) | Rel-9 | SP-41 | Alain |  |
| 249 | 116.1 | Stage 1 - Inter-Device Transfer – Requirements | 61d? | 2008-09-18 A | 2008-12-11 A | 100% |  | 2008-09-18 | 2008-12-11 | 61d? |  | finish no earlier than 2009-06-18 | S1 | 488h | 488h | IMS_SCC-IDT | PCG-21 | NEC | Joerg Swetina (joerg.swetina@nw.neclab.eu) | Rel-9 | SP-41 | Alain |  |
| 250 | 116.2 | Stage 2 - IMS Service Continuity Enhancements: Service, Policy and Interactions | 186d? | 2008-09-18 A | 2009-06-04 A | 100% |  | 2008-09-18 | 2009-06-04 | 186d? |  | finish no earlier than 2009-06-04 | S2 | 1488h | 1488h | IMS_SCC-SPI | PCG-21 | Huawei | HengLiang Zhang (hl_zhang@huawei.com) | Rel-9 | SP-41 | Maurice |  |
| 251 | 116.3 | Stage 3 - IMS Service Continuity Enhancements: Service, Policy, Interactions and Inter UE Transfer | 212d? | 2009-05-29 A | 2010-03-19 A | 100% |  | 2009-05-29 | 2010-03-19 | 212d? |  | finish no earlier than 2010-03-19 | C1 | 1696h | 1696h | IMS_SCC-SPI | PCG-23 | Qualcomm | Roozbeh Atarius (ratarius@qualcomm.com) | Rel-9 | CP-44 | Frederic | CP-090875 |
| 252 | 116.4 | Stage 2 - IMS Centralized Services | 186d? | 2008-09-18 A | 2009-06-04 A | 100% |  | 2008-09-18 | 2009-06-04 | 186d? |  | finish no earlier than 2009-06-04 | S2 | 1488h | 1488h | IMS_SCC-ICS | PCG-21 | Alcatel-Lucent | Andy Bennett (andybennett@alcatel-lucent.com) | Rel-9 | SP-41 | Maurice |  |
| 253 | 116.5 | Stage 3 - Enhancements to IMS Centralized Services | 212d? | 2009-05-29 A | 2010-03-19 A | 100% |  | 2009-05-29 | 2010-03-19 | 212d? |  | finish no earlier than 2010-03-19 | C1 | 1688h | 1688h | IMS_SCC-ICS | PCG-23 | Nokia Siemens Networks | Peter.Leis@nsn.com | Rel-9 | CP-44 | Frederic |  |
| 254 | 116.6 | Stage 3 - IMS Centralized Services support via I1 interface | 271d? | 2009-03-06 A | 2010-03-19 A | 100% |  | 2009-03-06 | 2010-03-19 | 271d? |  | finish no earlier than 2010-03-19 | C1 | 2168h | 2168h | IMS_SCC-ICS_I1 | PCG-22 | Huawei | Lili Yang(kadyyang@huawei.com) | Rel-9 | CP-43 | Frederic | CP-090874 |
| 255 | 117 | **Service Specific Access Control in EPS** | 333d? | 2008-12-11 A | 2010-03-19 A | 100% |  | 2008-12-11 | 2010-03-19 | 333d? |  |  | S1,C1 | 4368h | 4368h | SSAC | PCG-22 | NTT DoCoMo | Frederic Thepot (thepot@docomolab-euro.com) | Rel-9 | SP-42 | Alain |  |
| 256 | 117.1 | Stage 1 for SSAC | 1d? | 2008-12-11 A | 2008-12-11 A | 100% |  | 2008-12-11 | 2008-12-11 | 1d? |  | start no earlier than 2008-12-11 | S1 | 8h | 8h | SSAC | PCG-22 | NTT DoCoMo | Frederic Thepot (thepot@docomolab-euro.com) | Rel-9 | SP-42 | Alain |  |
| 257 | 117.2 | Stage 3 for SSAC | 212d? | 2009-05-29 A | 2010-03-19 A | 100% |  | 2009-05-29 | 2010-03-19 | 212d? |  | finish no earlier than 2010-03-19 | C1 | 1696h | 1696h | SSAC | PCG-23 | NTT DoCoMo | Hideyuki Yamashita (yamashitahi@s1.nttdocomo.co.jp) | Rel-9 | CP-44 | Frederic | CP-090880 |
| 258 | 118 | **Support for IMS Emergency Calls over GPRS and EPS** | 701d? | 2008-01-14 A | 2010-09-17 | 91% | 61.08d? | 2008-01-14 | 2010-09-17 | 701d? | 260d |  | S1,S2,S3,C1,C3,C4,R2,R3,R5 | 27235.7h | 21898.1h | IMS_EMER_GPRS_EPS | PCG-21 | Alcatel-Lucent | Deborah Barclay | Rel-9 | SP-38 | Maurice |  |
| 259 | 118.1 | Stage 1 of IMS_EMER_GPRS_EPS | 239d? | 2008-01-14 A | 2008-12-11 A | 100% |  | 2008-01-14 | 2008-12-11 | 239d? |  | finish no earlier than 2008-12-11 | S1 | 1912h | 1912h | IMS_EMER_GPRS_EPS | PCG-21 | Alcatel-Lucent | Deborah Barclay | Rel-9 | SP-38 | Alain |  |
| 260 | 118.2 | Stage 2 of IMS_EMER_GPRS_EPS | 364d? | 2008-01-14 A | 2009-06-04 A | 100% |  | 2008-01-14 | 2009-06-04 | 364d? |  | finish no earlier than 2009-06-04 | S2 | 2912h | 2912h | IMS_EMER_GPRS_EPS | PCG-21 | Alcatel-Lucent | Deborah Barclay | Rel-9 | SP-38 | Maurice |  |
| 261 | 118.3 | Security aspects of IMS_EMER_GPRS_EPS | 391d? | 2008-12-12 A | 2010-06-10 | 80% | 78.2d? | 2008-12-12 | 2010-06-10 | 391d? | 331d | finish no earlier than 2010-03-25 | S3 | 3128h | 2502.4h | IMS_EMER_GPRS_EPS-Sec | PCG-22 | Alcatel-Lucent | Deborah Barclay | Rel-9 | SP-42 | Dionisio |  |
| 262 | 118.4 | **Stage 3 of IMS_EMER_GPRS_EPS** | 212d? | 2009-05-29 A | 2010-03-19 A | 100% |  | 2009-05-29 | 2010-03-19 | 212d? |  |  | C1,C3,C4 | 5139.68h | 5139.68h | IMS_EMER_GPRS_EPS | PCG-23 | Alcatel-Lucent | Frank Alfano (falfano@alcatel-lucent.com) | Rel-9 | CP-44 | Frederic |  |
| 263 | 118.4.1 | CT1 aspects - Stage 3 of IMS_EMER_GPRS_EPS | 212d? | 2009-05-29 A | 2010-03-19 A | 100% |  | 2009-05-29 | 2010-03-19 | 212d? |  | finish no earlier than 2010-03-19 | C1 | 1696h | 1696h | IMS_EMER_GPRS_EPS | PCG-23 | Alcatel-Lucent | Frank Alfano (falfano@alcatel-lucent.com) | Rel-9 | CP-44 | Frederic | CP-090873 |
| 264 | 118.4.2 | CT3 aspects - Stage 3 of IMS_EMER_GPRS_EPS | 82d? | 2009-05-29 A | 2009-09-18 A | 100% |  | 2009-05-29 | 2009-09-18 | 82d? |  | start no earlier than 2009-05-29 | C3 | 651.68h | 651.68h | IMS_EMER_GPRS_EPS | PCG-23 | Alcatel-Lucent | Frank Alfano (falfano@alcatel-lucent.com) | Rel-9 | CP-44 | Gwiho |  |
| 265 | 118.4.3 | CT4 aspects - Stage 3 of IMS_EMER_GPRS_EPS | 137d? | 2009-05-29 A | 2009-12-04 A | 100% |  | 2009-05-29 | 2009-12-04 | 137d? |  | finish no earlier than 2009-12-04 | C4 | 1096h | 1096h | IMS_EMER_GPRS_EPS | PCG-23 | Alcatel-Lucent | Frank Alfano (falfano@alcatel-lucent.com) | Rel-9 | CP-44 | Kimmo |  |
| 266 | 118.5 | Support for IMS Emergency Calls over LTE | 206d? | 2008-12-05 A | 2009-09-18 A | 100% |  | 2008-12-05 | 2009-09-18 | 206d? |  |  | R2,R3 | 1648h | 1648h | IMS_EMER_LTE | PCG-22 | Alcatel-Lucent | Sudeep Palat (spalat@alcatel-lucent.com) | Rel-9 | RP-42 | Joern | RP-090698 |
| 267 | 118.6 | Conformance Test Aspects – Support for IMS Emergency Calls over LTE | 127d? | 2010-03-25 | 2010-09-17 |  |  | 2010-03-25 | 2010-09-17 | 127d? | 260d | finish no earlier than 2010-09-17 | R5 | 1016h |  | IMS_EMER_LTE_UEConTest | PCG-24 | Ericsson | leif.mattisson@ericsson.com | Rel-9 | RP-47 | Ingbert |  |
| 268 | 118.7 | **SRVCC support for IMS Emergency Calls** | 322d? | 2008-09-18 A | 2009-12-10 A | 100% |  | 2008-09-18 | 2009-12-10 | 322d? |  |  | S2,C1,C4,C3 | 5872h | 5872h | IMS_EMER_GPRS_EPS-SRVCC | PCG-21 | China Mobile | Yu Qing (Yuqing@chinamobile.com) | Rel-9 | SP-41 | Maurice |  |
| 269 | 118.7.1 | SRVCC support for IMS Emergency Calls | 322d? | 2008-09-18 A | 2009-12-10 A | 100% |  | 2008-09-18 | 2009-12-10 | 322d? |  | finish no earlier than 2009-12-10 | S2 | 2576h | 2576h | IMS_EMER_GPRS_EPS-SRVCC | PCG-21 | China Mobile | Yu Qing (Yuqing@chinamobile.com) | Rel-9 | SP-41 | Maurice |  |
| 270 | 118.7.2 | **CT aspects of SRVCC support for IMS Emergency Calls** | 137d? | 2009-05-29 A | 2009-12-04 A | 100% |  | 2009-05-29 | 2009-12-04 | 137d? |  |  | C1,C4,C3 | 3296h | 3296h | IMS_EMER_GPRS_EPS-SRVCC | PCG-24 | China Mobile | jiangyi@chinamobile.com | Rel-9 | CP-46 | Frederic |  |
| 271 | 118.7.2.1 | CT1 aspects of SRVCC support for IMS Emergency Calls | 137d? | 2009-05-29 A | 2009-12-04 A | 100% |  | 2009-05-29 | 2009-12-04 | 137d? |  | finish no earlier than 2009-12-04 | C1 | 1096h | 1096h | IMS_EMER_GPRS_EPS-SRVCC | PCG-23 | China Mobile | jiangyi@chinamobile.com | Rel-9 | CP-44 | Frederic |  |
| 272 | 118.7.2.2 | CT4 aspects of SRVCC support for IMS Emergency Calls | 137d? | 2009-05-29 A | 2009-12-04 A | 100% |  | 2009-05-29 | 2009-12-04 | 137d? |  | finish no earlier than 2009-12-04 | C4 | 1096h | 1096h | IMS_EMER_GPRS_EPS-SRVCC | PCG-23 | China Mobile | jiangyi@chinamobile.com | Rel-9 | CP-44 | Kimmo |  |
| 273 | 118.7.2.3 | CT3 aspects of SRVCC support for IMS Emergency Calls | 1d? | 2009-12-04 A | 2009-12-04 A | 100% |  | 2009-12-04 | 2009-12-04 | 1d? |  | finish no earlier than 2009-12-04 | C3 | 8h | 8h | IMS_EMER_GPRS_EPS-SRVCC | PCG-24 | China Mobile | jiangyi@chinamobile.com | Rel-9 | CP-46 | Kimmo |  |

Notes:
- 248: CP#47 completed
- 249: SP#42 completed / Text3: 22.101, 22.228
- 250: SP#44 completed. TR 23.838 for Approval / Text3: 23.838, 23.237, 23.292, 23.216
- 251: CP#47 completed / Text3: 24.216, 24.229, 24.237
- 252: SP#44 completed. TR 23.883 for Information + Approval / Text3: 23.883, 23.292
- 253: CP#47 completed / Text3: 24.292, 24.604, 24.607, 24.608, 24.611, 24.623
- 254: CP#47 completed / Text3: 24.237, 24.292, new 24.294
- 255: CP#47 completed. Triggered by Study UID_400036 on Service Specific Access Control in EPS (FS_SSAC)
- 256: SP#42 completed / Text3: 22.011 CR0136
- 257: CP#47 completed / Text3: 24.173, 27.007
- 258: SP#47 SA3 completion 03/10=>06/10
- 259: SP#42 completed / Text3: 22.101
- 260: SP#44 completed / Text3: 23.869, 23.060, 23.167, 23.203, 23.221, 23.228, 23.271, 23.401, 23.402
- 261: SP#47 completion 03/10=>06/10 / Text3: 33.401, 33.402
- 262: CP#47 completed
- 263: CP#47 completed / Text3: 23.122, 24.008, 24.229, 24.301, 24.302
- 264: CP#45 completed / Text3: 29.212, 29.213, 29.214, 29.215
- 265: CP#46 completed / Text3: 23.003, 23.008, 29.060, 29.272, 29.273, 29.274, 29.275, 29.276
- 266: RP#45 completed / Text3: 36.331, 36.413
- 267: Testing for UID_420041 Support for IMS Emergency Calls over LTE / Text3: 36.508, 36.523-1, 36.523-2, 36.523-3
- 268: CP/SP#46 completed
- 269: SP#46 completed. SP#43 WID updated SP-080562=>SP-090099 (added location continuity aspects) / Text3: 23.870, 23.216, 23.237
- 270: CP#46 completed. WID updated CP-090436=>CP-090882 (added CT3 part)
- 271: CP#46 completed / Text3: 24.229, 24.237
- 272: CP#46 completed / Text3: 29.205, 29.280
- 273: CP#46 completed / Text3: 29.163

| ID | WBS | Task | Duration | Start | Finish | Complete | Remaining | Baseline start | Baseline finish | Baseline duration | Total slack | Constraint | Resources | Work | Actual work | Text1 | Text2 | Text6 | Text7 | Text8 | Text4 | Text5 | Text11 |
| --- | --- | --- | --- | --- | --- | --- | --- | --- | --- | --- | --- | --- | --- | --- | --- | --- | --- | --- | --- | --- | --- | --- | --- |
| 274 | 119 | **LCS for LTE and EPS** | 723d? | 2008-06-05 A | 2011-03-11 | 79% | 149.48d? | 2008-06-05 | 2011-03-11 | 723d? | 135d |  | S2,C1,C4,R2,R1,R3,R4 | 20192h | 16791.3h | LCS_LTE_EPS | PCG-22 | Rel-9 | SP-43 | Maurice |  |  |  |
| 275 | 119.1 | **LCS Control Plane Solution for EPS** | 468d? | 2008-06-05 A | 2010-03-19 A | 100% |  | 2008-06-05 | 2010-03-19 | 468d? |  |  | S2,C4,C1 | 9224h | 9224h | LCS_EPS-CPS | PCG-21 | Rel-9 | SP-40 | Maurice | Polaris Wireless | Robert Gross |  |
| 276 | 119.1.1 | Stage 2 for LCS_CPS_EPS | 261d? | 2008-06-05 A | 2009-06-04 A | 100% |  | 2008-06-05 | 2009-06-04 | 261d? |  | finish no earlier than 2009-06-04 | S2 | 2088h | 2088h | LCS_EPS-CPS | PCG-21 | Rel-9 | SP-40 | Maurice | Polaris Wireless | Robert Gross |  |
| 277 | 119.1.2 | CT4 aspects - Control Plane LCS in the EPC | 212d? | 2009-05-29 A | 2010-03-19 A | 100% |  | 2009-05-29 | 2010-03-19 | 212d? |  | finish no earlier than 2010-03-19 | C4 | 1696h | 1696h | LCS_EPS-CPS | PCG-23 | Rel-9 | CP-44 | Kimmo | Polaris Wireless | Robert Gross |  |
| 278 | 119.1.3 | CT1 aspects - Control Plane LCS in the EPC | 212d? | 2009-05-29 A | 2010-03-19 A | 100% |  | 2009-05-29 | 2010-03-19 | 212d? |  | finish no earlier than 2010-03-19 | C1 | 1696h | 1696h | LCS_EPS-CPS | PCG-23 | Rel-9 | CP-44 | Frederic | Polaris Wireless | Robert Gross | CP-090876 |
| 279 | 119.2 | Positioning Support for LTE | 392d? | 2008-12-05 A | 2010-06-04 | 95% | 19.6d? | 2008-12-05 | 2010-06-04 | 392d? | 335d | finish no earlier than 2010-06-04 | R2,R1,R3,R4 | 3136h | 2979.2h | LCS_LTE | PCG-22 | Rel-9 | RP-42 | Joern | Qualcomm | Nathan Tenny (ntenny@qualcomm.com) | RP-100341 |
| 280 | 119.3 | Conformance Test Aspects – Positioning Support for LTE | 256d? | 2010-03-19 | 2011-03-11 |  |  | 2010-03-19 | 2011-03-11 | 256d? | 135d | start no earlier than 2010-03-19 | R5 | 2048h |  | LCS_LTE_UEConTest | PCG-24 | Rel-9 | RP-47 | Ingbert | Alcatel-Lucent | nidal.khrais@alcatel-lucent.com |  |
| 281 | 120 | **MBMS support in EPS** | 468d? | 2008-06-05 A | 2010-03-19 A | 100% |  | 2008-06-05 | 2010-03-19 | 468d? |  |  | S2,S3,S5,C3,C4,R2,R3,R4 | 13880h | 13880h | MBMS_EPS | PCG-21 | Rel-9 | SP-40 | Maurice | China Mobile | Liu Hong (liuhongyfw@chinamobile.com) |  |
| 282 | 120.1 | Stage 2 for MBMS_EPS | 261d? | 2008-06-05 A | 2009-06-04 A | 100% |  | 2008-06-05 | 2009-06-04 | 261d? |  | finish no earlier than 2009-06-04 | S2 | 2088h | 2088h | MBMS_EPS | PCG-21 | Rel-9 | SP-40 | Maurice | China Mobile | Liu Hong (liuhongyfw@chinamobile.com) |  |
| 283 | 120.2 | Security for MBMS_EPS | 261d? | 2008-12-11 A | 2009-12-10 A | 100% |  | 2008-12-11 | 2009-12-10 | 261d? |  | finish no earlier than 2009-12-10 | S3 | 2088h | 2088h | MBMS_EPS | PCG-22 | Rel-9 | SP-42 | Dionisio | China Mobile | Liu Hong (liuhongyfw@chinamobile.com) |  |
| 284 | 120.3 | MBMS Charging in EPS | 201d? | 2009-03-06 A | 2009-12-10 A | 100% |  | 2009-03-06 | 2009-12-10 | 201d? |  | finish no earlier than 2009-12-10 | S5 | 1600h | 1600h | MBMS_EPS | PCG-22 | Rel-9 | SP-43 | Dionisio | ZTE | guo.wenjie1@zte.com.cn |  |
| 285 | 120.4 | CT4 aspects of MBMS support in EPS (Stage 3) | 137d? | 2009-05-29 A | 2009-12-04 A | 100% |  | 2009-05-29 | 2009-12-04 | 137d? |  | finish no earlier than 2009-12-04 | C4 | 1096h | 1096h | MBMS_EPS | PCG-23 | Rel-9 | CP-44 | Kimmo | China Mobile, ZTE | wangjingyf@chinamobile.com, lu.fei1@zte.com.cn |  |
| 286 | 120.5 | CT3 aspects of MBMS support in EPS (Stage 3) | 137d? | 2009-05-29 A | 2009-12-04 A | 100% |  | 2009-05-29 | 2009-12-04 | 137d? |  | start no earlier than 2009-05-29 | C3 | 1096h | 1096h | MBMS_EPS | PCG-23 | Rel-9 | CP-44 | Gwiho | ZTE, China Mobile | zhou.xiaoyun@zte.com.cn, wangjingyf@chinamobile.com |  |
| 287 | 120.6 | MBMS support in LTE | 271d? | 2009-03-06 A | 2010-03-19 A | 100% |  | 2009-03-06 | 2010-03-19 | 271d? |  | finish no earlier than 2010-03-19 | R2,R3,R4 | 2168h | 2168h | MBMS_LTE | PCG-22 | Rel-9 | RP-43 | Joern | Huawei | arnaud.meylan@huawei.com | RP-100033 |
| 288 | 121 | **Access Network Discovery and Selection Function enhancements** | 333d? | 2008-12-11 A | 2010-03-19 A | 100% |  | 2008-12-11 | 2010-03-19 | 333d? |  |  | S2,C1 | 4720h | 4720h | eANDSF | PCG-22 | Rel-9 | SP-42 | Maurice | Motorola | Apostolis Salkintzis (salki@motorola.com) |  |
| 289 | 121.1 | Stage 2 for eANDSF | 126d? | 2008-12-11 A | 2009-06-04 A | 100% |  | 2008-12-11 | 2009-06-04 | 126d? |  | finish no earlier than 2009-06-04 | S2 | 1008h | 1008h | eANDSF | PCG-22 | Rel-9 | SP-42 | Maurice | Motorola | Apostolis Salkintzis (salki@motorola.com) |  |
| 290 | 121.2 | CT1 aspects - eANDSF | 131d? | 2009-09-18 A | 2010-03-19 A | 100% |  | 2009-09-18 | 2010-03-19 | 131d? |  | finish no earlier than 2010-03-19 | C1 | 1048h | 1048h | eANDSF | PCG-23 | Rel-9 | CP-45 | Frederic | Panasonic | benjamin.limck@sg.panasonic.com | CP-090869 |
| 291 | 122 | **Multiple PDN Connection to the Same APN for PMIP-based Interfaces** | 267d? | 2009-03-13 A | 2010-03-19 A | 100% |  | 2009-03-13 | 2010-03-19 | 267d? |  |  | S2,C4,C1 | 4120h | 4120h | MUPSAP | PCG-22 | Rel-9 | SP-43 | Maurice | Samsung | erik.guttman@partner.samsung.com |  |
| 292 | 122.1 | Stage 2 for MUPSAP | 61d? | 2009-03-13 A | 2009-06-04 A | 100% |  | 2009-03-13 | 2009-06-04 | 61d? |  | finish no earlier than 2009-06-04 | S2 | 488h | 488h | MUPSAP | PCG-22 | Rel-9 | SP-43 | Maurice | Samsung | erik.guttman@partner.samsung.com |  |
| 293 | 122.2 | MUPSAP - CT4 aspects | 56d? | 2009-09-18 A | 2009-12-04 A | 100% |  | 2009-09-18 | 2009-12-04 | 56d? |  | finish no earlier than 2009-12-04 | C4 | 448h | 448h | MUPSAP | PCG-23 | Rel-9 | CP-45 | Kimmo | Samsung | Surjyakanta Mohapatra (surjya.kanta@samsung.com) |  |
| 294 | 122.3 | MUPSAP - CT1 aspects | 131d? | 2009-09-18 A | 2010-03-19 A | 100% |  | 2009-09-18 | 2010-03-19 | 131d? |  | finish no earlier than 2010-03-19 | C1 | 1048h | 1048h | MUPSAP | PCG-23 | Rel-9 | CP-45 | Frederic | Samsung | Surjyakanta Mohapatra (surjya.kanta@samsung.com) | CP-090878 |
| 295 | 123 | Access Security Enhancements | 505d? | 2007-07-02 A | 2009-06-04 A | 100% |  | 2007-07-02 | 2009-06-04 | 505d? |  | finish no earlier than 2009-06-03 | S3 | 4040h | 4040h | ACCSEC2 |  | Rel-9 | SP-26 | Dionisio | Ericsson | Bengt.Sahlin@ericsson.com |  |
| 296 | 124 | **Protection against Unsolicited Communication for IMS (PUCI)** | 322d? | 2008-09-18 A | 2009-12-10 A | 100% |  | 2008-09-18 | 2009-12-10 | 322d? |  |  | S3,S1 | 5640h | 5640h | PUCI | PCG-21 | Rel-9 | SP-41 | Alain | NEC | Anand R. Prasad (anand@bq.jp.nec.com) |  |
| 297 | 124.1 | Stage 1 for PUCI | 61d? | 2008-09-18 A | 2008-12-11 A | 100% |  | 2008-09-18 | 2008-12-11 | 61d? |  | finish no earlier than 2009-06-18 | S1 | 488h | 488h | PUCI | PCG-21 | Rel-9 | SP-41 | Alain | NEC | Anand R. Prasad (anand@bq.jp.nec.com) |  |
| 298 | 124.2 | SA3 work on PUCI | 322d? | 2008-09-18 A | 2009-12-10 A | 100% |  | 2008-09-18 | 2009-12-10 | 322d? |  | finish no earlier than 2009-12-10 | S3 | 2576h | 2576h | PUCI | PCG-21 | Rel-9 | SP-41 | Dionisio | NEC | Anand R. Prasad (anand@bq.jp.nec.com) |  |

Notes:
- 274: CP#47, RP#47 completed. SP#44 completed
- 275: Triggered by abandoned Study UID_380068 (FS_LCS_EPS). Linked to UID_380064 Feature IMS_EMER_GPRS_EPS
- 276: SP#44 completed (Some alignments might be needed later on based on RAN progress) / Text3: 23.891, 23.271, 23.401, 23.402
- 277: CP#47 completed (IANA registrations outstanding). Stage 3 SLs and SLg interfaces & transport of positioning messages between E-SMLC and MME in the scope of UID_420006 (Positioning Support for LTE) / Text3: 24.080, 29.002, 29.272, 29.230, new 24.171, 29.171, 29.172, 29.173
- 278: CP#47 completed / Text3: 24.301
- 279: RP#47 exception 03/10=>06/10 in RP-100391 (complete RAN4 36.133 core reqs: measurement reqs for UE Rx-Tx time difference/RSTD, potentially add core reqs arising from autonomous muting). UID_400038 (LCS Control Plane Solution for EPS) depends on this WI / Text3: 34.213, 36.133, 36.211, 36.214, 36.300, 36.305, 36.331, 36.355, 36.410, 36.413, 36.455, new 36.171
- 280: Testing for UID_420006 Positioning Support for LTE / Text3: 36.508, 36.509, 36.521-3, 36.523-1, 36.523-2, 36.523-3, new 36.xxx (E-UTRA UE conformance specification; UE positioning in E-UTRA), 36.xxy (E-UTRA UE conformance specification; UE positioning test scenarios and assistance data)
- 281: RP#47 completed. SP#46, CP#46 completed
- 282: SP#44 completed / Text3: 23.246
- 283: SP#46 completed / Text3: 33.246
- 284: SP#46 completed / Text3: 32.273, 32.251, 32.298, 32.299
- 285: CP#46 completed / Text3: 29.274, 29.281, 23.007, 23.008
- 286: CP#46 completed / Text3: 29.061
- 287: RP#47 completed / Text3: 25.446, 36.101, 36.104, 36.141, 36.300, 36.304, 36.321, 36.322, 36.323, 36.331, 36.440, 36.441, 36.442, 36.444, 36.445
- 288: CP#47 completed. No new Rel-9 use cases defined. Implement service requirements not covered in Rel-8 / Text3: 22.278, SA3 33.402 CR#0055
- 289: SP#44 completed / Text3: 23.402, 23.002
- 290: CP#47 completed / Text3: 24.302, 24.312
- 291: CP#47 completed. Continues Rel-8 SAES Stage 2 UID_320005. Stage 1 in 22.278 (EPS Service requirements)
- 292: SP#44 completed / Text3: 23.060, 23.203, 23.401, 23.402
- 293: CP#46 completed / Text3: 29.275, 23.008, 29.282
- 294: CP#47 completed / Text3: 24.302
- 295: SP#44 completed. Stopped TR 33.801. CRs 33.102,43.020 on A5/2 removal done long time ago. A5/4 introduction CRs will be done under UID_440057 128 bit encryption for GSM and GPRS. SP#26 approved WID (improved GERAN security) / Text3: 33.102, 43.020, Stopped TR 33.801 “Access security review” (Reason: draft contained useful material for planning A5/2 removal and A5/4 introduction. Completion would require significant effort)
- 296: SP#46 TR completed but no specification work done in Rel-9. Related work in OMA Categorization Based Content Screening
- 297: SP#42 completed / Text3: 22.228
- 298: SP#46 completed. TR 33.837 converted to 33.937. No SA3 normative work done in Rel-9 / Text3: new 33.937

| ID | WBS | Task | Duration | Start | Finish | Complete | Remaining | Baseline start | Baseline finish | Baseline duration | Total slack | Constraint | Resources | Work | Actual work | Text1 | Text2 | Text4 | Text5 | Text6 | Text7 | Text8 | Text11 | Text9 | Text12 |
| --- | --- | --- | --- | --- | --- | --- | --- | --- | --- | --- | --- | --- | --- | --- | --- | --- | --- | --- | --- | --- | --- | --- | --- | --- | --- |
| 299 | 125 | **IMS Media Plane Security** | 271d? | 2009-03-13 A | 2010-03-25 | 99% | 4.03d? | 2009-03-13 | 2010-03-25 | 271d? | 386d |  | S3,C1,C4,C3 | 6467.2h | 4231.71h | MEDIASEC | PCG-22 | Vodafone | Peter.Howard@vodafone.com | Rel-9 | SP-43 | Dionisio |  |  |  |
| 300 | 125.1 | SA3 aspects - MEDIASEC | 271d? | 2009-03-13 A | 2010-03-25 A | 100% |  | 2009-03-13 | 2010-03-25 | 271d? |  | finish no earlier than 2010-03-25 | S3 | 2168h | 2168h | MEDIASEC | PCG-22 | Vodafone | Peter.Howard@vodafone.com | Rel-9 | SP-43 | Dionisio |  |  |  |
| 301 | 125.2 | **CN aspects of IMS Media Plane Security** | 131d? | 2009-09-18 A | 2010-03-19 | 97% | 4.15d? | 2009-09-18 | 2010-03-19 | 131d? | 390d |  | C1,C4,C3 | 2131.2h | 2063.71h | MEDIASEC_CORE | PCG-23 | Vodafone | peter.dawes@vodafone.com | Rel-9 | CP-45 | Frederic |  |  |  |
| 302 | 125.2.1 | CT1 aspects - MEDIASEC | 33d? | 2009-09-18 A | 2010-03-19 A | 100% |  | 2009-09-18 | 2010-03-19 | 33d? |  | finish no earlier than 2010-03-19 | C1 | 264h | 264h | MEDIASEC_CORE | PCG-23 | Vodafone | peter.dawes@vodafone.com | Rel-9 | CP-45 | Frederic |  |  |  |
| 303 | 125.2.2 | CT4 aspects - MEDIASEC | 131d? | 2009-09-18 A | 2010-03-19 A | 100% |  | 2009-09-18 | 2010-03-19 | 131d? |  | finish no earlier than 2010-03-19 | C4 | 1048h | 1048h | MEDIASEC_CORE | PCG-23 | Vodafone | peter.dawes@vodafone.com | Rel-9 | CP-45 | Kimmo |  |  |  |
| 304 | 125.2.3 | CT3 aspects - MEDIASEC | 76d? | 2009-12-04 A | 2010-03-19 | 90% | 7.6d? | 2009-12-04 | 2010-03-19 | 76d? | 390d | finish no earlier than 2010-03-19 | C3 | 608h | 547.2h | MEDIASEC_CORE | PCG-24 | Vodafone | peter.dawes@vodafone.com | Rel-9 | CP-46 |  | CP-091022 |  |  |
| 305 | 126 | **GBAPush enhancements (Generic push layer)** | 533d? | 2008-03-12 A | 2010-03-25 A | 100% |  | 2008-03-12 | 2010-03-25 | 533d? |  |  | S3 | 8528h | 8528h | eGBAPush | PCG-23 | Ericsson | Rolf Blom | Rel-9 | SP-44 | Dionisio |  |  |  |
| 306 | 126.1 | SA3 part of eGBAPush (Generic push layer) | 533d? | 2008-03-12 A | 2010-03-25 A | 100% |  | 2008-03-12 | 2010-03-25 | 533d? |  | finish no earlier than 2010-03-25 | S3 | 4264h | 4264h | eGBAPush | PCG-21 | Ericsson | Rolf Blom | Rel-9 | SP-39 | Dionisio |  |  |  |
| 307 | 127 | Extended Identity Management | 136d? | 2009-06-04 A | 2009-12-10 A | 100% |  | 2009-06-04 | 2009-12-10 | 136d? |  | finish no earlier than 2009-12-10 | S3 | 1088h | 1088h | GBA-IdM | PCG-23 | Nokia | Silke.Holtmanns at nokia.com | Rel-9 | SP-44 | Dionisio |  |  |  |
| 308 | 128 | **Network Domain Security (NDS) enhancements to support backhaul security** | 211d? | 2009-06-04 A | 2010-03-25 A | 100% |  | 2009-06-04 | 2010-03-25 | 211d? |  |  | S3,C4 | 4432h | 4432h | NDS_Backhaul | PCG-23 | Vodafone | Peter Howard | Rel-9 | SP-44 | Dionisio |  |  |  |
| 309 | 128.1 | SA3 part of NDS_Backhaul | 211d? | 2009-06-04 A | 2010-03-25 A | 100% |  | 2009-06-04 | 2010-03-25 | 211d? |  | finish no earlier than 2010-03-25 | S3 | 1688h | 1688h | NDS_Backhaul | PCG-23 | Vodafone | Peter Howard | Rel-9 | SP-44 | Dionisio | SP-090834 |  |  |
| 310 | 128.2 | CT4 part of NDS_Backhaul | 132d? | 2009-06-04 A | 2009-12-04 A | 100% |  | 2009-06-04 | 2009-12-04 | 132d? |  | finish no earlier than 2009-12-04 | C4 | 1056h | 1056h | NDS_Backhaul | PCG-23 | Vodafone | Peter Howard | Rel-9 | SP-44 | Kimmo |  |  |  |
| 311 | 129 | **128 bit encryption for GSM and GPRS** | 136d? | 2009-06-04 A | 2009-12-10 A | 100% |  | 2009-06-04 | 2009-12-10 | 136d? |  |  | S3,C1,C4,G2,G3new | 6040h | 6040h | A5/4-GEA4 | PCG-23 | Ericsson | Karl Norrman | Rel-9 | SP-44 | Dionisio |  |  |  |
| 312 | 129.1 | SA3 part of A5/4-GEA4 | 136d? | 2009-06-04 A | 2009-12-10 A | 100% |  | 2009-06-04 | 2009-12-10 | 136d? |  | finish no earlier than 2010-01-06 | S3 | 1088h | 1088h | A5/4-GEA4 | PCG-23 | Ericsson | Karl Norrman | Rel-9 | SP-44 | Dionisio |  |  |  |
| 313 | 129.2 | CT1 part of A5/4-GEA4 | 77d? | 2009-06-04 A | 2009-09-18 A | 100% |  | 2009-06-04 | 2009-09-18 | 77d? |  | start no earlier than 2009-06-04 | C1 | 616h | 616h | A5/4-GEA4 | PCG-23 | Ericsson | Karl Norrman | Rel-9 | SP-44 | Frederic |  |  |  |
| 314 | 129.3 | CT4 part of A5/4-GEA4 | 136d? | 2009-06-04 A | 2009-12-10 A | 100% |  | 2009-06-04 | 2009-12-10 | 136d? |  | start no earlier than 2009-06-04 | C4 | 1088h | 1088h | A5/4-GEA4 | PCG-23 | Ericsson | Karl Norrman | Rel-9 | SP-44 | Kimmo |  |  |  |
| 315 | 129.4 | GERAN2 part of A5/4-GEA4 | 67d? | 2009-06-04 A | 2009-09-04 A | 100% |  | 2009-06-04 | 2009-09-04 | 67d? |  | finish no earlier than 2009-09-04 | G2 | 536h | 536h | A5/4-GEA4 | PCG-23 | Ericsson | Karl Norrman | Rel-9 | SP-44 | Gert |  |  |  |
| 316 | 129.5 | GERAN3new (testing) part of A5/4-GEA4 | 122d? | 2009-06-04 A | 2009-11-20 A | 100% |  | 2009-06-04 | 2009-11-20 | 122d? |  | finish no earlier than 2009-11-20 | G3new | 976h | 976h | A5/4-GEA4 | PCG-23 | Ericsson | Karl Norrman | Rel-9 | SP-44 | Ingbert |  |  |  |
| 317 | 129.6 | Deleted - SA2 part of A5/4-GEA4 | 81d? | 2009-06-04 A | 2009-09-24 A | 100% |  | 2009-06-04 | 2009-09-24 | 81d? |  | finish no earlier than 2009-09-24 | S2 | 648h | 648h | A5/4-GEA4 | PCG-23 | Ericsson | Karl Norrman | Rel-9 | SP-44 | Maurice |  | PCG-23 | SP-45 |
| 318 | 130 | Deleted - Lawful Interception in the 3GPP Rel-9 | 211d? | 2009-06-04 A | 2010-03-25 A | 100% |  | 2009-06-04 | 2010-03-25 | 211d? |  | finish no earlier than 2010-03-25 | S3 | 1688h | 1688h | LI9 | PCG-23 | PIDS, Nortel | Koen Jaspers, Ronald Ryan | Rel-9 | SP-44 | Dionisio |  | PCG-24 | SP-47 |
| 319 | 131 | Timed Graphics | 337d? | 2008-12-11 A | 2010-03-25 A | 100% |  | 2008-12-11 | 2010-03-25 | 337d? |  | finish no earlier than 2010-03-25 | S4 | 2696h | 2696h | TG | PCG-22 | Ericsson | clinton.priddle@ericsson.com | Rel-9 | SP-42 | Paolo |  |  |  |
| 320 | 132 | Managing MTSI Media Adaptation | 272d? | 2009-03-12 A | 2010-03-25 A | 100% |  | 2009-03-12 | 2010-03-25 | 272d? |  | finish no earlier than 2009-12-10 | S4 | 1568h | 1568h | M3A | PCG-22 | Samsung | kyunghun.jung@samsung.com | Rel-9 | SP-43 | Paolo |  |  |  |
| 321 | 133 | **PSS and MBMS Aspects** | 272d? | 2009-03-12 A | 2010-03-25 A | 100% |  | 2009-03-12 | 2010-03-25 | 272d? |  |  | S4 | 6512h | 6512h | PMA | PCG-23 | Ericsson, Nokia | Clinton.Priddle@ericsson.com, imed.bouazizi@nokia.com | Rel-9 | SP-44 | Paolo |  |  |  |
| 322 | 133.1 | PSS and MBMS extensions | 271d? | 2009-03-12 A | 2010-03-25 A | 100% |  | 2009-03-12 | 2010-03-25 | 271d? |  | finish no earlier than 2010-03-25 | S4 | 2168h | 2168h | PMA-MBS_Ext | PCG-22 | Ericsson | Clinton.Priddle@ericsson.com | Rel-9 | SP-43 | Paolo |  |  |  |
| 323 | 133.2 | Improved Video Support for PSS and MBMS | 271d? | 2009-03-12 A | 2010-03-25 A | 100% |  | 2009-03-12 | 2010-03-25 | 271d? |  | finish no earlier than 2010-03-25 | S4 | 2168h | 2168h | PMA-IVS | PCG-22 | Nokia | imed.bouazizi@nokia.com | Rel-9 | SP-43 | Paolo |  |  |  |
| 324 | 134 | IMS based PSS and MBMS User Service extensions | 197d? | 2009-03-12 A | 2009-12-10 A | 100% |  | 2009-03-12 | 2009-12-10 | 197d? |  | finish no earlier than 2009-12-10 | S4 | 1576h | 1576h | IMS_PSS_MBMS_US_EXT | PCG-22 | Ericsson | Markus Kampmann | Rel-9 | SP-43 | Paolo |  |  |  |
| 325 | 135 | Syndicated Feed Reception within 3GPP environments | 136d? | 2009-06-04 A | 2009-12-10 A | 100% |  | 2009-06-04 | 2009-12-10 | 136d? |  | start no earlier than 2009-06-04 | S4 | 1088h | 1088h | SFR | PCG-23 | Ericsson | Thorsten.Lohmar@ericsson.com | Rel-9 | SP-44 | Paolo |  |  |  |
| 326 | 136 | Distortion Measurement Test Methods and Requirements | 131d? | 2009-09-24 A | 2010-03-25 A | 100% |  | 2009-09-24 | 2010-03-25 | 131d? |  | finish no earlier than 2010-03-25 | S4 | 1048h | 1048h | DTMR | PCG-23 | Motorola | Stephen Kendall (wcsk01@motorola.com) | Rel-9 | SP-45 | Paolo |  |  |  |

Notes:
- 299: CP#46 Stage 3 exception to 03/10. SP#47 SA3 completed
- 300: SP#47 completed / Text3: new 33.828, 33.328
- 301: CP#46 exception to 03/10. WID updated CP-090740=>CP-090884
- 302: CP#47 completed / Text3: 23.218, 24.229
- 303: CP#47 completed / Text3: 29.238, 23.334, 29.334
- 304: CP#46 exception to 03/10 in CP-091022 / Text3: 29.162
- 305: SP#43 umbrella to host 33.224, moved from Rel-8 to Rel-9. SP#47 completed / Text3: new 33.224
- 306: SP#47 completed / Text3: new 33.224
- 307: SP#46 completed. TR 33.924 (Stage 2) for Approval. Stage 1 not identified: GBA Liberty Interworking has been outlined and GBAOpenID interworking is analogous / Text3: new 33.924, CP#45 CT4 completed (Added service code in 29.109)
- 308: SP#47 completed. Continuation of Rel-8 UID_390044 SAE security architecture. Covers gaps in backhaul security in SAE (also applicable to UTRAN and GERAN backhaul)
- 309: SP#47 completed / Text3: 33.102, 33.210, 33.310, 33.401, 33.402
- 310: CP#46 completed. No impact on CT4 specs
- 311: Allow 128 as an alternative to 64 bit keys (Stage 2/3 + Test spec)
- 312: SP#46 completed. SP#45 TS 55.226v100 for Information+Approval / Text3: 33.102,43.020, new 55.226
- 313: CP#45 completed / Text3: 24.008,44.064
- 314: CP#46 completed. Kc128 enhancements are carried as UMTS keys => no CT4 impact / Text3: 29.002, 29.060
- 315: GP#43 WID approved + completed / Text3: 44.018,48.008,48.018,48.058
- 316: GP#44 completed. GP#43 WID approved / Text3: 51.010
- 317: SP#45 work stopped/abandoned / Text3: 23.060
- 318: SP#47 stopped. WI + new topics moved to Rel-10 / Text3: 33.106, 33.107, 33.108
- 319: SP#47 completed. Provide graphics in parallel to a video stream (without requiring an umbrella scene descriptor such as 3GPP DIMS in TS 26.142) / Text3: 26.114, 26.140, 26.234, 26.244, 26.245, 26.346, new 26.430
- 320: SP#46 completed. Work extending Rel-8 UID_34041 MTSI Video - Dynamic Rate Adaptation/Signalling of Image Size. Update speech/video adaptation algorithms used by network to control MTSI client terminal in congestion or poor transmission conditions. / Text3: 26.114
- 321: Umbrella WI. SP#47 completed
- 322: SP#47 completed. Extends Rel-8 UID_34043 (PSS_MBMS_OMTV) & ensures compatibility with UID_34046 (IMS_PSS_MBMS_US) / Text3: 26.234, 26.346
- 323: SP#47 completed / Text3: 26.234, 26.244, 26.346, new 26.903
- 324: SP#46 completed. Work extending Rel-8 UID_34046 (IMS_PSS_MBMS_US), SA2 UID_410034 IMSSCC-SPI (IMS Service Continuity Enhancements: Service, Policy and Interactions) / Text3: 26.237
- 325: SP#46 completed. TS 26.150v100 for Approval. RSS optimized for mobile use. Reuse/reference OMA's enabler DCD. / Text3: 26.150
- 326: SP#47 completed / Text3: 26.131, 26.132

| ID | WBS | Task | Duration | Start | Finish | Complete | Remaining | Baseline start | Baseline finish | Baseline duration | Total slack | Constraint | Resources | Work | Actual work | Text1 | Text2 | Text6 | Text7 | Text8 | Text4 | Text11 | Text9 | Text12 |
| --- | --- | --- | --- | --- | --- | --- | --- | --- | --- | --- | --- | --- | --- | --- | --- | --- | --- | --- | --- | --- | --- | --- | --- | --- |
| 327 | 137 | **OAM&P 9** | 601d? | 2008-02-22 A | 2010-06-10 | 89% | 63.71d? | 2008-02-22 | 2010-06-10 | 601d? | 331d |  | S5 | 36890.4h | 33108.4h | OAM9 | PCG-22 | Rel-9 | SP-42 | Dionisio |  |  |  |  |
| 328 | 137.1 | **Network Infrastructure Management** | 337d? | 2008-12-11 A | 2010-03-25 A | 100% |  | 2008-12-11 | 2010-03-25 | 337d? |  |  | S5 | 8760h | 8760h | OAM9-NIM | PCG-22 | Rel-9 | SP-42 | Dionisio |  |  |  |  |
| 329 | 137.1.1 | Software Management for Network Elements | 336d? | 2008-12-11 A | 2010-03-25 A | 100% |  | 2008-12-11 | 2010-03-25 | 336d? |  | finish no earlier than 2010-03-25 | S5 | 2688h | 2688h | OAM9-NE_SWM | PCG-22 | Rel-9 | SP-42 | Dionisio | Huawei, Nokia Siemens Networks |  |  |  |
| 330 | 137.1.2 | Service Oriented Architecture (SOA) for IRP | 211d? | 2009-06-04 A | 2010-03-25 A | 100% |  | 2009-06-04 | 2010-03-25 | 211d? |  | finish no earlier than 2010-03-25 | S5 | 1688h | 1688h | OAM9 | PCG-23 | Rel-9 | SP-44 | Dionisio | Ericsson, Nokia Siemens Networks |  |  |  |
| 331 | 137.1.3 | IRP SOAP Solution Sets continuation from Rel-8 | 211d? | 2009-06-04 A | 2010-03-25 A | 100% |  | 2009-06-04 | 2010-03-25 | 211d? |  | finish no earlier than 2010-03-25 | S5 | 1688h | 1688h | OAM9 | PCG-23 | Rel-9 | SP-44 | Dionisio | Ericsson |  |  |  |
| 332 | 137.2 | **Performance Management** | 327d? | 2009-03-12 A | 2010-06-10 | 85% | 48.6d? | 2009-03-12 | 2010-06-10 | 327d? | 331d |  | S5 | 7890.41h | 6716.78h | OAM9-PM | PCG-22 | Rel-9 | SP-42 | Dionisio |  |  |  |  |
| 333 | 137.2.1 | Enhancement of E-UTRAN Performance Measurements | 327d? | 2009-03-12 A | 2010-06-10 | 70% | 98.1d? | 2009-03-12 | 2010-06-10 | 327d? | 331d | finish no earlier than 2010-06-10 | S5 | 2616h | 1831.2h | OAM9 | PCG-22 | Rel-9 | SP-43 | Dionisio | Motorola, Huawei | SP-100072 |  |  |
| 334 | 137.2.2 | Enhancement of EPC Performance Measurements | 197d? | 2009-03-12 A | 2009-12-10 A | 100% |  | 2009-03-12 | 2009-12-10 | 197d? |  | finish no earlier than 2010-03-25 | S5 | 1570.41h | 1570.41h | OAM9 | PCG-22 | Rel-9 | SP-43 | Dionisio | China Mobile |  |  |  |
| 335 | 137.2.3 | Enhancement of UTRAN Performance Measurements | 136d? | 2009-06-04 A | 2009-12-10 A | 100% |  | 2009-06-04 | 2009-12-10 | 136d? |  | start no earlier than 2009-06-04 | S5 | 1088h | 1088h | OAM9 | PCG-23 | Rel-9 | SP-44 | Dionisio | China Mobile |  |  |  |
| 336 | 137.3 | Deleted - Trace | 196d? | 2009-03-13 A | 2009-12-10 A | 100% |  | 2009-03-13 | 2009-12-10 | 196d? |  | finish no earlier than 2009-12-10 | S5 | 1568h | 1568h | OAM9-Trace | PCG-22 | Rel-9 | SP-42 | Dionisio |  |  | PCG-24 | SP-46 |
| 337 | 137.4 | **Self-Organizing Networks (SON) - OAM aspects** | 601d? | 2008-02-22 A | 2010-06-10 | 88% | 69.33d? | 2008-02-22 | 2010-06-10 | 601d? | 331d |  | S5 | 11736h | 10382.2h | OAM9-SON | PCG-22 | Rel-9 | SP-43 | Dionisio |  |  |  |  |
| 338 | 137.4.1 | SON self-optimization management | 600d? | 2008-02-22 A | 2010-06-10 | 90% | 60d? | 2008-02-22 | 2010-06-10 | 600d? | 331d | finish no earlier than 2010-06-10 | S5 | 4800h | 4320h | LTE_SON-OAM | PCG-21 | Rel-9 | SP-39 | Dionisio | Huawei | SP-100071 |  |  |
| 339 | 137.4.2 | Automatic Radio Network Configuration Data Preparation | 266d? | 2009-06-04 A | 2010-06-10 | 85% | 39.9d? | 2009-06-04 | 2010-06-10 | 266d? | 331d | finish no earlier than 2010-06-10 | S5 | 2128h | 1808.8h | OAM9 | PCG-23 | Rel-9 | SP-44 | Dionisio | Nokia Siemens Networks | SP-100075 |  |  |
| 340 | 137.5 | Subscription Management (SuM) evolution | 266d? | 2009-06-04 A | 2010-06-10 | 65% | 93.1d? | 2009-06-04 | 2010-06-10 | 266d? | 331d | finish no earlier than 2010-06-10 | S5 | 2128h | 1383.2h | OAM9-SuM | PCG-23 | Rel-9 | SP-44 | Dionisio | Ericsson | SP-100073 |  |  |
| 341 | 138 | Charging Management small Enhancements | 211d? | 2009-06-04 A | 2010-03-25 A | 100% |  | 2009-06-04 | 2010-03-25 | 211d? |  |  | S5 | 1688h | 1688h | CH9 | PCG-23 | Rel-9 | SP-44 | Dionisio |  |  |  |  |
| 342 | 139 | **CS-IBCF and CS-TrGW definition in 3GPP specifications** | 472d? | 2008-05-30 A | 2010-03-19 A | 100% |  | 2008-05-30 | 2010-03-19 | 472d? |  |  | C3,C4 | 10714.3h | 10714.3h | CS-IBCF | PCG-21 | Rel-9 | CP-40 | Gwiho | Telecom Italia |  |  |  |
| 343 | 139.1 | CT3 aspects of CS-IBCF | 472d? | 2008-05-30 A | 2010-03-19 A | 100% |  | 2008-05-30 | 2010-03-19 | 472d? |  | finish no earlier than 2009-12-04 | C3 | 3770.34h | 3770.34h | CS-IBCF | PCG-21 | Rel-9 | CP-40 | Gwiho | Telecom Italia |  |  |  |
| 344 | 139.2 | CT4 aspects of CS-IBCF | 396d? | 2008-05-30 A | 2009-12-04 A | 100% |  | 2008-05-30 | 2009-12-04 | 396d? |  | finish no earlier than 2009-12-04 | C4 | 3168h | 3168h | CS-IBCF | PCG-21 | Rel-9 | CP-40 | Kimmo | Telecom Italia |  |  |  |
| 345 | 140 | **IMS – Interconnection Border Control Function (IBCF) – Transition Gateway (TrGW); Ix Interface; Stage 3** | 322d? | 2008-09-12 A | 2009-12-04 A | 100% |  | 2008-09-12 | 2009-12-04 | 322d? |  |  | C4,C3 | 6858.4h | 6858.4h | IMS_IBCF | PCG-21 | Rel-9 | CP-41 | Kimmo | Alcatel-Lucent |  |  |  |
| 346 | 140.1 | CT4 part of IMS_IBCF | 321d? | 2008-09-12 A | 2009-12-04 A | 100% |  | 2008-09-12 | 2009-12-04 | 321d? |  | finish no earlier than 2009-12-04 | C4 | 2568h | 2568h | IMS_IBCF | PCG-21 | Rel-9 | CP-41 | Kimmo | Alcatel-Lucent |  |  |  |
| 347 | 140.2 | CT3 part of IMS_IBCF | 295.8d? | 2008-09-12 A | 2009-12-04 A | 100% |  | 2008-09-12 | 2009-12-04 | 295.8d? |  | finish no earlier than 2010-03-19 | C3 | 2366.4h | 2366.4h | IMS_IBCF | PCG-21 | Rel-9 | CP-41 | Gwiho | Alcatel-Lucent |  |  |  |
| 348 | 141 | IMS Application Level Gateway Control Function (ALGCF) – IMS Access Media Gateway (IMA-MGW); Iq Interface; Stage 2 and Stage 3 | 321d? | 2008-09-12 A | 2009-12-04 A | 100% |  | 2008-09-12 | 2009-12-04 | 321d? |  | finish no earlier than 2009-12-04 | C4 | 2568h | 2568h | IMS_AGCF | PCG-21 | Rel-9 | CP-41 | Kimmo | Alcatel-Lucent |  |  |  |
| 349 | 142 | **Enhancements of IMS Customized Alerting Tone (CAT) Service** | 392d? | 2008-12-05 A | 2010-06-04 | 95% | 19.6d? | 2008-12-05 | 2010-06-04 | 392d? | 335d |  | C1 | 5846.4h | 5554.08h | eCAT | PCG-22 | Rel-9 | CP-42 | Frederic | China Mobile |  |  |  |
| 350 | 142.1 | Stage 3 Enhancements of IMS CAT Supplementary Service | 391d? | 2008-12-05 A | 2010-06-04 | 95% | 19.55d? | 2008-12-05 | 2010-06-04 | 391d? | 335d | finish no earlier than 2010-06-04 | C1 | 3128h | 2971.6h | eCAT-SS | PCG-22 | Rel-9 | CP-42 | Frederic | China Mobile | CP-090870 |  |  |

Notes:
- 327: SP#42 umbrella Feature created to host OAM WIs
- 328: SP#42 umbrella BB created to host OAM WIs
- 329: SP#47 completed / Text3: 32.531, 32.532, 32.533, new 32.537 / Text5: Bidipta Das (bidipta@huawei.com), Clemens Suerbaum (clemens.suerbaum@nsn.com)
- 330: SP#47 completed (covering SOA Architecture & SOA-supporting Solution Set). Triggered by UID_400029 Study on Service Oriented Architecture (SOA) for IRP (TR 32.824) / Text3: 32.101, 32.102, 32.150 / Text5: Edwin Tse (Ericsson), Joerg Schmidt (NSN)
- 331: SP#47 completed. Continuation of Rel-8 UID_400030 IRP SOAP Solution Sets / Text3: New (32.127/ 327/ 337/ 357/ 387/ 397/ 447/ 397/ 447/ 507/ 537), 32.121,32.122,32.123,32,32.321,32.322,32.323,32.325,32.331,32.332,32.333,32.335,32.351,32.352,32.353,32.381,32.382,32.383,32.385,32.391,32.392,32.393,32.395,32.441,32.442,32.443 / Text5: John Power
- 332: SP#42 umbrella BB created to host OAM WIs
- 333: SP#47 exception to 06/10 in SP-100072 / Text3: 32.425 / Text5: Yizhi Yao (yzyao@motorola.com),Lan Zou (zlan@huawei.com)
- 334: SP#46 completed / Text3: 32.426 / Text5: Li Jian (lijian@chinamobile.com), Liang Shuangchun (liangshuangchun@cmdi.chinamobile.com)
- 335: SP#46 completed / Text3: 32.405 / Text5: Liang Shuangchun, Li Jian, Bao Haitao
- 336: SP#46 stopped (no work in Rel-9)
- 337: SP#43 umbrella BB created to host OAM WIs
- 338: SP#47 exception to 06/10 in SP-100071. WID updated SP-090762=>SP-100091 / Text3: 32.425, new 32.521, 32.522, 32.523, 32.525 / Text5: Lan Zou (zlan@huawei.com)
- 339: SP#47 exception to 06/10 in SP-100075 / Text3: 32.501, 32.502, 32.503, 32.505, new 32.507 / Text5: clemens.suerbaum@nsn.com
- 340: SP#47 exception to 06/10 in SP-100073 / Text3: 32.140, 32.141, 32.152, 32.172, 32.175 / Text5: frode.nergard@ericsson.com
- 341: SP#47 completed
- 342: CP#47 completed. Rel-8 UID_380061 (Ipinterc) covers Stage 1 in SA1 22.101, 22.228 / Text5: mauro.ficaccio@telecomitalia.it
- 343: CP#47 completed / Text3: 29.235 / Text5: mauro.ficaccio@telecomitalia.it
- 344: CP#46 completed / Text3: 23.231, 29.232, new 29.238 / Text5: mauro.ficaccio@telecomitalia.it
- 345: CP#46 completed / Text5: Bruno.Landais@alcatel-lucent.fr
- 346: CP#46 completed / Text3: new 29.238 / Text5: Bruno.Landais@alcatel-lucent.fr
- 347: CP#46 completed / Text3: 29.162, 29.235 / Text5: Bruno.Landais@alcatel-lucent.fr
- 348: CP#46 completed / Text3: new 23.334, 29.334 / Text5: bruno.landais@alcatel-lucent.fr
- 349: CP#46 completion 12/09=>03/10. CP#42 umbrella Feature created to host CT1 CAT WI (Stage 1 in 22.182) / Text5: Jiang Yi
- 350: CP#46 exception to 03/10 in CP-090870 / Text3: 24.182 / Text5: Jiang Yi

| ID | WBS | Task | Type | Duration | Start | Finish | Complete | Remaining | Baseline start | Baseline finish | Baseline duration | Total slack | Constraint | Resources | Work | Actual work | Text1 | Text2 | Text4 | Text5 | Text6 | Text7 | Text8 | Text11 | Text9 | Text12 |
| --- | --- | --- | --- | --- | --- | --- | --- | --- | --- | --- | --- | --- | --- | --- | --- | --- | --- | --- | --- | --- | --- | --- | --- | --- | --- | --- |
| 351 | 143 | **Completion of IMS Restoration Procedures** |  | 212d? | 2009-05-29 A | 2010-03-19 | 99% | 0d? | 2009-05-29 | 2010-03-19 | 212d? | 0d |  | C3, C4,C1 | 6784h | 5088h | eIMS_RP | PCG-23 | Ericsson | Emiliano Merino (emiliano.merino@ericsson.com) | Rel-9 | CP-44 | Kimmo |  |  |  |
| 352 | 143.1 | CT4 aspects of eIMS_RP |  | 212d? | 2009-05-29 A | 2010-03-19 A | 100% |  | 2009-05-29 | 2010-03-19 | 212d? |  | finish no earlier than 2010-03-19 | C4 | 1696h | 1696h | eIMS_RP | PCG-23 | Ericsson | Emiliano Merino (emiliano.merino@ericsson.com) | Rel-9 | CP-44 | Kimmo |  |  |  |
| 353 | 143.2 | CT1 aspects of eIMS_RP |  | 212d? | 2009-05-29 A | 2010-03-19 A | 100% |  | 2009-05-29 | 2010-03-19 | 212d? |  | finish no earlier than 2010-03-19 | C1 | 1696h | 1696h | eIMS_RP | PCG-23 | Ericsson | Emiliano Merino (emiliano.merino@ericsson.com) | Rel-9 | CP-44 | Kimmo | CP-090871 |  |  |
| 354 | 143.3 | CT3 aspects of eIMS_RP |  | 212d? | 2009-05-29 A | 2010-03-19 A | 100% |  | 2009-05-29 | 2010-03-19 | 212d? |  | finish no earlier than 2010-03-19 | C3 | 1696h | 1696h | eIMS_RP | PCG-24 | Ericsson | Emiliano Merino (emiliano.merino@ericsson.com) | Rel-9 | CP-46 | Kimmo |  |  |  |
| 355 | 144 | IMS Stage 3 - IETF Protocol Alignment |  | 212d? | 2009-05-29 A | 2010-03-19 A | 100% |  | 2009-05-29 | 2010-03-19 | 212d? |  | finish no earlier than 2010-03-19 | C1 | 1696h | 1696h | IMSProtoc3 | PCG-23 | Alcatel-Lucent | Keith Drage (drage@alcatel-lucent.com) | Rel-9 | CP-44 | Frederic |  |  |  |
| 356 | 145 | Operational description of the Inter-IMS Network to Network Interface (II-NNI) |  | 212d? | 2009-05-29 A | 2010-03-19 | 98% | 4.24d? | 2009-05-29 | 2010-03-19 | 212d? | 390d | finish no earlier than 2010-03-19 | C3 | 1696h | 1662.08h | II-NNI | PCG-23 | Orange | sebastien.daudet@orange-ftgroup.com | Rel-9 | CP-44 | Gwiho | CP-090862 |  |  |
| 357 | 146 | Definition of Ml interface for Control Plane LCS (Stage 3) |  | 131d? | 2009-09-18 A | 2010-03-19 A | 100% |  | 2009-09-18 | 2010-03-19 | 131d? |  | finish no earlier than 2010-03-19 | C1 | 1048h | 1048h | EMC2 | PCG-23 | Alcatel-Lucent | Keith Drage (drage@alcatel-lucent.com) | Rel-9 | CP-45 | Frederic |  |  |  |
| 358 | 147 | PCC enhancements |  | 56d? | 2009-09-18 A | 2009-12-04 A | 100% |  | 2009-09-18 | 2009-12-04 | 56d? |  | finish no earlier than 2009-12-04 | C3 | 448h | 448h | PCC-Enh | PCG-23 | Huawei | Wei Weihua (weiwh@huawei.com) | Rel-9 | CP-45 | Gwiho |  |  |  |
| 359 | 148 | 3GPP IMS Conferencing Management Object (MO) |  | 2d? | 2009-12-03 A | 2009-12-04 A | 100% |  | 2009-12-03 | 2009-12-04 | 2d? |  | start no earlier than 2009-12-03 | C1 | 16h | 16h | IMS_ConfMO | PCG-24 |  |  | Rel-9 | CP-46 | Frederic |  |  |  |
| 360 | 149 | Deleted - Definition of 3GPP UICC services over the new high-speed interface | milestone | 0d? | 2010-03-19 A | 2010-03-19 A | 100% |  | 2010-03-19 | 2010-03-19 | 0d? |  |  | C6 |  |  | UICCHS | PCG-21 | Gemalto | Denis L'Heriteau | Rel-9 | CP-38 | Xavier |  | PCG-24 | CP-47 |
| 361 | 150 | In Case of Emergency (ICE) Graphics |  | 3d? | 2010-03-17 A | 2010-03-19 A | 100% |  | 2010-03-17 | 2010-03-19 | 3d? |  | finish no earlier than 2010-03-19 | C6 | 24h | 24h | ICE_Graphics | PCG-24 | Sagem-Orga | heiko.kruse@sagem-orga.com | Rel-9 | CP-47 | Xavier |  |  |  |
| 362 | 151 | **Rel-9 Improvements of the Radio Interface** |  | 397d? | 2008-09-12 A | 2010-03-19 A | 100% |  | 2008-09-12 | 2010-03-19 | 397d? |  |  | RP,GP | 19147.6h | 19147.6h | RInImp9 | PCG-21 |  |  | Rel-9 | RP-41 | Issam |  |  |  |
| 363 | 151.1 | LCR TDD UE OTA Performance Requirements |  | 186d? | 2008-09-12 A | 2009-05-29 A | 100% |  | 2008-09-12 | 2009-05-29 | 186d? |  | finish no earlier than 2009-05-29 | R4 | 1488h | 1488h | RInImp9-RFLCROTA | PCG-21 | RITT | Wu Xiang (wuxiang@chinattl.com) | Rel-9 | RP-41 | Issam | RP-090389 |  |  |
| 364 | 151.2 | **RF requirements for Multicarrier and Multi-RAT BS** |  | 347d? | 2008-11-21 A | 2010-03-19 A | 100% |  | 2008-11-21 | 2010-03-19 | 347d? |  |  | R4,G1 | 7403.6h | 7403.6h | RInImp9-RFmulti | PCG-21 | Ericsson | Johan.skold@ericsson.com | Rel-9 | RP-41 | Issam | RP-100027 |  |  |
| 365 | 151.2.1 | RAN4 part of RF requirements for Multicarrier and Multi RAT BS |  | 337d? | 2008-12-05 A | 2010-03-19 A | 100% |  | 2008-12-05 | 2010-03-19 | 337d? |  | finish no earlier than 2010-03-19 | R4 | 2696h | 2696h | RInImp9-RFmulti | PCG-22 | Ericsson | Johan.skold@ericsson.com | Rel-9 | RP-42 | Issam | RP-100027 |  |  |
| 366 | 151.2.2 | GERAN part of RF requirements for Multicarrier and Multi RAT BS |  | 261d? | 2008-11-21 A | 2009-11-20 A | 100% |  | 2008-11-21 | 2009-11-20 | 261d? |  | finish no earlier than 2009-11-20 | G1 | 2088h | 2088h | RInImp9-RFmulti-GERAN | PCG-22 | Ericsson | mats.y.samuelsson@ericsson.com | Rel-9 | GP-40 | Paolo |  |  |  |
| 367 | 151.3 | Extended UMTS/LTE 800 MHz |  | 207d? | 2008-12-05 A | 2009-09-18 A | 100% |  | 2008-12-05 | 2009-09-18 | 207d? |  |  | R4,R2,R3 | 1648h | 1648h | RInImp9-UMTSLTE800 | PCG-22 | NTT DoCoMo | Shingo Suwa (suwas@nttdocomo.co.jp) | Rel-9 | RP-42 | Issam | RP-090687 |  |  |
| 368 | 151.4 | UMTS/LTE 800 MHz for Europe |  | 272d? | 2009-03-06 A | 2010-03-19 A | 100% |  | 2009-03-06 | 2010-03-19 | 272d? |  | finish no earlier than 2010-03-19 | R4,R2,R3 | 2176h | 2176h | RInImp9-UMTSLTE800EU | PCG-22 | Ericsson | olav.queseth@ericsson.com | Rel-9 | RP-43 | Issam | RP-100028 |  |  |
| 369 | 151.5 | Performance requirement for LCR TDD with UE speeds up to 350 km/h |  | 196d? | 2009-03-06 A | 2009-12-04 A | 100% |  | 2009-03-06 | 2009-12-04 | 196d? |  | finish no earlier than 2009-12-04 | R4 | 1568h | 1568h | RInImp9-LCRTDD350 | PCG-22 | CATT | Yuexia Song (songyuexia@datangmobile.cn) | Rel-9 | RP-43 | Issam | RP-091035 |  |  |
| 370 | 151.6 | Extended UMTS/LTE 1500 MHz |  | 211d? | 2009-05-30 A | 2010-03-19 A | 100% |  | 2009-05-30 | 2010-03-19 | 211d? |  | finish no earlier than 2010-03-19 | R4,R2,R3 | 1688h | 1688h | UMTSLTE1500 | PCG-23 | NTT DoCoMo | Shingo Suwa (suwas@nttdocomo.co.jp) | Rel-9 | RP-44 | Issam | RP-100029 |  |  |
| 371 | 152 | **Rel-9 Improvements of the Radio Interface - UE Conformance Testing** |  | 350d? | 2009-05-19 A | 2010-09-17 | 49% | 178.61d? | 2009-05-19 | 2010-09-17 | 350d? | 260d |  | R5 | 8184h | 4007.6h | RInImp-UEConTest | PCG-23 |  |  | Rel-9 | RP-44 | Ingbert |  |  |  |
| 372 | 152.1 | Conformance Test Aspects – UMTS/LTE in 800 MHz for Europe |  | 350d? | 2009-05-19 A | 2010-09-17 | 20% | 280d? | 2009-05-19 | 2010-09-17 | 350d? | 260d | finish no earlier than 2010-09-17 | R5 | 2800h | 560h | UMTSLTE800EU_UEConTest | PCG-23 | Ericsson | fredrik.sundstrom@ericsson.com | Rel-9 | RP-44 | Ingbert | RP-100067 |  |  |
| 373 | 152.2 | Conformance Test Aspects – Extended UMTS/LTE 1500 MHz |  | 186d? | 2009-09-18 A | 2010-06-04 | 96% | 7.44d? | 2009-09-18 | 2010-06-04 | 186d? | 335d | finish no earlier than 2010-06-04 | R5 | 1488h | 1428.48h | UMTSLTE1500_UEConTest | PCG-23 | NTT DoCoMo | Nguyen Dung Dao (dao@nttdocomo.co.jp) | Rel-9 | RP-45 | Ingbert | RP-100071 |  |  |
| 374 | 152.3 | TDD UE Over The Air (Antenna) conformance testing methodology |  | 81d? | 2009-05-30 A | 2009-09-18 A | 100% |  | 2009-05-30 | 2009-09-18 | 81d? |  | finish no earlier than 2009-09-18 | R5 | 648h | 648h | UEAnt_TDDTest | PCG-23 | CATR | Qu Yan (quyan@emcite.com) | Rel-9 | RP-44 | Ingbert | RP-090727 |  |  |
| 375 | 152.4 | Conformance Test Aspects – Performance requirement for LCR TDD with UE speeds up to 350 km/h |  | 56d? | 2010-03-19 | 2010-06-04 |  |  | 2010-03-19 | 2010-06-04 | 56d? | 335d | finish no earlier than 2010-06-04 | R5 | 448h |  | RInImp9-LCRTDD350_UEConTest | PCG-24 | CATT | Xiaozhong Chen (chexiaozhong@datangmobile.cn) | Rel-9 | RP-47 | Ingbert |  |  |  |
| 376 | 153 | Conformance Test Aspects – SMS over IMS in E-UTRAN |  | 131d? | 2009-09-18 A | 2010-03-19 A | 100% |  | 2009-09-18 | 2010-03-19 | 131d? |  | finish no earlier than 2010-06-18 | R5 | 1048h | 1048h | SMSoverIMS_UEConTest | PCG-23 | Alcatel-Lucent | Nidal Khrais (khrais@alcatel-lucent.com) | Rel-9 | RP-45 | Ingbert | RP-100072 |  |  |

Notes:
- 351: CP#46 exception to 03/10. WID updated CP-090316=>CP-091050 (added CT3 part). Continuation of Rel-8 Feature UID_400012 IMS Restoration Procedures
- 352: CP#47 completed / Text3: 23.380, 23.820
- 353: CP#47 completed / Text3: 24.229
- 354: CP#47 completed / Text3: 29.061, 29.212, 29.213, 29.214, 29.215
- 355: CP#47 completed / Text3: 23.218, 24.229, 24.930
- 356: CP#46 exception to 03/10 in CP-090862 / Text3: 29.165
- 357: CP#47 completed [Stage 3 for Rel-7 Emergency Calls (EMC1)]. Related to Rel-9 UID_400038 LCS Control Plane Solution for EPS. Stage 2 in Rel-9 UID_400038 (23.271), UID_410037 (23.167) / Text3: 24.229
- 358: CP#46 completed / Text3: 29.212, 29.213, 29.215
- 359: CP#46 completed. Linked to Rel-6 UID_11051 (IMS Management objects) under the Feature UID_32021 (IMS Phase 2). MO compatible with OMA DM v1.2 & upwards and defined using OMA DM Device Description Framework (OMA-ERELD _DM-V1_2) / Text3: new 24.166
- 360: CP#47 work stopped/abandoned / Text3: 31.xyz
- 361: CP#47 approved WID and completed. Added capability to store ICE graphical information (picture). Linked to CT6 Rel-8 ICE Feature UID_380059 In Case of Emergency numbers storage and easy access on UICC / Text3: 31.102 CR#0433
- 362: RP#41 umbrella Feature created to host Rel-9 WIs
- 363: RP#44 completed (Technical work completed, RAN4 internal TR abandoned. / Text3: Produced no TR 25.8xy (LCR TDD UE OTA performance requirements)
- 364: RP#47 completed. RF requirements specification applicable to Multi-Standard Radio (MSR) Base Station with multiple carriers and/or multiple 3GPP Radio Access Technologies (RAT)
- 365: RP#47 completed / Text3: 25.104, 25.105, 36.104, new 37.104, 37.113, 37.141, 37.900
- 366: GP#44 Core spec completed (ongoing BS conformance spec). GP#40 WID approved / Text3: 45.005, 51.021
- 367: RP#45 completed / Text3: 25.101, 25.104, 25.113, 25.133, 34.124, 36.101, 36.104, 36.113, 36.124, 36.133, 36.141, 25.306, 25.307, 25.331, 36.331, 25.461, 25.466, new 36.800
- 368: RP#47 completed / Text3: 25.101, 25.104, 25.113, 25.133, 25.141, 34.124, 36.101, 36.104, 36.113, 36.124, 36.133, 36.141, new 36.810, 25.306, 25.307, 25.331, 36.331, 25.461, 25.466
- 369: RP#46 completed / Text3: 25.102, 25.105, 25.142
- 370: RP#47 completed. For potential deployment in Japan / Text3: 25.101, 25.104, 25.113, 25.133, 25.141, 25.306, 25.307, 25.331, 25.461, 25.466, 34.124, 36.101, 36.104, 36.113, 36.124, 36.133, 36.141, 36.331, new 36.821, 36.307
- 371: -
- 372: RP#47 completion 03/10=>09/10. Testing for UID_430009 UMTS/LTE 800 MHz for Europe / Text3: 34.108, 34.121-1, 34.121-2, 36.508, 36.521-1, 36.521-2, 36.521-3
- 373: RP#47 completion 03/10=>06/10 / Text3: 34.108, 34.121-1, 34.121-2, 34.123-1, 34.123-2, 36.508, 36.521-1, 36.521-2, 36.521-3, 36.523-1, 36.523-2, 36.523-3
- 374: RP#45 completed. Finalize TDD UE test methodology based on R4 TR 25.914 (UE and MS antenna performance evaluation method) and TS 25.144 Over the Air (Antenna) minimum performance requirements for the speech mode (terminal close to head) / Text3: 34.114
- 375: Testing for UID_430010 Performance requirement for LCR TDD with UE speeds up to 350 km/h / Text3: 34.122
- 376: RP#47 completed / Text3: 34.229-1, 34.229-2, 34.229-3

| ID | WBS | Task | Duration | Start | Finish | Complete | Remaining | Baseline start | Baseline finish | Baseline duration | Total slack | Constraint | Resources | Work | Actual work | Text1 | Text2 | Text6 | Text7 | Text8 | Text4 | Text5 | Text11 |
| --- | --- | --- | --- | --- | --- | --- | --- | --- | --- | --- | --- | --- | --- | --- | --- | --- | --- | --- | --- | --- | --- | --- | --- |
| 377 | 154 | **Rel-9 RAN improvements** | 272d? | 2009-03-06 A | 2010-03-19 A | 100% |  | 2009-03-06 | 2010-03-19 | 272d? |  |  | RP | 9536h | 9536h | RANimp | PCG-22 | Rel-9 | RP-43 | Issam |  |  |  |
| 378 | 154.1 | Dual-Cell HSUPA | 272d? | 2009-03-06 A | 2010-03-19 A | 100% |  | 2009-03-06 | 2010-03-19 | 272d? |  | finish no earlier than 2010-03-19 | R1,R2,R3,R4 | 1568h | 1568h | RANimp-DC_HSUPA | PCG-22 | Rel-9 | RP-43 | Patrick | Nokia Siemens Networks | Karri Ranta-aho (karri.ranta-aho@nsn.com) | RP-100030 |
| 379 | 154.2 | Support for different bands for Dual-Cell HSDPA | 197d? | 2009-03-06 A | 2009-12-04 A | 100% |  | 2009-03-06 | 2009-12-04 | 197d? |  |  | R4,R2,R3 | 1568h | 1568h | RANimp-MultiBand_DC_HSDPA | PCG-22 | Rel-9 | RP-43 | Issam | Nokia Siemens Networks | Tuomo Säynäjäkangas (tuomo.saynajakangas@nsn.com) | RP-091038 |
| 380 | 154.3 | Combination of DC-HSDPA with MIMO | 197d? | 2009-03-06 A | 2009-12-04 A | 100% |  | 2009-03-06 | 2009-12-04 | 197d? |  |  | R1,R2,R3,R4 | 1568h | 1568h | RANimp-DC_MIMO | PCG-22 | Rel-9 | RP-43 | Patrick | Ericsson | johan.bergman@ericsson.com | RP-091039 |
| 381 | 154.4 | Transmit Antenna Array (TxAA) extension for non-MIMO UEs | 197d? | 2009-03-06 A | 2009-12-04 A | 100% |  | 2009-03-06 | 2009-12-04 | 197d? |  |  | R1,R2,R3,R4 | 1568h | 1568h | RANimp-TxAA_nonMIMO | PCG-22 | Rel-9 | RP-43 | Patrick | Nokia | Arto Lehti (arto.lehti@nokia.com) | RP-091040 |
| 382 | 154.5 | Cell Portion for 1.28 Mcps TDD | 136d? | 2009-05-30 A | 2009-12-04 A | 100% |  | 2009-05-30 | 2009-12-04 | 136d? |  |  | R3,R1,R4 | 1088h | 1088h | CP_LCRTDD | PCG-23 | Rel-9 | RP-44 | Juha | CATT | Ying Zhang (zhangying2@datangmobile.cn) | RP-091041 |
| 383 | 155 | **LTE improvements** | 327d? | 2009-03-06 A | 2010-06-04 | 97% | 10.22d? | 2009-03-06 | 2010-06-04 | 327d? | 335d |  | RP | 6800h | 6587.42h | LTEimp | PCG-22 | Rel-9 | RP-42 | Issam |  |  |  |
| 384 | 155.1 | LTE Pico NodeB RF Requirements | 196d? | 2009-03-06 A | 2009-12-04 A | 100% |  | 2009-03-06 | 2009-12-04 | 196d? |  | finish no earlier than 2010-03-05 | R4 | 1568h | 1568h | LTEimp-Pico_eNB-RF | PCG-22 | Rel-9 | RP-43 | Issam | Huawei | Liyan Yin (yinliyan@huawei.com) | RP-091045 |
| 385 | 155.2 | Enhanced Dual-Layer transmission for LTE | 327d? | 2009-03-06 A | 2010-06-04 | 95% | 16.35d? | 2009-03-06 | 2010-06-04 | 327d? | 335d | finish no earlier than 2010-06-04 | R1,R2,R4 | 2616h | 2485.2h | LTEimp-eDL | PCG-22 | Rel-9 | RP-43 | Patrick | China Mobile | Xu Xiaodong (xuxiaodong@chinamobile.com) | RP-100034 |
| 386 | 156 | **System aspects of vocoder rate adaptation for LTE** | 140d? | 2009-05-30 A | 2009-12-10 A | 100% |  | 2009-05-30 | 2009-12-10 | 140d? |  |  | S2,S4,R2 | 3504h | 3504h | LTEimp-Vocoder | PCG-23 | Rel-9 | SP-45 | Maurice | Qualcomm | AC Mahendran (ac@qualcomm.com) |  |
| 387 | 156.1 | SA2 system aspects of vocoder rate adaptation for LTE | 81d? | 2009-06-04 A | 2009-09-24 A | 100% |  | 2009-06-04 | 2009-09-24 | 81d? |  | start no earlier than 2009-06-04 | S2 | 648h | 648h | LTEimp-Vocoder | PCG-23 | Rel-9 | SP-45 | Maurice | Qualcomm | AC Mahendran (ac@qualcomm.com) |  |
| 388 | 156.2 | SA4 system aspects of vocoder rate adaptation for LTE | 136d? | 2009-06-04 A | 2009-12-10 A | 100% |  | 2009-06-04 | 2009-12-10 | 136d? |  | finish no earlier than 2009-12-07 | S4 | 1088h | 1088h | LTEimp-Vocoder | PCG-23 | Rel-9 | SP-45 | Paolo | Qualcomm | Nikolai Leung |  |
| 389 | 156.3 | Vocoder rate adaptation for LTE | 81d? | 2009-05-30 A | 2009-09-18 A | 100% |  | 2009-05-30 | 2009-09-18 | 81d? |  | finish no earlier than 2009-09-18 | R2 | 648h | 648h | LTEimp-Vocoder | PCG-23 | Rel-9 | RP-44 | Joern | Alcatel-Lucent | Sudeep Palat (spalat@alcatel-lucent.com) | RP-090704 |
| 390 | 157 | Self-Organizing Networks (SON) | 272d? | 2009-03-06 A | 2010-03-19 A | 100% |  | 2009-03-06 | 2010-03-19 | 272d? |  | finish no earlier than 2010-03-19 | R3,R2 | 2176h | 2176h | SON | PCG-22 | Rel-9 | SP-42 | Juha | Nokia Siemens Networks | Krzysztof Kordybach | RP-100038 |
| 391 | 158 | **A-GNSS Performances and Testing Procedures** | 527d? | 2008-05-16 A | 2010-05-21 | 63% | 194.6d? | 2008-05-16 | 2010-05-21 | 527d? | 345d |  | GP | 12208h | 5358.4h | AGNSSPTP |  | Rel-9 |  | Paolo | Thales | Michel.monnerat@thalesaleniaspace.com | GP-092344 |
| 392 | 158.1 | A-GNSS Minimum Performances | 472d? | 2008-05-16 A | 2010-03-05 A | 100% |  | 2008-05-16 | 2010-03-05 | 472d? |  | finish no earlier than 2010-03-05 | G1 | 3776h | 3776h | AGNSSPTP- Perfreq |  | Rel-9 |  | Paolo | Thales | Michel.monnerat@thalesaleniaspace.com |  |
| 393 | 158.2 | A-GNSS Testing Procedures | 527d? | 2008-05-16 A | 2010-05-21 | 30% | 368.9d? | 2008-05-16 | 2010-05-21 | 527d? | 345d | finish no earlier than 2010-05-21 | G3new | 4216h | 1264.8h | AGNSSPTP-MStest |  | Rel-9 |  | Ingbert | Thales | Michel.monnerat@thalesaleniaspace.com | GP-092344 |
| 394 | 159 | **Voice services over Adaptive Multi-user channels on One Slot** | 392d? | 2008-11-21 A | 2010-05-21 | 73% | 104.46d? | 2008-11-21 | 2010-05-21 | 392d? | 345d |  | GP | 12520.7h | 9182.19h | VAMOS | PCG-22 | Rel-9 | SP-42 | Paolo | Nokia Siemens Networks, China Mobile | juergen.hofmann@nsn.com, liuxiaoyu@chinamobile.com | GP-092470 |
| 395 | 159.1 | VAMOS Stage 2 | 392d? | 2008-11-21 A | 2010-05-21 | 95% | 19.6d? | 2008-11-21 | 2010-05-21 | 392d? | 345d | finish no earlier than 2010-05-21 | GP | 3128.68h | 2971.88h | VAMOS | PCG-22 | Rel-9 | GP-40 | Paolo | Nokia Siemens Networks, China Mobile | juergen.hofmann@nsn.com, liuxiaoyu@chinamobile.com | GP-092470 |
| 396 | 159.2 | VAMOS Stage 3 | 391d? | 2008-11-21 A | 2010-05-21 | 70% | 117.3d? | 2008-11-21 | 2010-05-21 | 391d? | 345d | finish no earlier than 2010-05-21 | GP | 3128h | 2189.6h | VAMOS | PCG-22 | Rel-9 | GP-40 | Paolo | Nokia Siemens Networks, China Mobile | juergen.hofmann@nsn.com, liuxiaoyu@chinamobile.com | GP-092470 |
| 397 | 159.3 | VAMOS Radio Performance Requirements | 391d? | 2008-11-24 A | 2010-05-21 | 55% | 175.95d? | 2008-11-24 | 2010-05-21 | 391d? | 345d | finish no earlier than 2010-05-21 | GP | 3128h | 1720.4h | VAMOS | PCG-22 | Rel-9 | GP-40 | Paolo | Nokia Siemens Networks, China Mobile | juergen.hofmann@nsn.com, liuxiaoyu@chinamobile.com | GP-092470 |
| 398 | 160 | **Local Call Local Switch** | 412d? | 2009-02-20 A | 2010-09-17 | 33% | 274.96d? | 2009-02-20 | 2010-09-17 | 412d? | 260d |  | GP,C4,C3,C1 | 16848h | 4693.91h | LCLS | PCG-22 | Rel-9 | GP-41 | Paolo | Huawei | Xing Zhu |  |
| 399 | 160.1 | Local Call Local Switch | 326d? | 2009-02-20 A | 2010-05-21 | 75% | 81.5d? | 2009-02-20 | 2010-05-21 | 326d? | 345d | finish no earlier than 2010-05-21 | GP | 2608h | 1956h | LCLS | PCG-22 | Rel-9 | GP-41 | Paolo | Huawei | Xing Zhu | GP-092473 |
| 400 | 160.2 | **CN aspects of Local Call Local Switch** | 342d? | 2009-05-29 A | 2010-09-17 | 20% | 273.6d? | 2009-05-29 | 2010-09-17 | 342d? | 260d |  | C4 | 10944h | 1641.6h | LCLS-CN | PCG-23 | Rel-10 | CP-44 | Kimmo | Vodafone | David Hutton |  |
| 401 | 160.2.1 | CT4 aspects of LCLS | 342d? | 2009-05-29 A | 2010-09-17 | 60% | 136.8d? | 2009-05-29 | 2010-09-17 | 342d? | 260d | finish no earlier than 2010-09-17 | C4 | 2736h | 1641.6h | LCLS-CN | PCG-23 | Rel-10 | CP-44 | Kimmo | Vodafone | David Hutton |  |
| 402 | 160.2.2 | CT3 aspects of LCLS | 342d? | 2009-05-29 | 2010-09-17 |  |  | 2009-05-29 | 2010-09-17 | 342d? | 260d | finish no earlier than 2010-09-17 | C3 | 2736h |  | LCLS-CN | PCG-23 | Rel-10 | CP-44 | Gwiho | Vodafone | David Hutton |  |
| 403 | 160.2.3 | CT1 aspects of LCLS | 342d? | 2009-05-29 | 2010-09-17 |  |  | 2009-05-29 | 2010-09-17 | 342d? | 260d | finish no earlier than 2010-09-17 | C1 | 2736h |  | LCLS-CN | PCG-23 | Rel-10 | CP-44 | Frederic | Vodafone | David Hutton |  |

Notes:
- 377: RP#47 completed
- 378: RP#47 completed / Text3: 25.101, 25.104, 25.133, 25.211, 25.212, 25.213, 25.214, 25.215, 25.319, 25.306, 25.321, 25.331, 25.423, 25.433
- 379: RP#46 completed / Text3: 25.101, 25.104, 25.133, 25.306, 25.308, 25.331, 25.423, 25.433, new 25.317 (Requirements on Ues supporting a release-independent frequency band combination)
- 380: RP#46 completed / Text3: 25.101, 25.104, 25.133, 25.211, 25.212, 25.213, 25.214, 25.215, 25.308, 25.321, 25.331, 26.306, 25.423, 25.433
- 381: RP#46 completed / Text3: 25.101, 25.104, 25.211, 25.212, 25.213, 25.214, 25.215, 25.308, 25.306, 25.321, 25.331, 25.423, 25.433
- 382: RP#46 completed / Text3: 25.102, 25.105, 25.123, 25.225, 25.423, 25.433
- 383: -
- 384: RP#46 completed. WID updated RP-090096=>RP-091155 / Text3: 36.104, 36.141, new 36.931
- 385: RP#47 further exception to 06/10 in RP-091147 / Text3: 36.101, 36.211, 36.212, 36.213, 36.331
- 386: SP#46 completed. Triggered by RAN2 UID_440013 Vocoder rate adaptation for LTE
- 387: SP#45 completed (CR adding support for Explicit Congestion Notification) / Text3: 23.401 CR#1103r3
- 388: SP#46 completed / Text3: 26.114
- 389: RP#45 completed / Text3: 36.300 CR#0114
- 390: RP#47 completed / Text3: 25.413, 36.300, 36.413, 36.423, 36.902, 48.018
- 391: GP#44 exception to 05/10 in GP-092344. Linked to Rel-10 RAN4 UID_450027 (A-GNSS Minimum Performance for UTRAN)
- 392: GP#45 completed (open performance requirements alignment GPS/Galileo) / Text3: 45.005
- 393: GP#44 exception to 05/10 in GP-092344 / Text3: 51.010-1, new 51.010-7
- 394: GP#44 exception to 05/10 in GP-092470. GP#40 WID approved. Triggered by UID_50590 (MUROS) Study on Multi-User Reusing-One-Slot
- 395: GP#44 exception to 05/10 in GP-092470 / Text3: 45.001 (Overview of VAMOS solution)
- 396: GP#44 exception to 05/10 in GP-092470 / Text3: 24.008, 44.018, 45.002, 45.003, 45.004, 45.008, 48.008, 48.058
- 397: GP#44 exception to 05/10 in GP-092470 / Text3: 45.005 (Test Scenarios for VAMOS Performance requirements)
- 398: GP#44 exception to 05/10 in GP-092473. GP#41 WID approved. CP#46 WID (CP-090519) revised to Study item (CP-090812).
- 399: GP#44 exception to 05/10 in GP-092473. GP#41 WID approved / Text3: 48.008 (MSC-BSS interface; Layer 3 specification)
- 400: CP#46 WID (CP-090519) revised to Study item (CP-090812). Normative work can be done in Rel-9 but then a complete set of CRs and WID must be provided for approval at CP#47 03/10.
- 401: CP#47 completion 03/10=>09/10. Normative work target: 23.205, 23.153, 23.231, 29.232 / Text3: new 23.889
- 402: Normative work target: 29.007
- 403: Normative work target: 23.009

| ID | WBS | Task | Type | Duration | Start | Finish | Complete | Remaining | Baseline start | Baseline finish | Baseline duration | Total slack | Constraint | Resources | Work | Actual work | Text1 | Text2 | Text4 | Text5 | Text6 | Text7 | Text8 | Text11 | Text9 | Text12 |
| --- | --- | --- | --- | --- | --- | --- | --- | --- | --- | --- | --- | --- | --- | --- | --- | --- | --- | --- | --- | --- | --- | --- | --- | --- | --- | --- |
| 404 | 161 | **Cell Broadcast protocol Base Station Controller – Cell Broadcast Centre (BSC-CBC)** |  | 222d? | 2009-05-15 A | 2010-03-19 A | 100% |  | 2009-05-15 | 2010-03-19 | 222d? |  |  | GP,C1 | 5248h | 5248h | CEBRO | PCG-23 | Ericsson | Claes-Göran Persson | Rel-9 | GP-42 | Paolo |  |  |  |
| 405 | 161.1 | Cell Broadcast protocol Base Station Controller – Cell Broadcast Centre (BSC-CBC) |  | 212d? | 2009-05-15 A | 2010-03-05 A | 100% |  | 2009-05-15 | 2010-03-05 | 212d? |  | finish no earlier than 2010-03-05 | GP | 1696h | 1696h | CEBRO | PCG-23 | Ericsson | Claes-Göran Persson | Rel-9 | GP-42 | Paolo |  |  |  |
| 406 | 161.2 | Cell Broadcast protocol Base Station Controller – Cell Broadcast Centre (BSC-CBC) |  | 222d? | 2009-05-15 A | 2010-03-19 A | 100% |  | 2009-05-15 | 2010-03-19 | 222d? |  | finish no earlier than 2010-03-19 | C1 | 1776h | 1776h | CEBRO | PCG-23 | Ericsson | Claes-Göran Persson | Rel-9 | GP-42 | Frederic | CP-090867 |  |  |
| 407 | 162 | Hybrid Location |  | 136d? | 2009-05-18 A | 2009-11-20 A | 100% |  | 2009-05-18 | 2009-11-20 | 136d? |  | finish no earlier than 2009-11-20 | GP | 1088h | 1088h | HILT | PCG-23 | TruePosition | Matt Ward (mward@trueposition.com) | Rel-9 | GP-42 | Paolo |  |  |  |
| 408 | 163 | (Small) Technical Enhancements and Improvements for Rel-9 |  | 325d? | 2008-09-15 A | 2009-12-10 A | 100% |  | 2008-09-15 | 2009-12-10 | 325d? |  | finish no earlier than 2009-12-10 | All | 2600h | 2600h | TEI9 | PCG-22 |  |  | Rel-9 | SP-42 |  |  |  |  |
| 409 | 164 | Test - (Small) Technical Enhancements and Improvements for Rel-9 |  | 286d? | 2009-11-20 A | 2010-12-24 | 20% | 228.8d? | 2009-11-20 | 2010-12-24 | 286d? | 190d | finish no earlier than 2010-12-24 | R5,G3new | 2288h | 457.6h | TEI9_Test | PCG-24 |  |  | Rel-9 | GP-44 | Ingbert |  |  |  |
| 410 | 165 | **Deleted - SAES Enhancements (non RAN aspects)** |  | 381d? | 2007-06-25 A | 2008-12-08 A | 100% |  | 2007-06-25 | 2008-12-08 | 381d? |  |  | S2 | 11664h | 11664h | SAES_Ph2 | PCG-21 | Nokia Siemens Networks |  | Rel-9 | SP-39 | Maurice |  | PCG-21 | SP-39 |
| 411 | 165.1 | Deleted - Functions and procedures for SAE to support LTE MBMS |  | 381d? | 2007-06-25 A | 2008-12-08 A | 100% |  | 2007-06-25 | 2008-12-08 | 381d? |  | finish no earlier than 2008-12-08 | S2 | 3048h | 3048h | SAES_Ph2 |  |  |  | Rel-9 | SP-35 | Maurice |  | PCG-21 | SP-39 |
| 412 | 165.2 | Deleted - CS over EPS |  | 194d? | 2008-03-12 A | 2008-12-08 A | 100% |  | 2008-03-12 | 2008-12-08 | 194d? |  | finish no earlier than 2008-12-08 | S2 | 1552h | 1552h | SAES_Ph2 | PCG-21 |  |  | Rel-9 | SP-39 | Maurice |  | PCG-21 | SP-39 |
| 413 | 165.3 | **Deleted - SAE for generic support for non-3GPP accesses** |  | 251d? | 2007-06-25 A | 2008-06-09 A | 100% |  | 2007-06-25 | 2008-06-09 | 251d? |  |  | S2 | 4016h | 4016h | SAES_Ph2 | PCG-21 |  |  | Rel-9 | SP-39 | Maurice |  | PCG-21 | SP-39 |
| 414 | 165.3.1 | Deleted - Single Radio Aspects of SAE for Optimized Handover with WiMAX |  | 251d? | 2007-06-25 A | 2008-06-09 A | 100% |  | 2007-06-25 | 2008-06-09 | 251d? |  | finish no earlier than 2008-06-09 | S2 | 2008h | 2008h | SAES_Ph2 | PCG-21 |  |  | Rel-9 | SP-39 | Maurice |  | PCG-21 | SP-39 |
| 415 | 166 | Deleted - Harmonization of Gq'/Rx for Common IMS |  | 304d? | 2008-01-14 A | 2009-03-12 A | 100% |  | 2008-01-14 | 2009-03-12 | 304d? |  | finish no earlier than 2009-03-12 | S2 | 2432h | 2432h | IMS_Comm_GqRx_Harm | PCG-21 | Alcatel-Lucent | geoffrey.cristallo@alcatel-lucent.be | Rel-9 | SP-38 | Maurice |  | PCG-22 | SP-43 |
| 416 | 167 | Deleted - Support of WiMAX - LTE Mobility |  | 407d? | 2008-06-06 A | 2009-12-25 A | 100% |  | 2008-06-06 | 2009-12-25 | 407d? |  | start no earlier than 2008-06-06 | R2 | 3248h | 3248h | WiMAX_LTE_Mobility | PCG-21 | Samsung |  | Rel-9 | RP-38 | Joern |  | PCG-21 | SP-39 |
| 417 | 168 | Deleted - Support of WiMAX - UMTS Mobility |  | 407d? | 2008-06-06 A | 2009-12-25 A | 100% |  | 2008-06-06 | 2009-12-25 | 407d? |  | start no earlier than 2008-06-06 | R2 | 3248h | 3248h | WiMAX_UMTS_Mobility | PCG-21 | Intel |  | Rel-9 | RP-38 | Joern |  | PCG-21 | SP-39 |
| 418 | 169 | Release 9 Studies | milestone | 0d? | 2000-01-01 | 2000-01-01 |  |  | 2000-01-01 | 2000-01-01 | 0d? | 3057d |  | CP,RP,SP |  |  |  |  |  |  | Rel-9 |  |  |  |  |  |
| 419 | 170 | Study on Service Specific Access Control in EPS |  | 136d? | 2008-06-05 A | 2008-12-11 A | 100% |  | 2008-06-05 | 2008-12-11 | 136d? |  | start no earlier than 2008-06-05 | S1 | 1088h | 1088h | FS_SSAC | PCG-21 | NTT DoCoMo | Frederic Thepot (thepot@docomolab-euro.com) | Rel-9 | SP-40 | Alain |  |  |  |
| 420 | 171 | Study on CS Domain Services over EPS access |  | 492d? | 2007-04-25 A | 2009-03-12 A | 100% |  | 2007-04-25 | 2009-03-12 | 492d? |  | finish no earlier than 2009-03-12 | S2 | 3936h | 3936h | FS_CSoPS |  | T-Mobile | Karl-Heinz.Nenner@T-Mobile.net | Rel-9 | SP-35 | Maurice |  |  |  |
| 421 | 172 | Study on Extended Support of IMS Emergency Calls |  | 319d? | 2007-09-24 A | 2008-12-11 A | 100% |  | 2007-09-24 | 2008-12-11 | 319d? |  | finish no earlier than 2009-06-18 | S2 | 2552h | 2552h | FS_IMS-eCall |  | Qualcomm | Stephen Edge | Rel-9 | SP-37 | Maurice |  |  |  |
| 422 | 173 | Study on Service Continuity for Emergency Voice Calls |  | 721d? | 2006-06-08 A | 2009-03-12 A | 100% |  | 2006-06-08 | 2009-03-12 | 721d? |  | finish no earlier than 2009-03-12 | S2 | 5768h | 5768h | FS_VCCEm |  | Nortel | Ricky Kaura (rkaura@nortel.com) | Rel-9 | SP-32 | Maurice |  |  |  |
| 423 | 174 | Study on Security Aspects of Remote Provisioning and Change of Subscription for M2M Equipment |  | 582d? | 2004-04-06 A | 2009-12-10 A | 100% |  | 2004-04-06 | 2009-12-10 | 582d? |  | finish no earlier than 2009-12-10 | S3,C6 | 4656h | 4656h | FS_UM2M |  | Ericsson | vesa.lehtovirta@ericsson.com | Rel-9 | SP-37 | Dionisio |  |  |  |
| 424 | 175 | Study on System Maintenance over Itf-N |  | 602d? | 2007-06-07 A | 2009-09-24 A | 100% |  | 2007-06-07 | 2009-09-24 | 602d? |  | finish no earlier than 2009-09-24 | S5 | 4808h | 4808h | FS_OAM-Maint-Itf-N |  | ZTE | HUANG, Shuqiang | Rel-9 | SP-36 | Dionisio |  |  |  |
| 425 | 176 | Study on Self-Organizing Networks (SON) related OAM interfaces for Home NodeB |  | 522d? | 2007-06-07 A | 2009-06-04 A | 100% |  | 2007-06-07 | 2009-06-04 | 522d? |  | finish no earlier than 2009-12-10 | S5 | 4168h | 4168h | FS_OAM-SON-HNB |  | Huawei | Zou Lan (zlan@huawei.com) | Rel-9 | SP-36 | Dionisio |  |  |  |
| 426 | 177 | Study on Self-healing of Self-Organizing Networks (SON) |  | 416d? | 2008-02-22 A | 2009-09-24 A | 100% |  | 2008-02-22 | 2009-09-24 | 416d? |  | finish no earlier than 2009-09-24 | S5 | 3320.15h | 3320.15h | FS_OAM-SON-SH | PCG-21 | ZTE | zhu.weihong@zte.com.cn | Rel-9 | SP-39 | Dionisio |  |  |  |
| 427 | 178 | Study on Service Oriented Architecture (SOA) for IRP |  | 262d? | 2008-06-05 A | 2009-06-04 A | 100% |  | 2008-06-05 | 2009-06-04 | 262d? |  | finish no earlier than 2009-05-20 | S5 | 2088h | 2088h | FS_OAM_SOA_IRP | PCG-21 | Ericsson | edwin.tse@ericsson.com | Rel-9 | SP-40 | Dionisio |  |  |  |
| 428 | 179 | Study on Evaluation of the inclusion of Path Loss Based Technology in the UTRAN |  | 516d? | 2007-12-17 A | 2009-12-04 A | 100% |  | 2007-12-17 | 2009-12-04 | 516d? |  | finish no earlier than 2009-09-18 | R4 | 4120h | 4120h | FS_RAN-Pathloss | PCG-21 | Polaris Wireless | Norman Shaw (nshaw@polariswireless.com) | Rel-9 | RP-38 | Issam | RP-091080 |  |  |
| 429 | 180 | Study on LTE-Advanced |  | 461d? | 2007-03-23 A | 2010-03-19 A | 100% |  | 2007-03-23 | 2010-03-19 | 461d? |  | finish no earlier than 2010-03-19 | R1,R2,R3,R4 | 3688h | 3688h | FS_RAN_LTEA | PCG-21 | NTT DoCoMo | Tetsushi Abe | Rel-9 | RP-39 | Patrick | RP-100080 |  |  |
| 430 | 181 | Study on 1.28 Mcps TDD Home NodeB |  | 387d? | 2008-02-20 A | 2009-12-04 A | 100% |  | 2008-02-20 | 2009-12-04 | 387d? |  | finish no earlier than 2009-12-04 | R4 | 3096h | 3096h | FS_RAN-HNBLCRTDD | PCG-21 | TD Tech | Li Rong (lirong@td-tech.com) | Rel-9 | RP-41 | Issam | RP-091081 |  |  |
| 431 | 182 | Study on E-UTRAN Mobility Evaluation and Enhancement |  | 126d? | 2008-12-05 A | 2009-05-29 A | 100% |  | 2008-12-05 | 2009-05-29 | 126d? |  | finish no earlier than 2009-05-29 | R1 | 1008h | 1008h | FS_EUTRAN_mob | PCG-22 | Qualcomm | Rajat Prakash (rprakash@qualcomm.com) | Rel-9 | RP-42 | Patrick | RP-090426 |  |  |
| 432 | 183 | Study on Minimization of drive-tests in Next Generation Networks |  | 196d? | 2009-03-06 A | 2009-12-04 A | 100% |  | 2009-03-06 | 2009-12-04 | 196d? |  | finish no earlier than 2009-12-04 | R2 | 1568h | 1568h | FS_NGN_min_drive-tests | PCG-22 | Qualcomm | Masato Kitazoe (mkitazoe@qualcomm.com) | Rel-9 | RP-43 | Joern | RP-091084 |  |  |
| 433 | 184 | Study on Enhanced Interference Management for HNBs |  | 61d? | 2009-03-06 A | 2009-05-29 A | 100% |  | 2009-03-06 | 2009-05-29 | 61d? |  | start no earlier than 2009-03-06 | R4 | 488h | 488h | FS_eInterfMgmt_HNB | PCG-22 | Qualcomm | Farhad Meshkati (fmeshkat@qualcomm.com) | Rel-9 | RP-43 | Issam | RP-090429 |  |  |
| 434 | 185 | Study on Enhanced Interference Management Mechanisms for HNBs |  | 81d? | 2009-05-30 A | 2009-09-18 A | 100% |  | 2009-05-30 | 2009-09-18 | 81d? |  | finish no earlier than 2009-09-18 | R3 | 648h | 648h | FS_eInterfMgmtMchsm_HNB | PCG-23 | Qualcomm | Farhad Meshkati (fmeshkat@qualcomm.com) | Rel-9 | RP-44 | Juha | RP-090733 |  |  |
| 435 | 186 | Deleted - Study on Protection against SMS and MMS spam |  | 862d? | 2006-06-08 A | 2009-09-24 A | 100% |  | 2006-06-08 | 2009-09-24 | 862d? |  | finish no earlier than 2009-09-24 | S3 | 6896h | 6896h | FS_CPSMal |  | Orange | eric.gauthier@orange.ch | Rel-9 | SP-32 | Dionisio |  | PCG-23 | SP-45 |
| 436 | 187 | Release 8 Features | milestone | 0d? | 2000-01-03 | 2000-01-03 |  |  | 2000-01-03 | 2000-01-03 | 0d? | 3056d | start no earlier than 2000-01-03 | CP,GP,RP,SP |  |  |  |  |  |  | Rel-8 |  |  |  |  |  |

Notes:
- 404: CP#47 completed. GP#45 completed. GP#42 WID approved
- 405: GP#45 completed. GP#42 WID approved / Text3: new 48.049
- 406: CP#47 completed / Text3: 23.041
- 407: GP#44 completed. GP#42 WID approved (Hybrid Integrated Location Technology=HILT) / Text3: 43.059, 48.071
- 408: SP#46 completed
- 409: GP#44 created
- 410: SP#39 created to host Rel-9 Wis. BUT no agreed WID
- 411: SP#39 SAE functionality moved to Rel-9. WID returned to SA2 for re-consideration & remove MBMS for EPS from Rel 8
- 412: SP#39 SAE functionality moved to Rel-9. BUT no agreed WID
- 413: SP#39 SAE functionality moved to Rel-9. BUT no agreed WID
- 414: SP#39 SAE functionality moved to Rel-9. BUT no agreed WID
- 415: SP#43 stopped. LS_out to TISPAN informs about stopping this activity / Text3: 23.822, 23.203
- 416: RP#39: No agreed WID / Text3: 36.306, 36.331, 36.413, 36.300, 36.214, 36.133, 36.304
- 417: RP#39: No agreed WID / Text3: 25.306, 25.331, 25.413
- 418: -
- 419: SP#42 completed. Spin-off Feature UID_420020 (SSAC) / Text3: 22.986
- 420: SP#43 completed / Text3: 23.879
- 421: SP#42 completed / Text3: 23.868
- 422: SP#43 completed / Text3: 23.826
- 423: SP#46 completed. Triggered by SA1 Study UID_7027 (FS_M2M) TR 22.868 / Text3: 33.812
- 424: SP#45 completed / Text3: 32.822
- 425: SP#44 completed / Text3: 32.821
- 426: SP#45 completed / Text3: 32.823
- 427: SP#44 completed. Spin-off implementation WI UID_440064 Service Oriented Architecture (SOA) for IRP / Text3: 32.824
- 428: RP#46 completed / Text3: 25.907
- 429: RP#47 completed / Text3: 36.913 , new 36.814, 36.912, R2 36.806 (Relay architectures for E-UTRA), R4 36.815 (LTE-Advanced feasibility studies in RAN4)
- 430: RP#46 completed / Text3: 25.866
- 431: RP#44 completed (RP-090452 R1 LS to RAN on Conclusions for LTE Mobility Study Item - no further Rel-9 action/TR needed
- 432: RP#46 completed / Text3: 36.805
- 433: RP#44 completed. Spin-off RAN3 UID_440015 Study on Enhanced Interference Management Mechanisms for HNBs / Text3: 25.967
- 434: Triggered by RAN4 UID_430027 Study on Enhanced Interference Management for HNBs. RP#45 completed / Text3: 25.967
- 435: SP#45 work stopped/abandoned / Text3: 33.9xx
- 436: -

| ID | WBS | Task | Duration | Start | Finish | Complete | Remaining | Baseline start | Baseline finish | Baseline duration | Total slack | Constraint | Resources | Work | Actual work | Text1 | Text4 | Text5 | Text6 | Text8 | Text7 | Text2 |
| --- | --- | --- | --- | --- | --- | --- | --- | --- | --- | --- | --- | --- | --- | --- | --- | --- | --- | --- | --- | --- | --- | --- |
| 437 | 188 | **3GPP System Architecture Evolution Specification - Evolved Packet System (non RAN aspects)** | 1084d? | 2006-04-12 A | 2010-06-04 | 99% | 1.59d? | 2006-04-12 | 2010-06-04 | 1084d? | 335d |  | SP,CP | 261420h | 260414h | SAES | T-Mobile | michael.kurz@t-mobile.at | Rel-8 | Alain |  |  |
| 438 | 188.1 | Requirements for evolution of the 3GPP system architecture | 395d? | 2006-06-08 A | 2007-12-12 A | 100% |  | 2006-06-08 | 2007-12-12 | 395d? |  | finish no earlier than 2007-11-30 | S1 | 3160h | 3160h | AIPN-SAE | T-Mobile | michael.kurz@t-mobile.at | Rel-8 | Alain |  |  |
| 439 | 188.2 | **High level and common (for all accesses) functions** | 629d? | 2007-01-02 A | 2009-05-29 A | 100% |  | 2007-01-02 | 2009-05-29 | 629d? |  |  | SP,CP | 42536h | 42536h | EPS-ComF | Nokia Siemens Networks | balazs.bertenyi@nsn.com | Rel-8 | Maurice | SP-37 |  |
| 440 | 188.2.1 | Stage 2 for High level functions | 370d? | 2007-01-02 A | 2008-06-02 A | 100% |  | 2007-01-02 | 2008-06-02 | 370d? |  | finish no earlier than 2008-06-02 | S2 | 2960h | 2960h | SAES-SA-HLF | Motorola | Irfan.Ali@motorola.com | Rel-8 | Maurice |  |  |
| 441 | 188.2.2 | Stage 2 Security Architecture | 197d? | 2008-03-12 A | 2008-12-11 A | 100% |  | 2008-03-12 | 2008-12-11 | 197d? |  | finish no earlier than 2008-12-11 | S3 | 1576h | 1576h | SAES | Nokia Siemens Networks | marc.blommaert.ext@nsn.com | Rel-8 | Dionisio | SP-39 | PCG-21 |
| 442 | 188.2.3 | Stage 3 (CT1) for SAE impact on services, network functions and capabilities | 545d? | 2007-02-05 A | 2009-03-06 A | 100% |  | 2007-02-05 | 2009-03-06 | 545d? |  | finish no earlier than 2009-03-06 | C1 | 4360h | 4360h | SAES | Nokia Siemens Networks | robert.zaus@nsn.com | Rel-8 | Frederic |  |  |
| 443 | 188.2.4 | Stage 3 SAE impact on existing capabilities | 480d? | 2007-02-05 A | 2008-12-05 A | 100% |  | 2007-02-05 | 2008-12-05 | 480d? |  | finish no earlier than 2008-12-12 | C3 | 3840h | 3840h | SAES | Huawei | Wei Weihua (weiwh@huawei.com) | Rel-8 | Gwiho |  |  |
| 444 | 188.2.5 | Stage 3 (CT4) of SAE impact on existing capabilities | 545d? | 2007-02-05 A | 2009-03-06 A | 100% |  | 2007-02-05 | 2009-03-06 | 545d? |  | finish no earlier than 2009-03-06 | C4 | 4360h | 4360h | SAES | Huawei | shahab.lavasani@huawei.com | Rel-8 | Kimmo |  |  |
| 445 | 188.2.6 | Stage 2/3 for Network selection procedures | 480d? | 2007-02-05 A | 2008-12-05 A | 100% |  | 2007-02-05 | 2008-12-05 | 480d? |  | finish no earlier than 2009-03-06 | C1 | 3840h | 3840h | SAES | Nokia Siemens Networks | robert.zaus@nsn.com | Rel-8 | Frederic |  |  |
| 446 | 188.2.7 | Stage 3 EPC interworking with external PDNs (SGi) | 605d? | 2007-02-05 A | 2009-05-29 A | 100% |  | 2007-02-05 | 2009-05-29 | 605d? |  | finish no earlier than 2009-05-29 | C3 | 4840h | 4840h | SAES-St3-intwk | Huawei | Wei Weihua (weiwh@huawei.com) | Rel-8 | Gwiho |  |  |
| 447 | 188.2.8 | Stage 3 PCC within SAE | 605d? | 2007-02-05 A | 2009-05-29 A | 100% |  | 2007-02-05 | 2009-05-29 | 605d? |  | finish no earlier than 2009-05-29 | C3 | 4840h | 4840h | SAES-St3-PCC | Ericsson | j.javier.pastor@ericsson.com | Rel-8 | Gwiho |  |  |
| 448 | 188.2.9 | Stage 3 for SAE / LTE identities | 545d? | 2007-02-05 A | 2009-03-06 A | 100% |  | 2007-02-05 | 2009-03-06 | 545d? |  | finish no earlier than 2009-03-06 | C4 | 4360h | 4360h | SAES | Huawei | shahab.lavasani@huawei.com | Rel-8 | Kimmo |  |  |
| 449 | 188.2.10 | Unified guidelines for Diameter usage within 3GPP | 316d? | 2007-09-21 A | 2008-12-05 A | 100% |  | 2007-09-21 | 2008-12-05 | 316d? |  | finish no earlier than 2008-12-05 | C3 | 2528h | 2528h | SAES-DIAM | Huawei | Javier Gonzalez Gallego | Rel-8 | Gwiho | CP-37 |  |
| 450 | 188.3 | **SAE for LTE access** | 569d? | 2007-01-02 A | 2009-03-06 A | 100% |  | 2007-01-02 | 2009-03-06 | 569d? |  |  | S2,C1,C3,C4 | 57824h | 57824h | SAES-LTE | Motorola | Irfan.Ali@motorola.com | Rel-8 | Maurice |  |  |
| 451 | 188.3.1 | CT4 Stage 3 for protocol between EPCs | 545d? | 2007-02-05 A | 2009-03-06 A | 100% |  | 2007-02-05 | 2009-03-06 | 545d? |  | finish no earlier than 2009-03-06 | C4 | 4360h | 4360h | SAES | Huawei | shahab.lavasani@huawei.com | Rel-8 | Kimmo |  |  |
| 452 | 7.2.2.1 | **SAES-SA-FP_LTE with GTP variant** | 569d? | 2007-01-02 A | 2009-03-06 A | 100% |  | 2007-01-02 | 2009-03-06 | 569d? |  |  | S2,C4 | 11896h | 11896h | SAES-SA-FP_LTE-GTP | Nokia Siemens Networks | balazs.bertenyi@nsn.com | Rel-8 | Maurice |  |  |
| 453 | 188.3.2.1 | Stage 2 for SAES-SA-FP_LTE with GTP variant | 373d? | 2007-01-02 A | 2008-06-05 A | 100% |  | 2007-01-02 | 2008-06-05 | 373d? |  | finish no earlier than 2008-06-02 | S2 | 2984h | 2984h | SAES-SA-FP_LTE-GTP-St2 | Nokia Siemens Networks | balazs.bertenyi@nsn.com | Rel-8 | Maurice |  |  |
| 454 | 188.3.2.2 | CT4 Stage 3 for GTP v2 protocol | 545d? | 2007-02-05 A | 2009-03-06 A | 100% |  | 2007-02-05 | 2009-03-06 | 545d? |  | finish no earlier than 2009-03-06 | C4 | 4360h | 4360h | SAES | Huawei | shahab.lavasani@huawei.com | Rel-8 | Kimmo |  |  |
| 455 | 7.2.2.2 | **SAES-SA-FP_LTE with PMIP variant** | 569d? | 2007-01-02 A | 2009-03-06 A | 100% |  | 2007-01-02 | 2009-03-06 | 569d? |  |  | S2,C4 | 15736h | 15736h | SAES-SA-FP_LTE-IETF | Nokia Siemens Networks | balazs.bertenyi@nsn.com | Rel-8 | Maurice |  |  |
| 456 | 188.3.3.1 | Stage 2 for SAES-SA-FP_LTE with PMIP variant | 373d? | 2007-01-02 A | 2008-06-05 A | 100% |  | 2007-01-02 | 2008-06-05 | 373d? |  | finish no earlier than 2008-06-02 | S2 | 2984h | 2984h | SAES-SA-FP_LTE-IETF-St2 | Nokia Siemens Networks | balazs.bertenyi@nsn.com | Rel-8 | Maurice |  |  |
| 457 | 188.3.3.2 | CT4 Stage 3 for PMIP protocol within EPC | 545d? | 2007-02-05 A | 2009-03-06 A | 100% |  | 2007-02-05 | 2009-03-06 | 545d? |  | finish no earlier than 2009-03-06 | C4 | 4360h | 4360h | SAES | Huawei | shahab.lavasani@huawei.com | Rel-8 | Kimmo | CP-37 |  |
| 458 | 188.3.3.3 | Mobile IPv4 (MIPv4) based Mobility protocols | 480d? | 2007-02-05 A | 2008-12-05 A | 100% |  | 2007-02-05 | 2008-12-05 | 480d? |  | finish no earlier than 2008-12-05 | C4 | 3840h | 3840h | SAES | Motorola | Lewis Milton | Rel-8 | Kimmo | CP-41 |  |
| 459 | 188.3.4 | Stage 3 for UE NAS mobility procedures in idle and active mode | 545d? | 2007-02-05 A | 2009-03-06 A | 100% |  | 2007-02-05 | 2009-03-06 | 545d? |  | finish no earlier than 2009-03-06 | C1 | 4360h | 4360h | SAES | Nokia Siemens Networks | robert.zaus@nsn.com | Rel-8 | Frederic |  |  |
| 460 | 188.3.5 | Stage 3 for Session management, bearer control and QoS aspects | 545d? | 2007-02-05 A | 2009-03-06 A | 100% |  | 2007-02-05 | 2009-03-06 | 545d? |  | finish no earlier than 2009-03-06 | C1 | 4360h | 4360h | SAES | Nokia Siemens Networks | robert.zaus@nsn.com | Rel-8 | Frederic |  |  |
| 461 | 188.3.6 | Stage 3 for security aspects of LTE Access | 545d? | 2007-02-05 A | 2009-03-06 A | 100% |  | 2007-02-05 | 2009-03-06 | 545d? |  | finish no earlier than 2009-03-06 | C1 | 4360h | 4360h | SAES | Nokia Siemens Networks | robert.zaus@nsn.com | Rel-8 | Frederic |  |  |
| 462 | 188.3.7 | Stage 3 for QoS mechanisms | 480d? | 2007-02-05 A | 2008-12-05 A | 100% |  | 2007-02-05 | 2008-12-05 | 480d? |  | finish no earlier than 2008-12-12 | C3 | 3840h | 3840h | SAES | Ericsson | j.javier.pastor@ericsson.com | Rel-8 | Gwiho |  |  |
| 463 | 188.3.8 | Stage 3 for EPC - HSS interface | 545d? | 2007-02-05 A | 2009-03-06 A | 100% |  | 2007-02-05 | 2009-03-06 | 545d? |  | finish no earlier than 2009-03-06 | C4 | 4360h | 4360h | SAES | Huawei | shahab.lavasani@huawei.com | Rel-8 | Kimmo |  |  |

Notes:
- 437: SP#39 WID updated SP-070933=>SP-080132. Role model for SAE/LTE system wide project management by SA2 in SP-060166
- 438: SP#38 completed / Text3: 22.278, 22.011, 22.246
- 439: SP#39 WID updated SP-070933=>SP-080132
- 440: SP#40 completed / Text3: 23.402
- 441: SP#42 completed. SP#39 WID updated SP-070933=>SP-080132 / Text3: 33.401, 33.210, 33.310
- 442: CP#43 completed / Text3: 24.229, 24.305, 27.007
- 443: CP#42 completed. WID updated CP-080056=>CP-080772 / Text3: 29.061
- 444: CP#43 completed. WID updated CP-080724=>CP-090247. Network sharing, etc, MBMS removed / Text3: 29.274, 29.275
- 445: CP#42 completed. CP#41 WID updated CP-080075=>CP-080493. / Text3: 23.122, 24.302
- 446: CP#44 completed / Text3: 29.061
- 447: CP#44 completed / Text3: 29.212, 29.213, 29.214, 29.215
- 448: CP#43 completed. WID updated CP-080724=>CP-090247 / Text3: 23.003
- 449: CP#42 completed / Text3: 29.909
- 450: CP#43 completed. SP#39 WID updated SP-070933=>SP-080132
- 451: CP#43 completed. WID updated CP-080724=>CP-090247. PMIP and GTP based S8 interface (EPC-EPC) / Text3: 29.274, 29.275
- 452: CP#43 completed. SP#39 WID updated SP-070933=>SP-080132
- 453: SP#40 completed / Text3: 23.401, 23.060, 23.002, 23.246, 23.203, 23.107, 23.234, 23.271
- 454: CP#43 completed. WID updated CP-080724=>CP-090247 / Text3: 29.274
- 455: CP#43 completed. SP#39 WID updated SP-070933=>SP-080132
- 456: SP#40 completed. Multiple PDN related alignments, 23.060-derived changes.
- 457: CP#43 completed. WID updated CP-080724=>CP-090247. PMIP based S5 interface / Text3: 29.275, 29.282
- 458: CP#42 completed. CP#43 WID updated CP-080724=>CP-090247 / Text3: 29.279
- 459: CP#43 completed / Text3: 24.007, 24.301
- 460: CP#43 completed / Text3: 24.007, 24.301
- 461: CP#43 completed / Text3: 24.008, 24.301
- 462: CP#42 completed. CP#41 updated WID CP-080057=>CP-080576. / Text3: 29.213
- 463: CP#43 completed. WID updated CP-080724=>CP-090247. S6a, S6d, S13, S13' interface / Text3: 29.272

| ID | WBS | Task | Type | Duration | Start | Finish | Complete | Baseline start | Baseline finish | Baseline duration | Constraint | Resources | Work | Actual work | Text1 | Text4 | Text5 | Text6 | Text8 | Text3 | Text7 | Text2 | Text12 |
| --- | --- | --- | --- | --- | --- | --- | --- | --- | --- | --- | --- | --- | --- | --- | --- | --- | --- | --- | --- | --- | --- | --- | --- |
| 464 | 188.4 | **SAE for Interoperation between LTE and legacy cellular PS accesses** |  | 545d? | 2007-02-05 A | 2009-03-06 A | 100% | 2007-02-05 | 2009-03-06 | 545d? |  | S2,C1,C4 | 40152h | 40152h | SAES-SA-FP_3GPP | Motorola | Irfan.Ali@motorola.com | Rel-8 | Maurice |  |  |  |  |
| 465 | 188.4.1 | Stage 2 for Interoperation between LTE and 2G/3G |  | 424d? | 2007-02-05 A | 2008-09-18 A | 100% | 2007-02-05 | 2008-09-18 | 424d? | finish no earlier than 2008-09-11 | S2 | 3392h | 3392h | EPSto2_3G | Motorola | Irfan.Ali@motorola.com | Rel-8 | Maurice | 23.401, 23.402 | SP-37 |  |  |
| 466 | 188.4.2 | Stage 3 for Inter-system mobility between E-UTRAN and 2G/3G |  | 545d? | 2007-02-05 A | 2009-03-06 A | 100% | 2007-02-05 | 2009-03-06 | 545d? | finish no earlier than 2009-03-06 | C1 | 4360h | 4360h | SAES | Nokia Siemens Networks | robert.zaus@nsn.com | Rel-8 | Frederic | 24.008, 24.301 | CP-38 | PCG-21 |  |
| 467 | 188.4.3 | Stage 2 GPRS enhancements for LTE access |  | 272d? | 2007-09-04 A | 2008-09-18 A | 100% | 2007-09-04 | 2008-09-18 | 272d? | start no earlier than 2007-09-04 | S2 | 2176h | 2176h | SAES-GPRS_LTE | Vodafone | chris.pudney@vodafone.com | Rel-8 | Maurice | 23.401 |  |  |  |
| 468 | 188.4.4 | Stage 2 GPRS for EPC (23.060, etc.) |  | 179d? | 2008-01-14 A | 2008-09-18 A | 100% | 2008-01-14 | 2008-09-18 | 179d? | finish no earlier than 2008-09-18 | S2 | 1432h | 1432h | SAES | Nokia Siemens Networks | balazs.bertenyi@nsn.com | Rel-8 | Maurice | 23.060 | SP-39 | PCG-21 |  |
| 469 | 188.4.5 | Stage 3 for EPC - GPRS |  | 545d? | 2007-02-05 A | 2009-03-06 A | 100% | 2007-02-05 | 2009-03-06 | 545d? | finish no earlier than 2009-03-06 | C4 | 4360h | 4360h | SAES | Huawei | shahab.lavasani@huawei.com | Rel-8 | Kimmo | 29.274, 29.275, 29.281 |  |  |  |
| 470 | 188.4.6 | Stage 3 for EPC to UTRAN |  | 545d? | 2007-02-05 A | 2009-03-06 A | 100% | 2007-02-05 | 2009-03-06 | 545d? | finish no earlier than 2009-03-06 | C4 | 4360h | 4360h | SAES | Huawei | shahab.lavasani@huawei.com | Rel-8 | Kimmo | 29.274, 29.275, 29.281 | CP-38 | PCG-21 |  |
| 471 | 188.4.7 | Stage 3 for EPC to 3GPP2 |  | 545d? | 2007-02-05 A | 2009-03-06 A | 100% | 2007-02-05 | 2009-03-06 | 545d? | finish no earlier than 2009-03-06 | C4 | 4360h | 4360h | SAES | Huawei | shahab.lavasani@huawei.com | Rel-8 | Kimmo | 29.277, 29.276 | CP-38 | PCG-21 |  |
| 472 | 188.4.8 | Stage 2 for Interoperation between LTE and CDMA2000 |  | 329d? | 2007-06-18 A | 2008-09-18 A | 100% | 2007-06-18 | 2008-09-18 | 329d? | finish no earlier than 2008-04-25 | S2 | 2632h | 2632h | EPStoC2k | Motorola, Vodafone | Irfan.Ali@motorola.com, chris.pudney@vodafone.com | Rel-8 | Maurice | 23.401, 23.402 | CP-37 |  |  |
| 473 | 188.4.9 | Stage 3 for Inter-system mobility between E-UTRAN and CDMA2000 |  | 545d? | 2007-02-05 A | 2009-03-06 A | 100% | 2007-02-05 | 2009-03-06 | 545d? | finish no earlier than 2009-03-06 | C1 | 4360h | 4360h | SAES | Nokia Siemens Networks | robert.zaus@nsn.com | Rel-8 | Frederic | 24.301, 24.302 |  |  |  |
| 474 | 188.4.10 | Stage 3 for MME - SGSN signalling free protocol |  | 545d? | 2007-02-05 A | 2009-03-06 A | 100% | 2007-02-05 | 2009-03-06 | 545d? | finish no earlier than 2009-03-06 | C4 | 4360h | 4360h | SAES | Huawei | shahab.lavasani@huawei.com | Rel-8 | Kimmo | 29.272, 29.274 |  |  |  |
| 475 | 188.5 | **SAE for support for non-3GPP accesses** |  | 569d? | 2007-01-02 A | 2009-03-06 A | 100% | 2007-01-02 | 2009-03-06 | 569d? |  | S2,S3,C1,C4 | 53872h | 53872h | SAES-SA-FP_n3GPP | Motorola | Irfan.Ali@motorola.com | Rel-8 | Maurice |  |  |  |  |
| 476 | 7.2.4.1 | Stage 2 for Host-based Mobility aspects |  | 373d? | 2007-01-02 A | 2008-06-05 A | 100% | 2007-01-02 | 2008-06-05 | 373d? | finish no earlier than 2008-04-11 | S2 | 2984h | 2984h | SAES-SA-FP_n3GPP-HBMob | Motorola | Irfan.Ali@motorola.com | Rel-8 | Maurice | 23.402 |  |  |  |
| 477 | 7.2.4.2 | Stage 2 for Network-based Mobility aspects |  | 448d? | 2007-01-02 A | 2008-09-18 A | 100% | 2007-01-02 | 2008-09-18 | 448d? | finish no earlier than 2008-09-18 | S2 | 3584h | 3584h | SAES-SA-FP_n3GPP-NBMob | Motorola | Irfan.Ali@motorola.com | Rel-8 | Maurice | 23.402 |  |  |  |
| 478 | 188.5.3 | Stage 3 for Mobility management based on DSMIP v6 |  | 480d? | 2007-02-05 A | 2008-12-05 A | 100% | 2007-02-05 | 2008-12-05 | 480d? | finish no earlier than 2008-12-05 | C1 | 3840h | 3840h | SAES | Nokia Siemens Networks | robert.zaus@nsn.com | Rel-8 | Frederic | 24.303 |  |  |  |
| 479 | 188.5.4 | Stage 3 for Mobility management based on MIP v4 |  | 480d? | 2007-02-05 A | 2008-12-05 A | 100% | 2007-02-05 | 2008-12-05 | 480d? | start no earlier than 2007-02-05 | C1 | 3840h | 3840h | SAES | Nokia Siemens Networks | robert.zaus@nsn.com | Rel-8 | Frederic | 24.304 | CP-39 | PCG-21 |  |
| 480 | 188.5.5 | Stage 3 for Inter-system mobility between E-UTRAN and non 3GPP accesses |  | 545d? | 2007-02-05 A | 2009-03-06 A | 100% | 2007-02-05 | 2009-03-06 | 545d? | finish no earlier than 2009-03-06 | C1 | 4360h | 4360h | SAES | Nokia Siemens Networks | robert.zaus@nsn.com | Rel-8 | Frederic | 24.008, 24.301 | CP-38 | PCG-21 |  |
| 481 | 188.5.6 | Stage 2 for Optimized Dual-Radio Handover with WiMAX |  | 249d? | 2007-06-25 A | 2008-06-05 A | 100% | 2007-06-25 | 2008-06-05 | 249d? | finish no earlier than 2008-06-09 | S2 | 1992h | 1992h | SAES-SA-FP_n3GPP-OptWIMAX | Motorola | Irfan.Ali@motorola.com | Rel-8 | Maurice | 23.402 |  |  |  |
| 482 | 188.5.7 | Stage 2 Security aspects for non-3GPP Access |  | 197d? | 2008-03-12 A | 2008-12-11 A | 100% | 2008-03-12 | 2008-12-11 | 197d? | finish no earlier than 2008-12-11 | S3 | 1576h | 1576h | SAES | Nokia Siemens Networks | marc.blommaert.ext@nsn.com | Rel-8 | Dionisio | 33.402, 33.210, 33.310 | SP-39 | PCG-21 |  |
| 483 | 188.5.8 | Stage 3 security aspects for DSMIP v6 Access |  | 480d? | 2007-02-05 A | 2008-12-05 A | 100% | 2007-02-05 | 2008-12-05 | 480d? | finish no earlier than 2008-12-05 | C1 | 3840h | 3840h | SAES | Nokia Siemens Networks | robert.zaus@nsn.com | Rel-8 | Frederic | 24.303 | CP-37 |  |  |
| 484 | 188.5.9 | Stage 3 security aspects for MIPv4 Access |  | 480d? | 2007-02-05 A | 2008-12-05 A | 100% | 2007-02-05 | 2008-12-05 | 480d? | finish no earlier than 2008-12-05 | C1 | 3840h | 3840h | SAES | Nokia Siemens Networks | robert.zaus@nsn.com | Rel-8 | Frederic | 24.304 | CP-39 | PCG-21 |  |
| 485 | 188.5.10 | Stage 3 for Access to the EPC via non-3GPP access networks |  | 545d? | 2007-02-05 A | 2009-03-06 A | 100% | 2007-02-05 | 2009-03-06 | 545d? | finish no earlier than 2009-03-06 | C1 | 4360h | 4360h | SAES | Nokia Siemens Networks | robert.zaus@nsn.com | Rel-8 | Frederic | 24.302, 24.312 |  |  |  |
| 486 | 188.5.11 | Stage 3 for interfaces within EPC |  | 383d? | 2007-09-19 A | 2009-03-06 A | 100% | 2007-09-19 | 2009-03-06 | 383d? | finish no earlier than 2009-03-06 | C4 | 3064h | 3064h | SAES | Huawei | shahab.lavasani@huawei.com | Rel-8 | Kimmo | 29.274, 29.281 | CP-37 |  |  |
| 487 | 188.5.12 | Stage 3 for Interfaces EPC - non-3GPP IP access |  | 545d? | 2007-02-05 A | 2009-03-06 A | 100% | 2007-02-05 | 2009-03-06 | 545d? | finish no earlier than 2009-03-06 | C4 | 4360h | 4360h | SAES | Huawei | shahab.lavasani@huawei.com | Rel-8 | Kimmo | 29.273, 29.275 |  |  |  |
| 488 | 188.5.13 | Stage 3 for AAA/HSS related |  | 480d? | 2007-02-05 A | 2008-12-05 A | 100% | 2007-02-05 | 2008-12-05 | 480d? | finish no earlier than 2008-12-05 | C4 | 3840h | 3840h | SAES | Huawei | shahab.lavasani@huawei.com | Rel-8 | Kimmo | 29.273 |  |  |  |
| 489 | 188.5.14 | Stage 3 for EPC - AAA interface |  | 480d? | 2007-02-05 A | 2008-12-05 A | 100% | 2007-02-05 | 2008-12-05 | 480d? | finish no earlier than 2008-12-05 | C4 | 3840h | 3840h | SAES | Huawei | shahab.lavasani@huawei.com | Rel-8 | Kimmo | 29.273 |  |  |  |
| 490 | 188.5.15 | Deleted (already covered) SAES-SA-FP_n3GPP Optimized Handover with CDMA | milestone | 0d? | 2007-06-25 A | 2007-06-25 A | 100% | 2007-06-25 | 2007-06-25 | 0d? | finish no earlier than 2007-06-25 | S2 |  |  | SAES-SA-FP_n3GPP-OptCDMA | Nokia Siemens Networks |  | Rel-8 | Maurice |  |  |  | SP-37 |

Notes:
- 464: CP#43 completed. SP#39 WID updated SP-070933=>SP-080132
- 465: SP#41 completed
- 466: CP#43 completed
- 467: SP#41 completed. 25/03/08 claimed as SP#34 stopped. Resurrected. WID updated SP-060926 => SP-080132
- 468: SP#41 completed
- 469: CP#43 completed. WID updated CP-080724=>CP-090247
- 470: CP#43 completed. WID updated CP-080724=>CP-090247
- 471: CP#43 completed. WID updated CP-080724=>CP-090247. S101, S103 Interface MME - HRPD access S102, Interface to CDMA2000 1x RTT
- 472: SP#41 completed (except: Handover of multiple PDNs=>Rel-9)
- 473: CP#43 completed
- 474: CP#43 completed. WID updated CP-080724=>CP-090247
- 475: CP#43 completed. SP#39 retained in Rel-8 (in addition to the essential functionality defined in SP-070699). Replaces UID_340037
- 476: SP#40 completed
- 477: SP#41 completed
- 478: CP#41 WID updated CP-080075=>CP-080493. CP#42 completed
- 479: CP#41 WID updated CP-080075=>CP-080493. CP#42 completed
- 480: CP#43 completed
- 481: SP#40 completed
- 482: SP#42 completed. SP#39 WID updated SP-070933=>SP-080132
- 483: CP#42 completed. post-CP#39: split into DSMIP v6 and MIPv4 Access. CP#41 WID updated CP-080075=>CP-080493
- 484: CP#42 completed. post-CP#39: split into DSMIP v6 and MIPv4 Access. UID_390072->390172. CP#41 WID updated CP-080075=>CP-080493
- 485: CP#43 completed
- 486: CP#43 completed. WID updated CP-080724=>CP-090247. S10, S11. GTP based S5 Interface
- 487: CP#43 completed. WID updated CP-080724=>CP-090247. S2a, S2b, SWa, STa, SWn (Untrusted IP access - ePDG) interface
- 488: CP#42 completd. CP#43 WID updated CP-080724=>CP-090247
- 489: CP#42 completd. CP#43 WID updated CP-080724=>CP-090247
- 490: SP#37 stopped

| ID | WBS | Task | Type | Duration | Start | Finish | Complete | Remaining | Baseline start | Baseline finish | Baseline duration | Total slack | Constraint | Resources | Work | Actual work | Text1 | Text4 | Text5 | Text6 | Text8 | Text2 | Text7 | Text9 | Text12 | Text11 |
| --- | --- | --- | --- | --- | --- | --- | --- | --- | --- | --- | --- | --- | --- | --- | --- | --- | --- | --- | --- | --- | --- | --- | --- | --- | --- | --- |
| 491 | 188.6 | **Single Radio Voice Call Continuity for 3GPP (SRVCC)** |  | 569d? | 2007-01-02 A | 2009-03-06 A | 100% |  | 2007-01-02 | 2009-03-06 | 569d? |  |  | S2,C1,C4 | 10752h | 10752h | SAES-SRVCC | Nokia Siemens Networks | curt.c.wong@nokia.com | Rel-8 | Maurice |  |  |  |  |  |
| 492 | 188.6.1 | Stage 2 for 2G/3G SRVCC |  | 448d? | 2007-01-02 A | 2008-09-18 A | 100% |  | 2007-01-02 | 2008-09-18 | 448d? |  | finish no earlier than 2008-09-15 | S2 | 3584h | 3584h | SAES-SRVCC | Nokia Siemens Networks | curt.c.wong@nokia.com | Rel-8 | Maurice |  |  |  |  |  |
| 493 | 188.6.2 | Stage 3 for SRVCC in EPS |  | 201d? | 2008-05-30 A | 2009-03-06 A | 100% |  | 2008-05-30 | 2009-03-06 | 201d? |  | finish no earlier than 2009-03-06 | C1 | 1608h | 1608h | SAES-SRVCC | Nokia Siemens Networks | robert.zaus@nsn.com | Rel-8 | Frederic | PCG-21 | CP-41 |  |  |  |
| 494 | 188.6.3 | MME to MSC interface for SRVCC |  | 126d? | 2008-09-12 A | 2009-03-06 A | 100% |  | 2008-09-12 | 2009-03-06 | 126d? |  | finish no earlier than 2009-03-06 | C4 | 1008h | 1008h | SAES-SRVCC | Nokia Siemens Networks | Giorgi Gulbani | Rel-8 | Kimmo | PCG-21 | CP-41 |  |  |  |
| 495 | 188.7 | Voice Call Continuity for CDMA2000 1X |  | 249d? | 2007-06-25 A | 2008-06-05 A | 100% |  | 2007-06-25 | 2008-06-05 | 249d? |  | finish no earlier than 2008-06-13 | S2 | 1992h | 1992h | SAES-VCC_1X | Nokia Siemens Networks | balazs.bertenyi@nsn.com | Rel-8 | Maurice |  |  |  |  |  |
| 496 | 188.8 | SAE impacts on IMS |  | 373d? | 2007-01-02 A | 2008-06-05 A | 100% |  | 2007-01-02 | 2008-06-05 | 373d? |  | finish no earlier than 2008-06-13 | S2 | 2984h | 2984h | SAES-SA_IMS | Nokia Siemens Networks | balazs.bertenyi@nsn.com | Rel-8 | Maurice |  |  |  |  |  |
| 497 | 188.9 | **CS Fallback in EPS** |  | 258d? | 2008-03-12 A | 2009-03-06 A | 100% |  | 2008-03-12 | 2009-03-06 | 258d? |  |  | S2,C1,C4 | 4800h | 4800h | SAES-CSFB | T-Mobile, Vodafone | sabine.demel@t-mobile.at, chris.pudney@vodafone.com | Rel-8 | Maurice | PCG-21 | SP-39 |  |  |  |
| 498 | 188.9.1 | Stage 2 for CS Fallback in EPS |  | 62d? | 2008-03-12 A | 2008-06-05 A | 100% |  | 2008-03-12 | 2008-06-05 | 62d? |  | finish no earlier than 2008-12-05 | S2 | 496h | 496h | SAES-CSFB | T-Mobile, Vodafone | sabine.demel@t-mobile.at, chris.pudney@vodafone.com | Rel-8 | Maurice | PCG-21 | SP-40 |  |  |  |
| 499 | 188.9.2 | Stage 3 for CS Fallback in EPS |  | 201d? | 2008-05-30 A | 2009-03-06 A | 100% |  | 2008-05-30 | 2009-03-06 | 201d? |  | finish no earlier than 2009-03-06 | C1 | 1608h | 1608h | SAES-CSFB | NEC | yannick.lair@nectech.fr | Rel-8 | Frederic | PCG-21 | CP-40 |  |  |  |
| 500 | 188.9.3 | Stage 3 for CS Fallback in EPS |  | 136d? | 2008-05-30 A | 2008-12-05 A | 100% |  | 2008-05-30 | 2008-12-05 | 136d? |  | finish no earlier than 2008-12-05 | C4 | 1088h | 1088h | SAES-CSFB | NEC | yannick.lair@nectech.fr | Rel-8 | Kimmo | PCG-21 | CP-40 |  |  |  |
| 501 | 188.10 | System enhancements for the use of IMS services in local breakout |  | 62d? | 2008-03-12 A | 2008-06-05 A | 100% |  | 2008-03-12 | 2008-06-05 | 62d? |  | finish no earlier than 2008-06-05 | S2 | 496h | 496h | SAES-IMS_LBO | Telecom Italia | mario.madella@telecomitalia.it | Rel-8 | Maurice | PCG-21 | SP-39 |  |  |  |
| 502 | 188.11 | **EPC Data Definitions** |  | 309d? | 2008-01-07 A | 2009-03-12 A | 100% |  | 2008-01-07 | 2009-03-12 | 309d? |  |  | S5 | 7144h | 7144h | EPC-OAM |  |  | Rel-8 | Dionisio | PCG-21 | SP-39 |  |  |  |
| 503 | 188.11.1 | EPC Network Resource Model (NRM) Integration Reference Point (IRP) |  | 309d? | 2008-01-07 A | 2009-03-12 A | 100% |  | 2008-01-07 | 2009-03-12 | 309d? |  | finish no earlier than 2009-03-12 | S5 | 2472h | 2472h | EPC-OAM | Huawei | WANG, Xuelong | Rel-8 | Dionisio | PCG-21 | SP-38 |  |  |  |
| 504 | 188.11.2 | Performance measurements for EPC |  | 275d? | 2008-02-22 A | 2009-03-12 A | 100% |  | 2008-02-22 | 2009-03-12 | 275d? |  | finish no earlier than 2009-03-12 | S5 | 2200h | 2200h | EPC-OAM | China Mobile | Li Jian, Liang Shuangchun | Rel-8 | Dionisio | PCG-21 | SP-39 |  |  |  |
| 505 | 188.12 | EPC Charging |  | 309d? | 2008-01-07 A | 2009-03-12 A | 100% |  | 2008-01-07 | 2009-03-12 | 309d? |  | finish no earlier than 2009-03-12 | S5 | 2472h | 2472h | EPC-CH | Nokia Siemens Networks | GÖRMER, Gerald | Rel-8 | Dionisio | PCG-21 | SP-38 |  |  |  |
| 506 | 188.13 | Issues for CT1 TR 24.801 |  | 420d? | 2007-01-04 A | 2008-12-05 A | 100% |  | 2007-01-04 | 2008-12-05 | 420d? |  | finish no earlier than 2008-12-05 | C1 | 3360h | 3360h | SAES | Nokia Siemens Networks | robert.zaus@nsn.com | Rel-8 | Frederic | PCG-21 | CP-39 |  |  |  |
| 507 | 188.14 | Issues for CT3 TR 29.804 |  | 420d? | 2007-02-05 A | 2008-09-12 A | 100% |  | 2007-02-05 | 2008-09-12 | 420d? |  | finish no earlier than 2008-12-12 | C3 | 3360h | 3360h | SAES | Ericsson | j.javier.pastor@ericsson.com | Rel-8 | Gwiho | PCG-21 | CP-39 |  |  |  |
| 508 | 188.15 | Deleted - Issues for CT4 TR 29.803 |  | 420d? | 2007-01-04 A | 2008-09-12 A | 100% |  | 2007-01-04 | 2008-09-12 | 420d? |  | finish no earlier than 2008-12-11 | C4 | 3360h | 3360h | SAES | Huawei |  | Rel-8 | Kimmo | PCG-21 | CP-39 | PCG-21 | CP-41 |  |
| 509 | 188.16 | Domain Name System Procedures for Evolved Packet System (DEPS) |  | 179.75d? | 2008-05-30 A | 2009-03-06 A | 100% |  | 2008-05-30 | 2009-03-06 | 179.75d? |  | finish no earlier than 2009-03-06 | C4 | 1438h | 1438h | SAES-DEPS | TeliaSonera | jouni.korhonen@teliasonera.com | Rel-8 | Kimmo | PCG-21 | CP-40 |  |  |  |
| 510 | 188.17 | InterWorking Function (IWF) between MAP based and Diameter based interfaces |  | 126d? | 2008-09-12 A | 2009-03-06 A | 100% |  | 2008-09-12 | 2009-03-06 | 126d? |  | finish no earlier than 2009-03-06 | C4 | 1008h | 1008h | SAES-MAP2Diam | Huawei | liming49985@huawei.com | Rel-8 | Kimmo | PCG-21 | CP-41 |  |  |  |
| 511 | 188.18 | **CT6 aspects of SAE** |  | 587d? | 2008-03-07 A | 2010-06-04 | 95% | 32.24d? | 2008-03-07 | 2010-06-04 | 587d? | 335d |  | C6 | 8832h | 8346.98h | SAES | Nokia | Rune Lindholm | Rel-8 | Xavier | PCG-21 | SP-39 |  |  |  |
| 512 | 188.18.1 | CT6 aspects of SAE |  | 321d? | 2008-03-07 A | 2009-05-29 A | 100% |  | 2008-03-07 | 2009-05-29 | 321d? |  | finish no earlier than 2009-05-29 | C6 | 2568h | 2568h | SAES | Nokia | Rune Lindholm | Rel-8 | Xavier | PCG-21 | CP-39 |  |  |  |
| 513 | 188.18.2 | Test interworking of LTE Terminals with the USIM |  | 391d? | 2008-12-05 A | 2010-06-04 | 90% | 39.1d? | 2008-12-05 | 2010-06-04 | 391d? | 335d | finish no earlier than 2010-06-04 | C6 | 3128h | 2815.2h | SAES-USIM_LTE-Test | Comprion | Udo Willenbrink | Rel-8 | Xavier | PCG-22 | CP-42 |  |  |  |
| 514 | 188.19 | Deleted (covered by 380068): Functions and procedures for SAE to support LCS | milestone | 0d? | 2008-03-03 A | 2008-03-03 A | 100% |  | 2008-03-03 | 2008-03-03 | 0d? |  | finish no earlier than 2008-03-03 | S2 |  |  | SAES-SA-FP_LCS | Nokia Siemens Networks |  | Rel-8 | Maurice |  |  |  | SP-37 |  |
| 515 | 188.20 | Deleted (covered by 380064): SAE aspects of Emergency Calls | milestone | 0d? | 2008-03-03 A | 2008-03-03 A | 100% |  | 2008-03-03 | 2008-03-03 | 0d? |  | start no earlier than 2008-03-03 | S2 |  |  | SAES-SA-EmCall | Nokia Siemens Networks |  | Rel-8 | Maurice |  |  |  | SP-37 |  |
| 516 | 188.21 | Deleted - CT1 aspects of SAES |  | 16.7d? | 2007-09-04 A | 2007-09-27 A | 100% |  | 2007-09-04 | 2007-09-27 | 16.7d? |  | start no earlier than 2007-09-04 | CP,C1 | 133.62h | 133.62h | SAES-St3 |  |  | Rel-8 | Frederic |  |  |  | SP-37 |  |
| 517 | 188.22 | Deleted - CT1 aspects of SAES | milestone | 0d? | 2007-09-04 A | 2007-09-04 A | 100% |  | 2007-09-04 | 2007-09-04 | 0d? |  | start no earlier than 2007-09-04 | C1 |  |  | SAES-St3 |  |  | Rel-8 | Frederic |  |  |  | SP-37 |  |
| 518 | 188.23 | Deleted - Interoperability | milestone | 0d? | 2008-03-14 A | 2008-03-14 A | 100% |  | 2008-03-14 | 2008-03-14 | 0d? |  | start no earlier than 2008-03-14 | C1 |  |  | SAES-St3-interop |  |  | Rel-8 | Frederic |  |  |  | SP-37 |  |
| 519 | 188.24 | Deleted - CT3 aspects of SAES | milestone | 0d? | 2007-09-04 A | 2007-09-04 A | 100% |  | 2007-09-04 | 2007-09-04 | 0d? |  | start no earlier than 2007-09-04 | C3 |  |  | SAES-St3 |  |  | Rel-8 | Gwiho |  |  |  | SP-37 |  |
| 520 | 188.25 | Deleted - CT4 aspects of SAES | milestone | 0d? | 2007-09-04 A | 2007-09-04 A | 100% |  | 2007-09-04 | 2007-09-04 | 0d? |  | start no earlier than 2007-09-04 | C4 |  |  | SAES-St3 |  |  | Rel-8 | Kimmo |  |  |  | SP-37 |  |
| 521 | 188.26 | Deleted - UE to EPC NAS signalling (incl. MBMS and QoS aspects) | milestone | 0d? | 2008-03-14 A | 2008-03-14 A | 100% |  | 2008-03-14 | 2008-03-14 | 0d? |  | start no earlier than 2008-03-14 | C1 |  |  | SAES-St3-sig |  |  | Rel-8 | Frederic |  |  |  | SP-37 |  |
| 522 | 188.27 | Deleted - User and Control plane protocols | milestone | 0d? | 2007-09-21 A | 2007-09-21 A | 100% |  | 2007-09-21 | 2007-09-21 | 0d? |  | start no earlier than 2007-09-21 | C4 |  |  | SAES-St3-prot |  |  | Rel-8 | Kimmo |  |  |  | SP-37 |  |
| 523 | 188.28 | Deleted - Architecture enhancements for non-3GPP accesses | milestone | 0d? | 2007-09-04 A | 2007-09-04 A | 100% |  | 2007-09-04 | 2007-09-04 | 0d? |  | start no earlier than 2007-09-04 | S2 |  |  | SAES-non_3GPP | Motorola | Irfan.Ali@motorola.com | Rel-8 | Maurice |  |  |  | SP-34 |  |
| 524 | 188.29 | Deleted - Stage 2 of architecture for the 3GPP System Architecture Evolution | milestone | 0d? | 2007-10-02 A | 2007-10-02 A | 100% |  | 2007-10-02 | 2007-10-02 | 0d? |  | start no earlier than 2007-10-02 | S2 |  |  | SAES-St2 | Vodafone | chris.pudney@vodafone.com | Rel-8 | Maurice |  |  |  | SP-34 |  |
| 525 | 188.30 | Deleted - SA aspects of System Architecture Evolution |  | 384d? | 2006-04-12 A | 2007-10-01 A | 100% |  | 2006-04-12 | 2007-10-01 | 384d? |  | finish no earlier than 2007-10-02 | S2 | 3072h | 3072h | SAES-SA |  |  | Rel-8 | Maurice |  |  |  | SP-34 |  |
| 526 | 189 | Conformance Test Aspects – Mobility management based on DSMIPv6 (Dual-Stack Mobile IPv6) |  | 196d? | 2009-09-18 A | 2010-06-18 | 60% | 78.4d? | 2009-09-18 | 2010-06-18 | 196d? | 325d | finish no earlier than 2010-06-18 | R5 | 1568h | 940.8h | DSMIPv6-UEConfTest | Qualcomm | Lena Chaponniere (lchaponn@qualcomm.com) | Rel-8 | Ingbert | PCG-23 | RP-45 |  |  | RP-100073 |

Notes:
- 491: CP#43 completed. SP#41 Stage 2 completed. SP#38 WID approved (extract from SAE WID SP-070817).
- 492: SP#41 completed. SP#38 WID approved / Text3: 23.216
- 493: CP#43 completed / Text3: 23.009, 24.008, 24.301
- 494: CP#43 completed / Text3: 29.274, 29.277, 23.003, 23.008, 29.280
- 495: SP#40 completed
- 496: SP#40 completed
- 497: CP#43 completed. SP#40 Stage 2 completed.
- 498: SP#40 completed / Text3: 23.272, 23.401
- 499: CP#43 completed / Text3: 24.301, 24.801, 24.007, 24.008, 24.011, 29.018, 29.118 [Mobility Management Entity (MME) – Visitor Location Register (VLR) SGs interface specification]
- 500: CP#42 completed. WID updated CP-080321=>CP-080495=>CP-080791 / Text3: 23.007, 23.008, 29.274, 29.277
- 501: SP#40 completed / Text3: 23.228, 23.221, 23.203
- 502: SP#43 completed
- 503: SP#43 completed / Text3: 32.751, 32.752, 32.753, 32.755
- 504: SP#43 completed / Text3: 32.426
- 505: SP#43 completed / Text3: 32.240/296/251/252/298/299
- 506: CP#43 completed / Text3: 24.801
- 507: CP#41 completed / Text3: 29.804
- 508: CP#41 Work stopped and continued in Normative specifications / Text3: 29.803
- 509: CP#43 completed / Text3: 23.003, 29.303
- 510: CP#43 completed. Triggered by UID_380023 (FS_MAP2Diam) / Text3: 29.305
- 511: CP#44 completed core specification. Testing ongoing
- 512: CP#44 completed (Network Measurement Results collection via USAT are now specified) / Text3: 31.102, 31.111
- 513: CP#47 completion 03/10=>06/10 (Steering of Roaming + CSG display testing still to be assessed). Testing for UID_390021 CT6 aspects of SAE / Text3: 31.121, 31.124
- 514: SP#37 stopped
- 515: SP#37 stopped
- 516: SP#37 stopped
- 517: SP#37 stopped
- 518: SP#37 stopped
- 519: SP#37 stopped
- 520: SP#37 stopped / Text3: 29.803
- 521: SP#37 stopped
- 522: SP#37 stopped
- 523: SP#34 stopped. Replaced by UID_350027 and its children / Text3: 23.402
- 524: SP#34 stopped. Replaced by UIDs 340018 and 340037. (SP#34 report discussion of SP-060917.) / Text3: 23.002, 23.060, 23.107, 23.203, 23.228, 23.234, 23.246, 23.271, 23.279
- 525: SP#34 stopped
- 526: Testing for CT1's UID_360022 (24.303) under Rel-8 Feature SAES / Text3: 36.508, 36.523-1, 36.523-2, 36.523-3

| ID | WBS | Task | Duration | Start | Finish | Complete | Baseline start | Baseline finish | Baseline duration | Constraint | Resources | Work | Actual work | Text1 | Text4 | Text5 | Text6 | Text7 | Text8 | Text2 | Text9 | Text12 |
| --- | --- | --- | --- | --- | --- | --- | --- | --- | --- | --- | --- | --- | --- | --- | --- | --- | --- | --- | --- | --- | --- | --- |
| 527 | 190 | **IMS Centralized Service Control (ICSRA)** | 395d? | 2007-09-03 A | 2009-03-06 A | 100% | 2007-09-03 | 2009-03-06 | 395d? |  | S1,S2,C1,C3,C4 | 10680h | 10680h | ICSRA | AT&T | Randolph Wohlert (rwohlert@tri.sbc.com) | Rel-8 | SP-37 | Alain |  |  |  |
| 528 | 190.1 | Stage 1 for ICSRA | 138d? | 2007-09-03 A | 2008-03-12 A | 100% | 2007-09-03 | 2008-03-12 | 138d? | finish no earlier than 2007-12-14 | S1 | 1104h | 1104h | ICSRA | AT&T | Randolph Wohlert (rwohlert@tri.sbc.com) | Rel-8 | SP-38 | Alain | PCG-21 |  |  |
| 529 | 190.2 | Stage 2 for ICSRA | 125d? | 2007-12-14 A | 2008-06-05 A | 100% | 2007-12-14 | 2008-06-05 | 125d? | start no earlier than 2007-12-14 | S2 | 1000h | 1000h | ICSRA-St2 | Alcatel-Lucent |  | Rel-8 | SP-38 | Maurice | PCG-21 |  |  |
| 530 | 190.3 | **Stage 3 for ICSRA – Protocol, Addressing, Subscriber Data** | 201d? | 2008-05-30 A | 2009-03-06 A | 100% | 2008-05-30 | 2009-03-06 | 201d? |  | C1,C3,C4 | 6520h | 6520h | ICSRA | Ericsson | Sean Schneyer | Rel-8 |  |  |  |  |  |
| 531 | 190.3.1 | CT1 aspects - Stage 3 for ICSRA | 201d? | 2008-05-30 A | 2009-03-06 A | 100% | 2008-05-30 | 2009-03-06 | 201d? | finish no earlier than 2009-03-06 | C1 | 1608h | 1608h | ICSRA | Ericsson | Sean Schneyer | Rel-8 | CP-40 | Frederic | PCG-21 |  |  |
| 532 | 190.3.2 | CT3 aspects - Stage 3 for ICSRA | 201d? | 2008-05-30 A | 2009-03-06 A | 100% | 2008-05-30 | 2009-03-06 | 201d? | finish no earlier than 2009-03-06 | C3 | 1608h | 1608h | ICSRA | Mavenir | Brett Wallis | Rel-8 | CP-40 | Gwiho | PCG-21 |  |  |
| 533 | 190.3.3 | CT4 aspects - Stage 3 for ICSRA | 136d? | 2008-05-30 A | 2008-12-05 A | 100% | 2008-05-30 | 2008-12-05 | 136d? | start no earlier than 2008-05-30 | C4 | 1088h | 1088h | ICSRA | Ericsson | Sean Schneyer | Rel-8 | CP-40 | Kimmo | PCG-21 |  |  |
| 534 | 190.3.4 | Deleted - Stage 3 for ICSRA – I1 interface | 76d? | 2008-05-30 A | 2008-09-12 A | 100% | 2008-05-30 | 2008-09-12 | 76d? | finish no earlier than 2008-09-12 | C1 | 608h | 608h | ICSRA | Huawei | xupeili@huawei.com | Rel-8 | CP-40 | Frederic | PCG-21 | PCG-21 | CP-41 |
| 535 | 191 | **IMS Multimedia Telephony and Supplementary Services** | 487d? | 2007-05-02 A | 2009-03-12 A | 100% | 2007-05-02 | 2009-03-12 | 487d? |  | S1,S5,C1,C3,C4 | 46006.4h | 46006.4h | IMSTSS |  |  | Rel-8 | SP-37 | Alain |  |  |  |
| 536 | 191.1 | **General aspects of IMS Sup Services** | 395d? | 2007-09-03 A | 2009-03-06 A | 100% | 2007-09-03 | 2009-03-06 | 395d? |  | S1,C1,C3,C4 | 9752h | 9752h | IMSSS-Gal | Ericsson | Susana Sabater | Rel-8 | SP-37 | Alain |  |  |  |
| 537 | 191.1.1 | Service and Capability for Core IMS - inclusion of TISPAN requirements | 75d? | 2007-09-03 A | 2007-12-14 A | 100% | 2007-09-03 | 2007-12-14 | 75d? | finish no earlier than 2007-12-14 | S1 | 600h | 600h | TISCAPR8 | Ericsson | Susana Sabater | Rel-8 | SP-37 | Alain |  |  |  |
| 538 | 191.1.2 | Documentation of TISPAN R1 and R2 in CT1 | 208d? | 2007-11-28 A | 2008-09-12 A | 100% | 2007-11-28 | 2008-09-12 | 208d? | finish no earlier than 2008-09-12 | C1 | 1664h | 1664h | REDOC_TIS-C1 | Nokia Siemens Networks | peter.leis@nsn.com | Rel-8 | CP-38 | Frederic | PCG-21 |  |  |
| 539 | 191.1.3 | Documentation of TISPAN R1 and R2 in CT3 | 333d? | 2007-11-28 A | 2009-03-06 A | 100% | 2007-11-28 | 2009-03-06 | 333d? | finish no earlier than 2009-03-06 | C3 | 2664h | 2664h | REDOC_TIS-C3 | Nokia Siemens Networks | peter.leis@nsn.com | Rel-8 | CP-38 | Gwiho | PCG-21 |  |  |
| 540 | 191.1.4 | Documentation of TISPAN R1 and R2 in CT4 | 208d? | 2007-11-28 A | 2008-09-12 A | 100% | 2007-11-28 | 2008-09-12 | 208d? | finish no earlier than 2008-09-12 | C4 | 1664h | 1664h | REDOC_TIS-C4 | Nokia Siemens Networks | peter.leis@nsn.com | Rel-8 | CP-38 | Kimmo | PCG-21 |  |  |
| 541 | 191.2 | **IMS Multimedia Telephony Service** | 394d? | 2007-09-10 A | 2009-03-12 A | 100% | 2007-09-10 | 2009-03-12 | 394d? |  | S1,S5 | 5096h | 5096h | IMS-MMTel |  |  | Rel-8 | SP-37 | Alain |  |  |  |
| 542 | 191.2.1 | Merging TISPAN MMTel [requirements] for Common IMS | 65d? | 2007-09-10 A | 2007-12-07 A | 100% | 2007-09-10 | 2007-12-07 | 65d? | finish no earlier than 2007-12-07 | S1 | 520h | 520h | TMMTEL | Nokia Siemens Networks |  | Rel-8 | SP-37 | Alain |  |  |  |
| 543 | 191.2.2 | Multimedia Telephony Service and Supplementary Services (MMTel) offline Charging | 309d? | 2008-01-07 A | 2009-03-12 A | 100% | 2008-01-07 | 2009-03-12 | 309d? | finish no earlier than 2009-03-12 | S5 | 2472h | 2472h | MMTel-CH | Alcatel-Lucent | GARDELLA, Maryse | Rel-8 | SP-38 | Dionisio | PCG-21 |  |  |
| 544 | 191.3 | **Call Completion on Busy Subscriber (CCBS)/Call Completion on Non-Reachable (CCNR) on IMS** | 483d? | 2007-05-02 A | 2009-03-06 A | 100% | 2007-05-02 | 2009-03-06 | 483d? |  | C1,C3 | 11072h | 11072h | CCBS_CCNR | Deutsche Telekom | martin.huelsemann@telekom.de | Rel-8 | SP-38 | Frederic | PCG-21 |  |  |
| 545 | 191.3.1 | Stage 3 CCBS_CCNR | 483d? | 2007-05-02 A | 2009-03-06 A | 100% | 2007-05-02 | 2009-03-06 | 483d? | finish no earlier than 2009-03-06 | C1 | 3864h | 3864h | CCBS_CCNR | Deutsche Telekom | martin.huelsemann@telekom.de | Rel-8 | CP-38 | Frederic | PCG-21 |  |  |
| 546 | 191.3.2 | Stage 3 CCBS_CCNR | 418d? | 2007-05-02 A | 2008-12-05 A | 100% | 2007-05-02 | 2008-12-05 | 418d? | finish no earlier than 2008-12-05 | C3 | 3344h | 3344h | CCBS_CCNR | Deutsche Telekom | martin.huelsemann@telekom.de | Rel-8 | CP-38 | Gwiho | PCG-21 |  |  |
| 547 | 191.4 | **Flexible Alerting** | 288d? | 2008-01-30 A | 2009-03-06 A | 100% | 2008-01-30 | 2009-03-06 | 288d? |  | S1,C1 | 5278.4h | 5278.4h | FA | Nortel | milanpa@nortel.com | Rel-8 | SP-39 | Alain | PCG-21 |  |  |
| 548 | 191.4.1 | Stage 1 FA | 92d? | 2008-01-30 A | 2008-06-05 A | 100% | 2008-01-30 | 2008-06-05 | 92d? |  | S1 | 670.4h | 670.4h | FA | Telecom Italia |  | Rel-8 | SP-39 | Alain | PCG-21 |  |  |
| 549 | 191.4.2 | Stage 3 FA | 288d? | 2008-01-30 A | 2009-03-06 A | 100% | 2008-01-30 | 2009-03-06 | 288d? | finish no earlier than 2009-03-06 | C1 | 2304h | 2304h | FA | Nortel | milanpa@nortel.com | Rel-8 | CP-39 | Frederic | PCG-21 |  |  |
| 550 | 191.5 | **Communication Wait on IMS** | 331d? | 2007-11-30 A | 2009-03-06 A | 100% | 2007-11-30 | 2009-03-06 | 331d? |  | C1,C3 | 7416h | 7416h | CW_IMS | Deutsche Telekom | martin.huelsemann@telekom.de | Rel-8 | SP-38 | Frederic | PCG-21 |  |  |
| 551 | 191.5.1 | Stage 3 CW-IMS | 331d? | 2007-11-30 A | 2009-03-06 A | 100% | 2007-11-30 | 2009-03-06 | 331d? | finish no earlier than 2009-03-06 | C1 | 2648h | 2648h | CW_IMS | Deutsche Telekom | martin.huelsemann@telekom.de | Rel-8 | CP-38 | Frederic | PCG-21 |  |  |
| 552 | 191.5.2 | Stage 3 CW-IMS | 265d? | 2007-11-30 A | 2008-12-04 A | 100% | 2007-11-30 | 2008-12-04 | 265d? | finish no earlier than 2008-12-05 | C3 | 2120h | 2120h | CW_IMS | Deutsche Telekom | martin.huelsemann@telekom.de | Rel-8 | CP-38 | Gwiho | PCG-21 |  |  |
| 553 | 191.6 | Advice of Charge (AoC) support in IMS Charging | 309d? | 2008-01-07 A | 2009-03-12 A | 100% | 2008-01-07 | 2009-03-12 | 309d? | finish no earlier than 2009-03-12 | S5 | 2472h | 2472h | IMSTSS | Nokia Siemens Networks | GÖRMER, Gerald | Rel-8 | SP-38 | Dionisio | PCG-21 |  |  |
| 554 | 191.7 | Add Interconnection Border Control Function (IBCF) to IMS Charging | 128d? | 2007-09-17 A | 2008-03-12 A | 100% | 2007-09-17 | 2008-03-12 | 128d? | finish no earlier than 2008-03-12 | S5 | 1024h | 1024h | IMSTSS | Alcatel-Lucent | GARDELLA, Maryse | Rel-8 | SP-37 | Dionisio |  |  |  |

Notes:
- 527: CP#46 WID updated CP-080492=>CP-091046. Approved new TS 24.286. SP#40 SA1/2 completed
- 528: SP#38 WID approved. SP#39 completed / Text3: 22.101
- 529: SP#38 WID approved. SP#40 completed / Text3: 23.292, 23.206
- 530: CP#46 WID updated CP-080492=>CP-091046. Approved new TS 24.286
- 531: CP#46 WID updated CP-080492=>CP-091046. Approved new TS 24.286 / Text3: 24.229, new (24.292, 24.286)
- 532: CP#43 completed / Text3: new 29.292
- 533: CP#42 completed / Text3: 23.003, 29.232, 23.018, 29.002
- 534: 23/07/08 Line created at CT1 Zagreb request. CP#41 WID updated CP-080319=>CP-080492. CP#41 work stopped / Text3: 24.293
- 535: SP#43 completed
- 536: CP#43 completed
- 537: SP#39 completed / Text3: 22.228, 22.115, 22.101
- 538: CP#41 completed / Text3: 24.141, 24.147, 24.173, 24.229, 24.247, 24.341, 24.604, 24.605, 24.606, 24.607, 24.608, 24.610, 24.611, 24.616, 24.623, 24.628, 24.629, 24.647, 24.654
- 539: CP#43 completed. CP#46 withdrawn 29.612 from Rel-9 onwards / Text3: 29.162, 29.163, 29.658
- 540: CP#41 completed / Text3: 29.228, 29.229
- 541: SP#43 completed
- 542: SP#38 completed / Text3: 22.173
- 543: CP#43 completed / Text3: 32.275, 32.298/299
- 544: CP#43 completed
- 545: CP#43 completed / Text3: 24.642, 24.229, 24.173
- 546: CP#42 completed / Text3: 29.163
- 547: CP#43 completed
- 548: SP#40 completed / Text3: 22.173
- 549: CP#43 completed / Text3: 24.239, 24.173
- 550: CP#43 completed
- 551: CP#43 completed / Text3: 24.615, 24.229, 24.173
- 552: CP#42 completed / Text3: 29.163
- 553: SP#43 completed / Text3: 32.280, 32.240/260/296/298/299
- 554: SP#39 completed / Text3: 32.260, 32.298

| ID | WBS | Task | Duration | Start | Finish | Complete | Baseline start | Baseline finish | Baseline duration | Constraint | Resources | Work | Actual work | Text1 | Text2 | Text4 | Text5 | Text6 | Text7 | Text8 |
| --- | --- | --- | --- | --- | --- | --- | --- | --- | --- | --- | --- | --- | --- | --- | --- | --- | --- | --- | --- | --- |
| 555 | 192 | **3GPP2 Input to Common IMS** | 200d? | 2008-03-07 A | 2008-12-11 A | 100% | 2008-03-07 | 2008-12-11 | 200d? |  | S1,S2,S3,C1,C3,C4 | 8653.2h | 8653.2h | CIMS_3GPP2 | PCG-21 | Nortel | Amar Deol (deola@nortelnetworks.com) | Rel-8 | SP-39 | Alain |
| 556 | 192.1 | Stage 1 CIMS_3GPP2 (SA1) | 30.65d? | 2008-03-12 A | 2008-06-05 A | 100% | 2008-03-12 | 2008-06-05 | 30.65d? | finish no earlier than 2008-06-12 | S1 | 245.2h | 245.2h | CIMS_3GPP2 | PCG-21 | Nortel | Amar Deol (deola@nortelnetworks.com) | Rel-8 | SP-39 | Alain |
| 557 | 192.2 | Stage 2 CIMS_3GPP2 (SA2) | 62d? | 2008-03-12 A | 2008-06-05 A | 100% | 2008-03-12 | 2008-06-05 | 62d? | finish no earlier than 2008-09-11 | S2 | 496h | 496h | IMS_Common | PCG-21 | Nortel | Amar Deol (deola@nortelnetworks.com) | Rel-8 | SP-39 | Maurice |
| 558 | 192.3 | Security CIMS_3GPP2 (SA3) | 197d? | 2008-03-12 A | 2008-12-11 A | 100% | 2008-03-12 | 2008-12-11 | 197d? | finish no earlier than 2008-12-11 | S3 | 1576h | 1576h | IMS_Common | PCG-21 | Nortel | Amar Deol (deola@nortelnetworks.com) | Rel-8 | SP-39 | Dionisio |
| 559 | 192.4 | Stage 3 CIMS_3GPP2 (CT1) | 196d? | 2008-03-07 A | 2008-12-05 A | 100% | 2008-03-07 | 2008-12-05 | 196d? | finish no earlier than 2008-12-11 | C1 | 1568h | 1568h | REDOC_3GPP2 | PCG-21 | Alcatel-Lucent | orsic@alcatel-lucent.com | Rel-8 | CP-39 | Frederic |
| 560 | 192.5 | Stage 3 CIMS_3GPP2 (CT3) | 196d? | 2008-03-07 A | 2008-12-05 A | 100% | 2008-03-07 | 2008-12-05 | 196d? | finish no earlier than 2008-12-05 | C3 | 1568h | 1568h | REDOC_3GPP2 | PCG-21 | Alcatel-Lucent | orsic@alcatel-lucent.com | Rel-8 | CP-39 | Gwiho |
| 561 | 192.6 | Stage 3 CIMS_3GPP2 (CT4) | 200d? | 2008-03-07 A | 2008-12-11 A | 100% | 2008-03-07 | 2008-12-11 | 200d? | finish no earlier than 2008-12-11 | C4 | 1600h | 1600h | REDOC_3GPP2 | PCG-21 | Alcatel-Lucent | orsic@alcatel-lucent.com | Rel-8 | CP-39 | Kimmo |
| 562 | 193 | **IMS Enhancements for support of Packet Cable access** | 388d? | 2006-12-06 A | 2008-05-30 A | 100% | 2006-12-06 | 2008-05-30 | 388d? |  | S2,S3,C1,C3,C4 | 27448h | 27448h | PktCbl |  | Cablelabs | Bernie McKibben | Rel-8 |  | Maurice |
| 563 | 193.1 | **IMS Enhancements for Cable Client Types and Deployment Models** | 345d? | 2007-02-05 A | 2008-05-30 A | 100% | 2007-02-05 | 2008-05-30 | 345d? |  | S2,C1 | 6992h | 6992h | PktCbl-Deploy |  | Cablelabs | Bernie McKibben | Rel-8 |  | Maurice |
| 564 | 193.1.1 | Architecture aspects of PktCbl-Deploy | 219d? | 2007-02-05 A | 2007-12-06 A | 100% | 2007-02-05 | 2007-12-06 | 219d? | finish no earlier than 2007-12-03 | S2 | 1752h | 1752h | PktCbl-Deploy |  | Cablelabs | Bernie McKibben | Rel-8 |  | Maurice |
| 565 | 193.1.2 | CT1 aspects of PktCbl-Deploy | 310d? | 2007-03-26 A | 2008-05-30 A | 100% | 2007-03-26 | 2008-05-30 | 310d? | finish no earlier than 2008-06-15 | C1 | 2480h | 2480h | PktCbl-Deploy |  | Cablelabs | D.Hancock@ CableLabs.com | Rel-8 |  | Frederic |
| 566 | 193.2 | **IMS Inter-working aspects in Support of Cable Regulatory requirements** | 290d? | 2007-02-05 A | 2008-03-14 A | 100% | 2007-02-05 | 2008-03-14 | 290d? |  | S2,C1,C3 | 5640h | 5640h | PktCbl-Intw |  | Cablelabs | B.McKibben@CableLabs.com | Rel-8 |  | Maurice |
| 567 | 193.2.1 | Architecture PktCbl-Interwork | 160d? | 2007-02-05 A | 2007-09-14 A | 100% | 2007-02-05 | 2007-09-14 | 160d? | start no earlier than 2007-02-05 | S2 | 1280h | 1280h | PktCbl-Intw |  | Cablelabs | B.McKibben@CableLabs.com | Rel-8 |  | Maurice |
| 568 | 193.2.2 | CT1,CT3 PktCbl-Interwork | 255d? | 2007-03-26 A | 2008-03-14 A | 100% | 2007-03-26 | 2008-03-14 | 255d? | finish no earlier than 2008-03-15 | C1,C3 | 2040h | 2040h | PktCbl-Intw |  | Cablelabs | D.Hancock@ CableLabs.com | Rel-8 |  | Frederic |
| 569 | 193.3 | **IMS Enhancements for Security Requirements in Support of Cable Deployments** | 388d? | 2006-12-06 A | 2008-05-30 A | 100% | 2006-12-06 | 2008-05-30 | 388d? |  | S3,C1,C3,C4 | 11712h | 11712h | PktCbl-Sec |  | Cablelabs | s.dotson@cablelabs.com | Rel-8 |  | Dionisio |
| 570 | 193.3.1 | SA3 Aspects of PktCbl-Sec | 331d? | 2006-12-06 A | 2008-03-12 A | 100% | 2006-12-06 | 2008-03-12 | 331d? | finish no earlier than 2007-12-20 | S3 | 2648h | 2648h | PktCbl-Sec |  | Cablelabs | s.dotson@cablelabs.com | Rel-8 |  | Dionisio |
| 571 | 193.3.2 | CT1 Aspects of PktCbl-Sec | 310d? | 2007-03-26 A | 2008-05-30 A | 100% | 2007-03-26 | 2008-05-30 | 310d? | finish no earlier than 2008-06-06 | C1 | 2480h | 2480h | PktCbl-Sec |  | Cablelabs | D.Hancock@ CableLabs.com | Rel-8 |  | Frederic |
| 572 | 193.3.3 | CT3 Aspects of PktCbl-Sec | 180d? | 2007-03-26 A | 2007-11-30 A | 100% | 2007-03-26 | 2007-11-30 | 180d? | finish no earlier than 2008-03-15 | C3 | 1440h | 1440h | PktCbl-Intw | PCG-21 | Cablelabs | D.Hancock@ CableLabs.com | Rel-8 | CP-38 | Gwiho |
| 573 | 193.3.4 | CT4 Aspects of PktCbl-Sec | 255d? | 2007-03-26 A | 2008-03-14 A | 100% | 2007-03-26 | 2008-03-14 | 255d? | finish no earlier than 2008-03-14 | C4 | 2040h | 2040h | PktCbl-Sec |  | Cablelabs | D.Hancock@ CableLabs.com | Rel-8 |  | Kimmo |
| 574 | 194 | **IMS System enhancements for corporate network access** | 717d? | 2007-06-22 A | 2010-03-19 A | 100% | 2007-06-22 | 2010-03-19 | 717d? |  | S2,S1,C1,C4 | 14336.9h | 14336.9h | IMS_Corp |  | Orange | Delphin Barankanira | Rel-8 |  | Maurice |
| 575 | 194.1 | SA1 aspects of IMS_Corp | 23.6d? | 2008-03-12 A | 2008-06-05 A | 100% | 2008-03-12 | 2008-06-05 | 23.6d? | finish no earlier than 2008-06-05 | S1 | 188.8h | 188.8h | IMS_Corp | PCG-21 | Telecom Italia |  | Rel-8 | SP-39 | Alain |
| 576 | 194.2 | SA2 aspects of IMS_Corp | 325d? | 2007-06-22 A | 2008-09-18 A | 100% | 2007-06-22 | 2008-09-18 | 325d? | finish no earlier than 2008-12-25 | S2 | 2600h | 2600h | IMS_Corp |  | Orange | Delphin Barankanira | Rel-8 |  | Maurice |
| 577 | 194.3 | CT1 aspects of IMS_Corp | 532d? | 2008-03-07 A | 2010-03-19 A | 100% | 2008-03-07 | 2010-03-19 | 532d? | finish no earlier than 2010-03-19 | C1 | 4244.09h | 4244.09h | IMS_Corp | PCG-21 | Alcatel-Lucent | Keith Drage (drage@alcatel-lucent.com) | Rel-8 | CP-39 | Frederic |
| 578 | 194.4 | CT4 aspects of IMS_Corp | 196d? | 2008-02-26 A | 2008-12-05 A | 100% | 2008-02-26 | 2008-12-05 | 196d? | finish no earlier than 2008-12-11 | C4 | 1568h | 1568h | IMS_Corp | PCG-21 | Alcatel-Lucent | Keith Drage (drage@alcatel-lucent.com) | Rel-8 | CP-39 | Kimmo |

Notes:
- 555: TSG#42 completed
- 556: SP#40 completed / Text3: 22.228, 22.173, 22.101, 22.153
- 557: SP#40 completed / Text3: 23.002, 23.141, 23.203, 23.167, 23.228
- 558: SP#42 completed [issues addressed under UID_370078 (IMS-Sec)] / Text3: 33.141, 33.203, 33.210
- 559: CP#42 completed. WID updated CP-080218=>CP-080494=>CP-080795 / Text3: 23.218, 24.141, 24.147, 24.173, 24.229, 24.238, 24.247, 24.604, 24.605, 24.606, 24.607, 24.608, 24.610, 24.611, 24.629, 24.930
- 560: CP#42 completed. WID updated CP-080218=>CP-080494=>CP-080795 / Text3: 29.163, 29.212, 29.213, 29.214
- 561: CP#42 completed. WID updated CP-080218=>CP-080494=>CP-080795 / Text3: 29.228, 29.229, 29.328, 29.329
- 562: CP#40 completed
- 563: CP#40 completed
- 564: SP#38 completed / Text3: 23.228
- 565: CP#40 completed
- 566: CP#39 completed
- 567: SP#37 completed / Text3: 23.228
- 568: CP#39 completed / Text3: 24.229
- 569: CP#40 completed
- 570: SP#39 completed / Text3: 33.203, 33.210, 33.220
- 571: CP#40 completed / Text3: 24.229
- 572: CP#38 completed / Text3: 29.163
- 573: CP#39 completed / Text3: 29.228, 29.229, 23.008
- 574: CP#45 still some unresolved issue. SP#41 no Stage 2 impacts identified by Joint Workshop
- 575: SP#40 completed
- 576: SP#41 completed / Text3: 23.228
- 577: CP#47 completed / Text3: 24.229, 24.503
- 578: CP#42 completed / Text3: 29.228, 29.229, 23.003, 23.008, 29.433

| ID | WBS | Task | Duration | Start | Finish | Complete | Baseline start | Baseline finish | Baseline duration | Constraint | Resources | Work | Actual work | Text1 | Text2 | Text6 | Text7 | Text8 | Text4 | Text5 |
| --- | --- | --- | --- | --- | --- | --- | --- | --- | --- | --- | --- | --- | --- | --- | --- | --- | --- | --- | --- | --- |
| 579 | 195 | **Maintenance of TISPAN documentation** | 244d? | 2007-07-02 A | 2008-06-05 A | 100% | 2007-07-02 | 2008-06-05 | 244d? |  | S2,C1,C3,C4 | 5984h | 5984h | MAINTISP | PCG-21 | Rel-8 | SP-38 | Maurice |  |  |
| 580 | 195.1 | Maintenance of TISPAN R1 | 86d? | 2007-11-09 A | 2008-03-07 A | 100% | 2007-11-09 | 2008-03-07 | 86d? | start no earlier than 2007-11-09 | C1,C3,C4 | 688h | 688h | MAINT_R1 | PCG-21 | Rel-7 | CP-38 | Frederic | Alcatel-Lucent | Keith Drage (drage@alcatel-lucent.com) |
| 581 | 195.2 | Maintenance of TISPAN R2 | 86d? | 2007-11-09 A | 2008-03-07 A | 100% | 2007-11-09 | 2008-03-07 | 86d? | start no earlier than 2007-11-09 | C1,C3,C4 | 688h | 688h | MAINT_R2 | PCG-21 | Rel-8 | CP-38 | Frederic | Alcatel-Lucent | Keith Drage (drage@alcatel-lucent.com) |
| 582 | 195.3 | Documentation of TISPAN NGN R1 and R2 in 3GPP SA2 | 104d? | 2008-01-14 A | 2008-06-05 A | 100% | 2008-01-14 | 2008-06-05 | 104d? | finish no earlier than 2008-06-20 | S2 | 832h | 832h | IMS_Comm_Doc | PCG-21 | Rel-8 | SP-38 | Maurice | Nokia Siemens Networks | jozsef.varga@nsn.com |
| 583 | 195.4 | Maintenance of TISPAN release 1 common IMS | 114d? | 2007-07-02 A | 2007-12-06 A | 100% | 2007-07-02 | 2007-12-06 | 114d? | finish no earlier than 2007-12-06 | S2,S1 | 912h | 912h | IMS_Comm_Mtce7 | PCG-21 | Rel-7 | SP-38 | Maurice | BT, Ericsson | Dick Knight, Raymond Forbes |
| 584 | 195.5 | Maintenance of TISPAN release 2 common IMS | 114d? | 2007-07-02 A | 2007-12-06 A | 100% | 2007-07-02 | 2007-12-06 | 114d? | finish no earlier than 2007-12-06 | S2 | 912h | 912h | IMS_Comm_Mtce8 | PCG-21 | Rel-8 | SP-38 | Maurice | Telecom Italia | antonio.ascolese@telecomitalia.it |
| 585 | 196 | **IMS Service Continuity** | 318d? | 2008-03-12 A | 2009-05-29 A | 100% | 2008-03-12 | 2009-05-29 | 318d? |  | S2,S1,C1 | 5624h | 5624h | IMS-Cont | PCG-21 | Rel-8 | SP-39 | Maurice | LG Electronics | JaeSeung SONG (anthonys@lge.com) |
| 586 | 196.1 | Stage 1 IMS Service Continuity | 62d? | 2008-03-12 A | 2008-06-05 A | 100% | 2008-03-12 | 2008-06-05 | 62d? | start no earlier than 2008-03-12 | S1 | 496h | 496h | IMS-Cont | PCG-21 | Rel-8 | SP-39 | Alain | LG Electronics | JaeSeung SONG (anthonys@lge.com) |
| 587 | 196.2 | Stage 2 IMS Service Continuity | 62d? | 2008-03-12 A | 2008-06-05 A | 100% | 2008-03-12 | 2008-06-05 | 62d? | finish no earlier than 2008-06-05 | S2 | 496h | 496h | IMS-Cont | PCG-21 | Rel-8 | SP-39 | Maurice | LG Electronics | JaeSeung SONG (anthonys@lge.com) |
| 588 | 196.3 | Stage 3 IMS Service Continuity | 261d? | 2008-05-30 A | 2009-05-29 A | 100% | 2008-05-30 | 2009-05-29 | 261d? | finish no earlier than 2009-05-29 | C1 | 2088h | 2088h | IMS-Cont | PCG-21 | Rel-8 | CP-40 | Frederic | Huawei | Lili Yang (kadyyang@huawei.com) |
| 589 | 197 | **Security Enhancements for IMS** | 643.3d? | 2006-09-19 A | 2009-03-06 A | 100% | 2006-09-19 | 2009-03-06 | 643.3d? |  | S3,C1,C4 | 18624h | 18624h | IMS-Sec |  | Rel-8 | SP-37 | Dionisio | Ericsson | Bengt.Sahlin@ericsson.com |
| 590 | 197.1 | Stage 2 for IMS-Sec | 466d? | 2007-03-01 A | 2008-12-11 A | 100% | 2007-03-01 | 2008-12-11 | 466d? | finish no earlier than 2008-12-11 | S3 | 3728h | 3728h | IMS-Sec |  | Rel-8 |  | Dionisio | Ericsson | Bengt.Sahlin@ericsson.com |
| 591 | 197.2 | CT1 part of Stage 3 for IMS-Sec | 392d? | 2006-09-19 A | 2008-12-05 A | 100% | 2006-09-19 | 2008-12-05 | 392d? | finish no earlier than 2008-12-05 | C1 | 3136h | 3136h | IMS-Sec | PCG-21 | Rel-8 | CP-39 | Frederic | Ericsson |  |
| 592 | 197.3 | CT4 part of Stage 3 for IMS-Sec | 457d? | 2007-06-07 A | 2009-03-06 A | 100% | 2007-06-07 | 2009-03-06 | 457d? | finish no earlier than 2009-03-06 | C4 | 3656h | 3656h | IMS-Sec | PCG-21 | Rel-8 | CP-39 | Kimmo | Ericsson |  |
| 593 | 197.4 | CT1 part of NASS Bundled Authentication | 343d? | 2007-11-14 A | 2009-03-06 A | 100% | 2007-11-14 | 2009-03-06 | 343d? | finish no earlier than 2009-03-06 | C1 | 2744h | 2744h | NBA | PCG-21 | Rel-8 | CP-39 | Frederic | Alcatel-Lucent | Keith Drage (drage@alcatel-lucent.com) |
| 594 | 197.5 | CT4 part of NASS Bundled Authentication | 143d? | 2007-11-14 A | 2008-05-30 A | 100% | 2007-11-14 | 2008-05-30 | 143d? | start no earlier than 2007-11-14 | C4 | 1144h | 1144h | NBA-CT4 | PCG-21 | Rel-8 | CP-39 | Kimmo | Alcatel-Lucent |  |
| 595 | 198 | IMS initiated and controlled PSS and MBMS User Service | 262d? | 2008-03-12 A | 2009-03-12 A | 100% | 2008-03-12 | 2009-03-12 | 262d? | finish no earlier than 2009-03-12 | S4,S3 | 1003.2h | 1003.2h | IMS_PSS_MBMS_US |  | Rel-8 |  | Paolo | FT, Ericsson | olle.franceschi@ericsson.com |
| 596 | 199 | **Multimedia interworking between IMS and CS networks** | 836d? | 2005-09-23 A | 2008-12-05 A | 100% | 2005-09-23 | 2008-12-05 | 836d? |  | C3,C4 | 16112h | 16112h | MIW-IMS |  | Rel-8 |  | Gwiho | Vodafone | nico.gabriele@vodafone.com |
| 597 | 199.1 | Note: Stages 1 and 2 defined in earlier Release | 49d? | 2005-09-23 A | 2005-11-30 A | 100% | 2005-09-23 | 2005-11-30 | 49d? | start no earlier than 2005-09-23 | S2 | 392h | 392h | MIW-IMS |  | Rel-8 |  | Maurice | Vodafone | nico.gabriele@vodafone.com |
| 598 | 199.2 | Stage 3 of MW-IMS | 571d? | 2005-09-23 A | 2007-11-30 A | 100% | 2005-09-23 | 2007-11-30 | 571d? | finish no earlier than 2007-09-14 | C3 | 4568h | 4568h | MIW-IMS-St3 |  | Rel-8 |  | Gwiho | Vodafone | nico.gabriele@vodafone.com |
| 599 | 199.3 | Stage 3 for MW-IMS, MONA extension | 285d? | 2007-11-05 A | 2008-12-05 A | 100% | 2007-11-05 | 2008-12-05 | 285d? | finish no earlier than 2008-12-05 | C3 | 2280h | 2280h | MIW-IMS | PCG-21 | Rel-8 | CP-38 | Gwiho | Vodafone | Christer.Holmberg@ericsson.com |
| 600 | 199.4 | Mn interface (MGCF – IM MGW) | 273d? | 2007-11-21 A | 2008-12-05 A | 100% | 2007-11-21 | 2008-12-05 | 273d? | finish no earlier than 2008-12-19 | C4 | 2184h | 2184h | MIW-IMS | PCG-21 | Rel-8 | CP-38 | Kimmo | Vodafone | Christer.Holmberg@ericsson.com |
| 601 | 200 | IMS Stage 3 IETF Protocol Alignment | 446d? | 2007-06-22 A | 2009-03-06 A | 100% | 2007-06-22 | 2009-03-06 | 446d? | finish no earlier than 2009-03-06 | C1 | 3568h | 3568h | IMSProtoc2 |  | Rel-8 |  | Frederic | Alcatel-Lucent | Keith Drage (drage@alcatel-lucent.com) |
| 602 | 201 | **Interworking between User-to-User Signalling (UUS) and SIP** | 335d? | 2007-11-30 A | 2009-03-12 A | 100% | 2007-11-30 | 2009-03-12 | 335d? |  | C1,C3 | 7488h | 7488h | UUSIW | PCG-21 | Rel-8 | CP-38 | Kimmo | Huawei | Lili Yang (kadyyang@huawei.com) |
| 603 | 201.1 | Stage 3 MGCF UUSIW | 266d? | 2007-11-30 A | 2008-12-05 A | 100% | 2007-11-30 | 2008-12-05 | 266d? | finish no earlier than 2008-12-05 | C1 | 2128h | 2128h | UUSIW | PCG-21 | Rel-8 | CP-38 | Frederic | Huawei | Lili Yang (kadyyang@huawei.com) |
| 604 | 201.2 | Stage 3 MGCF UUSIW | 335d? | 2007-11-30 A | 2009-03-12 A | 100% | 2007-11-30 | 2009-03-12 | 335d? | finish no earlier than 2009-03-12 | C3 | 2680h | 2680h | UUSIW | PCG-21 | Rel-8 | CP-38 | Gwiho | Huawei | Lili Yang (kadyyang@huawei.com) |

Notes:
- 579: SP#40 completed
- 580: CP#39 completed / Text3: 24.404, 24.405, 24.406, 24.407, 24.408, 24.410, 24.411, 24.416, 29.421, 24.423, 24.428, 24.429, 29.433, 24.441, 24.403, 29.427, 24.430, 29.412
- 581: CP#39 completed. CP#46 withdrawn 29.624 from Rel-9 onwards / Text3: 24.406, 24.407, 24.410, 24.411, 24.423, 24.430, 24.447, 24.451, 24.454, 24.503, 24.505, 24.508, 24.516, 24.528, 24.529, 29.412, 29.421, 29.433, 29.458, 29.527, 29.624
- 582: WID approved SP#38. per OPs & ETSI GA 39. This is a joint effort of SA WG2 and TISPAN WG2. SP#40 completed / Text3: 23.228, 23.204, 23.167
- 583: SP#38 WID and TSs approved. SP#40 WID updated SP-070915=>SP-080315. SP#41 WID updated SP-080315=>SP-080501 / Text3: 22.273, 22.401, 23.406, 23.417, 23.508, 23.509, 23.511, 22.401, 22.173
- 584: SP#38 approved WID and TSs / Text3: 23.506, 23.507,23.517, 23.521
- 585: CP#44 completed. SP#40 Stage 1/2 completed
- 586: SP#40 completed
- 587: SP#40 completed / Text3: 23.237, 23.292
- 588: CP#44 completed / Text3: 24.237, 24.229, 24.216
- 589: CP#43 completed. SP#36 WID approved
- 590: SP#42 completed. SP#46 withdrawn draft 33.178-100 and 33.978 from Rel-8 onwards / Text3: 33.203, 33.141, 33.803
- 591: CP#42 completed
- 592: CP#43 completed
- 593: CP#43 completed / Text3: 24.229
- 594: CP#40 completed / Text3: 29.229, 29.228, 23.008
- 595: SP#43 completed. SP#39 WID approved / Text3: 26.237, 26.234, 26.346, 33.246
- 596: CP#42 completed
- 597: SP#31 Moved from FS section Feb 2006
- 598: Moved from R7 WP because it is part of Feature UID_713024. This feature was extended to R8 by the inclusion (at Nov 2007 CT3 meeting) of Stage 3 covering MONA (WI 380021) / Text3: 29.863, 29.163
- 599: CP#42 completed / Text3: 29.863, 29.163
- 600: CP#42 completed / Text3: 29.332
- 601: CP#43 completed / Text3: 23.218, 24.229, 24.930
- 602: CP#43 completed
- 603: CP#42 completed / Text3: 24.279, 24.229
- 604: Depending on IETF draft. CP#43 completed / Text3: 29.163

| ID | WBS | Task | Type | Duration | Start | Finish | Complete | Remaining | Baseline start | Baseline finish | Baseline duration | Total slack | Constraint | Resources | Work | Actual work | Text1 | Text2 | Text4 | Text5 | Text6 | Text7 | Text8 | Text3 | Text11 |
| --- | --- | --- | --- | --- | --- | --- | --- | --- | --- | --- | --- | --- | --- | --- | --- | --- | --- | --- | --- | --- | --- | --- | --- | --- | --- |
| 605 | 202 | **Support of Overlap signalling** |  | 331d? | 2007-11-30 A | 2009-03-06 A | 100% |  | 2007-11-30 | 2009-03-06 | 331d? |  |  | C3,C1,C4 | 10008.2h | 10008.2h | Overlap | PCG-21 | Deutsche Telekom | r.jesske@telekom.de | Rel-8 | CP-38 | Gwiho |  |  |
| 606 | 202.1 | Stage 3 Overlap (CT1) |  | 331d? | 2007-11-30 A | 2009-03-06 A | 100% |  | 2007-11-30 | 2009-03-06 | 331d? |  | finish no earlier than 2009-03-06 | C1 | 2648h | 2648h | Overlap | PCG-21 | Deutsche Telekom | r.jesske@telekom.de | Rel-8 | CP-38 | Frederic | 24.229 |  |
| 607 | 202.2 | Stage 3 Overlap (CT3) |  | 331d? | 2007-11-30 A | 2009-03-06 A | 100% |  | 2007-11-30 | 2009-03-06 | 331d? |  | finish no earlier than 2009-03-06 | C3 | 2648h | 2648h | Overlap | PCG-21 | Deutsche Telekom | r.jesske@telekom.de | Rel-8 | CP-38 | Gwiho | 29.163 |  |
| 608 | 202.3 | Stage 3 Overlap (CT4) |  | 258.02d? | 2007-11-30 A | 2008-12-05 A | 100% |  | 2007-11-30 | 2008-12-05 | 258.02d? |  | start no earlier than 2007-11-30 | C4 | 2064.16h | 2064.16h | Overlap | PCG-21 | Deutsche Telekom | r.jesske@telekom.de | Rel-8 | CP-38 | Kimmo | 29.228, 29.229 |  |
| 609 | 203 | AS/MRFC Stage 2 and 3 |  | 278d? | 2007-11-14 A | 2008-12-05 A | 100% |  | 2007-11-14 | 2008-12-05 | 278d? |  | finish no earlier than 2008-12-05 | C1 | 2224h | 2224h | MRFC_TS | PCG-21 | HP | mark.syrett@hp.com | Rel-8 | CP-38 | Frederic | 23.218, 24.229, 24.147, 24.247 |  |
| 610 | 204 | **IMS Restoration Procedures** |  | 201d? | 2008-05-30 A | 2009-03-06 A | 100% |  | 2008-05-30 | 2009-03-06 | 201d? |  |  | C4,C1 | 4824h | 4824h | IMS_RP | PCG-21 | Ericsson | german.blanco@ericsson.com | Rel-8 | SP-40 | Kimmo |  |  |
| 611 | 204.1 | IMS Restoration Procedures |  | 201d? | 2008-05-30 A | 2009-03-06 A | 100% |  | 2008-05-30 | 2009-03-06 | 201d? |  | finish no earlier than 2009-03-06 | C4 | 1608h | 1608h | IMS_RP | PCG-21 | Ericsson | german.blanco@ericsson.com | Rel-8 | SP-40 | Kimmo | 23.380, 29.228, 29.229, 29.230, 23.008 |  |
| 612 | 204.2 | IMS Restoration Procedures |  | 201d? | 2008-05-30 A | 2009-03-06 A | 100% |  | 2008-05-30 | 2009-03-06 | 201d? |  | finish no earlier than 2009-03-06 | C1 | 1608h | 1608h | IMS_RP | PCG-21 | Ericsson | german.blanco@ericsson.com | Rel-8 | SP-40 | Frederic | 24.229 |  |
| 613 | 205 | IMS Application Server Service Data Descriptions for AS interoperability |  | 125d? | 2008-09-12 A | 2009-03-06 A | 100% |  | 2008-09-12 | 2009-03-06 | 125d? |  | finish no earlier than 2009-03-06 | C4 | 1000h | 1000h | IMS_ASIO | PCG-21 | Alcatel-Lucent | nhberry@alcatel-lucent.com | Rel-8 | CP-41 | Kimmo | 29.328, 29.329, 29.364 |  |
| 614 | 206 | **I-WLAN Network Selection Principle (NSP)** |  | 451d? | 2007-06-14 A | 2009-03-06 A | 100% |  | 2007-06-14 | 2009-03-06 | 451d? |  |  | S1,C1,C6 | 6643.2h | 6643.2h | IWLANNSP |  | Telefonica O2 | chris.friel@o2.com | Rel-8 |  | Alain |  |  |
| 615 | 206.1 | Stage 1 for I-WLAN NSP | milestone | 0d? | 2007-06-14 A | 2007-06-14 A | 100% |  | 2007-06-14 | 2007-06-14 | 0d? |  |  | S1 |  |  | IWLANNSP | PCG-21 | Telefonica O2 | chris.friel@o2.com | Rel-8 | SP-39 | Alain | 22.234 |  |
| 616 | 206.2 | Stage 3 for I-WLAN NSP |  | 261d? | 2008-03-07 A | 2009-03-06 A | 100% |  | 2008-03-07 | 2009-03-06 | 261d? |  | finish no earlier than 2008-12-05 | C1 | 2088h | 2088h | IWLANNSP | PCG-21 | RIM | Adrian Buckley (abuckley@rim.com) | Rel-8 | CP-39 | Frederic | 24.234 |  |
| 617 | 206.3 | Stage 3 for I-WLAN NSP |  | 118.4d? | 2008-03-07 A | 2008-12-11 A | 100% |  | 2008-03-07 | 2008-12-11 | 118.4d? |  | finish no earlier than 2008-12-11 | C6 | 947.2h | 947.2h | IWLANNSP | PCG-21 | RIM | Adrian Buckley (abuckley@rim.com) | Rel-8 | CP-39 | Xavier | 31.102, 31.111 |  |
| 618 | 207 | **Mobility between 3GPP-WLAN Interworking and 3GPP Systems** |  | 386d? | 2007-09-14 A | 2009-03-06 A | 100% |  | 2007-09-14 | 2009-03-06 | 386d? |  |  | S2,C1 | 6216h | 6216h | IWLAN_Mob |  | Orange | xiaobao.chen@orange-ftgroup.com | Rel-8 | SP-37 | Maurice |  |  |
| 619 | 207.1 | Stage 2: I-WLAN Mobility |  | 190d? | 2007-09-14 A | 2008-06-05 A | 100% |  | 2007-09-14 | 2008-06-05 | 190d? |  | finish no earlier than 2008-09-08 | S2 | 1520h | 1520h | IWLAN_Mob | PCG-21 | Orange | xiaobao.chen@orange-ftgroup.com | Rel-8 | SP-38 | Maurice | 23.327 |  |
| 620 | 207.2 | CT1 aspects of I-WLAN Mobility |  | 201d? | 2008-05-30 A | 2009-03-06 A | 100% |  | 2008-05-30 | 2009-03-06 | 201d? |  | finish no earlier than 2009-03-06 | C1 | 1608h | 1608h | IWLAN_Mob | PCG-21 | Orange | reina.nader@orange-ftgroup.com | Rel-8 | CP-40 | Frederic | 24.327, 24.303 |  |
| 621 | 208 | Conformance Test Aspects – Mobility between 3GPP WLAN Interworking and 3GPP Systems |  | 131d? | 2009-12-04 A | 2010-06-04 | 60% | 52.4d? | 2009-12-04 | 2010-06-04 | 131d? | 335d | finish no earlier than 2010-06-04 | R5 | 1048h | 628.8h | IWLAN_Mob_UEConTest | PCG-24 | Qualcomm | Patrick Stupar (pstupar@qualcomm.com) | Rel-8 | RP-46 | Ingbert | 34.108, 34.123-1, 34.123-2, 34.123-3 | RP-100078 |
| 622 | 209 | **Enhancements for VGCS Applications (EVA)** |  | 919d? | 2006-03-15 A | 2009-09-18 A | 100% |  | 2006-03-15 | 2009-09-18 | 919d? |  |  | S1,C1,C4,G2 | 23503.5h | 23503.5h | EVA |  | Nortel | Amar Deol (deola@nortelnetworks.com) | Rel-8 |  | Alain |  |  |
| 623 | 209.1 | SA1 aspects of EVA |  | 191d? | 2006-03-15 A | 2006-12-06 A | 100% |  | 2006-03-15 | 2006-12-06 | 191d? |  | finish no earlier than 2006-12-06 | S1 | 1528h | 1528h | EVA |  | Nortel | Amar Deol (deola@nortelnetworks.com) | Rel-8 |  | Alain | 42.068 |  |
| 624 | 209.2 | VGCS/VBS and GPRS Interactions |  | 145d? | 2007-09-03 A | 2008-03-21 A | 100% |  | 2007-09-03 | 2008-03-21 | 145d? |  | finish no earlier than 2008-03-21 | S1 | 1160h | 1160h | EVA |  | Huawei | Ling Liu | Rel-8 | SP-37 | Alain | 42.068, 42.069 |  |
| 625 | 209.3 | CT1 aspects of EVA |  | 862d? | 2006-06-02 A | 2009-09-18 A | 100% |  | 2006-06-02 | 2009-09-18 | 862d? |  | finish no earlier than 2009-12-04 | C1 | 6887.53h | 6887.53h | EVA |  | Nortel | milanpa@nortel.com | Rel-8 |  | Frederic | 43.068, 44.068 |  |
| 626 | 209.4 | CT4 aspects of EVA |  | 391d? | 2006-06-02 A | 2007-11-30 A | 100% |  | 2006-06-02 | 2007-11-30 | 391d? |  | finish no earlier than 2007-06-01 | C4 | 3128h | 3128h | EVA |  | Nortel |  | Rel-8 |  | Kimmo | 29.002 |  |
| 627 | 209.5 | GERAN2 aspects of EVA |  | 431d? | 2006-06-30 A | 2008-02-22 A | 100% |  | 2006-06-30 | 2008-02-22 | 431d? |  | finish no earlier than 2008-02-22 | G2 | 3448h | 3448h | EVA |  | Nortel | frank.billenkamp@nortel.com | Rel-8 |  | Gert | 44.018, 48.008 |  |
| 628 | 210 | **Personal Network Management** |  | 955d? | 2005-07-11 A | 2009-03-06 A | 100% |  | 2005-07-11 | 2009-03-06 | 955d? |  |  | S1,C1,S3 | 27008h | 27008h | PNM |  | Vodafone | armin.toepfer@vodafone.com | Rel-8 |  | Alain |  |  |
| 629 | 210.1 | Stage 1 for PNM |  | 276d? | 2005-07-11 A | 2006-07-31 A | 100% |  | 2005-07-11 | 2006-07-31 | 276d? |  | start no earlier than 2005-07-11 | S1 | 2208h | 2208h | PNM |  | Vodafone | armin.toepfer@vodafone.com | Rel-8 |  | Alain | 22.259 |  |
| 630 | 210.2 | Stage 2 for PNM |  | 445d? | 2007-03-26 A | 2008-12-05 A | 100% |  | 2007-03-26 | 2008-12-05 | 445d? |  | finish no earlier than 2008-12-05 | C1 | 3560h | 3560h | PNM |  | Vodafone | yang.lu@vodafone.com | Rel-8 |  | Frederic | 23.259 |  |

Notes:
- 605: CP#43 completed
- 606: CP#43 completed
- 607: CP#43 completed
- 608: CP#42 completed
- 609: CP#42 completed. Triggered by Study UID_7048 (MRFC)
- 610: CP#43 completed. CP#41 WID updated CP-080281=>CP-080447. Triggered by Study TR 23.820 (FS_IMS_RP) UID_350018
- 611: CP#43 completed
- 612: CP#43 completed
- 613: CP#43 completed. Triggered by UID_360030 (FS_IMS_ASIO)
- 614: CP#43 completed. SP#36 Stage 1 completed
- 615: SP#36 completed
- 616: CP#43 completed
- 617: CP#42 completed
- 618: CP#43 completed. SP#40 Stage 2 completed
- 619: SP#40 completed
- 620: CP#43 completed
- 621: Testing for Rel-8 UID_400013 CT1 aspects of mobility between 3GPP WLAN Interworking and 3GPP Systems (24.327)
- 622: CP#45 completed (Voice Group Call Service)
- 623: SP#38 completed
- 624: SP#39 completed
- 625: CP#45 completed. CT1 will not do more but SA1 may remove the requirement not solved by CT1
- 626: CP#38 completed
- 627: GP#37 completed
- 628: CP#43 completed. Feb 06 moved FS=>Feature. SP#31 Stage 1 completed. SP#40 WID updated with reduced scope SP-060574=>SP-080327
- 629: SP#31 completed. SP#40 WID updated SP-060574=>SP-080327
- 630: CP#42 completed

| ID | WBS | Task | Type | Duration | Start | Finish | Complete | Remaining | Baseline start | Baseline finish | Baseline duration | Total slack | Constraint | Resources | Work | Actual work | Text1 | Text4 | Text5 | Text6 | Text8 | Text3 | Text12 | Text7 | Text2 | Text11 |
| --- | --- | --- | --- | --- | --- | --- | --- | --- | --- | --- | --- | --- | --- | --- | --- | --- | --- | --- | --- | --- | --- | --- | --- | --- | --- | --- |
| 631 | 210.3 | **Stage 3 for PNM** |  | 510d? | 2007-03-26 A | 2009-03-06 A | 100% |  | 2007-03-26 | 2009-03-06 | 510d? |  |  | C1,C4 | 11720h | 11720h | PNM | Vodafone | yang.lu@vodafone.com | Rel-8 | Frederic |  |  |  |  |  |
| 632 | 210.3.1 | CT1 aspects of Stage 3 PNM |  | 510d? | 2007-03-26 A | 2009-03-06 A | 100% |  | 2007-03-26 | 2009-03-06 | 510d? |  | finish no earlier than 2008-12-05 | C1 | 4080h | 4080h | PNM | Vodafone | yang.lu@vodafone.com | Rel-8 | Frederic | 24.259, 24.229 |  |  |  |  |
| 633 | 210.3.2 | CT4 aspects of Stage 3 PNM |  | 445d? | 2007-03-26 A | 2008-12-05 A | 100% |  | 2007-03-26 | 2008-12-05 | 445d? |  | finish no earlier than 2008-12-11 | C4 | 3560h | 3560h | PNM | Vodafone | yang.lu@vodafone.com | Rel-8 | Kimmo |  |  |  |  |  |
| 634 | 210.4 | Key establishment between a UICC hosting device and a remote device |  | 235d? | 2006-12-06 A | 2007-10-30 A | 100% |  | 2006-12-06 | 2007-10-30 | 235d? |  | finish no earlier than 2007-10-30 | S3 | 1880h | 1880h | PNM | Ericsson | Vesa.Lehtovirta@ericsson.com | Rel-8 | Dionisio | 33.259 |  |  |  |  |
| 635 | 210.5 | Deleted - Actual Requirements of PNM | milestone | 0d? | 2007-03-26 A | 2007-03-26 A | 100% |  | 2007-03-26 | 2007-03-26 | 0d? |  | finish no earlier than 2007-03-26 | C1 |  |  | PNM | Ericsson |  | Rel-8 | Frederic |  | SP-37 |  |  |  |
| 636 | 211 | **eCall Data Transfer** |  | 637d? | 2006-09-28 A | 2009-03-06 A | 100% |  | 2006-09-28 | 2009-03-06 | 637d? |  |  | S1,C1 | 9744h | 9744h | EData | Airbiquity | rrobinson@airbiquity.com | Rel-8 | Alain |  |  |  |  |  |
| 637 | 211.1 | eData Requirements |  | 380d? | 2006-09-28 A | 2008-03-12 A | 100% |  | 2006-09-28 | 2008-03-12 | 380d? |  | finish no earlier than 2006-12-07 | S1 | 3040h | 3040h | EData | Airbiquity | rrobinson@airbiquity.com | Rel-8 | Alain | 22.101, 22.105 |  | SP-37 |  |  |
| 638 | 211.2 | Transfer of data during an emergency call |  | 201d? | 2008-05-30 A | 2009-03-06 A | 100% |  | 2008-05-30 | 2009-03-06 | 201d? |  | finish no earlier than 2009-03-06 | C1 | 1608h | 1608h | EData | T-Mobile | Dieter Jacobsohn | Rel-8 | Frederic | 24.008 |  | SP-40 | PCG-21 |  |
| 639 | 212 | eCall data transfer Phase 2: Comparison of alternative in-band modem solutions and standardization of one in-band modem solution |  | 472d? | 2007-12-06 A | 2009-09-24 A | 100% |  | 2007-12-06 | 2009-09-24 | 472d? |  | finish no earlier than 2009-09-24 | S4 | 3768.09h | 3768.09h | eCall_Phase2 | Airbiquity | lhong@airbiquity.com & rrobinson@airbiquity.com | Rel-8 | Paolo | 26.267, 26.268, 26.269, 26.967, 26.969 |  |  |  |  |
| 640 | 213 | eCall Conformance Testing |  | 181d? | 2009-09-04 A | 2010-05-14 | 90% | 18.1d? | 2009-09-04 | 2010-05-14 | 181d? | 350d | finish no earlier than 2010-05-14 | G3new | 1448h | 1303.2h | eCall_MSTest | Ericsson, Qualcomm | Vikrant Jain (vikrantj@qualcomm.com) | Rel-8 | Ingbert | 51.010-1, 51.010-2 |  | GP-45 | PCG-23 |  |
| 641 | 214 | Conformance Test Aspects – non-modem procedures of eCall sessions in UTRA |  | 186d? | 2009-09-18 A | 2010-06-04 | 80% | 37.2d? | 2009-09-18 | 2010-06-04 | 186d? | 335d | finish no earlier than 2010-06-04 | R5 | 1488h | 1190.4h | UMTS_eCall_UEConTest | Ericsson, Qualcomm | Shubhang Vora (svora@qualcomm.com) | Rel-8 | Ingbert | 34.108, 34.123-1, 34.123-2, 34.123-3 |  | RP-45 | PCG-23 | RP-100074 |
| 642 | 215 | **IP Interconnection of Services** |  | 668d? | 2006-08-16 A | 2009-03-06 A | 100% |  | 2006-08-16 | 2009-03-06 | 668d? |  |  | S1,S2,S5,C3 | 17520h | 17520h | IPinterc | Telefonica O2 | chris.friel@O2.com | Rel-8 | Alain |  |  | SP-38 | PCG-21 |  |
| 643 | 215.1 | Stage 1 for IPinterc |  | 70d? | 2007-12-06 A | 2008-03-12 A | 100% |  | 2007-12-06 | 2008-03-12 | 70d? |  | start no earlier than 2007-12-06 | S1 | 560h | 560h | IPinterc | Telefonica O2 | chris.friel@O2.com | Rel-8 | Alain | 22.101, 22.228 |  | SP-38 | PCG-21 |  |
| 644 | 215.2 | **System enhancements for interconnection interfaces between two IMSs** |  | 668d? | 2006-08-16 A | 2009-03-06 A | 100% |  | 2006-08-16 | 2009-03-06 | 668d? |  |  | S2,S5,C3 | 11616h | 11616h | IMS_NNI | Telecom Italia | Mario Madella (mario.madella@telecomitalia.it) | Rel-8 | Maurice |  |  |  |  |  |
| 645 | 215.2.1 | Stage 2 for IMS_NNI |  | 120d? | 2007-06-22 A | 2007-12-06 A | 100% |  | 2007-06-22 | 2007-12-06 | 120d? |  | finish no earlier than 2007-12-21 | S2 | 960h | 960h | IMS_NNI | Telecom Italia | Mario Madella (mario.madella@telecomitalia.it) | Rel-8 | Maurice | 23.002, 23.228 |  |  |  |  |
| 646 | 215.2.2 | IMS inter-operator service interconnection interface |  | 461d? | 2007-06-01 A | 2009-03-06 A | 100% |  | 2007-06-01 | 2009-03-06 | 461d? |  | finish no earlier than 2009-03-06 | C3 | 3688h | 3688h | FBI2-IOPSI | Telecom Italia | antonio.ascolese@telecomitalia.it | Rel-8 | Gwiho | 29.865, 29.165 |  |  |  |  |
| 647 | 215.2.3 | Charging harmonization for NGN between 3GPP and ATIS-TMOC |  | 51d? | 2006-09-28 A | 2006-12-07 A | 100% |  | 2006-09-28 | 2006-12-07 | 51d? |  | finish no earlier than 2006-12-07 | S5 | 408h | 408h | FBI2-TISP2-CH | Amdocs | Brown, Yishai | Rel-8 | Dionisio | 32.297 |  |  |  |  |
| 648 | 215.2.4 | Deleted - Protocol impact of FBI for TISPAN R2 |  | 152d? | 2006-08-16 A | 2007-03-15 A | 100% |  | 2006-08-16 | 2007-03-15 | 152d? |  | finish no earlier than 2007-03-15 | C1 | 1216h | 1216h | FBI2-TISP2-c1 | Ericsson |  | Rel-8 | Frederic |  | SP-38 |  |  |  |
| 649 | 215.2.5 | Deleted (never approved) - Stage 2 of FBI for TISPAN R2 - Rel 8 | milestone | 0d? | 2007-11-30 A | 2007-11-30 A | 100% |  | 2007-11-30 | 2007-11-30 | 0d? |  | finish no earlier than 2007-11-30 | S2 |  |  | FBI2-TISP2-s2 | Nokia Siemens Networks |  | Rel-8 | Maurice |  | SP-36 |  |  |  |
| 650 | 216 | **Support of (G)MSC-S – (G)MSC-S Nc Interface based on the SIP-I protocol** |  | 386d? | 2007-09-14 A | 2009-03-06 A | 100% |  | 2007-09-14 | 2009-03-06 | 386d? |  |  | C4,C3 | 11872h | 11872h | SIP_Nc | Vodafone | David.Hutton@vodafone.com | Rel-8 | Kimmo |  |  |  |  |  |
| 651 | 216.1 | Stage 1 for SIP_Nc (covered by Feature IPinterc) |  | 70d? | 2007-12-06 A | 2008-03-12 A | 100% |  | 2007-12-06 | 2008-03-12 | 70d? |  | start no earlier than 2007-12-06 | S1 | 560h | 560h | IPinterc | Telefonica O2 | chris.friel@O2.com | Rel-8 | Alain | 22.101, 22.228 |  | CP-41 | PCG-21 |  |
| 652 | 216.2 | SIP-I based circuit-switched core network; Stage 2 |  | 321d? | 2007-09-14 A | 2008-12-05 A | 100% |  | 2007-09-14 | 2008-12-05 | 321d? |  | finish no earlier than 2008-12-11 | C4 | 2568h | 2568h | SIP_Nc-St2 | Vodafone | David.Hutton@vodafone.com | Rel-8 | Kimmo | 23.231, 23.153, 23.205 |  |  |  |  |
| 653 | 216.3 | Application of SIP-I Protocols to Circuit Switched (CS) core network architecture; Stage 3 |  | 321d? | 2007-09-14 A | 2008-12-05 A | 100% |  | 2007-09-14 | 2008-12-05 | 321d? |  | finish no earlier than 2008-12-11 | C4 | 2568h | 2568h | SIP_Nc-St3 | Vodafone | David.Hutton@vodafone.com | Rel-8 | Kimmo | 29.231, 29.232, 29.332 |  |  |  |  |
| 654 | 216.4 | Interworking between the 3GPP CS domain with SIP-I as signalling protocol and other networks |  | 386d? | 2007-09-14 A | 2009-03-06 A | 100% |  | 2007-09-14 | 2009-03-06 | 386d? |  | finish no earlier than 2009-03-06 | C3 | 3088h | 3088h | SIP_Nc | Nokia Siemens Networks | Thomas.Belling@nsn.com | Rel-8 | Gwiho | 29.235, 23.172, 23.202, 29.007, 29.163, 29.414 |  |  |  |  |

Notes:
- 631: CP#43 completed. Moved from FS section Feb 06: SP-33: Create new section to capture the PNM stage 2 aspects and identify any impacts to existing stage 2 specifications.
- 632: CP#43 completed
- 633: CP#42 No impact to CT4 specifications
- 634: 07/08: Moved from Rel-7 to Rel-8 WP; Feature=>BB as per SA3/SA WID in SP-060839, keeping the same UID
- 635: SP#37 stopped
- 636: SP#39 completed. Linked to SA4 Feature UID_34042 (eCall_Phase2). CP#40 approved Stage 3 WID.
- 637: SA4 to select a suitable in-band modem. SP#39 completed
- 638: CP#43 completed
- 639: SP#45 completed. TR 26.969 for Approval. Triggered by Study UID_360015 (eCALLIBMS). Linked to SA1 Feature UID_330005 (EData)
- 640: GP#43 WID approved. Testing for Rel-8 eCall_Phase2 (UID_34042) and EData (UID_330005)
- 641: RP#47 completion 03/10=>06/10. Testing for Rel-8 eCall_Phase2 (UID_34042) and Edata (UID_330005)
- 642: SP#43 completed. Covers Stage 1 for IMS_NNI (UID_360024),SIP_Nc (UID_360026),CS-IBCF (UID_400008). SP#41 WID updated SP-070871=>SP-080565 [Moved under it as BBs 2 existing Features: CS-IBCF, IMS_NNI]
- 643: SP#39 completed.
- 644: CP#43 completed. SP#36 Name changed from "System enhancements for TISPAN Rel2". Stage 1 in Feature UID_380060 (IPinterc). CP#41 updated WID CP-080054=>CP-080578 (Feature IMS_NNI=>BB under Ipinterc)
- 645: SP#38 completed. SP#41 WID updated SP-070490=>SP-080554
- 646: CP#43 completed
- 647: SP#34 completed
- 648: SP#38 stopped
- 649: SP#36 stopped
- 650: CP#43 completed. Stage 1 in Feature UID_380060 (IPinterc). CP#40 updated WID CP-070517=>CP-080282
- 651: 22/07/08 Created. Stage 1 for SIP_Nc (covered by SA1 Feature UID_380060 Ipinterc)
- 652: CP#42 completed
- 653: CP#42 completed
- 654: CP#43 completed. CP#42 target 12/08=>03/09

| ID | WBS | Task | Type | Duration | Start | Finish | Complete | Baseline start | Baseline finish | Baseline duration | Constraint | Resources | Work | Actual work | Text1 | Text4 | Text5 | Text6 | Text7 | Text8 | Text3 | Text2 | Text11 | Text9 | Text12 |
| --- | --- | --- | --- | --- | --- | --- | --- | --- | --- | --- | --- | --- | --- | --- | --- | --- | --- | --- | --- | --- | --- | --- | --- | --- | --- |
| 655 | 217 | **Earthquake and Tsunami Warning System** |  | 440d? | 2007-09-10 A | 2009-05-15 A | 100% | 2007-09-10 | 2009-05-15 | 440d? |  | S1,S2,CP,G2 | 6136h | 6136h | ETWS | NTT DoCoMo | kitaharar@nttdocomo.co.jp | Rel-8 | SP-37 | Alain |  |  |  |  |  |
| 656 | 217.1 | Stage 1 for ETWS |  | 133d? | 2007-09-10 A | 2008-03-12 A | 100% | 2007-09-10 | 2008-03-12 | 133d? | finish no earlier than 2008-03-12 | S1 | 1064h | 1064h | ETWS | NTT DoCoMo | kitaharar@nttdocomo.co.jp | Rel-8 | SP-37 | Alain | 22.168 |  |  |  |  |
| 657 | 217.2 | SA2 aspects of ETWS |  | 179d? | 2008-01-14 A | 2008-09-18 A | 100% | 2008-01-14 | 2008-09-18 | 179d? | finish no earlier than 2008-09-08 | S2 | 1432h | 1432h | ETWS | NTT DoCoMo | tanakai@nttdocomo.co.jp | Rel-8 | SP-38 | Maurice | 23.828, 23.401 | PCG-21 |  |  |  |
| 658 | 217.3 | CT1 aspects of ETWS |  | 50.5d? | 2008-05-30 A | 2008-12-05 A | 100% | 2008-05-30 | 2008-12-05 | 50.5d? | finish no earlier than 2008-12-05 | C1 | 404h | 404h | ETWS | NTT DoCoMo | yamashitahi@s1.nttdocomo.co.jp | Rel-8 | CP-40 | Frederic | 23.041 | PCG-21 |  |  |  |
| 659 | 217.4 | CT4 aspects of ETWS |  | 50.5d? | 2008-09-26 A | 2008-12-05 A | 100% | 2008-09-26 | 2008-12-05 | 50.5d? | finish no earlier than 2008-12-05 | C4 | 404h | 404h | ETWS | NTT DoCoMo | yamashitahi@s1.nttdocomo.co.jp | Rel-8 | CP-40 | Kimmo | 29.168 | PCG-21 |  |  |  |
| 660 | 217.5 | ETWS primary notification message definition in GERAN |  | 47d? | 2009-03-12 A | 2009-05-15 A | 100% | 2009-03-12 | 2009-05-15 | 47d? | finish no earlier than 2009-05-15 | G2 | 376h | 376h | ETWS | Ericsson | claes-goran.persson@ericsson.com | Rel-8 | SP-43 | Gert | 44.018, 44.060 | PCG-22 |  |  |  |
| 661 | 218 | Conformance Test Aspects – UMTS Earthquake and Tsunami Warning System (ETWS) FDD |  | 207d? | 2009-05-29 A | 2010-03-12 A | 100% | 2009-05-29 | 2010-03-12 | 207d? | finish no earlier than 2010-03-12 | R5 | 1656h | 1656h | ETWS_UMTS_UEConTestFDD | NTT DoCoMo | Makoto Ito (itohm@nttdocomo.co.jp) | Rel-8 | RP-44 | Ingbert | 34.108, 34.123-1, 34.123-2 | PCG-23 | RP-100068 |  |  |
| 662 | 219 | **In Case of Emergency numbers storage and easy access on UICC** |  | 519d? | 2007-03-13 A | 2009-03-06 A | 100% | 2007-03-13 | 2009-03-06 | 519d? |  | S1,C6 | 8864h | 8864h | ICE | Vodafone | armin.toepfer@vodafone.com | Rel-8 | SP-38 | Alain |  | PCG-21 |  |  |  |
| 663 | 219.1 | Stage 1 for ICE |  | 262d? | 2007-03-13 A | 2008-03-12 A | 100% | 2007-03-13 | 2008-03-12 | 262d? | finish no earlier than 2008-03-12 | S1 | 2096h | 2096h | ICE | Vodafone | armin.toepfer@vodafone.com | Rel-8 | SP-38 | Alain | 22.030, 22.101 | PCG-21 |  |  |  |
| 664 | 219.2 | CT6 aspects of ICE |  | 519d? | 2007-03-13 A | 2009-03-06 A | 100% | 2007-03-13 | 2009-03-06 | 519d? | finish no earlier than 2009-03-06 | C6 | 4152h | 4152h | ICE | Vodafone | armin.toepfer@vodafone.com | Rel-8 | SP-38 | Xavier | 31.102 | PCG-21 |  |  |  |
| 665 | 220 | Local Charging Zone Requirements |  | 380d? | 2006-09-28 A | 2008-03-12 A | 100% | 2006-09-28 | 2008-03-12 | 380d? | finish no earlier than 2006-12-07 | S1 | 3040h | 3040h | LCZR | China Mobile | liuhongyfw@chinamobile.com | Rel-8 |  | Alain | 22.115 |  |  |  |  |
| 666 | 221 | **Customized Alerting Tone (CAT) Service** |  | 729d? | 2006-12-06 A | 2009-09-18 A | 100% | 2006-12-06 | 2009-09-18 | 729d? |  | S1,C1,C3,C4 | 12302h | 12302h | CAT | China Mobile | fenglingjuan@chinamobile.com | Rel-8 |  | Alain |  |  |  |  |  |
| 667 | 221.1 | Stage 1 for CAT |  | 207d? | 2006-12-06 A | 2007-09-20 A | 100% | 2006-12-06 | 2007-09-20 | 207d? | start no earlier than 2006-12-06 | S1 | 1656h | 1656h | CAT | China Mobile | fenglingjuan@chinamobile.com | Rel-8 | SP-37 | Alain | 22.182 |  |  |  |  |
| 668 | 221.2 | TISPAN requirements for customized multimedia information services |  | 71d? | 2007-09-03 A | 2007-12-10 A | 100% | 2007-09-03 | 2007-12-10 | 71d? | finish no earlier than 2007-12-10 | S1 | 568h | 568h | TISCMI | China Mobile | fenglingjuan@chinamobile.com | Rel-8 | SP-37 | Alain | 22.182 |  |  |  |  |
| 669 | 221.3 | IMS CAT Supplementary Service |  | 164d? | 2008-04-21 A | 2008-12-04 A | 100% | 2008-04-21 | 2008-12-04 | 164d? | finish no earlier than 2008-12-05 | C1 | 1312h | 1312h | CAT-SS | Nortel | milanpa@nortel.com | Rel-8 | CP-39 | Frederic | 24.182 | PCG-21 |  |  |  |
| 670 | 221.4 | CAT solution for voice and video call in CS domain |  | 389.8d? | 2008-03-12 A | 2009-09-18 A | 100% | 2008-03-12 | 2009-09-18 | 389.8d? | finish no earlier than 2009-09-11 | C3 | 3118.4h | 3118.4h | CAT-SS | Nortel | milanpa@nortel.com | Rel-8 | CP-39 | Gwiho | 29.163 | PCG-21 |  |  |  |
| 671 | 221.5 | CAT Service in 3GPP CS domain |  | 126d? | 2008-09-12 A | 2009-03-06 A | 100% | 2008-09-12 | 2009-03-06 | 126d? | finish no earlier than 2009-03-06 | C4 | 1008h | 1008h | CAT-3G_CS | China Mobile | zhaoyuyi@chinamobile.com | Rel-8 | CP-41 | Kimmo | 23.205, 23.231, 29.002 | PCG-21 |  |  |  |
| 672 | 221.6 | CAT Service in 3GPP CS domain |  | 57.95d? | 2008-09-12 A | 2008-12-05 A | 100% | 2008-09-12 | 2008-12-05 | 57.95d? | start no earlier than 2008-09-12 | C1 | 463.6h | 463.6h | CAT-3G_CS | China Mobile | zhaoyuyi@chinamobile.com | Rel-8 | CP-41 | Frederic | 24.008, 23.014 | PCG-21 |  |  |  |
| 673 | 222 | **Service-Level Interworking for Messaging Services** |  | 509d? | 2007-03-26 A | 2009-03-06 A | 100% | 2007-03-26 | 2009-03-06 | 509d? |  | S1,S2,C3,C1 | 8584h | 8584h | MESSIW | Huawei | ling.liu@huawei.com; duanxiaoqin@huawei.com | Rel-8 |  | Alain |  |  |  |  |  |
| 674 | 222.1 | Stage 1 for MESSIW | milestone | 0d? | 2007-03-26 A | 2007-03-26 A | 100% | 2007-03-26 | 2007-03-26 | 0d? | finish no earlier than 2007-12-01 | S1 |  |  | MESSIW | Huawei | ling.liu@huawei.com | Rel-8 |  | Alain | 22.105, 22.340 |  |  |  |  |
| 675 | 222.2 | Stage 2 for MESSIW |  | 227d? | 2007-04-26 A | 2008-03-07 A | 100% | 2007-04-26 | 2008-03-07 | 227d? | finish no earlier than 2008-03-07 | S2 | 1816h | 1816h | MESSIW | Huawei | patrice.hede@huawei.com | Rel-8 |  | Maurice | 23.811, 23.204 |  |  |  |  |
| 676 | 222.3 | Stage 3 for MESSIW |  | 201d? | 2008-05-30 A | 2009-03-06 A | 100% | 2008-05-30 | 2009-03-06 | 201d? | finish no earlier than 2008-12-05 | C3 | 1608h | 1608h | MESSIW | Huawei | xupeili@huawei.com | Rel-8 | CP-40 | Gwiho | 29.311 | PCG-21 |  |  |  |
| 677 | 222.4 | Stage 3 for MESSIW |  | 136d? | 2008-05-30 A | 2008-12-05 A | 100% | 2008-05-30 | 2008-12-05 | 136d? | finish no earlier than 2008-12-12 | C1 | 1088h | 1088h | MESSIW | Huawei | xupeili@huawei.com | Rel-8 | CP-40 | Frederic | 24.229 | PCG-21 |  |  |  |
| 678 | 223 | **Multimedia Priority Service** |  | 858d? | 2006-06-08 A | 2009-09-18 A | 100% | 2006-06-08 | 2009-09-18 | 858d? |  | S1,C1,C3,C4 | 22424h | 22424h | PRIOR | Telcordia | jgarraha@telcordia.com | Rel-8 | SP-34 | Alain |  |  |  |  |  |
| 679 | 223.1 | Service Requirements for PRIOR |  | 391d? | 2006-06-08 A | 2007-12-06 A | 100% | 2006-06-08 | 2007-12-06 | 391d? | finish no earlier than 2007-11-30 | S1 | 3128h | 3128h | PRIOR-EMR | Telcordia | jgarraha@telcordia.com | Rel-8 | SP-32 | Alain | 22.153 |  |  |  |  |
| 680 | 223.2 | Stage 3 for PRIOR |  | 732d? | 2006-12-01 A | 2009-09-18 A | 100% | 2006-12-01 | 2009-09-18 | 732d? | finish no earlier than 2009-09-18 | C1 | 5856h | 5856h | PRIOR | Alcatel-Lucent | Keith Drage (drage@alcatel-lucent.com) | Rel-8 | CP-34 | Frederic | 24.229 |  |  |  |  |
| 681 | 223.3 | Deleted - Stage 3 for PRIOR |  | 441d? | 2007-09-21 A | 2009-05-29 A | 100% | 2007-09-21 | 2009-05-29 | 441d? | finish no earlier than 2009-05-29 | C3 | 3528h | 3528h | PRIOR | Alcatel-Lucent | Keith Drage (drage@alcatel-lucent.com) | Rel-8 | CP-37 | Gwiho | 29.212, 29.213, 29.214, 29.163 |  |  | PCG-23 | CP-44 |
| 682 | 223.4 | Stage 3 for PRIOR |  | 381d? | 2007-09-21 A | 2009-03-06 A | 100% | 2007-09-21 | 2009-03-06 | 381d? | finish no earlier than 2009-03-06 | C4 | 3048h | 3048h | PRIOR | Alcatel-Lucent | Keith Drage (drage@alcatel-lucent.com) | Rel-8 | CP-37 | Kimmo | 23.008, 29.228, 29.229 |  |  |  |  |

Notes:
- 655: SP#43 GERAN task included. Larger scope Feature UID_380057 (PWS) moved to Rel-9
- 656: SP#39 completed
- 657: SP#41 completed
- 658: CP#42 completed. WID updated CP-080318=>CP-080659=>CP-080951
- 659: CP#42 completed. WID updated CP-080318=>CP-080659=>CP-080951
- 660: SP#44 completed with CT1 help (GERAN2 LS_in SP-090154)
- 661: RP#47 completed. Testing for Rel-8 ETWS UID_370051
- 662: CP#43 completed (ICE Graphics not included in Rel-8)
- 663: SP#39 Stage 1 completed
- 664: CP#43 completed (ICE Graphics not in Rel-8 / not explicitly in SA1 WID either)
- 665: SP#39 Stage 1 completed
- 666: CP#45 completed
- 667: -
- 668: SP#38 completed
- 669: CP#42 completed. CP#41 WID updated CP-080074=>CP-080496.
- 670: CP#45 completed. CP#44 sent LS to ITU-T (CP-090501) request to specify explicit parameter for CAT signalling and APM container for 3GPP to define the contents. Triggered by Study UID_360031 (FS_CAT_VVC_CS) TR 29.882
- 671: CP#43 completed. Triggered by Study UID_360031 (FS_CAT_VVC_CS) TR 29.882.
- 672: Triggered by Study UID_360031 (FS_CAT_VVC_CS) TR 29.882. CP#42 completed
- 673: CP#43 completed. SP#39 Stage 2 completed
- 674: SP#35 completed
- 675: SP#39 completed
- 676: CP#43 completed
- 677: CP#42 completed. WID updated CP-080391=>CP-080575=>CP-080773
- 678: CP#45 completed. SP#38 Stage 1 completed. No Stage 2 identified
- 679: SP#38 completed
- 680: CP#45 completed
- 681: CP#44 closed (Reason: No Rel-8 solution expected (LS sent to SA2, but not prioritized in SA2)
- 682: CP#43 completed

| ID | WBS | Task | Duration | Start | Finish | Complete | Baseline start | Baseline finish | Baseline duration | Constraint | Resources | Work | Actual work | Text1 | Text4 | Text5 | Text6 | Text8 | Text3 | Text7 | Text2 | Text9 | Text12 |
| --- | --- | --- | --- | --- | --- | --- | --- | --- | --- | --- | --- | --- | --- | --- | --- | --- | --- | --- | --- | --- | --- | --- | --- |
| 683 | 224 | **OSA Rel-8** | 202d? | 2007-08-23 A | 2008-05-30 A | 100% | 2007-08-23 | 2008-05-30 | 202d? |  | S1,C5 | 23552h | 23552h | OSA8 | Orange | Song Dong | Rel-8 | Alain |  |  |  |  |  |
| 684 | 224.1 | OSA Stage 1 - Service Requirements | 145d? | 2007-08-23 A | 2008-03-12 A | 100% | 2007-08-23 | 2008-03-12 | 145d? | finish no earlier than 2007-12-04 | S1 | 1160h | 1160h | OSA8 | Orange, AePONA | Song Dong | Rel-8 | Alain | 22.127 |  |  |  |  |
| 685 | 224.2 | OSA Stage 1 - NGN Service Requirement | 140d? | 2007-09-03 A | 2008-03-14 A | 100% | 2007-09-03 | 2008-03-14 | 140d? | finish no earlier than 2008-03-14 | S1 | 1120h | 1120h | OSA8-IMS | Orange | Song Dong | Rel-8 | Alain | 22.127 | SP-37 |  |  |  |
| 686 | 224.3 | **OSA Stage 2/3 enhancements** | 157d? | 2007-10-25 A | 2008-05-30 A | 100% | 2007-10-25 | 2008-05-30 | 157d? |  | C5 | 20016h | 20016h | OSA8 | Alcatel-Lucent | unmehopa@alcatel-lucent.com | Rel-8 | Kimmo | 23.198, 29.198, 29.199 |  |  |  |  |
| 687 | 224.3.1 | Deleted - Ensure Parlay-X composable with identity management frameworks, in particular Liberty Alliance | 157d? | 2007-10-25 A | 2008-05-30 A | 100% | 2007-10-25 | 2008-05-30 | 157d? | finish no earlier than 2008-12-25 | C5 | 1256h | 1256h | OSA8 | Ericsson, FT/Orange, Sprint, Telecom Italia | catherine.mulligan@ericsson.com | Rel-8 | Kimmo | existing 29.199-xy | CP-37 | PCG-21 | PCG-21 | CP-40 |
| 688 | 224.3.2 | Parlay-X Content Management web service (store/manage meta-data) | 157d? | 2007-10-25 A | 2008-05-30 A | 100% | 2007-10-25 | 2008-05-30 | 157d? | finish no earlier than 2008-12-04 | C5 | 1256h | 1256h | OSA8 | Alcatel-Lucent | unmehopa@alcatel-lucent.com | Rel-8 | Kimmo | 29.199-21 | CP-37 |  |  |  |
| 689 | 224.3.3 | Parlay-X Policy web service | 157d? | 2007-10-25 A | 2008-05-30 A | 100% | 2007-10-25 | 2008-05-30 | 157d? | finish no earlier than 2008-12-04 | C5 | 1256h | 1256h | OSA8 | Alcatel-Lucent | unmehopa@alcatel-lucent.com | Rel-8 | Kimmo | 29.199-22 | CP-37 |  |  |  |
| 690 | 224.3.4 | Parlay-X Terminal status web service | 157d? | 2007-10-25 A | 2008-05-30 A | 100% | 2007-10-25 | 2008-05-30 | 157d? | finish no earlier than 2008-05-30 | C5 | 1256h | 1256h | OSA8 | Alcatel-Lucent | unmehopa@alcatel-lucent.com | Rel-8 | Kimmo | 29.199-08 | CP-37 |  |  |  |
| 691 | 224.3.5 | Deleted - Identify communication format used by a particular application | 157d? | 2007-10-25 A | 2008-05-30 A | 100% | 2007-10-25 | 2008-05-30 | 157d? | finish no earlier than 2008-05-30 | C5 | 1256h | 1256h | OSA8 | Ericsson | catherine.mulligan@ericsson.com | Rel-8 | Kimmo | existing 29.199-xy | CP-37 | PCG-21 | PCG-21 | CP-40 |
| 692 | 224.3.6 | Deleted - Security on User Profile Management - reuse GUP API (22.127 CR 0084 S1-071794) | 128d? | 2007-12-05 A | 2008-05-30 A | 100% | 2007-12-05 | 2008-05-30 | 128d? | finish no earlier than 2008-12-25 | C5 | 1024h | 1024h | OSA8 | Telecom Italia | vincenzo.amorino@telecomitalia.it | Rel-8 | Kimmo | PXWS Framework | CP-38 | PCG-21 | PCG-21 | CP-40 |
| 693 | 224.3.7 | Deleted - Privacy on Subscriber Identity (Liberty Alliance, OASIS) (22.127 CR 0085 S1-071835) | 128d? | 2007-12-05 A | 2008-05-30 A | 100% | 2007-12-05 | 2008-05-30 | 128d? | finish no earlier than 2008-12-25 | C5 | 1024h | 1024h | OSA8 | Telecom Italia | vincenzo.amorino@telecomitalia.it | Rel-8 | Kimmo | PXWS Framework | CP-38 | PCG-21 | PCG-21 | CP-40 |
| 694 | 224.3.8 | Deleted - Topology Hiding (22.127 CR 0086 S1-071838) | 128d? | 2007-12-05 A | 2008-05-30 A | 100% | 2007-12-05 | 2008-05-30 | 128d? | finish no earlier than 2008-12-25 | C5 | 1024h | 1024h | OSA8 | Telecom Italia | vincenzo.amorino@telecomitalia.it | Rel-8 | Kimmo | PXWS Framework | CP-38 | PCG-21 | PCG-21 | CP-40 |
| 695 | 224.3.9 | Deleted - Subscriber event notification (22.127 CR 0087 S1-071836) | 128d? | 2007-12-05 A | 2008-05-30 A | 100% | 2007-12-05 | 2008-05-30 | 128d? | finish no earlier than 2008-12-25 | C5 | 1024h | 1024h | OSA8 | Telecom Italia | vincenzo.amorino@telecomitalia.it | Rel-8 | Kimmo | PXWS Framework | CP-38 | PCG-21 | PCG-21 | CP-40 |
| 696 | 224.3.10 | Deleted - Event notification (22.127 CR 0088 S1-071762) | 128d? | 2007-12-05 A | 2008-05-30 A | 100% | 2007-12-05 | 2008-05-30 | 128d? | finish no earlier than 2008-12-25 | C5 | 1024h | 1024h | OSA8 | Telecom Italia | vincenzo.amorino@telecomitalia.it | Rel-8 | Kimmo | PXWS Framework | CP-38 | PCG-21 | PCG-21 | CP-40 |
| 697 | 224.3.11 | Deleted - Access policy (22.127 CR 0089 S1-071763) | 128d? | 2007-12-05 A | 2008-05-30 A | 100% | 2007-12-05 | 2008-05-30 | 128d? | finish no earlier than 2008-12-25 | C5 | 1024h | 1024h | OSA8 | Telecom Italia | vincenzo.amorino@telecomitalia.it | Rel-8 | Kimmo | PXWS Framework | CP-38 | PCG-21 | PCG-21 | CP-40 |
| 698 | 224.3.12 | Deleted - API usage accounting (22.127 CR 0090 S1-071792) | 128d? | 2007-12-05 A | 2008-05-30 A | 100% | 2007-12-05 | 2008-05-30 | 128d? | finish no earlier than 2008-12-25 | C5 | 1024h | 1024h | OSA8 | Telecom Italia | vincenzo.amorino@telecomitalia.it | Rel-8 | Kimmo | PXWS Framework | CP-38 | PCG-21 | PCG-21 | CP-40 |
| 699 | 224.3.13 | Presence alignment with OMA and IETF (22.127 CR 0092 S1-071764) | 128d? | 2007-12-05 A | 2008-05-30 A | 100% | 2007-12-05 | 2008-05-30 | 128d? | finish no earlier than 2008-05-30 | C5 | 1024h | 1024h | OSA8 | Alcatel-Lucent | unmehopa@alcatel-lucent.com | Rel-8 | Kimmo | 29.199-14/13 | CP-38 | PCG-21 |  |  |
| 700 | 224.3.14 | Deleted - Service identification (22.127 CR 0095 S1-071837) | 128d? | 2007-12-05 A | 2008-05-30 A | 100% | 2007-12-05 | 2008-05-30 | 128d? | finish no earlier than 2008-05-30 | C5 | 1024h | 1024h | OSA8 | Ericsson | catherine.mulligan@ericsson.com | Rel-8 | Kimmo | existing 29.199-xy | CP-38 | PCG-21 | PCG-21 | CP-40 |
| 701 | 224.3.15 | Framework Enterprise Operator (Service Subscription function) | 102d? | 2008-01-10 A | 2008-05-30 A | 100% | 2008-01-10 | 2008-05-30 | 102d? | finish no earlier than 2008-05-30 | C5 | 816h | 816h | OSA8 | Alcatel-Lucent | unmehopa@alcatel-lucent.com | Rel-8 | Kimmo | 29.198-03 | CP-39 | PCG-21 |  |  |
| 702 | 224.3.16 | Mobility Emergency Location | 102d? | 2008-01-10 A | 2008-05-30 A | 100% | 2008-01-10 | 2008-05-30 | 102d? | finish no earlier than 2008-05-30 | C5 | 816h | 816h | OSA8 | Alcatel-Lucent | unmehopa@alcatel-lucent.com | Rel-8 | Kimmo | 29.198-06 | CP-39 | PCG-21 |  |  |
| 703 | 224.3.17 | Connectivity Manager SCF | 102d? | 2008-01-10 A | 2008-05-30 A | 100% | 2008-01-10 | 2008-05-30 | 102d? |  | C5 | 816h | 816h | OSA8 | Alcatel-Lucent | unmehopa@alcatel-lucent.com | Rel-8 | Kimmo | 29.198-10 | CP-39 | PCG-21 |  |  |
| 704 | 224.3.18 | PAM Presence Agent | 102d? | 2008-01-10 A | 2008-05-30 A | 100% | 2008-01-10 | 2008-05-30 | 102d? | finish no earlier than 2008-05-30 | C5 | 816h | 816h | OSA8 | Alcatel-Lucent | unmehopa@alcatel-lucent.com | Rel-8 | Kimmo | 29.198-14 | CP-39 | PCG-21 |  |  |
| 705 | 225 | **Paging Permission with Access Control (PPACR)** | 389d? | 2007-06-12 A | 2008-12-05 A | 100% | 2007-06-12 | 2008-12-05 | 389d? |  | S1,C1 | 5888h | 5888h | PPACR | NTT DoCoMo | Morita Takashi | Rel-8 | Alain |  |  |  |  |  |
| 706 | 225.1 | Stage 1 for PPACR | 69d? | 2007-06-12 A | 2007-09-14 A | 100% | 2007-06-12 | 2007-09-14 | 69d? | finish no earlier than 2007-09-14 | S1 | 552h | 552h | PPACR-S1 | NTT DoCoMo | Morita Takashi | Rel-8 | Alain | 22.011 | SP-37 |  |  |  |
| 707 | 225.2 | Stage 3 for PPACR (CT1) | 278d? | 2007-11-14 A | 2008-12-05 A | 100% | 2007-11-14 | 2008-12-05 | 278d? | finish no earlier than 2008-12-05 | C1 | 2224h | 2224h | PPACR-CT1 | NTT DoCoMo |  | Rel-8 | Frederic | 24.008, 23.122, 24.301 | CP-38 | PCG-21 |  |  |

Notes:
- 683: TSG#40 completed. New OSA work in OMA. SA1 need to remove unfulfilled Requirements to align with CT5 Stage 2/3 reality.
- 684: TSG#40 New OSA work in OMA. SA1 to remove non-fulfilled Requirements.
- 685: TSG#40 New OSA work in OMA. SA1 to remove non-fulfilled Requirements.
- 686: CP#40 WID updated CP-070349=>CP-080252. Started work completed. Unfulfilled Rel-8 Stage 1 and New OSA work to be done in OMA. SA1 needs to remove non-fulfilled requirements in 22.127
- 687: CP#40: Work moved to OMA
- 688: CP#40 completed
- 689: CP#40 completed
- 690: CP#40 completed
- 691: CP#40: Work moved to OMA
- 692: SP#38 SP-070853 R8 CRs 22.127 OSA Stage 1. CP#40: Work moved to OMA
- 693: SP#38 SP-070853 R8 CRs 22.127 OSA Stage 1. CP#40: Work moved to OMA
- 694: SP#38 SP-070853 R8 CRs 22.127 OSA Stage 1. CP#40: Work moved to OMA
- 695: SP#38 SP-070853 R8 CRs 22.127 OSA Stage 1. CP#40: Work moved to OMA
- 696: SP#38 SP-070853 R8 CRs 22.127 OSA Stage 1. CP#40: Work moved to OMA
- 697: SP#38 SP-070853 R8 CRs 22.127 OSA Stage 1. CP#40: Work moved to OMA
- 698: SP#38 SP-070853 R8 CRs 22.127 OSA Stage 1. CP#40: Work moved to OMA
- 699: CP#40 completed
- 700: SP#38 SP-070853 R8 CRs 22.127 OSA Stage 1. CP#40: Work moved to OMA
- 701: CP#40 completed
- 702: CP#40 completed
- 703: CP#40 completed
- 704: CP#40 completed
- 705: CP#42 completed. Triggered by Study UID_330016 (PPAC).
- 706: SP#37 completed
- 707: CP#42 completed

| ID | WBS | Task | Duration | Start | Finish | Complete | Remaining | Baseline start | Baseline finish | Baseline duration | Total slack | Constraint | Resources | Work | Actual work | Text1 | Text2 | Text4 | Text6 | Text7 | Text8 | Text11 |
| --- | --- | --- | --- | --- | --- | --- | --- | --- | --- | --- | --- | --- | --- | --- | --- | --- | --- | --- | --- | --- | --- | --- |
| 708 | 226 | **Charging for multi-phases services** | 70d? | 2007-12-06 A | 2008-03-12 A | 100% |  | 2007-12-06 | 2008-03-12 | 70d? |  |  | S1 | 560h | 560h | CHRGMPH | PCG-21 | Telecom Italia | Rel-8 | SP-38 | Alain |  |
| 709 | 226.1 | Stage 1 for CHRGMPH | 70d? | 2007-12-06 A | 2008-03-12 A | 100% |  | 2007-12-06 | 2008-03-12 | 70d? |  | start no earlier than 2007-12-06 | S1 | 560h | 560h | CHRGMPH-s1 | PCG-21 | Telecom Italia | Rel-8 | SP-38 | Alain |  |
| 710 | 227 | **Home NodeB / eNodeB** | 327d? | 2007-12-06 A | 2009-03-06 A | 100% |  | 2007-12-06 | 2009-03-06 | 327d? |  |  | S1,C1,C4 | 5720h | 5720h | HomeNB | PCG-21 | Vodafone | Rel-8 | SP-38 | Alain |  |
| 711 | 227.1 | Stage 1 for HNB_eHNB | 70d? | 2007-12-06 A | 2008-03-12 A | 100% |  | 2007-12-06 | 2008-03-12 | 70d? |  | start no earlier than 2007-12-06 | S1 | 560h | 560h | HomeNB-S1 | PCG-21 | Vodafone | Rel-8 | SP-38 | Alain |  |
| 712 | 227.2 | CSG and Idle Mode Mobility for LTE Home eNodeB | 126d? | 2008-09-12 A | 2009-03-06 A | 100% |  | 2008-09-12 | 2009-03-06 | 126d? |  | finish no earlier than 2009-03-06 | C1 | 1008h | 1008h | HomeNB-LTE | PCG-21 | Huawei | Rel-8 | CP-41 | Frederic |  |
| 713 | 227.3 | CSG and Idle Mode Mobility for 3G Home NodeB | 126d? | 2008-09-12 A | 2009-03-06 A | 100% |  | 2008-09-12 | 2009-03-06 | 126d? |  | finish no earlier than 2009-03-06 | C1 | 1008h | 1008h | HomeNB-3G | PCG-21 | Qualcomm | Rel-8 | CP-41 | Frederic |  |
| 714 | 227.4 | Support of Closed Subscriber Group (CSG) | 66d? | 2008-12-05 A | 2009-03-06 A | 100% |  | 2008-12-05 | 2009-03-06 | 66d? |  | finish no earlier than 2009-03-06 | C4 | 528h | 528h | HomeNB | PCG-22 | CT#42 | Rel-8 | CP-42 | Kimmo | CT#42 report |
| 715 | 228 | **UTRA HNB** | 326d? | 2008-03-07 A | 2009-06-04 A | 100% |  | 2008-03-07 | 2009-06-04 | 326d? |  |  | RP,S5 | 6832h | 6832h | HNB | PCG-21 |  | Rel-8 | SP-39 | Issam |  |
| 716 | 228.1 | Support of UTRA HNB | 201d? | 2008-05-30 A | 2009-03-06 A | 100% |  | 2008-05-30 | 2009-03-06 | 201d? |  | finish no earlier than 2009-03-06 | R2 | 1608h | 1608h | HNB-supp | PCG-21 | Huawei | Rel-8 | SP-40 | Joern | RP-090040 |
| 717 | 228.2 | FDD Home NodeB RF requirements | 261d? | 2008-03-07 A | 2009-03-06 A | 100% |  | 2008-03-07 | 2009-03-06 | 261d? |  | finish no earlier than 2009-03-06 | R4 | 2088h | 2088h | HNB-RF | PCG-21 | Motorola | Rel-8 | SP-39 | Issam | RP-090041 |
| 718 | 228.3 | UTRAN Architecture for 3G HNB | 136d? | 2008-05-30 A | 2008-12-05 A | 100% |  | 2008-05-30 | 2008-12-05 | 136d? |  | finish no earlier than 2008-12-05 | R3 | 1088h | 1088h | HNB-arch | PCG-21 | Alcatel-Lucent | Rel-8 | SP-40 | Juha | RP-090042 |
| 719 | 228.4 | 3G Home NodeB OAM&P Type 1 Management Interface | 127d? | 2008-12-11 A | 2009-06-04 A | 100% |  | 2008-12-11 | 2009-06-04 | 127d? |  | finish no earlier than 2009-06-04 | S5 | 1008h | 1008h | HNB-3G_OAM | PCG-22 | Huawei | Rel-8 | SP-42 | Dionisio |  |
| 720 | 229 | **UTRA HNB – UE Conformance Testing** | 327d? | 2009-03-06 A | 2010-06-04 | 70% | 98.1d? | 2009-03-06 | 2010-06-04 | 327d? | 335d |  | R5 | 5224h | 3656.8h | HNB-UEConTest | PCG-22 |  | Rel-8 | RP-43 | Ingbert |  |
| 721 | 229.1 | Conformance Test Aspects – UTRA HNB (FDD) | 326d? | 2009-03-06 A | 2010-06-04 | 70% | 97.8d? | 2009-03-06 | 2010-06-04 | 326d? | 335d | finish no earlier than 2010-06-04 | R5 | 2608h | 1825.6h | HNB-UEConTestFDD | PCG-22 | Huawei | Rel-8 | RP-43 | Ingbert | RP-100064 |
| 722 | 230 | Lawful Interception in the 3GPP Rel-8 | 524d? | 2007-03-12 A | 2009-03-12 A | 100% |  | 2007-03-12 | 2009-03-12 | 524d? |  | finish no earlier than 2009-03-12 | S3 | 4192h | 4192h | LI8 |  | BMWI, Verizon | Rel-8 |  | Dionisio |  |
| 723 | 231 | **Generic Bootstrapping Architecture Push Function** | 258d? | 2008-03-12 A | 2009-03-06 A | 100% |  | 2008-03-12 | 2009-03-06 | 258d? |  |  | S3,C1,C4 | 6468.8h | 6468.8h | GBAPush | PCG-21 | Ericsson | Rel-8 | SP-39 | Dionisio |  |
| 724 | 231.1 | SA3 part of GBAPush (33.223) | 193d? | 2008-03-12 A | 2008-12-05 A | 100% |  | 2008-03-12 | 2008-12-05 | 193d? |  | finish no earlier than 2008-12-05 | S3 | 1544h | 1544h | GBAPush | PCG-21 | Ericsson | Rel-8 | SP-39 | Dionisio |  |
| 725 | 231.2 | CT1 part of GBAPush | 178.8d? | 2008-03-12 A | 2009-03-06 A | 100% |  | 2008-03-12 | 2009-03-06 | 178.8d? |  | finish no earlier than 2009-03-06 | C1 | 1430.4h | 1430.4h | GBAPush | PCG-21 | Ericsson | Rel-8 | SP-39 | Frederic |  |
| 726 | 231.3 | CT4 part of GBAPush | 178.8d? | 2008-03-12 A | 2009-03-06 A | 100% |  | 2008-03-12 | 2009-03-06 | 178.8d? |  | finish no earlier than 2009-03-06 | C4 | 1430.4h | 1430.4h | GBAPush | PCG-21 | Ericsson | Rel-8 | SP-39 | Kimmo |  |
| 727 | 232 | Requirements and Test methods for Wideband Terminals | 197d? | 2008-03-12 A | 2008-12-11 A | 100% |  | 2008-03-12 | 2008-12-11 | 197d? |  | start no earlier than 2008-03-12 | S4 | 1576h | 1576h | RETEM_WB_T |  | FT, Ericsson | Rel-8 |  | Paolo |  |
| 728 | 233 | Extending PSS and MBMS User Services for optimized Mobile TV | 266d? | 2007-12-06 A | 2008-12-11 A | 100% |  | 2007-12-06 | 2008-12-11 | 266d? |  | finish no earlier than 2008-12-11 | S4 | 2128h | 2128h | PSS_MBMS_OMTV |  | Ericsson | Rel-8 |  | Paolo |  |
| 729 | 234 | **Encoding formats, transport formats and media description signalling for interworking, QoE, and other enhancements to MTSI-MHI** | 331d? | 2007-12-06 A | 2009-03-12 A | 100% |  | 2007-12-06 | 2009-03-12 | 331d? |  |  | S4,C3,C1,C4 | 9640h | 9640h | MTSI_eMHI | PCG-21 | Ericsson, Qualcomm | Rel-8 | SP-40 | Paolo |  |
| 730 | 234.1 | MTSI Video - Dynamic Rate Adaptation/Signalling of Image Size | 331d? | 2007-12-06 A | 2009-03-12 A | 100% |  | 2007-12-06 | 2009-03-12 | 331d? |  | finish no earlier than 2009-03-12 | S4 | 2648h | 2648h | MTSI_eMHI-DRASIS |  | Qualcomm, Samsung | Rel-8 |  | Paolo |  |
| 731 | 234.2 | CT3 part of Enhancement of interworking between MTSI and CS networks | 201d? | 2008-05-30 A | 2009-03-06 A | 100% |  | 2008-05-30 | 2009-03-06 | 201d? |  | finish no earlier than 2009-03-06 | C3 | 1608h | 1608h | MTSI_eMHI | PCG-21 | Huawei | Rel-8 | CP-40 | Gwiho |  |
| 732 | 234.3 | CT1 part of Enhancement of interworking between MTSI and CS networks | 141d? | 2008-05-30 A | 2008-12-12 A | 100% |  | 2008-05-30 | 2008-12-12 | 141d? |  | start no earlier than 2008-05-30 | C1 | 1128h | 1128h | MTSI_eMHI | PCG-21 | Huawei | Rel-8 | CP-40 | Frederic |  |
| 733 | 234.4 | CT4 part of Enhancement of interworking between MTSI and CS networks | 201d? | 2008-05-30 A | 2009-03-06 A | 100% |  | 2008-05-30 | 2009-03-06 | 201d? |  | finish no earlier than 2009-03-06 | C4 | 1608h | 1608h | MTSI_eMHI | PCG-21 | Huawei | Rel-8 | CP-40 | Kimmo |  |

Notes:
- 708: SP#39 Stage 1 completed / Text3: 22.115 / Text5: Marco.DeLuca1@telecomitalia.it
- 709: SP#39 completed / Text3: 22.115 / Text5: Marco.DeLuca1@telecomitalia.it
- 710: CP#43 completed. SP#39 Stage 1 completed / Text5: John Watson
- 711: SP#39 completed / Text3: 22.011, 22.115 / Text5: John Watson
- 712: CP#43 completed / Text3: 23.122, 24.301, 24.801, 24.285 / Text5: zhang.peng@huawei.com
- 713: CP#43 completed / Text3: 23.122, 24.008, 24.285 / Text5: Osok Song
- 714: CP#43 completed. SP#42 SP-080874 22.011CR0141 confirmed Requirement to support roaming subscribers with CSG home network subscription but did NOT confirmed requirement for home network independent support of roamers in CSG / Text3: 29.002, 29.272, 23.008, 23.003 / Text5: Hannu Hietalahti
- 715: RP#43 completed. SP#44 completed
- 716: RP#43 completed. RP#41 WID updated RP-080483=>RP-080752. / Text3: 25.304, 25.306, 25.331, 25.367 / Text5: Yang Xudong (yangxudong@huawei.com)
- 717: RP#43 completed / Text3: 25.104, 25.141, 25.967 / Text5: Ying Cai (yingcai@motorola.com)
- 718: RP#42 completed / Text3: 25.401, 25.410, 25.412, 25.413, 25.414, 25.415, new 25.467, 25.468, 25.469 / Text5: Martin Warner (mw15@alcatel-lucent.com)
- 719: SP#44 completed. Complements work in BroadBand Forum / Text3: 32.581, 32.582, 32.583, 32.584 / Text5: Zou Lan (zlan@huawei.com)
- 720: Testing for Feature UID_390033 UTRA HNB
- 721: - / Text3: 34.108, 34.123-1, 34.123-2, 34.123-3 / Text5: Trica Li (trica_li@huawei.com)
- 722: SP#43 completed / Text3: 33.106, 33.107, 33.108 / Text5: berthold.wilhelm@bnetza.de, ron_ryan@verizon.net
- 723: CP#43 completed / Text5: Rolf Blom
- 724: SP#42 completed 33.223 as Rel-8. TS 33.224 moved to Rel-9 under new UID_420039 / Text3: 33.223 / Text5: Rolf Blom
- 725: CP#43 completed / Text3: 24.109 / Text5: Rolf Blom
- 726: CP#43 completed / Text3: 29.109 / Text5: Rolf Blom
- 727: SP#42 completed. SP#39 WID approved. / Text3: 26.131, 26.132 / Text5: stephane.ragot@orange-ftgroup.com, wanqing.shi@sonyericsson.com
- 728: SP#42 completed. SP#38 WID approved. / Text3: 26.234, 26.346, 26.946 / Text5: thorsten.lohmar@ericsson.com
- 729: TSG#43 completed / Text5: olle.franceschi@ericsson.com, nleung@qualcomm.com
- 730: SP#43 completed. SP#40 WID updated SP-070755=>SP-080246. [Feature=>BB under new Feature UID_400028 (MTSI)] / Text3: 26.114 / Text5: nleung@qualcomm.com & kyunghun.jung@samsung.com
- 731: CP#43 completed / Text3: 29.163 / Text5: Tingfang Tang (tagna_online@huawei.com)
- 732: CP#42 completed (No CT1-impact). WID updated CP-080422=>CP-080774 / Text5: Tingfang Tang (tagna_online@huawei.com)
- 733: CP#43 completed / Text3: 29.332 / Text5: Tingfang Tang (tagna_online@huawei.com)

| ID | WBS | Task | Duration | Start | Finish | Complete | Baseline start | Baseline finish | Baseline duration | Constraint | Resources | Work | Actual work | Text1 | Text6 | Text8 | Text4 | Text5 | Text2 | Text7 | Text9 | Text12 |
| --- | --- | --- | --- | --- | --- | --- | --- | --- | --- | --- | --- | --- | --- | --- | --- | --- | --- | --- | --- | --- | --- | --- |
| 734 | 235 | **OAM&P 8** | 653d? | 2007-06-07 A | 2009-12-04 A | 100% | 2007-06-07 | 2009-12-04 | 653d? |  | S5,C1 | 43227.2h | 43227.2h | OAM8 | Rel-8 | Dionisio |  |  |  |  |  |  |
| 735 | 235.1 | **Network Infrastructure Management** | 653d? | 2007-06-07 A | 2009-12-04 A | 100% | 2007-06-07 | 2009-12-04 | 653d? |  | S5 | 19464h | 19464h | OAM8-NIM | Rel-8 | Dionisio |  |  |  |  |  |  |
| 736 | 235.1.1 | Telecom Management Methodology | 461d? | 2007-06-07 A | 2009-03-12 A | 100% | 2007-06-07 | 2009-03-12 | 461d? | finish no earlier than 2009-03-12 | S5 | 3688h | 3688h | OAM8 | Rel-8 | Dionisio | Ericsson | thomas.tovinger@ericsson.com |  |  |  |  |
| 737 | 235.1.2 | Advanced Alarming on Itf-N | 266d? | 2007-06-07 A | 2008-06-12 A | 100% | 2007-06-07 | 2008-06-12 | 266d? | finish no earlier than 2008-12-11 | S5 | 2128h | 2128h | OAM8 | Rel-8 | Dionisio | Nokia Siemens Networks | SUERBAUM, Clemens |  |  |  |  |
| 738 | 235.1.3 | CN CS Bearer Transport Network (BTN) relative NRM | 266d? | 2007-06-07 A | 2008-06-12 A | 100% | 2007-06-07 | 2008-06-12 | 266d? | finish no earlier than 2008-12-11 | S5 | 2128h | 2128h | OAM8 | Rel-8 | Dionisio | China Mobile | LI, Jian |  |  |  |  |
| 739 | 235.1.4 | Alignment with eTOM and M.3060 architectural concepts | 210d? | 2008-02-22 A | 2008-12-11 A | 100% | 2008-02-22 | 2008-12-11 | 210d? | start no earlier than 2008-02-22 | S5 | 1680h | 1680h | OAM8 | Rel-8 | Dionisio | TeliaSonera | Berggren, Tommy | PCG-21 | SP-39 |  |  |
| 740 | 235.1.5 | IRP SOAP Solution Sets | 201d? | 2008-06-05 A | 2009-03-12 A | 100% | 2008-06-05 | 2009-03-12 | 201d? | finish no earlier than 2009-03-12 | S5 | 1608h | 1608h | OAM8 | Rel-8 | Dionisio | Ericsson | edwin.tse@ericsson.com | PCG-21 | SP-40 |  |  |
| 741 | 235.1.6 | Create missing specifications for IRP XML definitions | 52d? | 2009-09-24 A | 2009-12-04 A | 100% | 2009-09-24 | 2009-12-04 | 52d? | finish no earlier than 2010-03-12 | S5 | 416h | 416h | OAM8 | Rel-8 | Dionisio | ZTE | Shuqiang Huang (huangsq@zte.com.cn) | PCG-23 | SP-45 |  |  |
| 742 | 235.1.7 | Deleted - End point modelling for reference point | 324d? | 2007-09-17 A | 2008-12-11 A | 100% | 2007-09-17 | 2008-12-11 | 324d? | finish no earlier than 2008-12-11 | S5 | 2592h | 2592h | OAM8 | Rel-8 | Dionisio | Motorola | YAO, Yizhi |  | SP-37 | PCG-21 | SP-41 |
| 743 | 235.2 | **Performance Management** | 461d? | 2007-06-07 A | 2009-03-12 A | 100% | 2007-06-07 | 2009-03-12 | 461d? |  | S5 | 13712h | 13712h | OAM8-PM | Rel-8 | Dionisio |  |  |  |  |  |  |
| 744 | 235.2.1 | IP bearer network Performance measurement definitions | 396d? | 2007-06-07 A | 2008-12-11 A | 100% | 2007-06-07 | 2008-12-11 | 396d? | finish no earlier than 2008-12-11 | S5 | 3168h | 3168h | OAM8 | Rel-8 | Dionisio | China Mobile | lilianyuan@chinamobile.com |  |  |  |  |
| 745 | 235.2.2 | HSUPA performance measurements | 396d? | 2007-06-07 A | 2008-12-11 A | 100% | 2007-06-07 | 2008-12-11 | 396d? | finish no earlier than 2008-12-11 | S5 | 3168h | 3168h | OAM8 | Rel-8 | Dionisio | China Mobile | LI, Jian |  |  |  |  |
| 746 | 235.2.3 | Key Performance Indicators (KPIs) for UMTS and GSM | 461d? | 2007-06-07 A | 2009-03-12 A | 100% | 2007-06-07 | 2009-03-12 | 461d? | finish no earlier than 2009-03-12 | S5 | 3688h | 3688h | OAM8 | Rel-8 | Dionisio | China Mobile | Liang Shuangchun |  |  |  |  |
| 747 | 235.3 | **Trace Management** | 196d? | 2008-03-07 A | 2008-12-05 A | 100% | 2008-03-07 | 2008-12-05 | 196d? |  | S5,C1,C3,C4 | 5777.6h | 5777.6h | OAM8-Trace | Rel-8 | Dionisio |  |  |  |  |  |  |
| 748 | 235.3.1 | Service Level Tracing in IMS | 196d? | 2008-03-07 A | 2008-12-05 A | 100% | 2008-03-07 | 2008-12-05 | 196d? | finish no earlier than 2008-12-05 | C1 | 1568h | 1568h | OAM8-Trace | Rel-8 | Frederic | Vodafone | peter.dawes@vodafone.com |  |  |  |  |
| 749 | 235.3.2 | Service Level Tracing in IMS | 175.4d? | 2008-03-07 A | 2008-12-05 A | 100% | 2008-03-07 | 2008-12-05 | 175.4d? | finish no earlier than 2008-12-05 | C3 | 1403.2h | 1403.2h | OAM8-Trace | Rel-8 | Gwiho | Vodafone | peter.dawes@vodafone.com | PCG-21 | CP-40 |  |  |
| 750 | 235.3.3 | Service Level Tracing in IMS | 175.4d? | 2008-03-07 A | 2008-12-05 A | 100% | 2008-03-07 | 2008-12-05 | 175.4d? | finish no earlier than 2008-12-05 | C4 | 1403.2h | 1403.2h | OAM8-Trace | Rel-8 | Frederic | Vodafone | peter.dawes@vodafone.com | PCG-21 | CP-40 |  |  |
| 751 | 236 | **Charging Management small Enhancements** | 716d? | 2006-03-16 A | 2008-12-11 A | 100% | 2006-03-16 | 2008-12-11 | 716d? |  | S5 | 12544h | 12544h | CH8 | Rel-8 | Dionisio |  |  |  |  |  |  |
| 752 | 236.1 | Online charging correlation | 457d? | 2006-03-16 A | 2007-12-14 A | 100% | 2006-03-16 | 2007-12-14 | 457d? | start no earlier than 2006-03-16 | S5 | 3656h | 3656h | CH8 | Rel-8 | Dionisio | Orange | Chahine, Rony |  |  |  |  |
| 753 | 236.2 | SMS online charging | 137d? | 2007-06-07 A | 2007-12-14 A | 100% | 2007-06-07 | 2007-12-14 | 137d? | finish no earlier than 2007-12-14 | S5 | 1096h | 1096h | CH8 | Rel-8 | Dionisio | Vodafone | WONG, Gavin |  |  |  |  |
| 754 | 236.3 | Introduce Online Charging from SMS-SC into the SMS Charging Specifications | 61d? | 2008-09-18 A | 2008-12-11 A | 100% | 2008-09-18 | 2008-12-11 | 61d? | finish no earlier than 2008-12-11 | S5 | 488h | 488h | CH8 | Rel-8 | Dionisio | Acision | Gebler, Erik - Acision [erik.gebler (at) acision.com] | PCG-21 | SP-41 |  |  |
| 755 | 236.4 | Deleted - WLAN Offline Charging | 244d? | 2008-01-07 A | 2008-12-11 A | 100% | 2008-01-07 | 2008-12-11 | 244d? | finish no earlier than 2008-12-11 | S5 | 1952h | 1952h | CH8 | Rel-8 | Dionisio | Alcatel-Lucent | GARDELLA, Maryse | PCG-21 | SP-38 | PCG-22 | SP-42 |
| 756 | 237 | **Conferencing enhancements for Mp interface** | 266d? | 2007-11-30 A | 2008-12-05 A | 100% | 2007-11-30 | 2008-12-05 | 266d? |  | C4 | 6384h | 6384h | eMp | Rel-8 | Kimmo | Huawei | Chencheng@huawei.com | PCG-21 |  |  |  |
| 757 | 237.1 | Stage 2 for eMp | 266d? | 2007-11-30 A | 2008-12-05 A | 100% | 2007-11-30 | 2008-12-05 | 266d? | finish no earlier than 2008-12-11 | C4 | 2128h | 2128h | eMp | Rel-8 | Kimmo | Huawei | Chencheng@huawei.com | PCG-21 | CP-38 |  |  |
| 758 | 237.2 | Stage 3 for eMp | 266d? | 2007-11-30 A | 2008-12-05 A | 100% | 2007-11-30 | 2008-12-05 | 266d? | finish no earlier than 2008-12-05 | C4 | 2128h | 2128h | eMp | Rel-8 | Kimmo | Huawei | Chencheng@huawei.com | PCG-21 | CP-38 |  |  |

Notes:
- 734: -
- 735: -
- 736: SP#43 completed / Text3: 32.155, 32.153
- 737: SP#40 completed / Text3: 32.121, 32.122, 32.123
- 738: SP#40 completed / Text3: 32.632, 32.633, 32.635
- 739: SP#42 completed / Text3: 32.101/2, 32-series
- 740: SP#43 completed. WID updated SP-080276=>SP-090148 (removed the planned but not delivered new TSs 32.127, 32.327, 32.337, 32.357, 32.387, 32.397, 32.447) / Text3: 32.111-7, 32.617, 32.417, 32.367, 32.347, 32.111-1, 32.111-2, 32.111-3, 32.111-5, 32.307, 32.317, 32.341, 32.342, 32.343, 32.345, 32.361, 32.362, 32.363, 32.365, 32.411, 32.412, 32.413, 32.415, 32.611, 32.612, 32.613, 32.615, 32.625
- 741: SP#46 completed. Create missing XML definitions specs for IRPs (Advanced Alarm Management, Communication Surveillance, Self-Configuration of Network Elements, Software Management) needed for implementation of Rel-8 Notification Log IRP (TS 32.33x) / Text3: new (32.125, 32.355, 32.505, 32.535), 32.150, 32.153, 32.335
- 742: SP#41 Work stopped. Contributions related to E-UTRAN/EPC to be submitted to UID_380036 E-UTRAN NRM IRP/ UID_380037 EPC NRM IRP / Text3: 32.152, 32.62/3/4x, 32.73x
- 743: -
- 744: SP#42 completed. SP#36 WID updated SP-050319=>SP-070301 / Text3: 32.321, 32.322, 32.323, 32.325
- 745: SP#42 completed / Text3: 32.405
- 746: SP#43 completed / Text3: 32.410
- 747: -
- 748: CP#42 completed. CP#40 WID updated CP-060521=>CP-080315. / Text3: 24.323, 24.229
- 749: CP#42 completed (No CT3-impact). CP#40 WID updated CP-060521=>CP-080315
- 750: CP#42 completed. CP#40 WID updated CP-060521=>CP-080315. / Text3: 29.228, 29.229
- 751: SP#42 completed.
- 752: SP#38 completed / Text3: 32.296
- 753: SP#38 completed / Text3: 32.274, 32.240/299
- 754: SP#42 completed. Linked to SA2 UID 32081 (Support of SMS over IP networks) and CT4 UID 340016 (Routeing of MT-SMS via the HPLMN). / Text3: 32.274, 32.299
- 755: SP#42 stopped / Text3: 32.252, 32.298, 32.299
- 756: CP#42 completed. WID updated CP-070868=>CP-080725
- 757: CP#42 completed. WID updated CP-070868=>CP-080725 / Text3: 23.333
- 758: CP#42 completed. WID updated CP-070868=>CP-080725 / Text3: 29.333

| ID | WBS | Task | Type | Duration | Start | Finish | Complete | Baseline start | Baseline finish | Baseline duration | Constraint | Resources | Work | Actual work | Text1 | Text4 | Text5 | Text6 | Text8 | Text7 | Text12 | Text2 | Text9 | Text11 |
| --- | --- | --- | --- | --- | --- | --- | --- | --- | --- | --- | --- | --- | --- | --- | --- | --- | --- | --- | --- | --- | --- | --- | --- | --- |
| 759 | 238 | **Contact Manager for 3GPP UICC applications** |  | 642d? | 2006-06-22 A | 2008-12-05 A | 100% | 2006-06-22 | 2008-12-05 | 642d? |  | C6 | 13352h | 13352h | eUPHBOOK | Gemalto | Jacques.seif@gemalto.com | Rel-8 | Xavier |  |  |  |  |  |
| 760 | 238.1 | Requirements for Contact Manager |  | 392d? | 2006-06-22 A | 2007-12-21 A | 100% | 2006-06-22 | 2007-12-21 | 392d? | finish no earlier than 2007-12-21 | C6 | 3136h | 3136h | eUPHBOOK-St1 | Gemalto | Jacques.seif@gemalto.com | Rel-8 | Xavier |  |  |  |  |  |
| 761 | 238.2 | External interface for eUPHBOOK |  | 220d? | 2007-05-07 A | 2008-03-07 A | 100% | 2007-05-07 | 2008-03-07 | 220d? | finish no earlier than 2008-03-07 | C6 | 1760h | 1760h | eUPHBOOK-Ext_Spec | Gemalto | Jacques.seif@gemalto.com | Rel-8 | Xavier |  |  |  |  |  |
| 762 | 238.3 | Internal interface for eUPHBOOK |  | 415d? | 2007-05-07 A | 2008-12-05 A | 100% | 2007-05-07 | 2008-12-05 | 415d? | finish no earlier than 2008-12-05 | C6 | 3320h | 3320h | eUPHBOOK-Int_Spec | Gemalto | Jacques.seif@gemalto.com | Rel-8 | Xavier | CP-37 |  |  |  |  |
| 763 | 238.4 | Deleted - Implementation of eUPHBOOK | milestone | 0d? | 2007-06-21 A | 2007-06-21 A | 100% | 2007-06-21 | 2007-06-21 | 0d? | start no earlier than 2007-06-21 | C6 |  |  | eUPHBOOK-St23 | Giesecke & Devrient | Claus Dietze | Rel-8 | Xavier |  | SP-33 |  |  |  |
| 764 | 239 | **Deleted - Contact Manager Conformance Test specifications** |  | 471d? | 2008-06-02 A | 2010-03-19 A | 100% | 2008-06-02 | 2010-03-19 | 471d? |  | C6 | 11304h | 11304h | eUPHBOOK-Test | Comprion, Gemalto | Udo Willenbrink, Jacques Seif | Rel-8 | Xavier | CP-40 | CP-47 | PCG-21 | PCG-24 |  |
| 765 | 239.1 | Deleted - Contact Manager for 3GPP UICC applications test specifications |  | 471d? | 2008-06-02 A | 2010-03-19 A | 100% | 2008-06-02 | 2010-03-19 | 471d? | finish no earlier than 2010-03-19 | C6 | 3768h | 3768h | eUPHBOOK-Test | Comprion | Udo Willenbrink | Rel-8 | Xavier | CP-40 | CP-47 | PCG-21 | PCG-24 |  |
| 766 | 239.2 | Deleted - Contact Manager API for Java™ Card test specification |  | 471d? | 2008-06-02 A | 2010-03-19 A | 100% | 2008-06-02 | 2010-03-19 | 471d? | finish no earlier than 2010-03-19 | C6 | 3768h | 3768h | eUPHBOOK-Test | Gemalto | jacques.seif@gemalto.com | Rel-8 | Xavier | CP-40 | CP-47 | PCG-21 | PCG-24 |  |
| 767 | 240 | **Rel-8 LTE – 3G Long Term Evolution - Evolved Packet System RAN part** |  | 644d? | 2006-09-25 A | 2009-03-12 A | 100% | 2006-09-25 | 2009-03-12 | 644d? |  | RP,S5 | 44896h | 44896h | LTE | NTT DoCoMo | Takehiro Nakamura (nakamurata@nttdocomo.co.jp) | Rel-8 |  |  |  |  |  | RP-080741 |
| 768 | 240.1 | LTE – Physical Layer |  | 380d? | 2006-09-25 A | 2008-03-07 A | 100% | 2006-09-25 | 2008-03-07 | 380d? | finish no earlier than 2007-09-14 | R1 | 3040h | 3040h | LTE-Phys | NTT DoCoMo | Sadayuki Abeta | Rel-8 | Patrick |  |  |  |  | RP-080741 |
| 769 | 240.2 | LTE – Radio Interface Layer 2 and 3 Protocol Aspect |  | 575d? | 2006-09-25 A | 2008-12-05 A | 100% | 2006-09-25 | 2008-12-05 | 575d? | finish no earlier than 2008-12-11 | R2 | 4600h | 4600h | LTE-L23 | Nokia Siemens Networks | benoist.sebire@nokia.com | Rel-8 | Joern |  |  |  |  | RP-080741 |
| 770 | 240.3 | LTE – eUTRAN Interfaces |  | 575d? | 2006-09-25 A | 2008-12-05 A | 100% | 2006-09-25 | 2008-12-05 | 575d? | finish no earlier than 2008-12-11 | R3 | 4600h | 4600h | LTE-interfaces | Ericsson | Martin Israelsson | Rel-8 | Juha |  |  |  |  | RP-080741 |
| 771 | 240.4 | LTE – Evolved UTRA and UTRAN RF Radio Transmission/Reception, System Performance Requirements and Conformance Testing |  | 575d? | 2006-09-25 A | 2008-12-05 A | 100% | 2006-09-25 | 2008-12-05 | 575d? | finish no earlier than 2008-12-11 | R4 | 4600h | 4600h | LTE-RF | Nokia Siemens Networks | Tuomo Saynajakangas | Rel-8 | Issam |  |  |  |  | RP-080741 |
| 772 | 240.5 | LTE – FDD repeaters |  | 386d? | 2007-09-14 A | 2009-03-06 A | 100% | 2007-09-14 | 2009-03-06 | 386d? | finish no earlier than 2009-03-06 | R4 | 3088h | 3088h | LTE-Repeaters | Powerwave Technologies, Andrew Wireless | ralf.michanikl@andrew.com, Alf.Ahlstrom@pwav.com | Rel-8 | Issam | RP-37 |  |  |  | RP-090037 |
| 773 | 240.6 | **E-UTRAN Data Definitions** |  | 389d? | 2007-09-17 A | 2009-03-12 A | 100% | 2007-09-17 | 2009-03-12 | 389d? |  | S5 | 13096h | 13096h | E-UTRAN-OAM |  |  | Rel-8 | Dionisio | SP-39 |  | PCG-21 |  |  |
| 774 | 240.6.1 | Subscriber and Equipment Trace for E-UTRAN and EPC |  | 389d? | 2007-09-17 A | 2009-03-12 A | 100% | 2007-09-17 | 2009-03-12 | 389d? | finish no earlier than 2009-03-12 | S5 | 3112h | 3112h | E-UTRAN-OAM | Ericsson | PETERSEN, Robert | Rel-8 | Dionisio | SP-37 |  |  |  |  |
| 775 | 240.6.2 | E-UTRAN Network Resource Model (NRM) Integration Reference Point (IRP) |  | 309d? | 2008-01-07 A | 2009-03-12 A | 100% | 2008-01-07 | 2009-03-12 | 309d? | finish no earlier than 2009-03-12 | S5 | 2472h | 2472h | E-UTRAN-OAM | Ericsson | ELMDAHL, Per | Rel-8 | Dionisio | SP-38 |  | PCG-21 |  |  |
| 776 | 240.6.3 | Performance measurements for E-UTRAN |  | 275d? | 2008-02-22 A | 2009-03-12 A | 100% | 2008-02-22 | 2009-03-12 | 275d? | finish no earlier than 2009-03-12 | S5 | 2200h | 2200h | E-UTRAN-OAM | Motorola, Huawei | YAO, Yizhi | Rel-8 | Dionisio | SP-39 |  | PCG-21 |  |  |
| 777 | 240.6.4 | Key Performance Indicators (KPIs) for E-UTRAN |  | 275d? | 2008-02-22 A | 2009-03-12 A | 100% | 2008-02-22 | 2009-03-12 | 275d? | finish no earlier than 2009-03-12 | S5 | 2200h | 2200h | E-UTRAN-OAM | Ericsson | HÜBINETTE, Ulf | Rel-8 | Dionisio | SP-39 |  | PCG-21 |  |  |
| 778 | 240.7 | **Self-Organizing Networks (SON)** |  | 210d? | 2008-02-22 A | 2008-12-11 A | 100% | 2008-02-22 | 2008-12-11 | 210d? |  | S5 | 6720h | 6720h | LTE_SON-OAM | Vodafone | GOMPAKIS, Panagiotis | Rel-8 | Dionisio | SP-39 |  | PCG-21 |  |  |
| 779 | 240.7.1 | SON Concepts and requirements |  | 210d? | 2008-02-22 A | 2008-12-11 A | 100% | 2008-02-22 | 2008-12-11 | 210d? |  | S5 | 1680h | 1680h | LTE_SON-OAM | Vodafone | GOMPAKIS, Panagiotis | Rel-8 | Dionisio | SP-39 |  | PCG-21 |  |  |
| 780 | 240.7.2 | Self-Establishment of eNBs, including automated Software Management |  | 210d? | 2008-02-22 A | 2008-12-11 A | 100% | 2008-02-22 | 2008-12-11 | 210d? | start no earlier than 2008-02-22 | S5 | 1680h | 1680h | LTE_SON-OAM | Nokia Siemens Networks | SUERBAUM, Clemens | Rel-8 | Dionisio | SP-39 |  | PCG-21 |  |  |
| 781 | 240.7.3 | SON Automatic Neighbour Relations (ANR) List Management |  | 210d? | 2008-02-22 A | 2008-12-11 A | 100% | 2008-02-22 | 2008-12-11 | 210d? | finish no earlier than 2008-12-11 | S5 | 1680h | 1680h | LTE_SON-OAM | Ericsson | edwin.tse@ericsson.com | Rel-8 | Dionisio | SP-39 |  | PCG-21 |  |  |
| 782 | 241 | **Rel-8 LTE – Terminal Conformance Test Specification** |  | 657d? | 2007-06-01 A | 2009-12-04 A | 100% | 2007-06-01 | 2009-12-04 | 657d? |  | R5 | 14336h | 14336h | LTE-UEConTest |  |  | Rel-8 | Ingbert |  |  |  |  |  |
| 783 | 241.1 | 3G LTE – Terminal Protocol Conformance Test Specifications |  | 657d? | 2007-06-01 A | 2009-12-04 A | 100% | 2007-06-01 | 2009-12-04 | 657d? | finish no earlier than 2009-12-04 | R5 | 5256h | 5256h | LTE-UEConTest_SIG | NEC, Motorola | david.lecompte@nectech.fr, Jacob.John@motorola.com | Rel-8 | Ingbert |  |  |  |  | RP-091060 |
| 784 | 241.2 | LTE – Terminal Radio Transmission and Reception Conformance Test Specifications |  | 657d? | 2007-06-01 A | 2009-12-04 A | 100% | 2007-06-01 | 2009-12-04 | 657d? |  | R5 | 5256h | 5256h | LTE-UEConTest_RF | Agilent | andrea_leonardi@agilent.com | Rel-8 | Ingbert |  |  |  |  | RP-091059 |

Notes:
- 759: CP#42 completed. CP#40: WID updated CP-070622=>CP-080382. aka Enhanced USIM phonebook
- 760: CP#38 completed / Text3: 21.111
- 761: CP#39 completed / Text3: 31.220
- 762: CP#42 completed / Text3: 31.221
- 763: SP#33 stopped / Text3: 31.102
- 764: CP#47 work stopped/abandoned
- 765: CP#47 work stopped/abandoned / Text3: 31.320 (external interface for communication with the ME)
- 766: CP#47 work stopped/abandoned / Text3: 31.321 (internal interface (API))
- 767: RP#43 completed. Role model for SAE/LTE system wide project management by SA2 in SP-060166 / Text3: 36.300, 36.938
- 768: RP#39 completed / Text3: 36.201, 36.211, 36.212, 36.213, 36.214, 25.215, 25.225
- 769: RP#42 completed / Text3: 36.302, 36.304, 36.306, 36.314, 36.321, 36.322, 36.323, 36.331, 25.302, 25.304, 25.331
- 770: RP#42 completed / Text3: 36.401, 36.410, 36.411, 36.412, 36.413, 36.414, 36.420, 36.421, 36.422, 36.423, 36.424, 25.413
- 771: RP#42 completed. RP#47 abandoned draft 36.801, 36.803, 36.804 / Text3: 36.101, 36.104, 36.113, 36.124, 36.133, 36.141, 36.942, 25.123, 25.133
- 772: RP#43 completed. RP#47 create Rel-9 TR 36.956 (see R4-100386, RP-100320_RAN4 Report) / Text3: 36.106, 36.143, 25.113
- 773: SP#43 completed
- 774: SP#43 completed / Text3: 32.42x, 32.44x
- 775: SP#43 completed / Text3: 32.761, 32.762, 32.763, 32.765
- 776: SP#43 completed / Text3: 32.425
- 777: SP#43 completed / Text3: 32.450, 32.451
- 778: SP#42 completed (WT UID_390007 moved to Rel-9). SP#40 updated WID SP-080064=>SP-080275.
- 779: SP#42 completed. SP#40 updated WID SP-080064=>SP-080275. SP#41 UID_390004 split to monitor 32.500 progress. / Text3: 32.500
- 780: SP#42 completed. WID updated SP-080065=>SP-080849 / Text3: new (32.501, 32.502, 32.503, 32.531, 32.532, 32.533)
- 781: SP#42 completed / Text3: 32.511, 32.761, 32.762, 32.763, 32.765
- 782: Testing for Feature UID_20068 (LTE)
- 783: RP#46 completed / Text3: 36.521-1, 36.521-2, 36.508, 36.509, 36.523-1, 36.523-2, 36.523-3
- 784: RP#46 completed / Text3: 36.521-1, 36.521-2, 36.521-3

| ID | WBS | Task | Duration | Start | Finish | Complete | Baseline start | Baseline finish | Baseline duration | Constraint | Resources | Work | Actual work | Text1 | Text6 | Text8 | Text4 | Text5 | Text11 | Text2 | Text7 | Text9 | Text12 |
| --- | --- | --- | --- | --- | --- | --- | --- | --- | --- | --- | --- | --- | --- | --- | --- | --- | --- | --- | --- | --- | --- | --- | --- |
| 785 | 242 | **Rel-8 Improvements of the Radio Interface** | 525d? | 2007-03-05 A | 2009-03-06 A | 100% | 2007-03-05 | 2009-03-06 | 525d? |  | RP | 18152h | 18152h | RInImp8 | Rel-8 | Issam |  |  |  |  |  |  |  |
| 786 | 242.1 | UMTS 1500 MHz | 140d? | 2007-03-05 A | 2007-09-14 A | 100% | 2007-03-05 | 2007-09-14 | 140d? | finish no earlier than 2007-09-14 | R4 | 1120h | 1120h | RInImp8-UMTS1500 | Rel-8 | Issam | NTT DoCoMo | Takehiro Nakamura (nakamurata@nttdocomo.co.jp) | RP-070526 |  |  |  |  |
| 787 | 242.2 | UMTS 700 MHz FDD | 325d? | 2007-03-05 A | 2008-05-30 A | 100% | 2007-03-05 | 2008-05-30 | 325d? | finish no earlier than 2008-06-12 | R4 | 2600h | 2600h | RInImp8-UMTS700 | Rel-8 | Issam | Nokia | Tuomo Saynajakangas | RP-080260 |  |  |  |  |
| 788 | 242.3 | UMTS 2300 MHz TDD LCR | 195d? | 2007-12-17 A | 2008-09-12 A | 100% | 2007-12-17 | 2008-09-12 | 195d? | finish no earlier than 2008-09-12 | R4 | 1560h | 1560h | RInImp8-UMTS2300TDD | Rel-8 | Issam | CATT | songyuexia@datangmobile.cn | RP-080517 | PCG-21 | RP-38 |  |  |
| 789 | 242.4 | Further Improved Minimum Performance Requirements for HSDPA UE (FDD) - Two-Branch Interference Cancellation | 265d? | 2007-03-05 A | 2008-03-07 A | 100% | 2007-03-05 | 2008-03-07 | 265d? | finish no earlier than 2008-03-12 | R4 | 2120h | 2120h | RInImp8-2BIC | Rel-8 | Issam | AT&T | Marc Grant | RP-080041 |  |  |  |  |
| 790 | 242.5 | CS Voice Service over HSPA | 167d? | 2007-07-19 A | 2008-03-07 A | 100% | 2007-07-19 | 2008-03-07 | 167d? |  | R2 | 1336h | 1336h | RInImp8-CsHspa | Rel-8 | Joern | Nokia Siemens Networks | woonhee.hwang@nsn.com | RP-080042 |  | RP-37 |  |  |
| 791 | 242.6 | Performance requirements for 15 code reception with 16QAM/QPSK (FDD) | 126d? | 2007-06-11 A | 2008-03-07 A | 100% | 2007-06-11 | 2008-03-07 | 126d? | finish no earlier than 2008-06-12 | R4 | 1008h | 1008h | RInImp8-Hsdpa15codes | Rel-8 | Issam | Vodafone | tim.frost@vodafone.com | RP-080043 |  | RP-37 |  |  |
| 792 | 242.7 | UMTS 1880 MHz TDD | 126d? | 2008-09-12 A | 2009-03-06 A | 100% | 2008-09-12 | 2009-03-06 | 126d? | finish no earlier than 2009-03-09 | R4 | 1008h | 1008h | RInImp9-UMTS1880TDD | Rel-8 | Issam | CATT | Yuexia Song (songyuexia@datangmobile.cn) | RP-090044 | PCG-21 | RP-41 |  |  |
| 793 | 242.8 | Deleted - UMTS 2300 MHz FDD/TDD | 400d? | 2007-03-05 A | 2008-09-12 A | 100% | 2007-03-05 | 2008-09-12 | 400d? | finish no earlier than 2008-12-11 | R4 | 3200h | 3200h | RInImp8-UMTS2300 | Rel-8 | Issam | AT&T | Marc Grant | RP-080515 |  |  | PCG-21 | RP-41 |
| 794 | 243 | **Rel-8 Improvements of the Radio Interface - UE Conformance Testing** | 396d? | 2007-06-01 A | 2008-12-05 A | 100% | 2007-06-01 | 2008-12-05 | 396d? |  | R5 | 6256h | 6256h | RInImp-UEConTest | Rel-8 | Ingbert |  |  |  |  |  |  |  |
| 795 | 243.1 | Conformance Test Aspects – CS Voice Service over HSPA | 336d? | 2007-06-01 A | 2008-09-12 A | 100% | 2007-06-01 | 2008-09-12 | 336d? | finish no earlier than 2008-09-12 | R5 | 2688h | 2688h | RInImp8-CsHspa_UEConTest | Rel-8 | Ingbert | Huawei | baoyi@huawei.com | RP-080542 |  |  |  |  |
| 796 | 243.2 | Conformance Test Aspects – Performance requirements for 15 code reception with 16QAM/QPSK (FDD) | 195d? | 2008-03-07 A | 2008-12-05 A | 100% | 2008-03-07 | 2008-12-05 | 195d? | finish no earlier than 2008-12-05 | R5 | 1560h | 1560h | RInImp8-UEConTest_ Hsdpa15codes | Rel-8 | Ingbert | Ericsson | Mikael.Ziren@Ericsson.com | RP-080818 | PCG-21 | RP-40 |  |  |
| 797 | 244 | **Rel-8 RAN improvements** | 520d? | 2007-06-04 A | 2009-05-29 A | 100% | 2007-06-04 | 2009-05-29 | 520d? |  | RP | 29776h | 29776h | RANimp | Rel-8 |  |  |  |  |  |  |  |  |
| 798 | 244.1 | Combination of 64QAM and MIMO for HSDPA (FDD) | 205d? | 2007-06-04 A | 2008-09-12 A | 100% | 2007-06-04 | 2008-09-12 | 205d? | finish no earlier than 2008-09-12 | R1 | 1640h | 1640h | RANimp-64QamMimoHsdpa | Rel-8 | Patrick | Ericsson | Johan.Bergman@ericsson.com | RP-080518 |  |  |  |  |
| 799 | 244.2 | Improved L2 for uplink | 186d? | 2007-09-14 A | 2008-05-30 A | 100% | 2007-09-14 | 2008-05-30 | 186d? | finish no earlier than 2008-05-30 | R2 | 1488h | 1488h | RANimp-UplinkL2dataRates | Rel-8 | Joern | Ericsson | Janne.Peisa@ericsson.com | RP-080265 |  | RP-37 |  |  |
| 800 | 244.3 | Enhanced Uplink for CELL_FACH State in FDD | 321d? | 2007-09-14 A | 2008-12-05 A | 100% | 2007-09-14 | 2008-12-05 | 321d? | finish no earlier than 2008-12-12 | R2 | 2568h | 2568h | RANimp-UplinkEnhState | Rel-8 | Joern | Nokia Siemens Networks | markus.wimmer@nsn.com | RP-080804 |  | RP-37 |  |  |
| 801 | 244.4 | Enhanced UE DRX for FDD | 261d? | 2007-09-14 A | 2008-09-12 A | 100% | 2007-09-14 | 2008-09-12 | 261d? | finish no earlier than 2008-09-12 | R2 | 2088h | 2088h | RANimp-DRX | Rel-8 | Joern | Nokia | luis.barreto@nokia.com | RP-080520 |  | RP-37 |  |  |
| 802 | 244.5 | Enhancements for SRNS Relocation Procedure | 261d? | 2007-09-14 A | 2008-09-12 A | 100% | 2007-09-14 | 2008-09-12 | 261d? | finish no earlier than 2008-09-12 | R3 | 2088h | 2088h | RANimp-SrnsReloc | Rel-8 | Juha | Nokia Siemens Networks | masatoshi.nakamata@nsn.com | RP-080521 |  | RP-37 |  |  |
| 803 | 244.6 | Enhancements for FDD HSPA Evolution | 321d? | 2007-09-14 A | 2008-12-05 A | 100% | 2007-09-14 | 2008-12-05 | 321d? | finish no earlier than 2008-12-05 | R3,R2 | 2568h | 2568h | RANimp-HSPAEvo | Rel-8 | Juha | Nokia Siemens Networks | masatoshi.nakamata@nsn.com | RP-080805 |  | RP-37 |  |  |
| 804 | 244.7 | 64QAM for 1.28 Mcps TDD HSDPA | 264d? | 2007-12-04 A | 2008-12-05 A | 100% | 2007-12-04 | 2008-12-05 | 264d? | finish no earlier than 2008-12-05 | R1 | 2112h | 2112h | RANimp-64Qam1.28TDD | Rel-8 | Patrick | ZTE | zfmail@zte.com.cn | RP-080806 | PCG-21 | RP-38 |  |  |
| 805 | 244.8 | Enhanced CELL_FACH state in 1.28 Mcps TDD | 264d? | 2007-12-04 A | 2008-12-05 A | 100% | 2007-12-04 | 2008-12-05 | 264d? | finish no earlier than 2008-12-12 | R2 | 2112h | 2112h | RANimp-EnhState1.28TDD | Rel-8 | Joern | ZTE | zhang.yincheng@zte.com.cn | RP-080807 | PCG-21 | RP-38 |  |  |
| 806 | 244.9 | Continuous Connectivity for packet data users for 1.28 Mcps TDD | 321d? | 2008-03-07 A | 2009-05-29 A | 100% | 2008-03-07 | 2009-05-29 | 321d? | finish no earlier than 2009-05-29 | R1 | 2568h | 2568h | RANimp-LCRCPC | Rel-8 | Patrick | TD Tech | chenying@td-tech.com | RP-090394 | PCG-21 | RP-39 |  |  |
| 807 | 244.10 | HSPA VoIP to WCDMA/GSM CS continuity | 261d? | 2008-03-07 A | 2009-03-06 A | 100% | 2008-03-07 | 2009-03-06 | 261d? | finish no earlier than 2009-03-06 | R2 | 2088h | 2088h | RANimp-HSPAVoIP | Rel-8 | Joern | Nokia | Simone.Provvedi@nokia.com | RP-090050 | PCG-21 | RP-39 |  |  |
| 808 | 244.11 | HS-DSCH Serving Cell Change Enhancements | 196d? | 2008-03-07 A | 2008-12-05 A | 100% | 2008-03-07 | 2008-12-05 | 196d? | finish no earlier than 2008-12-12 | R2 | 1568h | 1568h | RANimp-HSDSCH | Rel-8 | Joern | Ericsson | henrik.enbuske@ericsson.com | RP-080811 | PCG-21 | RP-39 |  |  |
| 809 | 244.12 | MIMO for 1.28 Mcps TDD | 201d? | 2007-11-01 A | 2009-03-06 A | 100% | 2007-11-01 | 2009-03-06 | 201d? | finish no earlier than 2009-05-29 | R1,R4 | 1608h | 1608h | RANimp-MIMOLCR | Rel-8 | Patrick | CATT | wangke@datangmobile.cn | RP-090313 | PCG-21 | RP-40 |  |  |
| 810 | 244.13 | Dual-Cell HSDPA operation on adjacent carriers | 140d? | 2008-05-30 A | 2008-12-11 A | 100% | 2008-05-30 | 2008-12-11 | 140d? | finish no earlier than 2009-05-29 | R1,R4 | 1120h | 1120h | RANimp-DCHSDPA | Rel-8 | Patrick | Ericsson | johan.bergman@ericsson.com | RP-080814 | PCG-21 | RP-40 |  |  |

Notes:
- 785: -
- 786: SR in RP-070526. Introduction of Band XI / Text3: 25.101, 25.104, 25.133, 25.141, 25.331, 25.942, 25.306, 25.307, 34.121
- 787: Introduction of UMTS 700 MHz (Bands XII XIV) in 25.307. RP#47 abandoned draft 25.822 / Text3: 25.101, 25.104, 25.133, 25.141, 25.331, 25.942, 25.306, 25.307, 34.121
- 788: RP#41 completed. RP#47 abandoned draft 25.828 / Text3: 25.102, 25.105, 25.113, 25.123, 25.142, 34.124, 25.306, 25.331, 34.122
- 789: SR in RP-080041.
- 790: SR in RP-080042. / Text3: 25.323, 25.331, 25.322
- 791: SR in RP-080043. / Text3: 25.101
- 792: RP#43 completed as Rel-8 / Text3: 25.102, 25.105, 25.113, 25.123, 25.142, 34.124, 25.307
- 793: SR in RP-080515. RP#41 stopped / Text3: 25.101, 25.104, 25.133, 25.141, 25.331, 25.942, 25.306, 25.307, 34.121
- 794: 05/08: Linked to Feature UID_20028 (RInImp)
- 795: SR in RP-080542. RP#41 completed. / Text3: 34.108, 34.123-1, 34.123-2, 34.123-3
- 796: RP#42 completed. SR in RP-080818. Linked to UID_370033. / Text3: 34.121-1, 34.121-2
- 797: -
- 798: SR in RP-080518. RP#41 completed / Text3: 25.308, 25.211, 25.212, 25.213, 25.306, 25.331, 25.433, 25.435, 25.423, 25.425, 25.101, 25.104, 25.141
- 799: SR in RP-080265. RP#40 completed / Text3: 25.319, 25.301, 25.306, 25.321, 25.331, 25.433, 25.435, 25.423, 25.425, 25.427
- 800: SR in RP-080804. RP#42 completed / Text3: 25.309, 25.211, 25.214, 25.321, 25.331, 25.423, 25.433
- 801: SR in RP-080520. RP#41 completed / Text3: 25.306, 25.308, 25.321, 25.331, 25.423
- 802: SR in RP-080521. RP#41 completed / Text3: 25.306, 25.308, 25.321, 25.331, 25.423, 25.433, 25.214, 25.133
- 803: SR in RP-080805. RP#42 completed. WID updated RP-070760=>RP-080830 / Text3: 25.401, 25.413, 25.420, 25.423, 25.427, 25.433, 25.446, 25.301, 25.346
- 804: SR in RP-080806. RP#42 completed / Text3: 25.102, 25.105, 25.123, 25.142, 25.201, 25.221, 25.222, 25.223, 25.224, 25.306, 25.308, 25.321, 25.331, 25.423, 25.433
- 805: SR in RP-080807. RP#42 completed / Text3: 25.123, 25.221, 25.222, 25.224, 25.301, 25.302, 25.304, 25.306, 25.308, 25.319, 25.321, 25.331, 25.401, 25.423, 25.425, 25.433, 25.435
- 806: RP#44 completed / Text3: 25.929, 25.308, 25.319
- 807: RP#43 completed / Text3: 25.331, 25.413
- 808: SR in RP-080811. RP#42 completed / Text3: 25.101, 25.104, 25.133, 25.212, 25.214, 25.308, 25.321, 25.331, 25.423, 25.433
- 809: RP#43 completed (part missing R4 performance part) / Text3: 25.201, 25.221, 25.222, 25.223, 25.224, 25.306, 25.308, 25.321, 25.331, 25.423, 25.433, 25.102, 25.105, 25.142
- 810: RP#42 completed except R4 performance part 05/09. Triggered by FS_RAN-DCHS UID_390032 / Text3: 25.101, 25.104, 25.133, 25.141, 25.211, 25.212, 25.213, 25.214, 25.215, 25.306, 25.308, 25.321, 25.331, 25.423, 25.433

| ID | WBS | Task | Duration | Start | Finish | Complete | Remaining | Baseline start | Baseline finish | Baseline duration | Total slack | Constraint | Resources | Work | Actual work | Text1 | Text6 | Text8 | Text2 | Text4 | Text7 | Text11 |
| --- | --- | --- | --- | --- | --- | --- | --- | --- | --- | --- | --- | --- | --- | --- | --- | --- | --- | --- | --- | --- | --- | --- |
| 811 | 245 | **Rel-8 RAN improvements - UE Conformance Testing** | 602d? | 2008-05-30 A | 2010-09-17 | 78% | 131.97d? | 2008-05-30 | 2010-09-17 | 602d? | 260d |  | R5 | 29351.2h | 19319.6h | RANimp-UEConTest | Rel-8 | Ingbert |  |  |  |  |
| 812 | 245.1 | Conformance Test Aspects – Combination of 64QAM and MIMO for HSDPA (FDD) | 322d? | 2008-09-12 A | 2009-12-04 A | 100% |  | 2008-09-12 | 2009-12-04 | 322d? |  | finish no earlier than 2009-12-04 | R5 | 2576h | 2576h | RANimp-UEConTest_64QamMimoHsdpa | Rel-8 | Ingbert | PCG-21 | Ericsson | RP-41 | RP-091058 |
| 813 | 245.2 | Conformance Test Aspects – Improved L2 for uplink | 341d? | 2008-05-30 A | 2009-09-18 A | 100% |  | 2008-05-30 | 2009-09-18 | 341d? |  | finish no earlier than 2009-09-18 | R5 | 2728h | 2728h | RANimp-UEConTest_UplinkL2dataRates | Rel-8 | Ingbert | PCG-21 | Ericsson | RP-40 | RP-090712 |
| 814 | 245.3 | Conformance Test Aspects – 64QAM for 1.28 Mcps TDD HSDPA | 261d? | 2008-05-30 A | 2009-05-29 A | 100% |  | 2008-05-30 | 2009-05-29 | 261d? |  | finish no earlier than 2009-05-29 | R5 | 2088h | 2088h | RANimp-UEConTest_64Qam1.28TDD | Rel-8 | Ingbert | PCG-21 | ZTE | RP-40 | RP-090415 |
| 815 | 245.4 | Conformance Test Aspects – Dual-Cell HSDPA operation on adjacent carriers | 391d? | 2008-12-05 A | 2010-06-04 | 90% | 39.1d? | 2008-12-05 | 2010-06-04 | 391d? | 335d | finish no earlier than 2010-06-04 | R5 | 3128h | 2815.2h | RANimp-UEConTest_DCHSDPA | Rel-8 | Ingbert | PCG-22 | Qualcomm | RP-42 | RP-100061 |
| 816 | 245.5 | Conformance Test Aspects – Enhanced Uplink for CELL_FACH State in FDD | 326d? | 2009-03-06 A | 2010-06-04 | 80% | 65.2d? | 2009-03-06 | 2010-06-04 | 326d? | 335d | finish no earlier than 2010-06-04 | R5 | 2608h | 2086.4h | RANimp-UEConTest_EnhancedRACHCellFACHState | Rel-8 | Ingbert | PCG-22 | Nokia | RP-43 | RP-100065 |
| 817 | 245.6 | Conformance Test Aspects – Receiver Type3i | 196d? | 2009-03-06 A | 2009-12-04 A | 100% |  | 2009-03-06 | 2009-12-04 | 196d? |  | finish no earlier than 2009-12-04 | R5 | 1568h | 1568h | RANimp-UEConTest_ReceiverType3i | Rel-8 | Ingbert | PCG-22 | Qualcomm | RP-43 | RP-091066 |
| 818 | 245.7 | Conformance Test Aspects – Enhanced CELL_FACH State in LCR TDD | 341d? | 2009-05-30 A | 2010-09-17 | 50% | 170.5d? | 2009-05-30 | 2010-09-17 | 341d? | 260d | finish no earlier than 2010-09-17 | R5 | 2728h | 1364h | RANimp-UEConTest_EnhancedCellFACHStateLCRTDD | Rel-8 | Ingbert | PCG-23 | CATT | RP-44 | RP-100066 |
| 819 | 245.8 | Conformance Test Aspects – 1.28 Mcps TDD Improved L2 support for high data rates | 337d? | 2009-05-29 A | 2010-09-10 | 50% | 168.5d? | 2009-05-29 | 2010-09-10 | 337d? | 265d | finish no earlier than 2010-09-10 | R5 | 2696h | 1348h | RANimp-UEConTest_ImprovedL2LCRTDD | Rel-8 | Ingbert | PCG-23 | CATT | RP-44 | RP-100069 |
| 820 | 245.9 | Conformance Test Aspects – Continuous Connectivity for packet data users for 1.28 Mcps TDD | 261d? | 2009-09-18 A | 2010-09-17 | 35% | 169.65d? | 2009-09-18 | 2010-09-17 | 261d? | 260d | finish no earlier than 2010-09-17 | R5 | 2088h | 730.8h | RANimp-UEConTest_CPCLCRTDD | Rel-8 | Ingbert | PCG-23 | ZTE | RP-45 | RP-100075 |
| 821 | 245.10 | Conformance Test Aspects – MIMO for 1.28 Mcps TDD | 186d? | 2009-09-18 A | 2010-06-04 | 65% | 65.1d? | 2009-09-18 | 2010-06-04 | 186d? | 335d | finish no earlier than 2010-06-04 | R5 | 1488h | 967.2h | RANimp-UEConTest_MIMOLCRTDD | Rel-8 | Ingbert | PCG-23 | ZTE | RP-45 | RP-100076 |
| 822 | 245.11 | Conformance Test Aspects – HS-DSCH Serving Cell Change Enhancements | 131d? | 2009-09-18 A | 2010-03-19 A | 100% |  | 2009-09-18 | 2010-03-19 | 131d? |  | finish no earlier than 2010-03-12 | R5 | 1048h | 1048h | HSDSCH_UEConTest | Rel-8 | Ingbert | PCG-23 | Qualcomm | RP-45 | RP-100077 |
| 823 | 246 | 3.84 Mcps TDD MBSFN Integrated Mobile Broadcast | 395d? | 2007-06-04 A | 2008-12-05 A | 100% |  | 2007-06-04 | 2008-12-05 | 395d? |  |  | R1 | 3160h | 3160h | MBSFN-DOB | Rel-8 | Patrick |  | Ericsson |  | RP-080218 |
| 824 | 247 | Conformance Test Aspects – 3.84 Mcps TDD MBSFN Integrated Mobile Broadcast | 211d? | 2009-05-30 A | 2010-03-19 A | 100% |  | 2009-05-30 | 2010-03-19 | 211d? |  | finish no earlier than 2010-03-19 | R5 | 1688h | 1688h | MBSFN_IMB_UEConTest | Rel-8 | Ingbert | PCG-23 | IPwireless | RP-44 | RP-100070 |
| 825 | 248 | GERAN support for GERAN - 3G Long Term Evolution interworking | 641d? | 2006-09-08 A | 2009-02-20 A | 100% |  | 2006-09-08 | 2009-02-20 | 641d? |  | finish no earlier than 2009-02-20 | GP | 5128h | 5128h | GELTE | Rel-8 | Paolo |  | Nokia, Nokia Siemens Networks |  |  |
| 826 | 249 | U-TDOA Enhancement | 131d? | 2007-05-18 A | 2007-11-16 A | 100% |  | 2007-05-18 | 2007-11-16 | 131d? |  | finish no earlier than 2007-05-18 | GP | 1048h | 1048h | GUTEN | Rel-8 | Paolo |  | TruePosition |  |  |
| 827 | 250 | **GAN Enhancements** | 604.2d? | 2007-05-15 A | 2009-09-04 A | 100% |  | 2007-05-15 | 2009-09-04 | 604.2d? |  |  | GP | 9432h | 9432h | GANENH | Rel-8 | Paolo |  | T-Mobile |  |  |
| 828 | 250.1 | Update to GAN specifications | 126d? | 2007-08-31 A | 2008-02-22 A | 100% |  | 2007-08-31 | 2008-02-22 | 126d? |  | finish no earlier than 2008-02-22 | GP | 1008h | 1008h | GANENH-SPEC | Rel-8 | Paolo |  | T-Mobile |  |  |
| 829 | 250.2 | Update TS 51.010 Mobile Station (MS) Conformance Specification for GAN Enhancements | 526d? | 2007-05-15 A | 2009-09-04 A | 100% |  | 2007-05-15 | 2009-09-04 | 526d? |  | finish no earlier than 2009-09-04 | G3new | 4208h | 4208h | GANENH-MStest | Rel-8 | Ingbert |  | T-Mobile |  |  |
| 830 | 251 | **AoIP (A-interface over IP)** | 2335d? | 2000-01-03 A | 2008-12-11 A | 100% |  | 2000-01-03 | 2008-12-11 | 2335d? |  |  | GP,S4,C4,C1,C3 | 41412.1h | 41412.1h | AoIP | Rel-8 | Paolo | PCG-21 | China Mobile, Ericsson |  |  |
| 831 | 251.1 | GERAN aspects of AoIP | 2321d? | 2000-01-03 A | 2008-11-21 A | 100% |  | 2000-01-03 | 2008-11-21 | 2321d? |  | finish no earlier than 2008-11-21 | GP | 18560h | 18560h | AoIP | Rel-8 | Paolo | PCG-21 | China Mobile, Ericsson | SP-40 |  |
| 832 | 251.2 | Media Requirements for CS over IP based User Plane | 267d? | 2007-12-05 A | 2008-12-11 A | 100% |  | 2007-12-05 | 2008-12-11 | 267d? |  | finish no earlier than 2008-12-11 | S4 | 1996.09h | 1996.09h | AoIP-CSoIP | Rel-8 | Paolo | PCG-21 | China Mobile, Ericsson | SP-40 |  |
| 833 | 251.3 | Core Network Impacts for A-Interface User Plane over IP | 136d? | 2008-05-30 A | 2008-12-05 A | 100% |  | 2008-05-30 | 2008-12-05 | 136d? |  | start no earlier than 2008-05-30 | C4 | 1088h | 1088h | AoIP-CN | Rel-8 | Kimmo | PCG-21 | Ericsson | CP-40 |  |
| 834 | 251.4 | Core Network Impacts for A-Interface User Plane over IP | 68d? | 2008-05-30 A | 2008-12-05 A | 100% |  | 2008-05-30 | 2008-12-05 | 68d? |  | finish no earlier than 2008-12-05 | C1 | 544h | 544h | AoIP-CN | Rel-8 | Frederic | PCG-21 | Ericsson | CP-40 |  |
| 835 | 251.5 | Core Network Impacts for A-Interface User Plane over IP | 68d? | 2008-05-30 A | 2008-12-05 A | 100% |  | 2008-05-30 | 2008-12-05 | 68d? |  | finish no earlier than 2008-12-05 | C3 | 544h | 544h | AoIP-CN | Rel-8 | Gwiho | PCG-21 | Ericsson | CP-40 |  |
| 836 | 252 | New multicarrier BTS class | 261d? | 2007-08-31 A | 2008-08-29 A | 100% |  | 2007-08-31 | 2008-08-29 | 261d? |  | finish no earlier than 2008-08-29 | G1 | 2088h | 2088h | MCBTS | Rel-8 | Paolo |  | Alcatel-Lucent |  |  |

Notes:
- 811: Linked to Feature UID_20029 (RANimp)
- 812: RP#46 completed / Text3: 34.108, 34.121-1, 34.121-2, 34.123-1, 34.123-2 / Text5: leif.mattisson@ericsson.com
- 813: RP#45 completed. Testing for UID_370036 / Text3: 34.108, 34.123-1, 34.123-2, 34.123-3 / Text5: leif.mattisson@ericsson.com
- 814: RP#44 completed. Testing for UID_380075 / Text3: 34.108, 34.122, 34.123-1, 34.123-2, 34.123-3 / Text5: ma.zijiang@zte.com.cn
- 815: RP#47 completion 03/10=>06/10. Testing for UID_400052 / Text3: 34.108, 34.121-1, 34.121-2, 34.123-1, 34.123-2, 34.123-3 / Text5: Shubhang Vora (svora@qualcomm.com)
- 816: RP#47 completion 03/10=>06/10. Testing for UID_370037 / Text3: 34.108, 34.121-1, 34.121-2, 34.123-1, 34.123-2, 34.123-3 / Text5: jarkko.hellsten@nokia.com
- 817: RP#46 completed. Testing for Receiver Type3i in 25.101 UE radio Tx and Rx FDD / Text3: 34.108, 34.121-1, 34.121-2 / Text5: Ashok Kumar Narayanaswamy (anarayan@qualcomm.com)
- 818: Testing for UID_380076 / Text3: 34.108, 34.123-1, 34.123-2, 34.123-3 / Text5: Xiaozhong Chen (chenxiaozhong@datangmobile.cn)
- 819: Testing for Rel-7 UID_340039 Improved L2 support for high data rates and Rel-8 UID_370036 Improved L2 for uplink / Text3: 34.108, 34.123-1, 34.123-2, 34.123-3 / Text5: Xiaozhong Chen (chenxiaozhong@datangmobile.cn)
- 820: Testing for UID_390028 / Text3: 34.108, 34.123-1, 34.123-2, 34.123-3 / Text5: He Huang (huang.he4@zte.com.cn)
- 821: PR#47 updated WID RP-090752=>RP-100120. Testing for UID_400050 / Text3: 34.108, 34.122, 34.123-1, 34.123-2, 34.123-3 / Text5: He Huang (huang.he4@zte.com.cn)
- 822: RP#47 completed. Testing for UID_390030 / Text3: 34.108, 34.121-1, 34.121-2, 34.123-1, 34.123-2, 34.123-3 / Text5: Shubhang Vora (svora@qualcomm.com)
- 823: RP#42 completed. WID updated RP-070493=>RP-081124 (changed WI title "MBSFN Downlink Optimized Broadcast (DOB) 3.84 Mcps TDD" => "3.84Mcps TDD MBSFN Integrated Mobile Broadcast"). RP#39 SR in RP-080218. / Text3: 25.102, 25.105, 25.123, 25.201, 25.221, 25.222, 25.223, 25.224, 25.304, 25.306, 25.331, 25.346, 25.402, 25.433 / Text5: Lars.Lindbom@ericsson.com
- 824: RP#47 completed. Testing for Rel-8 MBSFN-DOB UID_360008 / Text3: 34.108, 34.122, 34.123-1, 34.123-2, 34.123-3 / Text5: Phil Young (pyoung@ipwireless.com)
- 825: GP#41 completed (MS conformance testing open) / Text3: 24.008, 43.055, 43.129, 43.246, 44.018, 44.060, 45.002, 45.008, 45.010, 48.008, 48.018, 51.010 / Text5: sergio.parolari@nsn.com, vlora.rexhepi@nokia.com
- 826: GP#36 completed U-TDOA (Uplink Time Difference of Arrival) / Text3: 43.059, 45.008, 48.071 / Text5: Terry Brooks (terri.brooks@trueposition.com)
- 827: GP#37 completed. GP#43 completed Testing / Text5: mohammed.versi@t-mobile.com
- 828: GP#37 completed / Text3: 43.318, 44.318 / Text5: mohammed.versi@t-mobile.com
- 829: GP#43 completed / Text3: 51.010 / Text5: mohammed.versi@t-mobile.com
- 830: GP#40/TSG#42 completed . Triggered by TR 43.903 Study on A-interface over IP (AINTIP) UID_50589. / Text5: wangshuaiyu@chinamobile.com, paul.schliwa-bertling@ericsson.com
- 831: GP#40 completed. GP#39 updated WID GP-080901=>GP-081362. / Text3: 48.001, 48.002, 48.008, 48.020, 49.008, 48.103 / Text5: wangshuaiyu@chinamobile.com, paul.schliwa-bertling@ericsson.com
- 832: SP#42 completed / Text3: 26.102, 26.103, 26.202 / Text5: Karl.Hellwig@Ericsson.com
- 833: CP#42 completed. Updated WID CP-080278=>CP-080722 / Text3: 23.205, 23.153, 23.231, 29.232 / Text5: philip.hodges@ericsson.com
- 834: CP#42 completed. Updated WID CP-080278=>CP-080722 / Text3: 23.009 / Text5: philip.hodges@ericsson.com
- 835: CP#42 completed. Updated WID CP-080278=>CP-080722 / Text3: 29.007 / Text5: philip.hodges@ericsson.com
- 836: GP#39 completed / Text3: 45.005, 45.050, 51.021 / Text5: thomas.bitzer@alcatel-lucent.de

| ID | WBS | Task | Type | Duration | Start | Finish | Complete | Remaining | Baseline start | Baseline finish | Baseline duration | Total slack | Constraint | Resources | Work | Actual work | Text1 | Text4 | Text6 | Text8 | Text11 | Text2 | Text3 | Text7 | Text12 | Text9 |
| --- | --- | --- | --- | --- | --- | --- | --- | --- | --- | --- | --- | --- | --- | --- | --- | --- | --- | --- | --- | --- | --- | --- | --- | --- | --- | --- |
| 837 | 253 | **Support for Additional Navigation Satellite Systems (ANSS) for LCS** |  | 150d? | 2008-05-16 A | 2008-12-11 A | 100% |  | 2008-05-16 | 2008-12-11 | 150d? |  |  | S1,G2 | 3384h | 3384h | ANSS | Qualcomm | Rel-8 | Paolo | RP-080813 |  |  |  |  |  |
| 838 | 253.1 | Stage 1 for ANSS for LCS |  | 1d? | 2008-12-11 A | 2008-12-11 A | 100% |  | 2008-12-11 | 2008-12-11 | 1d? |  | start no earlier than 2008-12-11 | S1 | 8h | 8h | ANSS |  | Rel-8 | Alain |  | PCG-22 | 22.071 | SP-42 |  |  |
| 839 | 253.2 | Support for Additional Navigation Satellite Systems (ANSS) for LCS |  | 136d? | 2008-05-16 A | 2008-11-21 A | 100% |  | 2008-05-16 | 2008-11-21 | 136d? |  | start no earlier than 2008-05-16 | G2 | 1088h | 1088h | ANSS | Qualcomm | Rel-8 | Paolo |  |  | 43.059, 44.031, 49.031, 44.071, 48.031, 51.010 |  |  |  |
| 840 | 253.3 | Support for Additional Navigation Satellite Systems (ANSS) for LCS |  | 136d? | 2008-05-30 A | 2008-12-05 A | 100% |  | 2008-05-30 | 2008-12-05 | 136d? |  | finish no earlier than 2008-12-08 | R2 | 1088h | 1088h | RANimp-ANSS | Qualcomm | Rel-8 | Joern | RP-080813 | PCG-21 | 25.305, 25.306, 25.331, 25.413, 25.423, 25.433, 25.453 | RP-40 |  |  |
| 841 | 254 | **Conformance testing for the Latency Reductions feature** |  | 532d? | 2008-02-22 A | 2010-03-05 A | 100% |  | 2008-02-22 | 2010-03-05 | 532d? |  |  | G1, G3new | 10592h | 10592h | CTLATRED | Ericsson | Rel-8 | Paolo |  | PCG-21 |  |  |  |  |
| 842 | 254.1 | MS conformance testing for the Latency Reductions feature |  | 532d? | 2008-02-22 A | 2010-03-05 A | 100% |  | 2008-02-22 | 2010-03-05 | 532d? |  | finish no earlier than 2010-03-05 | G3new | 4248h | 4248h | CTLATRED-MStest | Ericsson | Rel-8 | Ingbert |  | PCG-21 | 51.010 |  |  |  |
| 843 | 254.2 | BTS conformance testing for the Latency Reductions feature |  | 261d? | 2008-02-22 A | 2009-02-20 A | 100% |  | 2008-02-22 | 2009-02-20 | 261d? |  | finish no earlier than 2009-02-20 | G1 | 2088h | 2088h | CTLATRED-BTStest | Ericsson | Rel-8 | Paolo |  | PCG-21 | 51.021 |  |  |  |
| 844 | 255 | MS conformance testing of changes introduced by WI “Support of Packet-switched Handover for GERAN A/Gb mode” |  | 196d? | 2008-02-22 A | 2008-11-21 A | 100% |  | 2008-02-22 | 2008-11-21 | 196d? |  | finish no earlier than 2008-11-21 | G3new | 1568h | 1568h | PSHCT-MStest | Rohde & Schwarz | Rel-8 | Ingbert |  | PCG-21 | 51.010 |  |  |  |
| 845 | 256 | (Small) Technical Enhancements and Improvements for Rel-8 |  | 509d? | 2007-01-01 A | 2008-12-11 A | 100% |  | 2007-01-01 | 2008-12-11 | 509d? |  | finish no earlier than 2008-12-11 | All | 4072h | 4072h | TEI8 |  | Rel-8 |  |  |  |  |  |  |  |
| 846 | 257 | Test - (Small) Technical Enhancements and Improvements for Rel-8 |  | 672d? | 2007-03-07 A | 2010-12-24 | 80% | 134.4d? | 2007-03-07 | 2010-12-24 | 672d? | 190d | finish no earlier than 2010-12-24 | R5,G3new | 5376h | 4300.8h | TEI8_Test |  | Rel-8 | Ingbert |  | PCG-21 |  | RP-40 |  |  |
| 847 | 258 | **Deleted - All-IP Network** |  | 448d? | 2004-06-28 A | 2006-03-15 A | 100% |  | 2004-06-28 | 2006-03-15 | 448d? |  |  | S1 | 7168h | 7168h | AIPN | NTT DoCoMo | Rel-8 | Alain |  |  |  |  | SP-38 |  |
| 848 | 258.1 | Deleted - Stage 1 |  | 448d? | 2004-06-28 A | 2006-03-15 A | 100% |  | 2004-06-28 | 2006-03-15 | 448d? |  | finish no earlier than 2006-03-15 | S1 | 3584h | 3584h | AIPN | NTT DoCoMo | Rel-8 | Alain |  |  | 22.258 |  | SP-38 |  |
| 849 | 259 | Deleted - was Rel7 - LCS for 3GPP Interworking WLAN | milestone | 0d? | 2007-09-28 A | 2007-09-28 A | 100% |  | 2007-09-28 | 2007-09-28 | 0d? |  | start no earlier than 2007-09-28 | S2 |  |  | LCS4_IWLAN | LG Electronics | Rel-8 | Maurice |  |  | 23.234, 23.271, 23.167 |  | SP-35 |  |
| 850 | 260 | Deleted - never approved- FBI Phase 2 | milestone | 0d | 2007-09-28 A | 2007-09-28 A | 100% |  | 2007-09-28 | 2007-09-28 | 0d |  | start no earlier than 2007-09-28 | S2 |  |  | FBI2 | Nokia Siemens Networks | Rel-8 | Maurice |  |  |  |  | SP-38 |  |
| 851 | 261 | Deleted -Enhancements to BS30 Bearer service for Videotelephony | milestone | 0d? | 2007-03-15 A | 2007-03-15 A | 100% |  | 2007-03-15 | 2007-03-15 | 0d? |  | finish no earlier than 2007-03-15 | S1 |  |  | BS30 |  | Rel-8 | Alain |  |  | 22.002, 22.004, 22.101, 22.105, 24.008 |  | SP-38 |  |
| 852 | 262 | Deleted - IMS Enhancements Rel-8 |  | 75d? | 2007-09-03 A | 2007-12-14 A | 100% |  | 2007-09-03 | 2007-12-14 | 75d? |  |  | S1 | 600h | 600h | IMS8 | Telecom Italia | Rel-8 | Alain |  |  |  | SP-37 | SP-38 |  |
| 853 | 263 | Deleted - MS conformance testing of Support of Conversational Services in A/Gb mode via the PS domain |  | 401d? | 2008-02-25 A | 2009-09-04 A | 100% |  | 2008-02-25 | 2009-09-04 | 401d? |  | finish no earlier than 2009-09-04 | G3new | 3208h | 3208h | SCSAGBCT-MStest | Nokia | Rel-8 | Ingbert |  | PCG-21 | 51.010 |  | GP-43 | PCG-23 |
| 854 | 264 | Release 8 Studies | milestone | 0d? | 2008-03-20 | 2008-03-20 |  |  | 2008-03-20 | 2008-03-20 | 0d? | 912d | finish no earlier than 2008-03-20 | CP,GP,RP,SP |  |  |  |  | Rel-8 |  |  |  |  |  |  |  |
| 855 | 265 | Study on Customised Alerting Tone (CAT) Requirements |  | 245d? | 2005-10-07 A | 2006-09-14 A | 100% |  | 2005-10-07 | 2006-09-14 | 245d? |  | start no earlier than 2005-10-07 | S1 | 1960h | 1960h | FS_CAT | China Mobile | Rel-8 | Alain |  |  | 22.982 |  |  |  |
| 856 | 266 | Study on Facilitating Machine to Machine Communication in GSM and UMTS (M2M) |  | 350d? | 2005-11-04 A | 2007-03-08 A | 100% |  | 2005-11-04 | 2007-03-08 | 350d? |  | finish no earlier than 2006-06-16 | S1 | 2800h | 2800h | FS_M2M | Siemens | Rel-8 | Alain |  |  | 22.868 |  |  |  |
| 857 | 267 | Study on Network Composition |  | 526d? | 2005-12-07 A | 2007-12-12 A | 100% |  | 2005-12-07 | 2007-12-12 | 526d? |  | finish no earlier than 2006-09-27 | S1 | 4208h | 4208h | FS_NetComp | Nokia Siemens Networks | Rel-8 | Alain |  |  | 22.980 |  |  |  |
| 858 | 268 | Study on Requirements of IMS Multimedia Conferencing |  | 330d? | 2006-06-08 A | 2007-09-12 A | 100% |  | 2006-06-08 | 2007-09-12 | 330d? |  | finish no earlier than 2007-03-21 | S1 | 2640h | 2640h | FS_IMSconf | China Mobile | Rel-8 | Alain |  |  | 22.948 |  |  |  |
| 859 | 269 | Study on support of a Public Warning System |  | 140d? | 2007-09-03 A | 2008-03-14 A | 100% |  | 2007-09-03 | 2008-03-14 | 140d? |  |  | S1 | 1120h | 1120h | FS_PWS | T-Mobile | Rel-8 | Alain |  |  | 22.968 |  |  |  |
| 860 | 270 | Study on Paging Permission with Access Control |  | 256d? | 2006-09-28 A | 2007-09-20 A | 100% |  | 2006-09-28 | 2007-09-20 | 256d? |  | finish no earlier than 2007-09-20 | S1 | 2048h | 2048h | FS_PPAC | NTT DoCoMo | Rel-8 | Alain |  |  | 22.908 |  |  |  |
| 861 | 271 | Study on Non 3GPP access NSP |  | 392d? | 2006-12-06 A | 2008-06-05 A | 100% |  | 2006-12-06 | 2008-06-05 | 392d? |  | finish no earlier than 2007-11-19 | S1 | 3136h | 3136h | FS_N3GtoNSP | Telefonica O2 | Rel-8 | Alain |  |  | 22.912 |  |  |  |
| 862 | 272 | Study on Value Added Services for Short Message Service |  | 263d? | 2006-12-06 A | 2007-12-07 A | 100% |  | 2006-12-06 | 2007-12-07 | 263d? |  | finish no earlier than 2007-12-07 | S1 | 2104h | 2104h | FS_VAS4SMS | China Mobile | Rel-8 | Alain |  |  | 22.942 |  |  |  |
| 863 | 273 | Study on Service continuity between mobile and WLAN networks |  | 262d? | 2006-12-06 A | 2007-12-06 A | 100% |  | 2006-12-06 | 2007-12-06 | 262d? |  | finish no earlier than 2008-12-25 | S1 | 2096h | 2096h | FS_SMLSWLAN | BT | Rel-8 | Alain |  |  | 22.937 |  |  |  |
| 864 | 274 | Study on Services Alignment and Migration |  | 331d? | 2006-12-06 A | 2008-03-12 A | 100% |  | 2006-12-06 | 2008-03-12 | 331d? |  | finish no earlier than 2007-09-20 | S1 | 2648h | 2648h | FS_ServAl | China Mobile | Rel-8 | Alain |  |  | 22.983 | SP-37 |  |  |

Notes:
- 837: GP#40 completed. Align with RANimp-ANSS ongoing work item. GP#40 WID updated GP-080776=>GP-081784 (Conformance testing moved to A-GNSS WID) / Text5: Mungal Dhanda
- 838: SP#42 completed by 22.071 CR0077
- 839: GP#40 completed. Align with RANimp-ANSS ongoing work item. GP#40 WID updated GP-080776=>GP-081784 (Conformance testing moved to A-GNSS WID) / Text5: Mungal Dhanda
- 840: SR in RP-080813. RP#42 WI closed at 95%. GERAN leading the work / considers performance requirements for Rel-9 / Text5: Etienne Chaponniere (echaponn@qualcomm.com)
- 841: GP#44 completion 11/09=>03/10 / Text5: mats.y.samuelsson@ericsson.com, hakan.e.grunditz@ericsson.com
- 842: GP#45 completed / Text5: hakan.e.grunditz@ericsson.com
- 843: GP#41 completed / Text5: mats.y.samuelsson@ericsson.com
- 844: GP#40 completed / Text5: Franz.Segerer@ROHDE-SCHWARZ.COM
- 845: SP#42 completed
- 846: -
- 847: SP#38 stopped. 25/07/08 Moved UID_31059 Study on All-IP Network (FS_AIPN/was AIPFS ) to Rel-7 out of the stopped Rel-8 Feature UID_31067 Deleted - All-IP Network (AIPN) / Text5: c.masyu@nttdocomo.co.jp
- 848: 22.258 withdrawn, superseded by 22.278 (UID 320022). SP#38 stopped / Text5: c.masyu@nttdocomo.co.jp
- 849: SP-35 stopped / Text5: dhshim@lge.com
- 850: SP#38 stopped
- 851: SP#38 stopped (no support) / Text5: andre.jarvis@three.co.uk
- 852: SP#38 stopped
- 853: GP#43 work stopped/abandoned (completion 0%) / Text5: arsi.heino@nokia.com
- 854: -
- 855: Spin-off WID UID_370028 under Feature CAT UID_340029 / Text5: fenglingjuan@chinamobile.com
- 856: SP#35 completed. Spin-off SA3 SID UID_370053. SP#40 Spin-off new Feature UID_410030 (NIMTC) / Text5: Juergen Merkel
- 857: SP#38 completed / Text5: Joerg Swetina (joerg.swetina@nw.neclab.eu)
- 858: SP#37 completed. Spin-off New Feature UID_370026 (VAS4SM) / Text5: zhengjianping@chinamobile.com
- 859: SP#39 completed. Spin-off Rel-9 Feature UID_380057 (PWS) / Text5: mark.younge@t-mobile.com
- 860: SP#37 completed. Spin-off new Feature UID_370084 (PPACR) / Text5: noguchi@nttdocomo.co.jp
- 861: SP#38 completed. Spin-off New Feature UID_380062 (N3GTONSP). SP#40 WID updated SP-060930=>SP-080318. TR re-approved with new # 22.812=>22.912 / Text5: chris.friel@o2.com
- 862: SP#38 completed. Spin-off New Feature UID_370026 (VAS4SM) / Text5: wubin@chinamobile.com
- 863: SP#38 completed / Text5: mike.meyerstein@bt.com
- 864: SP#39 completed. Spin-off Feature UID_330017 (ServAl) / Text5: fenglingjuan@chinamobile.com

| ID | WBS | Task | Duration | Start | Finish | Complete | Remaining | Baseline start | Baseline finish | Baseline duration | Total slack | Constraint | Resources | Work | Actual work | Text1 | Text4 | Text5 | Text6 | Text8 | Text3 | Text2 | Text7 | Text11 | Text9 | Text12 |
| --- | --- | --- | --- | --- | --- | --- | --- | --- | --- | --- | --- | --- | --- | --- | --- | --- | --- | --- | --- | --- | --- | --- | --- | --- | --- | --- |
| 865 | 275 | **Study on 3GPP System Architecture Evolution** | 1115d? | 2004-12-03 A | 2009-03-12 A | 100% |  | 2004-12-03 | 2009-03-12 | 1115d? |  |  | S2,S3 | 23456h | 23456h | FS_SAE | Vodafone | Chris Pudney | Rel-8 | Maurice |  |  |  |  |  |  |
| 866 | 275.1 | Stage 2 Interim conclusion for RAN Work to start | 990d? | 2004-12-03 A | 2008-09-18 A | 100% |  | 2004-12-03 | 2008-09-18 | 990d? |  | finish no earlier than 2005-09-23 | S2 | 7920h | 7920h | FS_SAE | Vodafone | Chris Pudney | Rel-8 | Maurice | 23.882 |  |  |  |  |  |
| 867 | 275.2 | Stage 2 study on 3GPP architectural development | 704d? | 2006-01-09 A | 2008-09-18 A | 100% |  | 2006-01-09 | 2008-09-18 | 704d? |  | finish no earlier than 2007-09-28 | S2 | 5632h | 5632h | FS_SAE | Vodafone | Chris Pudney | Rel-8 | Maurice | 23.882 |  |  |  |  |  |
| 868 | 275.3 | Security study for Inter-access mobility between non-3GPP and 3GPP system | 334d? | 2007-09-03 A | 2009-03-12 A | 100% |  | 2007-09-03 | 2009-03-12 | 334d? |  | finish no earlier than 2009-03-12 | S3 | 2672h | 2672h | FS_SAE | Nokia | dajiang.zhang@nokia.com | Rel-8 | Dionisio | 33.821, 33.822 |  |  |  |  |  |
| 869 | 276 | Study on Stage 2 aspects of IMS Service Brokering | 589d? | 2006-06-19 A | 2008-09-18 A | 100% |  | 2006-06-19 | 2008-09-18 | 589d? |  | finish no earlier than 2008-09-18 | S2 | 4712h | 4712h | FS_ISB_ST2 | Telcordia | raquel@research.telcordia.com | Rel-8 | Maurice | 23.810 |  |  |  |  |  |
| 870 | 277 | Study on IMS utilizing multicast bearer services | 447d? | 2006-03-22 A | 2007-12-06 A | 100% |  | 2006-03-22 | 2007-12-06 | 447d? |  | finish no earlier than 2007-12-03 | S2 | 3576h | 3576h | FS_MLTICAST-IMS | Nokia Siemens Networks |  | Rel-8 | Maurice | 23.847 |  |  |  |  |  |
| 871 | 278 | Study on Mobility between 3GPP-WLAN Interworking and 3GPP Systems | 393d? | 2007-03-20 A | 2008-09-18 A | 100% |  | 2007-03-20 | 2008-09-18 | 393d? |  | finish no earlier than 2008-09-18 | S2 | 3144h | 3144h | FS_SM3GWLAN | Orange |  | Rel-8 | Maurice | 23.827 withdrawn |  |  |  |  |  |
| 872 | 279 | Study on Multimedia Session Continuity | 291d? | 2007-04-26 A | 2008-06-05 A | 100% |  | 2007-04-26 | 2008-06-05 | 291d? |  | finish no earlier than 2008-06-05 | S2 | 2328h | 2328h | FS_MMSC | LG Electronics |  | Rel-8 | Maurice | 23.893 |  |  |  |  |  |
| 873 | 280 | **Study on centralized IMS service control** | 363d? | 2006-10-23 A | 2008-03-12 A | 100% |  | 2006-10-23 | 2008-03-12 | 363d? |  |  | S2,S1 | 7952h | 7952h | FS_ICS | Ericsson | peter.bleckert@ericsson.com | Rel-8 | Alain |  | PCG-21 | SP-38 |  |  |  |
| 874 | 280.1 | Study on centralized IMS services requirements | 268d? | 2007-03-05 A | 2008-03-12 A | 100% |  | 2007-03-05 | 2008-03-12 | 268d? |  | start no earlier than 2007-03-05 | S1 | 2144h | 2144h | FS_ICS-S1 | Ericsson | peter.bleckert@ericsson.com | Rel-8 | Alain | 22.892 |  | SP-37 |  |  |  |
| 875 | 280.2 | Study on centralized IMS services control | 363d? | 2006-10-23 A | 2008-03-12 A | 100% |  | 2006-10-23 | 2008-03-12 | 363d? |  | finish no earlier than 2008-02-21 | S2 | 2904h | 2904h | FS_IMS_CSC | Alcatel-Lucent | Andy Bennett (andybennett@alcatel-lucent.com) | Rel-8 | Maurice | 23.892 |  |  |  |  |  |
| 876 | 281 | Study on Architecture of IMS based Customized Alerting Tone (CAT) | 208d? | 2007-12-04 A | 2008-09-18 A | 100% |  | 2007-12-04 | 2008-09-18 | 208d? |  | finish no earlier than 2008-09-08 | S2 | 1664h | 1664h | FS_CAT-St2 | China Mobile | WANG, Jing (wangjing@chinamobilecom) | Rel-8 | Maurice | 23.872 | PCG-21 | SP-38 |  |  |  |
| 877 | 282 | Study on Home (e)NodeB Security | 321d? | 2007-12-20 A | 2009-03-12 A | 100% |  | 2007-12-20 | 2009-03-12 | 321d? |  | finish no earlier than 2009-03-10 | S3 | 2568h | 2568h | FS_HNB_Sec | Huawei | yangyanmei@huawei.com | Rel-8 | Dionisio | 33.820 | PCG-21 | SP-38 |  |  |  |
| 878 | 283 | Study on Transferring of emergency call data – in-band modem solution | 265d? | 2006-12-07 A | 2007-12-12 A | 100% |  | 2006-12-07 | 2007-12-12 | 265d? |  | finish no earlier than 2008-09-18 | S4 | 2120h | 2120h | eCALLIBMS | Airbiquity | lhong@airbiquity.com | Rel-8 | Paolo | 26.967 |  |  |  |  |  |
| 879 | 284 | Study on Element Operations Systems Function (EOSF) definition | 266d? | 2007-06-07 A | 2008-06-12 A | 100% |  | 2007-06-07 | 2008-06-12 | 266d? |  | finish no earlier than 2008-12-11 | S5 | 2128h | 2128h | OAM7-NIM- EOSF | China Mobile | LI, Jian | Rel-8 | Dionisio | 32.819 |  |  |  |  |  |
| 880 | 285 | Study on SA5 MTOSI XML Harmonization | 351d? | 2006-05-10 A | 2007-09-12 A | 100% |  | 2006-05-10 | 2007-09-12 | 351d? |  | finish no earlier than 2007-12-14 | S5 | 2808h | 2808h | OAM8-NIM-XML | Nortel | jduguay@nortel.com | Rel-8 | Dionisio | 32.818 |  |  |  |  |  |
| 881 | 286 | Study on Common Profile Storage (CPS) Framework of User Data for network services and management | 244d? | 2006-07-03 A | 2007-06-07 A | 100% |  | 2006-07-03 | 2007-06-07 | 244d? |  | finish no earlier than 2007-06-07 | S5 | 1952h | 1952h | OAM7-CPS | T-Mobile | istvan.aba@t-mobile.at | Rel-8 | Dionisio | 32.808 |  |  |  |  |  |
| 882 | 287 | Study on Management for LTE and SAE | 526d? | 2006-12-07 A | 2008-12-11 A | 100% |  | 2006-12-07 | 2008-12-11 | 526d? |  | finish no earlier than 2008-12-11 | S5 | 4208h | 4208h | FS_OAM_LTE_SAE | Ericsson | PETERSEN, Robert | Rel-8 | Dionisio | 32.816 |  |  |  |  |  |
| 883 | 288 | Study on Charging Aspects of 3GPP System Evolution | 179d? | 2007-04-02 A | 2007-12-06 A | 100% |  | 2007-04-02 | 2007-12-06 | 179d? |  | finish no earlier than 2007-12-06 | S5 | 1432h | 1432h | FS_SAEcharg | Nokia Siemens Networks | GÖRMER, Gerald | Rel-8 | Dionisio | 32.820 |  |  |  |  |  |
| 884 | 289 | Study on AS-MRFC media server control protocol | 583d? | 2006-03-22 A | 2008-06-13 A | 100% |  | 2006-03-22 | 2008-06-13 | 583d? |  | finish no earlier than 2008-06-13 | C1 | 4664h | 4664h | MRFC | HP | mark.syrett@hp.com | Rel-8 | Frederic | 24.880 |  |  |  |  |  |
| 885 | 290 | Study on IMS Restoration Procedures | 310d? | 2007-03-26 A | 2008-05-30 A | 100% |  | 2007-03-26 | 2008-05-30 | 310d? |  | finish no earlier than 2008-05-30 | C4 | 2480h | 2480h | FS_IMS_RP | Ericsson | german.blanco@ericsson.com | Rel-8 | Kimmo | 23.820 |  |  |  |  |  |
| 886 | 291 | Study on IMS Application Server Service Data Descriptions for AS interoperability | 261d? | 2007-09-14 A | 2008-09-12 A | 100% |  | 2007-09-14 | 2008-09-12 | 261d? |  | finish no earlier than 2008-09-12 | C4 | 2088h | 2088h | FS_IMS_ASIO | Alcatel-Lucent | Jean-Jacques Trottin | Rel-8 | Kimmo | 29.864 |  |  |  |  |  |
| 887 | 292 | Study on Customized Alerting Tone (CAT) solution for voice and video call in CS domain | 261d? | 2007-09-14 A | 2008-09-12 A | 100% |  | 2007-09-14 | 2008-09-12 | 261d? |  |  | C4 | 626.4h | 626.4h | FS_CAT_VVC_CS | China Mobile | zhanghao@chinamobile.com | Rel-8 | Kimmo | 29.882 |  |  |  |  |  |
| 888 | 293 | Study on InterWorking Function between MAP based and Diameter based interfaces | 266d? | 2007-11-30 A | 2008-12-05 A | 100% |  | 2007-11-30 | 2008-12-05 | 266d? |  | finish no earlier than 2008-12-05 | C4 | 2128h | 2128h | FS_MAP2Diam | Huawei | liming49985@huawei.com | Rel-8 | Kimmo | 29.805 | PCG-21 | CP-38 |  |  |  |
| 889 | 294 | Study on Scope of future HSPA Evolution for 1.28 Mcps TDD | 186d? | 2007-09-14 A | 2008-05-30 A | 100% |  | 2007-09-14 | 2008-05-30 | 186d? |  | finish no earlier than 2008-05-30 | R1 | 1488h | 1488h | FS_RAN-LCRTDDHSPAEvo | RITT | Xu Fei | Rel-8 | Patrick | 25.824 |  | RP-37 | RP-080290 |  |  |
| 890 | 295 | Study on Synchronized E-DCH for UTRA FDD | 126d? | 2007-09-14 A | 2008-03-07 A | 100% |  | 2007-09-14 | 2008-03-07 | 126d? |  | finish no earlier than 2008-03-14 | R1 | 1008h | 1008h | FS_RAN-UplinkSync | Nokia Siemens Networks | Karri.Ranta-aho@nsn.com | Rel-8 | Patrick | 25.823 |  | RP-37 | RP-080068 |  |  |
| 891 | 296 | Study on Improved network controlled mobility between LTE and 3GPP2/mobile WiMAX radio technologies | 131d? | 2007-06-04 A | 2007-12-03 A | 100% |  | 2007-06-04 | 2007-12-03 | 131d? |  | finish no earlier than 2007-12-03 | R4 | 1048h | 1048h | FS_RAN-LTEmob | Motorola | hao.bi@Motorola.com | Rel-8 | Issam | 36.938 |  |  | RP-070827 |  |  |
| 892 | 297 | Study on 3G Home NodeB/eNodeB | 325d? | 2007-03-05 A | 2008-05-30 A | 100% |  | 2007-03-05 | 2008-05-30 | 325d? |  | finish no earlier than 2008-05-30 | R4 | 2600h | 2600h | FS_RAN-HNBeNB | Motorola | howard.thomas@motorola.com | Rel-8 | Issam | 25.820 |  |  | RP-080289 |  |  |
| 893 | 298 | Study on HS-PDSCH serving cell change enhancements | 60d? | 2007-12-17 A | 2008-03-07 A | 100% |  | 2007-12-17 | 2008-03-07 | 60d? |  | finish no earlier than 2008-06-12 | R4 | 480h | 480h | FS_RAN-HSPDSCH | Qualcomm |  | Rel-8 | Issam | none | PCG-21 | RP-38 | RP-080070 |  |  |
| 894 | 299 | Study on Dual-Cell HSDPA operation | 261d? | 2007-08-15 A | 2009-03-06 A | 100% |  | 2007-08-15 | 2009-03-06 | 261d? |  | finish no earlier than 2009-03-06 | R1 | 2088h | 2088h | FS_RAN-DCHS | Qualcomm | Josef Blanz | Rel-8 | Patrick | withdrawn 25.825 v100 | PCG-21 | RP-39 | RP-090066 |  |  |
| 895 | 300 | Study on A-interface over IP | 126d? | 2007-08-31 A | 2008-02-22 A | 100% |  | 2007-08-31 | 2008-02-22 | 126d? |  | finish no earlier than 2008-02-22 | GP | 1008h | 1008h | AINTIP | China Mobile, Ericsson | paul.schliwa-bertling@ericsson.com | Rel-8 | Paolo | 43.903 |  |  |  |  |  |
| 896 | 301 | Study on Multi-User Reusing-One-Slot | 602d? | 2007-11-16 A | 2010-03-05 | 98% | 12.04d? | 2007-11-16 | 2010-03-05 | 602d? | 400d | finish no earlier than 2010-03-05 | GP | 4808h | 4711.68h | MUROS | Nokia Siemens Networks | juergen.hofmann@nsn.com | Rel-8 | Paolo | 45.914 |  |  | GP-092021 |  |  |
| 897 | 302 | Study on Optimized Transmit Pulse Shape for Downlink EGPRS2-B | 602d? | 2007-11-16 A | 2010-03-05 | 95% | 30.1d? | 2007-11-16 | 2010-03-05 | 602d? | 400d | finish no earlier than 2010-03-05 | G1 | 4808h | 4567.2h | WIDER | RIM, Nokia Siemens Networks | jdwyer@RIM.COM and eddie.riddington@nsn.com | Rel-8 | Paolo | 45.913 |  |  | GP-092126 |  |  |
| 898 | 303 | Deleted - equals 340035 -FS on Service continuity between mobile and WLAN networks | 75d? | 2007-09-03 A | 2007-12-14 A | 100% |  | 2007-09-03 | 2007-12-14 | 75d? |  | finish no earlier than 2007-12-14 | S1 | 600h | 600h | FSSCMobToW | BT | mike.meyerstein@bt.com | Rel-8 | Alain | 22.937 |  | SP-37 |  | PCG-21 | SP-39 |
| 899 | 304 | Deleted - Study on Evaluation of LCS Control Plane Solution for EPS | 100d? | 2008-01-14 A | 2008-05-30 A | 100% |  | 2008-01-14 | 2008-05-30 | 100d? |  | finish no earlier than 2009-03-20 | S2 | 800h | 800h | FS_LCS_EPS | SiRF |  | Rel-8 | Maurice | 23.891 |  | SP-38 |  | PCG-21 | SP-40 |
| 900 | 305 | Release 7 Features | 1d? | 2000-01-03 | 2000-01-03 |  |  | 2000-01-03 | 2000-01-03 | 1d? | 3056d | start no earlier than 2000-01-01 | CP,GP,RP,SP | 8h |  |  |  |  | Rel-7 |  |  |  |  |  |  |  |

Notes:
- 865: SP#43 completed
- 866: SP#41 completed
- 867: SP#41 completed
- 868: SP#43 completed
- 869: SP#41 completed. No spin-off activity proposed. [Note: IMS Service Brokering enhancements UID_31088 moved back from R8 to R7 to give a home to 22228CR0036_(Rel-7)_S1-051232. Hence, Rel-7 ISB has Stage 1 only (and is misaligned with Rel-7 Stages 2/3.]
- 870: SP#38 completed
- 871: 08/08/08 TR 23.827 v 0.4.0 no progress for 1 year. MCC recommended FS be completed and 23.827 brought under CR. SP#41 completed (draft TR 23.827 not SA approved/published; TR content implemented in TSs)
- 872: SP#40 completed
- 873: SP#39 completed
- 874: SP#39 completed
- 875: SP#39 completed
- 876: SP#41 completed as Rel-8
- 877: SP#43 completed
- 878: SP#38 completed. Spin-off WID UID_34042 (eCall_Phase2)
- 879: SP#40 completed. SID updated SP-050608=>SP-070307
- 880: SP#37 completed. SID updated SP-050295=>SP-070305
- 881: SP#36 completed. Spin-off New Feature UID_400034 (UDC)
- 882: SP#42 completed
- 883: SP#38 completed
- 884: CP#40 completed. Spin-off New Feature UID_380035 (MRFC_TS)
- 885: CP#40 completed. Spin-off WID UID_400012 (IMS_RP)
- 886: CP#41 completed. Linked to SA5 Study on Common Profile Storage framework UID_320006. Spin-off WID UID_410003 (IMS_ASIO)
- 887: CP#41 completed. Spin-off WID under Feature CAT UID_340029
- 888: CP#41 Spin-off WID UID_410007 (MAP2Diam). CP#42 completed
- 889: RP#40 completed. SR in RP-080290
- 890: SID in RP-070678. RP#39 completed. SR in RP-080068
- 891: RP#38 completed. SR in RP-070827
- 892: RP#40 completed. SR in RP-080289
- 893: SID in RP-071044. SR in RP-080070. The study produced no TR. RP#39 completed. Spin-off New implementation WID in RP-080227
- 894: RP#43 closed. TR 25.825 v100 withdrawn. Conclusions in RP-090318 RAN1 findings of the UTRA Multi-Carrier Evolution study). RP#42 New WID RP-080490 (RANimp-DCHSDPA) UID_400052 approved
- 895: GP#37 completed. Spin-off implementation Feature AoIP (A-interface over IP) UID_50591
- 896: GP#45 completion 03/10=>09/10 (was 11/08=>02/09=>05/09=>11/09=>03/10). Spin-off implementation WI UID_420002 VAMOS (Voice services over Adaptive Multi-user channels on One Slot)
- 897: GP#45 completion =03/10=>09/10 (was 11/08=>02/09=>05/09=>11/09=>03/10)
- 898: SP#39 stopped
- 899: SP#40 spin-off Feature UID_400038 (LCS_CPS_EPS). SP#40 FS stopped
- 900: -

| ID | WBS | Task | Type | Duration | Start | Finish | Complete | Baseline start | Baseline finish | Baseline duration | Constraint | Resources | Work | Actual work | Text1 | Text4 | Text5 | Text6 | Text8 | Text12 | Text11 | Text7 | Text2 |
| --- | --- | --- | --- | --- | --- | --- | --- | --- | --- | --- | --- | --- | --- | --- | --- | --- | --- | --- | --- | --- | --- | --- | --- |
| 901 | 306 | **Identification of Communication Services in IMS** |  | 620d? | 2005-05-02 A | 2007-09-14 A | 100% | 2005-05-02 | 2007-09-14 | 620d? |  | S2,S1,C1,S5 | 13016h | 13016h | ServID | Ericsson | stephen.terrill@ericsson.com | Rel-7 | Maurice |  |  |  |  |
| 902 | 306.1 | TR on ServID |  | 232d? | 2005-05-02 A | 2006-03-21 A | 100% | 2005-05-02 | 2006-03-21 | 232d? | finish no earlier than 2006-03-20 | S2 | 1856h | 1856h | ServID | Ericsson | stephen.terrill@ericsson.com | Rel-7 | Maurice |  |  |  |  |
| 903 | 306.2 | Stage 1,2 of ServID |  | 144d? | 2005-11-11 A | 2006-05-31 A | 100% | 2005-11-11 | 2006-05-31 | 144d? | start no earlier than 2005-11-11 | S1,S2 | 1152h | 1152h | ServID | Ericsson | stephen.terrill@ericsson.com | Rel-7 | Maurice |  |  |  |  |
| 904 | 306.3 | Stage 3 of ServID |  | 250d? | 2006-03-31 A | 2007-03-15 A | 100% | 2006-03-31 | 2007-03-15 | 250d? | finish no earlier than 2007-03-15 | C1 | 2000h | 2000h | ServID | Ericsson | christer.holmberg@ericsson.com | Rel-7 | Frederic |  |  |  |  |
| 905 | 306.4 | Charging of ServID |  | 381d? | 2006-03-31 A | 2007-09-14 A | 100% | 2006-03-31 | 2007-09-14 | 381d? | finish no earlier than 2007-09-14 | S5 | 3048h | 3048h | ServID | Orange | alain.bibas@orange-ft.com | Rel-7 | Dionisio |  |  |  |  |
| 906 | 307 | **Supporting Globally Routable User Agent URIs in IMS** |  | 415d? | 2005-11-14 A | 2007-06-15 A | 100% | 2005-11-14 | 2007-06-15 | 415d? |  | S2,S1,C1 | 7760h | 7760h | GRUU | RIM | Adrian Buckley (abuckley@rim.com) | Rel-7 | Maurice |  |  |  |  |
| 907 | 307.1 | Deleted - TR on GRUU |  | 219d? | 2005-11-14 A | 2006-09-14 A | 100% | 2005-11-14 | 2006-09-14 | 219d? | finish no earlier than 2006-09-14 | S2 | 1752h | 1752h | GRUU | RIM | Adrian Buckley (abuckley@rim.com) | Rel-7 | Maurice | SP-32 |  |  |  |
| 908 | 307.2 | Stage 1,2 of GRUU |  | 65d? | 2006-07-03 A | 2006-09-29 A | 100% | 2006-07-03 | 2006-09-29 | 65d? | start no earlier than 2006-07-03 | S1,S2 | 520h | 520h | GRUU | RIM | Adrian Buckley (abuckley@rim.com) | Rel-7 | Maurice |  |  |  |  |
| 909 | 307.3 | Stage 3 of GRUU |  | 271d? | 2006-06-02 A | 2007-06-15 A | 100% | 2006-06-02 | 2007-06-15 | 271d? | finish no earlier than 2007-06-15 | C1 | 2168h | 2168h | GRUU | CableLabs | Bernie McKibben | Rel-7 | Frederic |  |  |  |  |
| 910 | 308 | **Multimedia Telephony Service for IMS** |  | 357d? | 2006-02-01 A | 2007-06-15 A | 100% | 2006-02-01 | 2007-06-15 | 357d? |  | S1,C1,S4 | 8976h | 8976h | MTSI | Ericsson | peter.bleckert@ericsson.com | Rel-7 | Alain |  |  |  |  |
| 911 | 308.1 | Stage 1 of MTSI |  | 173d? | 2006-02-01 A | 2006-09-29 A | 100% | 2006-02-01 | 2006-09-29 | 173d? | start no earlier than 2006-02-01 | S1 | 1384h | 1384h | MTSI-REQ | Ericsson | peter.bleckert@ericsson.com | Rel-7 | Alain |  |  |  |  |
| 912 | 308.2 | Stage 3 of MTSI |  | 330d? | 2006-03-10 A | 2007-06-14 A | 100% | 2006-03-10 | 2007-06-14 | 330d? | finish no earlier than 2007-06-15 | C1 | 2640h | 2640h | MTSI | Ericsson | christer.holmberg@ericsson.com | Rel-7 | Frederic |  |  |  |  |
| 913 | 308.3 | Media handling and interaction in MTSI |  | 262d? | 2006-03-15 A | 2007-03-15 A | 100% | 2006-03-15 | 2007-03-15 | 262d? | finish no earlier than 2007-03-15 | S4 | 2096h | 2096h | MTSI-MHI | Ericsson | olle.franceschi@ericsson.com | Rel-7 | Paolo |  |  |  |  |
| 914 | 308.4 | Deleted - duplicates UID7039 - IMS Multimedia Telephony Service | milestone | 0d? | 2007-06-15 A | 2007-06-15 A | 100% | 2007-06-15 | 2007-06-15 | 0d? | start no earlier than 2007-06-15 | S1 |  |  | MMTEL | Ericsson | peter.bleckert@ericsson.com | Rel-7 | Alain | SP-32 |  |  |  |
| 915 | 309 | Multimedia Telephony Service for IMS (MTSI) - UE Conformance Testing |  | 387d | 2007-09-19 A | 2009-03-12 A | 100% | 2007-09-19 | 2009-03-12 | 387d | finish no earlier than 2009-03-13 | R5 | 1664h | 1664h | MTSI-UEConfTest | Ericsson, Motorola | Leif.Mattisson@ericsson.com, Jacob.John@motorola.com | Rel-7 | Ingbert |  | RP-090056 |  |  |
| 916 | 310 | TISPAN requirements for Multimedia Telephony with PSTN/ISDN simulation services |  | 58d? | 2007-09-18 A | 2007-12-06 A | 100% | 2007-09-18 | 2007-12-06 | 58d? | start no earlier than 2007-09-18 | S1 | 464h | 464h | TMMTEL7 |  |  | Rel-7 | Alain |  |  | SP-37 |  |
| 917 | 311 | **Maintenance of TISPAN release 1 common IMS** |  | 58d? | 2007-09-18 A | 2007-12-06 A | 100% | 2007-09-18 | 2007-12-06 | 58d? |  | S2 | 1392h | 1392h | MCIMSTR1 | Ericsson | Raymond Forbes | Rel-7 | Maurice |  |  | SP-38 | PCG-21 |
| 918 | 311.1 | SA1 aspects of MCIMSTR1 |  | 58d? | 2007-09-18 A | 2007-12-06 A | 100% | 2007-09-18 | 2007-12-06 | 58d? | finish no earlier than 2007-12-06 | S1 | 464h | 464h | MCIMSTR1-S1 | Telecom Italia | Marco.DeLuca1@telecomitalia.it | Rel-7 | Alain |  |  | SP-38 | PCG-21 |
| 919 | 311.2 | SA2 aspects of MCIMSTR1 |  | 58d? | 2007-09-18 A | 2007-12-06 A | 100% | 2007-09-18 | 2007-12-06 | 58d? | finish no earlier than 2007-12-06 | S2 | 464h | 464h | MCIMSTR1-S2 | Ericsson | Raymond Forbes | Rel-7 | Maurice |  |  | SP-38 | PCG-21 |
| 920 | 312 | **PS domain and IMS impacts for supporting IMS Emergency calls** |  | 1760d? | 2000-09-18 A | 2007-06-15 A | 100% | 2000-09-18 | 2007-06-15 | 1760d? |  | S2,S1 | 44157h | 44157h | EMC1 | Siemens | Rainer Liebhart | Rel-7 | Maurice |  |  |  |  |
| 921 | 10.1.1 | Service Requirements for IP-based emergency calls |  | 985d | 2000-09-18 A | 2004-06-25 A | 100% | 2000-09-18 | 2004-06-25 | 985d | finish no earlier than 2004-06-25 | S1 | 7880h | 7880h | EMC1 | Siemens | Rainer Liebhart | Rel-7 | Alain |  |  |  |  |
| 922 | 312.2 | Study on Stage 2 for IMS-level solution |  | 668d? | 2003-02-26 A | 2005-09-16 A | 100% | 2003-02-26 | 2005-09-16 | 668d? | finish no earlier than 2005-09-16 | S2 | 5344h | 5344h | EMC1 | Siemens | Rainer Liebhart | Rel-7 | Maurice |  |  |  |  |
| 923 | 312.3 | Study on Stage 2 for GPRS-level solution |  | 301d? | 2004-10-14 A | 2005-12-08 A | 100% | 2004-10-14 | 2005-12-08 | 301d? | finish no earlier than 2005-12-08 | S2 | 2408h | 2408h | EMC1 | Siemens | Rainer Liebhart | Rel-7 | Maurice |  |  |  |  |
| 924 | 312.4 | Stage 2 Specification Phase - IMS-level |  | 200d? | 2005-09-05 A | 2006-06-09 A | 100% | 2005-09-05 | 2006-06-09 | 200d? | finish no earlier than 2006-06-09 | S2 | 1600h | 1600h | EMC1 | Siemens | Rainer Liebhart | Rel-7 | Maurice |  |  |  |  |
| 925 | 312.5 | Deleted - Stage 2 Specification Phase - GPRS-level | milestone | 0d? | 2007-03-02 A | 2007-03-02 A | 100% | 2007-03-02 | 2007-03-02 | 0d? | start no earlier than 2007-03-02 | S2 |  |  | EMC1 | Siemens | Rainer Liebhart | Rel-7 | Maurice | SP-32 |  |  |  |

Notes:
- 901: WID approved SP#28. WID updated SP#32
- 902: - / Text3: 23.816
- 903: - / Text3: 22.228, 23.228, 23.203
- 904: CP#32 approved WID / Text3: 23.218, 24.229
- 905: - / Text3: 32.260, 32.298, 32.299
- 906: SP#29 approved WID
- 907: Abandoned
- 908: SP#29 approved WID / Text3: 22.228, 23.228, 23.218, 24.229
- 909: CP#32 approved WID / Text3: 24.229
- 910: -
- 911: - / Text3: 22.173
- 912: - / Text3: 24.173
- 913: - / Text3: 26.114
- 914: - / Text3: 22.173
- 915: RP#43 completed. Linked UID_7038 (MTSI) / Text3: 34.123-1, 34.123-2, 34.123-3, 34.229-1, 34.229-2
- 916: - / Text3: 22.273 (EI 181 002 maintenance)
- 917: - / Text3: http://www.3gpp.org/specs/TISPAN-IMS-ansfer.htm
- 918: - / Text3: 22.173, 22.273
- 919: - / Text3: 23.406, 23.417, 23.508,23.509, 23.511
- 920: -
- 921: - / Text3: 22.976 (DB shows 04/2003 withdrawn Study on PS domain services and capabilities (az: belongs this really here ?!)
- 922: - / Text3: 23.867
- 923: - / Text3: 23.867
- 924: - / Text3: 23.167, 23.228, 23.060, 23.002, 23.271
- 925: -

| ID | WBS | Task | Type | Duration | Start | Finish | Complete | Baseline start | Baseline finish | Baseline duration | Constraint | Resources | Work | Actual work | Text1 | Text4 | Text5 | Text6 | Text8 | Text3 | Text12 | Text10 | Text11 |
| --- | --- | --- | --- | --- | --- | --- | --- | --- | --- | --- | --- | --- | --- | --- | --- | --- | --- | --- | --- | --- | --- | --- | --- |
| 926 | 10.1 | **Emergency Call Enhancements for IP& PS Based Calls – stage 3** |  | 375d | 2006-01-09 A | 2007-06-15 A | 100% | 2006-01-09 | 2007-06-15 | 375d |  | C1 | 12845h | 12845h | EMC1 | Ericsson | alf.heidermark@ericsson.com | Rel-7 | Frederic |  |  |  |  |
| 927 | 10.1.2 | CT1 IMS aspects to support IMS Emergency sessions |  | 350.82d | 2006-01-09 A | 2007-06-15 A | 100% | 2006-01-09 | 2007-06-15 | 350.82d | finish no earlier than 2007-06-15 | C1 | 2806.57h | 2806.57h | EMC1 | Ericsson | alf.heidermark@ericsson.com | Rel-7 | Frederic | 24.229 |  |  |  |
| 928 | 10.1.2 | Deleted - CT3 IMS aspects to support IMS Emergency sessions |  | 95d | 2006-05-08 A | 2006-09-15 A | 100% | 2006-05-08 | 2006-09-15 | 95d | finish no earlier than 2006-09-15 | C3 | 760h | 760h | EMC1 | Ericsson | alf.heidermark@ericsson.com | Rel-7 | Gwiho | 29.163 | CP-33 |  |  |
| 929 | 10.1.5 | Deleted - CT3 PS domain aspects to support IMS Emergency sessions |  | 95d | 2006-05-08 A | 2006-09-15 A | 100% | 2006-05-08 | 2006-09-15 | 95d | start no earlier than 2006-05-08 | C3 | 760h | 760h | EMC1 | Ericsson | alf.heidermark@ericsson.com | Rel-7 | Gwiho | 29.061 | CP-33 |  |  |
| 930 | 10.1.5 | CT1 PS domain aspects to support IMS Emergency sessions |  | 349.9d | 2006-01-09 A | 2007-06-15 A | 100% | 2006-01-09 | 2007-06-15 | 349.9d | finish no earlier than 2007-06-15 | C1 | 2799.2h | 2799.2h | EMC1 | Ericsson | alf.heidermark@ericsson.com | Rel-7 | Frederic | 24.008, 24.234 |  |  |  |
| 931 | 10.1.5 | CT4 PS domain aspects to support IMS Emergency sessions |  | 365d | 2006-01-09 A | 2007-06-01 A | 100% | 2006-01-09 | 2007-06-01 | 365d | finish no earlier than 2007-06-01 | C4 | 2920h | 2920h | EMC1-GPRSc4 | Ericsson | alf.heidermark@ericsson.com | Rel-7 | Kimmo | 29.060 |  |  |  |
| 932 | 313 | IMS Support of Conferencing |  | 355d? | 2005-11-04 A | 2007-03-15 A | 100% | 2005-11-04 | 2007-03-15 | 355d? | finish no earlier than 2007-03-15 | C1 | 2840h | 2840h | IMSconf | Alcatel-Lucent | Keith Drage (drage@alcatel-lucent.com) | Rel-7 | Frederic | 24.147, 24.229 |  |  |  |
| 933 | 314 | Performance Characterization of VoIMS over HSDPA\EUL channels |  | 713d? | 2005-03-15 A | 2007-12-06 A | 100% | 2005-03-15 | 2007-12-06 | 713d? | finish no earlier than 2007-12-06 | S4 | 5704h | 5704h | VoIMS-PCVoIMS | Alcatel-Lucent | mcgowan@alcatel-lucent.com | Rel-7 | Paolo | 26.935 |  |  |  |
| 934 | 315 | **WLAN-UMTS Interworking Phase 2** |  | 371d? | 2004-01-05 A | 2005-06-07 A | 100% | 2004-01-05 | 2005-06-07 | 371d? |  | S1 | 3888h | 3888h | WLAN2 | Telenor | frederic.paint@telenor.com | Rel-7 | Alain | 33.234 (SP-36 SA3 CRs approved) |  |  |  |
| 935 | 315.1 | Stage 1 on Session Continuity |  | 115d? | 2004-01-05 A | 2004-06-11 A | 100% | 2004-01-05 | 2004-06-11 | 115d? | start no earlier than 2004-01-05 | S1 | 920h | 920h | WLAN-SC |  |  | Rel-7 | Alain | 22.234 |  | SP-24 |  |
| 936 | 315.2 | Stage 2 on Session Continuity: covered by SAE | milestone | 0d? | 2005-06-07 A | 2005-06-07 A | 100% | 2005-06-07 | 2005-06-07 | 0d? | finish no earlier than 2005-06-07 | S2 |  |  | WLAN-SC |  |  | Rel-7 | Maurice |  |  |  |  |
| 937 | 316 | **WLAN Interworking – Private Network access from WLAN 3GPP IP Access** |  | 252d? | 2005-10-10 A | 2006-09-26 A | 100% | 2005-10-10 | 2006-09-26 | 252d? |  | S2,C1,C3,C4 | 8936h | 8936h | WLANPNA | NEC | Toshiyuki Tamura (tamurato@aj.jp.nec.com) | Rel-7 | Maurice |  |  |  |  |
| 938 | 316.1 | WLAN-PNA - Stage 2 |  | 185d? | 2005-10-10 A | 2006-06-23 A | 100% | 2005-10-10 | 2006-06-23 | 185d? | start no earlier than 2005-10-10 | S2 | 1480h | 1480h | WLANPNA-st2 | NEC | Toshiyuki Tamura (tamurato@aj.jp.nec.com) | Rel-7 | Maurice | 23.234, 33.234 |  |  |  |
| 939 | 316.2 | **WLAN-PNA - Stage 3** |  | 170d? | 2006-02-01 A | 2006-09-26 A | 100% | 2006-02-01 | 2006-09-26 | 170d? |  | C1,C3,C4 | 5440h | 5440h | WLANPNA-st3 | NEC |  | Rel-7 | Frederic |  |  |  |  |
| 940 | 316.2.1 | CT1 aspets for WLAN-PNA |  | 170d? | 2006-02-01 A | 2006-09-26 A | 100% | 2006-02-01 | 2006-09-26 | 170d? | start no earlier than 2006-02-01 | C1 | 1360h | 1360h | WLANPNA-st3 | NEC |  | Rel-7 | Frederic | 24.234 |  |  |  |
| 941 | 316.2.2 | CT3 aspets for WLAN-PNA |  | 170d? | 2006-02-01 A | 2006-09-26 A | 100% | 2006-02-01 | 2006-09-26 | 170d? | start no earlier than 2006-02-01 | C3 | 1360h | 1360h | WLANPNA-st3 | NEC |  | Rel-7 | Gwiho | 29.161 |  |  |  |
| 942 | 316.2.3 | Deleted - CT4 aspets for WLAN-PNA |  | 170d? | 2006-02-01 A | 2006-09-26 A | 100% | 2006-02-01 | 2006-09-26 | 170d? | start no earlier than 2006-02-01 | C4 | 1360h | 1360h | WLANPNA-st3 | NEC |  | Rel-7 | Kimmo | 29.234 | CP-32 |  |  |
| 943 | 317 | **Enhancements to support QoS provisioning over 3GPP/WLAN Interworking** |  | 520d? | 2005-03-14 A | 2007-03-09 A | 100% | 2005-03-14 | 2007-03-09 | 520d? |  | S2,C4,C1 | 8360h | 8360h | WLANQOS | Samsung |  | Rel-7 | Maurice |  |  |  |  |
| 944 | 317.1 | Deleted - TR on support of QoS on WLAN |  | 232d? | 2005-03-14 A | 2006-01-31 A | 100% | 2005-03-14 | 2006-01-31 | 232d? | start no earlier than 2005-03-14 | S2 | 1856h | 1856h | WLANQOS | Samsung |  | Rel-7 | Maurice | 23.836 | SP-32 |  |  |
| 945 | 317.2 | Stage 2 on support of QoS over 3GPP/WLAN interworking |  | 108d? | 2006-02-01 A | 2006-06-30 A | 100% | 2006-02-01 | 2006-06-30 | 108d? | start no earlier than 2006-02-01 | S2 | 864h | 864h | WLANQOS | Samsung |  | Rel-7 | Maurice | 23.234 |  |  |  |
| 946 | 317.3 | Stage 3 CT4 on support of QoS over 3GPP/WLAN Interworking |  | 121d? | 2006-09-22 A | 2007-03-09 A | 100% | 2006-09-22 | 2007-03-09 | 121d? | finish no earlier than 2007-03-09 | C4 | 968h | 968h | WLANQOS | Huawei | zhang.peng@huawei.com | Rel-7 | Kimmo | 29.234, 23.008 |  |  |  |
| 947 | 317.4 | Stage 3 CT1 on support of QoS over 3GPP/WLAN Interworking |  | 64d? | 2006-09-04 A | 2006-11-30 A | 100% | 2006-09-04 | 2006-11-30 | 64d? | finish no earlier than 2006-11-30 | C1 | 512h | 512h | WLANQOS | Huawei | zhang.peng@huawei.com | Rel-7 | Frederic | 24.234 |  |  |  |
| 948 | 318 | **Location Services enhancements** |  | 906d? | 2004-06-28 A | 2007-12-17 A | 100% | 2004-06-28 | 2007-12-17 | 906d? |  | S1,S2,GP,C4,R2 | 46933.6h | 46933.6h | LCS3 |  |  | Rel-7 | Alain |  |  |  |  |
| 949 | 318.1 | Stage 2 for LCS3 (including IMS emergency location aspects) |  | 446d? | 2004-12-31 A | 2006-09-15 A | 100% | 2004-12-31 | 2006-09-15 | 446d? | finish no earlier than 2006-09-15 | S2 | 3568h | 3568h | LCS3 | SiRF | brodilitz@sirf.com | Rel-7 | Maurice | 23.271 |  |  |  |
| 950 | 318.2 | LCS Enhancements related to Location-Based Services |  | 695d? | 2005-01-03 A | 2007-08-31 A | 100% | 2005-01-03 | 2007-08-31 | 695d? | finish no earlier than 2007-08-31 | GP | 5560h | 5560h | LCS3-LBS | SiRF | kjudge@sirf.com | Rel-7 | Paolo | 43.059, 44.031, 48.008, 49.031 |  |  |  |
| 951 | 318.3 | CT4 aspects for LCS UEPos-LBS |  | 240d? | 2006-01-02 A | 2006-12-01 A | 100% | 2006-01-02 | 2006-12-01 | 240d? | finish no earlier than 2006-12-01 | C4 | 1920h | 1920h | LCS3-UEPos-LBS | SiRF | brodilitz@sirf.com | Rel-7 | Kimmo | 24.030, 24.080, 29.002 |  |  |  |
| 952 | 318.4 | UE positioning - Velocity |  | 394d? | 2005-03-15 A | 2006-09-15 A | 100% | 2005-03-15 | 2006-09-15 | 394d? | finish no earlier than 2006-09-15 | R2 | 3152h | 3152h | LCS3-UEPos-Velocity | SiRF | BRodilitz@SiRF.com | Rel-7 | Joern | 25.305, 25.331, 25.410, 25.413, 25.453 |  |  | RP-060459 |
| 953 | 318.5 | Inclusion of Uplink TDOA UE positioning method in the UTRAN specifications |  | 849d? | 2004-09-15 A | 2007-12-17 A | 100% | 2004-09-15 | 2007-12-17 | 849d? | finish no earlier than 2007-12-17 | R2 | 6792h | 6792h | LCS3-UEPos-UTDOA | TruePosition | Robert Gross | Rel-7 | Joern | 25.305, 25.453 |  |  | RP-070797 |

Notes:
- 926: -
- 927: -
- 928: Cancelled for Rel-7 and there is now corresponding Rel-8 WI
- 929: Cancelled for Rel-7 and there is now corresponding Rel-8 WI
- 930: -
- 931: -
- 932: CP#35 revised WID
- 933: -
- 934: Created at TSG#27 because of WLAN items belonging to Rel-7
- 935: -
- 936: -
- 937: -
- 938: Approved at SP#29
- 939: Approved at CP#29
- 940: Approved at CP#29
- 941: Approved at CP#29
- 942: CT4#31; no impacts identified, therefore completed. CP-32 stopped
- 943: Moved from FS section Feb 06. SP-30 updated WID
- 944: SP-32 stopped
- 945: SP-30 updated WID
- 946: CP-32 approved WID
- 947: CP-32 approved WID
- 948: -
- 949: SP#27 approved WID.
- 950: -
- 951: -
- 952: Completed Sept 2006; SR in RP-060459
- 953: Completed Nov 2007; SR in RP-070797

| ID | WBS | Task | Type | Duration | Start | Finish | Complete | Baseline start | Baseline finish | Baseline duration | Constraint | Resources | Work | Actual work | Text1 | Text4 | Text5 | Text6 | Text8 | Text12 | Text11 | Text2 | Text7 |
| --- | --- | --- | --- | --- | --- | --- | --- | --- | --- | --- | --- | --- | --- | --- | --- | --- | --- | --- | --- | --- | --- | --- | --- |
| 954 | 318.6 | **LCS for 3GPP Interworking WLAN** |  | 700d? | 2004-06-28 A | 2007-03-02 A | 100% | 2004-06-28 | 2007-03-02 | 700d? |  | S1 | 11901.6h | 11901.6h | LCS3-IWLAN | Telcordia | Mike Loushine | Rel-7 | Alain |  |  |  |  |
| 955 | 318.6.1 | FS on 3GPP system to WLAN Interworking with LCS |  | 512.7d? | 2004-06-28 A | 2006-06-30 A | 100% | 2004-06-28 | 2006-06-30 | 512.7d? | finish no earlier than 2005-09-29 | S1 | 4101.6h | 4101.6h | LCS3-IWLAN-FSs1 | Telcordia | Mike Loushine, Vijay Varma | Rel-7 | Alain |  |  |  |  |
| 956 | 318.6.2 | Deleted - Study of work on an LCS architecture for I-WLAN. |  | 180d? | 2006-06-26 A | 2007-03-02 A | 100% | 2006-06-26 | 2007-03-02 | 180d? | finish no earlier than 2007-03-02 | S2 | 1440h | 1440h | LCS3-IWLAN-FSs2 | LG Electronics | dhshim@lge.com ; phede@lge.com | Rel-7 | Maurice | SP-35 |  |  |  |
| 957 | 318.6.3 | Stage 2 for LCS architecture for I-WLAN |  | 95d? | 2006-10-23 A | 2007-03-02 A | 100% | 2006-10-23 | 2007-03-02 | 95d? | finish no earlier than 2007-03-02 | S2 | 760h | 760h | LCS3-IWLAN | LG Electronics | dhshim@lge.com ; phede@lge.com | Rel-7 | Maurice |  |  |  |  |
| 958 | 318.7 | Deleted - UE positioning Rel-7 |  | 849d? | 2004-09-15 A | 2007-12-17 A | 100% | 2004-09-15 | 2007-12-17 | 849d? |  | RP | 6792h | 6792h | LCS3-UEpos |  |  | Rel-7 |  | RP-38 |  |  |  |
| 959 | 318.8 | Deleted - RAN2 aspects for LBS | milestone | 0d? | 2005-06-15 A | 2005-06-15 A | 100% | 2005-06-15 | 2005-06-15 | 0d? | start no earlier than 2005-06-15 | R2 |  |  | LCS3-UEPos-LBS | SiRF | BRodilitz@SiRF.com | Rel-7 | Joern | RP-31 |  |  |  |
| 960 | 319 | **MBMS Enhancements** |  | 625d? | 2005-07-11 A | 2007-11-30 A | 100% | 2005-07-11 | 2007-11-30 | 625d? |  | S1 | 10844.6h | 10844.6h | MBMSE | China Mobile | liuhongyfw@chinamobile.com | Rel-7 | Alain |  |  |  |  |
| 961 | 319.1 | Stage 1 of MBMSE |  | 109d? | 2005-07-11 A | 2005-12-08 A | 100% | 2005-07-11 | 2005-12-08 | 109d? | finish no earlier than 2005-12-08 | S1,R1,C3 | 872h | 872h | MBMSE | China Mobile | liuhongyfw@chinamobile.com | Rel-7 | Alain |  |  |  |  |
| 962 | 319.2 | MBMS FDD Physical layer Enhancements |  | 117.29d? | 2006-12-15 A | 2007-06-04 A | 100% | 2006-12-15 | 2007-06-04 | 117.29d? | finish no earlier than 2007-06-04 | R1 | 938.32h | 938.32h | MBMSE-RANPhysFDD | Ericsson | Lars.Lindbom@ericsson.com | Rel-7 | Patrick |  | RP-070290 |  |  |
| 963 | 319.3 | MBMS TDD Physical layer Enhancements |  | 117.29d? | 2006-12-15 A | 2007-06-04 A | 100% | 2006-12-15 | 2007-06-04 | 117.29d? | finish no earlier than 2007-06-04 | R1 | 938.32h | 938.32h | MBMSE-RANPhysTDD | IPWireless | Nicholas Anderson | Rel-7 | Patrick |  | RP-070291 |  |  |
| 964 | 319.4 | MBMS Low Chip Rate TDD Physical Layer Enhancement |  | 127d? | 2007-03-16 A | 2007-09-10 A | 100% | 2007-03-16 | 2007-09-10 | 127d? | finish no earlier than 2007-09-10 | R1 | 1016h | 1016h | MBMSE-RANPhysLCRTDD | RITT | Lin Hui | Rel-7 | Patrick |  | RP-070292 |  |  |
| 965 | 319.5 | MBMS Mz interface |  | 260d? | 2006-12-04 A | 2007-11-30 A | 100% | 2006-12-04 | 2007-11-30 | 260d? | finish no earlier than 2007-05-11 | C3 | 2080h | 2080h | MBMSMz | Huawei | Deng Tingting (ttdeng@huawei.com) | Rel-7 | Gwiho |  |  |  |  |
| 966 | 320 | **MBMS - UE Conformance Testing** |  | 657d? | 2007-06-01 A | 2009-12-04 A | 100% | 2007-06-01 | 2009-12-04 | 657d? |  | R5 | 13848h | 13848h | MBMSE_UEConTest |  |  | Rel-7 | Ingbert |  |  | PCG-21 | SP-40 |
| 967 | 320.1 | Conformance Test Aspects – MBMS TDD Physical layer Enhancements – MBSFN for HCR and VHCR TDD |  | 336d? | 2007-06-01 A | 2008-09-12 A | 100% | 2007-06-01 | 2008-09-12 | 336d? | start no earlier than 2007-06-01 | R5 | 2688h | 2688h | MBMSE-RANPhysTDD_UEConTest | IPWireless | tspeight@ipwireless.com | Rel-7 | Ingbert |  | RP-080541 |  |  |
| 968 | 320.2 | Conformance Test Aspects – MBMS LCR TDD Physical Layer Enhancement |  | 342d? | 2008-05-30 A | 2009-09-18 A | 100% | 2008-05-30 | 2009-09-18 | 342d? | finish no earlier than 2009-09-18 | R5 | 2728h | 2728h | MBMSE-RANPhysLCRTDD_UEConTest | CATT | chenxiaozhong@datangmobile.cn | Rel-7 | Ingbert |  | RP-090715 | PCG-21 | RP-40 |
| 969 | 320.3 | Conformance Test Aspects – MBSFN for FDD |  | 397d? | 2008-05-30 A | 2009-12-04 A | 100% | 2008-05-30 | 2009-12-04 | 397d? | finish no earlier than 2009-12-04 | R5 | 3176h | 3176h | MBMSE-UEConTest_RANPhysFDD | Huawei | Xiang Li (trica_li@huawei.com) | Rel-7 | Ingbert |  | RP-091214 | PCG-21 | RP-40 |
| 970 | 321 | MBMS User Service Extensions |  | 392d? | 2005-12-07 A | 2007-06-07 A | 100% | 2005-12-07 | 2007-06-07 | 392d? | finish no earlier than 2007-06-07 | S4 | 3136h | 3136h | MBMSUSE | Ericsson | Thorsten.Lohmar@ericsson.com | Rel-7 | Paolo |  |  |  |  |
| 971 | 322 | **Advanced Global Navigation Satellite System (A-GNSS) concept** |  | 830d? | 2004-06-28 A | 2007-08-31 A | 100% | 2004-06-28 | 2007-08-31 | 830d? |  | S1,GP,R2 | 9553.6h | 9553.6h | LCS3-AGNSS | Alcatel | Michel.monnerat@thalesaleniaspace.com | Rel-7 | Alain |  |  |  |  |
| 972 | 322.1 | Towards A-GNSS Concept |  | 811.2d? | 2004-06-28 A | 2007-08-31 A | 100% | 2004-06-28 | 2007-08-31 | 811.2d? | finish no earlier than 2007-08-31 | GP | 6489.6h | 6489.6h | AGNSS-GP | Alcatel | richard.couty@space.alcatel.fr | Rel-7 | Paolo |  |  |  |  |
| 973 | 322.2 | Global Navigation Satellite System (GNSS) in UTRAN |  | 383d? | 2005-12-15 A | 2007-06-04 A | 100% | 2005-12-15 | 2007-06-04 | 383d? | finish no earlier than 2007-06-04 | R2 | 3064h | 3064h | LCS3-GNSS-UTRAN | France Telecom | alain.abinakhoul@francetelecom.com | Rel-7 | Joern |  | RP-070482 |  |  |
| 974 | 322.3 | Deleted - Towards A-GNSS Concept | milestone | 0d? | 2007-02-16 A | 2007-02-16 A | 100% | 2007-02-16 | 2007-02-16 | 0d? | start no earlier than 2007-02-16 | S1 |  |  | GNSS | Alcatel | richard.couty@space.alcatel.fr | Rel-7 | Alain | SP-34 |  |  |  |
| 975 | 323 | A-GPS Minimum Performance |  | 351d? | 2006-04-28 A | 2007-08-31 A | 100% | 2006-04-28 | 2007-08-31 | 351d? | finish no earlier than 2007-08-31 | GP | 2808h | 2808h | GAGR | Spirent | richard.catmur@spirentcom.com | Rel-7 | Paolo |  |  |  |  |
| 976 | 324 | **USSD message delivery and transfer to USIM** |  | 376d? | 2004-03-05 A | 2005-08-12 A | 100% | 2004-03-05 | 2005-08-12 | 376d? |  | S1,C6 | 2762.4h | 2762.4h | USSD-USIM | Axalto | Christophe Dubois (cdubois@axalto.com) | Rel-7 | Alain |  |  |  |  |
| 977 | 324.1 | Stage 1 |  | 152d? | 2004-03-18 A | 2004-10-15 A | 100% | 2004-03-18 | 2004-10-15 | 152d? | start no earlier than 2004-03-18 | S1 | 1216h | 1216h | USSD-USIM | Axalto | Christophe Dubois (cdubois@axalto.com) | Rel-7 | Alain |  |  |  |  |
| 978 | 324.2 | Alignment with requirements regarding USSD usage |  | 193.3d? | 2004-03-05 A | 2005-08-12 A | 100% | 2004-03-05 | 2005-08-12 | 193.3d? | finish no earlier than 2005-08-12 | C6 | 1546.4h | 1546.4h | USSD-USIM | Axalto | Christophe Dubois (cdubois@axalto.com) | Rel-7 | Xavier |  |  |  |  |

Notes:
- 954: - / Text3: 22.935
- 955: - / Text3: 22.935
- 956: Updated WID at SP#32 to change "stage 2" to "study" , duplicated UID 320017 deleted. SP#33 TR for Information. Last mention SP-35 Mar 2007 (abandoned ?) / Text3: 23.837
- 957: WID at SP#55 / Text3: 23.234, 23.271, 23.167
- 958: -
- 959: - / Text3: 25.305, 25.331, 25.410, 25.413, 25.453
- 960: -
- 961: Structure created by MCC to include RAN aspects under SA1 Feature / Text3: 22.146, 22.246, 22.228
- 962: Completed May 2007; SR in RP-070290 / Text3: 25.211, 25.212, 25.213, 25.101, 25.104, 25.331, 25.433, 25.346, 25.306
- 963: Completed May 2007; SR in RP-070291 / Text3: 25.346, 25.221, 25.222, 25.223, 25.224, 25.306, 25.331, 25.402, 25.433, 25.102, 25.105, 25.123
- 964: Completed May 2007; SR in RP-070292 / Text3: 25.346, 25.221, 25.222, 25.223, 25.224, 25.306, 25.331, 25.402, 25.433, 25.102, 25.105, 25.123
- 965: - / Text3: 29.061
- 966: Linked to Rel-7 Feature UID_31084 (MBMSE)
- 967: SR in RP-080541. RP#41 completed / Text3: 34.108, 34.122, 34.123-1/2/3
- 968: RP#45 completed / Text3: 34.108, 34.123-1
- 969: RP#46 completed / Text3: 34.108, 34.109, 34.121-1, 34.121-2, 34.123-1, 34.123-2, 34.123-3
- 970: - / Text3: 26.346, 26.946
- 971: -
- 972: GP#36 completed
- 973: Completed Sept 2006; SR in RP-070482 / Text3: 25.305, 25.331, 25.306, 25.413, 25.423, 25.433, 25.453, 25.302, 25.215, 25.401, 25.402, 25.450, 25.452
- 974: -
- 975: - / Text3: 45.005, 51.010
- 976: -
- 977: - / Text3: 22.090
- 978: -

| ID | WBS | Task | Type | Duration | Start | Finish | Complete | Baseline start | Baseline finish | Baseline duration | Constraint | Resources | Work | Actual work | Text1 | Text4 | Text5 | Text6 | Text8 | Text3 | Text12 |
| --- | --- | --- | --- | --- | --- | --- | --- | --- | --- | --- | --- | --- | --- | --- | --- | --- | --- | --- | --- | --- | --- |
| 979 | 325 | **Combinational Services** |  | 296d? | 2005-01-17 A | 2006-03-06 A | 100% | 2005-01-17 | 2006-03-06 | 296d? |  | S1,S2,C1,S4 | 5176h | 5176h | CSICS | TeliaSonera | Robert.Frank@teliasonera.com | Rel-7 | Alain |  |  |
| 980 | 325.1 | Stage 1 for CSICS |  | 104d? | 2005-01-17 A | 2005-06-09 A | 100% | 2005-01-17 | 2005-06-09 | 104d? | start no earlier than 2005-01-17 | S1 | 832h | 832h | CSICS | TeliaSonera | Robert.Frank@teliasonera.com | Rel-7 | Alain | 22.279 |  |
| 981 | 325.2 | Stage 2 for CSICS |  | 130d? | 2005-01-17 A | 2005-07-15 A | 100% | 2005-01-17 | 2005-07-15 | 130d? | start no earlier than 2005-01-17 | S2 | 1040h | 1040h | CSICS | TeliaSonera | Robert.Frank@teliasonera.com | Rel-7 | Maurice | 23.279 |  |
| 982 | 325.3 | Stage 3 for CSICS CN aspects |  | 221d? | 2005-05-02 A | 2006-03-06 A | 100% | 2005-05-02 | 2006-03-06 | 221d? | finish no earlier than 2006-03-06 | C1 | 1768h | 1768h | CSICS | Vodafone | Peter Dawes | Rel-7 | Frederic | 24.879, 24.279, 24.229, 24.008 |  |
| 983 | 325.4 | Stage 3 for codec aspects |  | 192d? | 2005-03-15 A | 2005-12-07 A | 100% | 2005-03-15 | 2005-12-07 | 192d? | finish no earlier than 2005-12-07 | S4 | 1536h | 1536h | CSICS-Codec | Ericsson | Per.Frojdh@ericsson.com | Rel-7 | Paolo | 26.141, 26.235 |  |
| 984 | 326 | **CAMEL Trunk Triggers** |  | 251d? | 2004-12-17 A | 2005-12-05 A | 100% | 2004-12-17 | 2005-12-05 | 251d? |  | S1,C4 | 6024h | 6024h | TTCAMEL | Nortel | Amar Deol (deola@nortelnetworks.com) | Rel-7 | Alain |  |  |
| 985 | 326.1 | Stage 1 for CAMEL Trunk Triggers |  | 251d? | 2004-12-17 A | 2005-12-05 A | 100% | 2004-12-17 | 2005-12-05 | 251d? |  | S1 | 2008h | 2008h | TTCAMEL | Nortel | Amar Deol (deola@nortelnetworks.com) | Rel-7 | Alain | 22.078 |  |
| 986 | 326.2 | CAMEL Trunk Originated Trigger Detection Points |  | 251d? | 2004-12-17 A | 2005-12-05 A | 100% | 2004-12-17 | 2005-12-05 | 251d? | start no earlier than 2004-12-17 | C4 | 2008h | 2008h | CamelR7 | Nortel | David Hutton (dhutton@nortel.com) | Rel-7 | Kimmo |  |  |
| 987 | 327 | **IMS Service Brokering enhancements** |  | 69d? | 2005-12-07 A | 2006-03-13 A | 100% | 2005-12-07 | 2006-03-13 | 69d? |  | S1 | 1104h | 1104h | ISB | Telcordia | jbakker@telcordia.com | Rel-7 | Alain | 22.228 |  |
| 988 | 327.1 | Stage 1 for ISB |  | 69d? | 2005-12-07 A | 2006-03-13 A | 100% | 2005-12-07 | 2006-03-13 | 69d? | finish no earlier than 2006-03-13 | S1 | 552h | 552h | ISB-s1 | Telcordia | jbakker@telcordia.com | Rel-7 | Alain | 22.228 |  |
| 989 | 328 | **Enhancements of VGCS for public authority officials** |  | 731d? | 2004-08-27 A | 2007-06-15 A | 100% | 2004-08-27 | 2007-06-15 | 731d? |  | S1,C1,C4,G2 | 25920h | 25920h | EVGCS |  |  | Rel-7 | Alain | 43.068, 44.068, 24.008, 29.002 |  |
| 990 | 328.1 | Stage 1 | milestone | 0d? | 2004-08-27 A | 2004-08-27 A | 100% | 2004-08-27 | 2004-08-27 | 0d? | finish no earlier than 2004-08-27 | S1 |  |  | EVGCS | Siemens | Joerg Swetina (joerg.swetina@nw.neclab.eu) | Rel-7 | Alain | 42.068, 43.068 |  |
| 991 | 328.2 | **Architecture and protocol aspects** |  | 731d? | 2004-08-27 A | 2007-06-15 A | 100% | 2004-08-27 | 2007-06-15 | 731d? |  | C1,C4 | 14904h | 14904h | EVGCS | Siemens | robert.zaus@nsn.com | Rel-7 | Frederic | 43.068, 44.068 |  |
| 992 | 328.2.1 | CT1 aspects of EVGCS |  | 731d? | 2004-08-27 A | 2007-06-15 A | 100% | 2004-08-27 | 2007-06-15 | 731d? | finish no earlier than 2006-09-15 | C1 | 5848h | 5848h | EVGCS | Siemens | robert.zaus@nsn.com | Rel-7 | Frederic | 43.068, 44.068, 24.008 |  |
| 993 | 328.2.2 | CT4 aspects of EVGCS |  | 401d? | 2004-08-27 A | 2006-03-10 A | 100% | 2004-08-27 | 2006-03-10 | 401d? | finish no earlier than 2006-03-10 | C4 | 3208h | 3208h | EVGCS | Siemens | robert.zaus@nsn.com | Rel-7 | Kimmo | 29.002 |  |
| 994 | 328.3 | GERAN2 aspects |  | 646d? | 2004-08-27 A | 2007-02-16 A | 100% | 2004-08-27 | 2007-02-16 | 646d? | finish no earlier than 2007-02-16 | G2 | 5168h | 5168h | EVGCS | Siemens | kenneth.isaacs@roke.co.uk | Rel-7 | Gert |  |  |
| 995 | 329 | **Improvements of VGCS for parallel use of services** |  | 523d? | 2005-03-15 A | 2007-03-15 A | 100% | 2005-03-15 | 2007-03-15 | 523d? |  | S1 | 12230.2h | 12230.2h | IVGCS |  |  | Rel-7 | Alain |  |  |
| 996 | 329.1 | Service Requirements for VGCS improvements |  | 62d? | 2005-03-15 A | 2005-06-08 A | 100% | 2005-03-15 | 2005-06-08 | 62d? | finish no earlier than 2005-06-08 | S1 | 496h | 496h | IVGCS | T-Mobile | kurt.bischinger@t-mobile.at | Rel-7 | Alain | 42.068 |  |
| 997 | 329.2 | Stage 2 modifications for VGCS improvements |  | 335d? | 2005-12-01 A | 2007-03-14 A | 100% | 2005-12-01 | 2007-03-14 | 335d? | start no earlier than 2005-12-01 | C1 | 2680h | 2680h | IVGCS | T-Mobile | kurt.bischinger@t-mobile.at | Rel-7 | Frederic | 43.068 |  |
| 998 | 329.3 | **Protocol aspects** |  | 336d? | 2005-12-01 A | 2007-03-15 A | 100% | 2005-12-01 | 2007-03-15 | 336d? |  | C1 | 5376h | 5376h | IVGCS | T-Mobile | Dieter Jacobsohn | Rel-7 | Frederic | 44.068 |  |
| 999 | 329.3.1 | CT1 aspects of IVGCS |  | 336d? | 2005-12-01 A | 2007-03-15 A | 100% | 2005-12-01 | 2007-03-15 | 336d? | finish no earlier than 2007-03-15 | C1 | 2688h | 2688h | IVGCS | T-Mobile |  | Rel-7 | Frederic | 43.068, 44.068 |  |
| 1000 | 329.3.2 | Deleted - CT4 aspects of IVGCS | milestone | 0d? | 2007-03-09 A | 2007-03-09 A | 100% | 2007-03-09 | 2007-03-09 | 0d? | finish no earlier than 2007-03-09 | C4 |  |  | IVGCS-St3-c4 | T-mobile |  | Rel-7 | Kimmo | 29.002 | CP-35 |
| 1001 | 330 | **OSA Rel-7** |  | 584d? | 2005-03-15 A | 2007-06-08 A | 100% | 2005-03-15 | 2007-06-08 | 584d? |  | S1,C5 | 17920h | 17920h | OSA7 | AePONA | eamonn.murray@aepona.com | Rel-7 | Alain |  |  |
| 1002 | 330.1 | Service Requirements for OSA Service Broker |  | 62d? | 2005-03-15 A | 2005-06-08 A | 100% | 2005-03-15 | 2005-06-08 | 62d? | finish no earlier than 2005-06-08 | S1 | 496h | 496h | OSA7-SB | AePONA | eamonn.murray@aepona.com | Rel-7 | Alain | 22.127 |  |
| 1003 | 330.2 | Stage 2 OSA API Service Brokering |  | 156d? | 2006-04-28 A | 2006-12-01 A | 100% | 2006-04-28 | 2006-12-01 | 156d? |  | C5 | 1248h | 1248h | OSA7-SB | AePONA | damian.oneill@aepona.com | Rel-7 | Kimmo | 23.198 |  |
| 1004 | 330.3 | Stage 3 OSA API Service Brokering |  | 156d? | 2006-04-28 A | 2006-12-01 A | 100% | 2006-04-28 | 2006-12-01 | 156d? | finish no earlier than 2006-12-01 | C5 | 1248h | 1248h | OSA7-SB | AePONA | damian.oneill@aepona.com | Rel-7 | Kimmo | 29.198-16 |  |

Notes:
- 979: -
- 980: -
- 981: -
- 982: -
- 983: -
- 984: -
- 985: -
- 986: -
- 987: No CR submitted in rel-8 (according to CR database).
- 988: No Rel-8 changes
- 989: Moved from Rel-6 UID_50563 Enhancements of VGCS in public networks for communication of public authority officials
- 990: Voice Group Call Service
- 991: -
- 992: -
- 993: -
- 994: -
- 995: Voice Group Call Service
- 996: -
- 997: -
- 998: Previous name (before CT32) was Architecture and protocol aspects
- 999: -
- 1000: CT4#33 stage 2 solution is still open. ...
- 1001: -
- 1002: az: WID URL corrected
- 1003: -
- 1004: -

| ID | WBS | Task | Type | Duration | Start | Finish | Complete | Baseline start | Baseline finish | Baseline duration | Constraint | Resources | Work | Actual work | Text1 | Text3 | Text4 | Text5 | Text6 | Text8 | Text12 | Text11 |
| --- | --- | --- | --- | --- | --- | --- | --- | --- | --- | --- | --- | --- | --- | --- | --- | --- | --- | --- | --- | --- | --- | --- |
| 1005 | 330.4 | **OSA Stage 2/3 enhancements** |  | 291d? | 2006-04-28 A | 2007-06-08 A | 100% | 2006-04-28 | 2007-06-08 | 291d? |  | C5 | 10256h | 10256h | OSA7 | 29.198/9, 23.198 | AePONA | damian.oneill@aepona.com | Rel-7 | Kimmo |  |  |
| 1006 | 330.4.1 | Parlay X Message Broadcast Web Service |  | 156d? | 2006-04-28 A | 2006-12-01 A | 100% | 2006-04-28 | 2006-12-01 | 156d? | finish no earlier than 2006-12-01 | C5 | 1248h | 1248h | OSA7 | 29.199-15, 23.198 | ETRI |  | Rel-7 | Kimmo |  |  |
| 1007 | 330.4.2 | Parlay X Geocoding Web Service |  | 156d? | 2006-04-28 A | 2006-12-01 A | 100% | 2006-04-28 | 2006-12-01 | 156d? | finish no earlier than 2006-12-01 | C5 | 1248h | 1248h | OSA7 | 29.199-16, 23.198 | ETRI |  | Rel-7 | Kimmo |  |  |
| 1008 | 330.4.3 | Parlay X Application driven QoS Web Service |  | 226d? | 2006-04-28 A | 2007-03-09 A | 100% | 2006-04-28 | 2007-03-09 | 226d? | finish no earlier than 2007-03-09 | C5 | 1808h | 1808h | OSA7 | 29.199-17, 23.198 | BT |  | Rel-7 | Kimmo |  |  |
| 1009 | 330.4.4 | Parlay-X Device Capabilities and Configuration |  | 162d? | 2006-10-26 A | 2007-06-08 A | 100% | 2006-10-26 | 2007-06-08 | 162d? | finish no earlier than 2007-06-09 | C5 | 1296h | 1296h | OSA7 | 29.199-18, 23.198 | Telenor |  | Rel-7 | Kimmo |  |  |
| 1010 | 330.4.5 | Parlay-X Multimedia Streaming Session Management Web Service |  | 97d? | 2006-10-26 A | 2007-03-09 A | 100% | 2006-10-26 | 2007-03-09 | 97d? | start no earlier than 2006-10-26 | C5 | 776h | 776h | OSA7 | 29.199-19, 23.198 | Telenor |  | Rel-7 | Kimmo |  |  |
| 1011 | 330.4.6 | Parlay-X Multimedia Multicast Control Web Service |  | 97d? | 2006-10-26 A | 2007-03-09 A | 100% | 2006-10-26 | 2007-03-09 | 97d? | start no earlier than 2006-10-26 | C5 | 776h | 776h | OSA7 | 29.199-20, 23.198 | ETRI |  | Rel-7 | Kimmo |  |  |
| 1012 | 330.4.7 | OSA API Conference Call Control SCF |  | 97d? | 2006-10-26 A | 2007-03-09 A | 100% | 2006-10-26 | 2007-03-09 | 97d? | start no earlier than 2006-10-26 | C5 | 776h | 776h | OSA7 | 29.198-04-5, 23.198 | Ericsson |  | Rel-7 | Kimmo |  |  |
| 1013 | 331 | **Selective Disabling of UE Capabilities** |  | 624.36d? | 2005-01-24 A | 2007-06-15 A | 100% | 2005-01-24 | 2007-06-15 | 624.36d? |  | S1,S2,C1 | 12351.7h | 12351.7h | SDoUE |  | Motorola |  | Rel-7 | Alain |  |  |
| 1014 | 331.1 | Stage 1 of SDoUE |  | 393.6d? | 2005-01-24 A | 2006-12-08 A | 100% | 2005-01-24 | 2006-12-08 | 393.6d? | finish no earlier than 2006-12-08 | S1 | 3148.8h | 3148.8h | SDoUE-CR | 22.011 | Motorola |  | Rel-7 | Alain |  |  |
| 1015 | 331.2 | Deleted - TR on different possible architectures |  | 195d? | 2005-03-21 A | 2005-12-16 A | 100% | 2005-03-21 | 2005-12-16 | 195d? | finish no earlier than 2005-12-16 | S2 | 1560h | 1560h | SDoUE-FS | 23.805 abandonned at SP-30; descendant C1 24.305 | Vodafone | Gavin.Wong@vodafone.com | Rel-7 | Maurice | SP-30 |  |
| 1016 | 331.3 | Stage 3 of SDoUE |  | 331d? | 2006-03-10 A | 2007-06-15 A | 100% | 2006-03-10 | 2007-06-15 | 331d? | finish no earlier than 2007-06-15 | C1 | 2648h | 2648h | SDoUE | 24.305 | Ericsson | christian.herrero@ericsson.com | Rel-7 | Frederic |  |  |
| 1017 | 332 | **Network selection enhancements (NSP)** |  | 328d? | 2006-03-15 A | 2007-06-15 A | 100% | 2006-03-15 | 2007-06-15 | 328d? |  | S1 | 6320h | 6320h | NSP-CR | 22.101, 22.011, 23.122, 24.008, 25.304, 31.102, 45.008 | O2 | chris.friel@o2.com | Rel-7 | Alain |  |  |
| 1018 | 332.1 | Stage 1 of NSP |  | 191d? | 2006-03-15 A | 2006-12-06 A | 100% | 2006-03-15 | 2006-12-06 | 191d? | start no earlier than 2006-03-15 | S1 | 1528h | 1528h | NSP-TS | 22.101, 22.011, 23.122, 24.008, 25.304, 31.102, 45.008 | O2 | chris.friel@o2.com | Rel-7 | Alain |  |  |
| 1019 | 332.2 | Procedural aspects of NSP |  | 271d? | 2006-06-02 A | 2007-06-15 A | 100% | 2006-06-02 | 2007-06-15 | 271d? | finish no earlier than 2007-06-15 | C1 | 2168h | 2168h | NSP-CR | 23.122, 24.008, 31.102 | Motorola | Andrew Howell | Rel-7 | Frederic |  |  |
| 1020 | 333 | Network Selection enhancements (NSP) - UE Conformance Testing |  | 396d? | 2007-06-01 A | 2008-12-05 A | 100% | 2007-06-01 | 2008-12-05 | 396d? | finish no earlier than 2008-12-05 | R5 | 3168h | 3168h | NSP-CR_UEConTest | 34.108, 34.123-1, 34.123-2, 34.123-3 | Nokia | jarkko.hellsten@nokia.com | Rel-7 | Ingbert |  | RP-080819 |
| 1021 | 334 | **Access Class Barring and Overload Protection** |  | 650d? | 2004-03-15 A | 2006-09-08 A | 100% | 2004-03-15 | 2006-09-08 | 650d? |  | S2,C1 | 3568h | 3568h | ACBOP | 23.898 | Vodafone | Chris Pudney | Rel-7 | Maurice |  |  |
| 1022 | 334.1 | TR on Stage 2 |  | 274d? | 2004-03-15 A | 2005-03-31 A | 100% | 2004-03-15 | 2005-03-31 | 274d? | finish no earlier than 2005-03-31 | S2 | 2192h | 2192h | ACBOP | 23.898 | NTT DoCoMo | Jean-Jacques Davidian (davidian@docomo.fr) | Rel-7 | Maurice |  |  |
| 1023 | 334.2 | Stage 3 CN aspects of ACBOP |  | 172d? | 2005-06-06 A | 2006-01-31 A | 100% | 2005-06-06 | 2006-01-31 | 172d? | start no earlier than 2005-06-06 | C1 | 1376h | 1376h | ACBOP | 24.008 |  |  | Rel-7 | Frederic |  |  |
| 1024 | 334.3 | Deleted - Potential impact on Iu interface Overload functionality | milestone | 0d? | 2004-03-15 A | 2004-03-15 A | 100% | 2004-03-15 | 2004-03-15 | 0d? | finish no earlier than 2004-03-15 | RP |  |  | ACBOP | 25.413 |  |  | Rel-7 | Issam | RP-25 |  |
| 1025 | 334.4 | Deleted - Extra ACBOP information in RAN | milestone | 0d? | 2004-03-15 A | 2004-03-15 A | 100% | 2004-03-15 | 2004-03-15 | 0d? | finish no earlier than 2004-03-15 | RP |  |  | ACBOP | 25.331 |  |  | Rel-7 | Issam | RP-25 |  |
| 1026 | 334.5 | Deleted - Extra ACBOP information in GERAN | milestone | 0d? | 2006-09-08 A | 2006-09-08 A | 100% | 2006-09-08 | 2006-09-08 | 0d? | start no earlier than 2006-09-08 | GP |  |  | ACBOP | 44.018 |  |  | Rel-7 | Paolo | RP-33 |  |
| 1027 | 335 | **System enhancements for fixed broadband access to IMS** |  | 876d? | 2003-11-05 A | 2007-03-14 A | 100% | 2003-11-05 | 2007-03-14 | 876d? |  | S2,S3,S5,C1,C3,C4 | 36656h | 36656h | FBI |  |  |  | Rel-7 | Maurice |  |  |
| 1028 | 335.1 | **TISPAN Rel 1 related aspects** |  | 873d? | 2003-11-05 A | 2007-03-09 A | 100% | 2003-11-05 | 2007-03-09 | 873d? |  | S2 | 31568h | 31568h | FBI-TIS1 |  |  |  | Rel-7 | Maurice |  |  |
| 1029 | 335.1.1 | Stage 2 of FBI for TISPAN R1 |  | 365d? | 2004-10-14 A | 2006-03-08 A | 100% | 2004-10-14 | 2006-03-08 | 365d? | start no earlier than 2004-10-14 | S2 | 2920h | 2920h | FBI-TIS1 |  |  |  | Rel-7 | Maurice |  |  |

Notes:
- 1005: CP#34: WID updated. Completion 12/06 =>03/07
- 1006: -
- 1007: -
- 1008: -
- 1009: -
- 1010: -
- 1011: -
- 1012: -
- 1013: Moved from FS section Feb 06
- 1014: Moved from FS section Feb 06
- 1015: Moved from FS section Feb 06. Abandoned at SP-30
- 1016: -
- 1017: -
- 1018: -
- 1019: -
- 1020: RP#42 completed. SR in RP-080819. Linked to UID_7041 (NSP-CR).
- 1021: -
- 1022: -
- 1023: NEW - inserted on 2/9/2004
- 1024: -
- 1025: -
- 1026: -
- 1027: -
- 1028: -
- 1029: -

| ID | WBS | Task | Duration | Start | Finish | Complete | Baseline start | Baseline finish | Baseline duration | Constraint | Resources | Work | Actual work | Text1 | Text4 | Text5 | Text6 | Text8 | Text3 | Text12 |
| --- | --- | --- | --- | --- | --- | --- | --- | --- | --- | --- | --- | --- | --- | --- | --- | --- | --- | --- | --- | --- |
| 1030 | 335.1.2 | **Protocol impact of FBI for TISPAN R1** | 873d? | 2003-11-05 A | 2007-03-09 A | 100% | 2003-11-05 | 2007-03-09 | 873d? |  | C1 | 20720h | 20720h | FBI-TIS1 | Siemens | peter.leis@nsn.com | Rel-7 | Frederic |  |  |
| 1031 | 335.1.2.1 | CT1 aspects of FBI for TISPAN R1 | 802d? | 2003-11-05 A | 2006-11-30 A | 100% | 2003-11-05 | 2006-11-30 | 802d? | finish no earlier than 2006-11-30 | C1 | 6416h | 6416h | FBI-TIS1 | Siemens | peter.leis@nsn.com | Rel-7 | Frederic | 24.819, 24.229 |  |
| 1032 | 335.1.2.2 | CT3 aspects of FBI for TISPAN R1 | 808d? | 2003-11-05 A | 2006-12-08 A | 100% | 2003-11-05 | 2006-12-08 | 808d? | finish no earlier than 2006-12-08 | C3 | 6464h | 6464h | FBI-TIS1 | Siemens | peter.leis@nsn.com | Rel-7 | Gwiho | 29.163, 29.209 |  |
| 1033 | 335.1.2.3 | CT4 aspects of FBI for TISPAN R1 | 301d? | 2006-01-13 A | 2007-03-09 A | 100% | 2006-01-13 | 2007-03-09 | 301d? | finish no earlier than 2007-03-09 | C4 | 2408h | 2408h | FBI-TIS1-st3-c4 | Siemens | peter.leis@nsn.com | Rel-7 | Kimmo | 29.229 |  |
| 1034 | 335.1.3 | Security Enhancements for FBI | 118d? | 2005-06-28 A | 2005-12-08 A | 100% | 2005-06-28 | 2005-12-08 | 118d? | start no earlier than 2005-06-28 | S3 | 944h | 944h | FBI-ISE | Ericsson | Bengt.Sahlin@ericsson.com | Rel-7 | Dionisio | 33.203 |  |
| 1035 | 335.2 | **PacketCable Related aspects** | 291d? | 2006-02-01 A | 2007-03-14 A | 100% | 2006-02-01 | 2007-03-14 | 291d? |  | S2,S5,C1 | 5088h | 5088h | FBI-PCBL | CableLabs | Bernie McKibben | Rel-7 | Maurice |  |  |
| 1036 | 335.2.1 | Stage 1,2 of FBI for PacketCable | 228d? | 2006-02-01 A | 2006-12-15 A | 100% | 2006-02-01 | 2006-12-15 | 228d? | finish no earlier than 2006-12-15 | S2 | 1824h | 1824h | FBI-PCBL | CableLabs | Bernie McKibben | Rel-7 | Maurice | 22.228, 23.228 |  |
| 1037 | 335.2.2 | Protocol impact of FBI for PacketCable | 228d? | 2006-05-01 A | 2007-03-14 A | 100% | 2006-05-01 | 2007-03-14 | 228d? | finish no earlier than 2007-03-15 | C1 | 1824h | 1824h | FBI-PCBL |  |  | Rel-7 | Frederic |  |  |
| 1038 | 335.2.3 | SA5 Charging aspects of FBI for PacketCable | 180d? | 2006-03-31 A | 2006-12-07 A | 100% | 2006-03-31 | 2006-12-07 | 180d? | finish no earlier than 2006-12-07 | S5 | 1440h | 1440h | FBI-PCBL-CH | CableLabs | Bernie McKibben | Rel-7 | Dionisio | 32.240, 32.260, 32.298, 32.299 |  |
| 1039 | 336 | **Support of SMS over generic 3GPP IP access** | 696d? | 2004-10-14 A | 2007-06-14 A | 100% | 2004-10-14 | 2007-06-14 | 696d? |  | S2,C4,C1 | 12408h | 12408h | SMSIP | Huawei | zhangwenlin@huawei.com | Rel-7 | Maurice |  |  |
| 1040 | 336.1 | FS on SMSIP | 173d? | 2004-10-14 A | 2005-06-13 A | 100% | 2004-10-14 | 2005-06-13 | 173d? | start no earlier than 2004-10-14 | S2 | 1384h | 1384h | SMSIP | Huawei | zhangwenlin@huawei.com | Rel-7 | Maurice | 23.804 |  |
| 1041 | 336.2 | Stage 2 for SMSIP | 333d? | 2005-06-08 A | 2006-09-15 A | 100% | 2005-06-08 | 2006-09-15 | 333d? | finish no earlier than 2006-09-15 | S2 | 2664h | 2664h | SMSIP | Huawei | zhangwenlin@huawei.com | Rel-7 | Maurice | 23.204 |  |
| 1042 | 336.3 | **Stage 3 for SMSIP** | 527d? | 2005-06-08 A | 2007-06-14 A | 100% | 2005-06-08 | 2007-06-14 | 527d? |  | C4,C1 | 8360h | 8360h | SMSIP-St3 | Nokia | jari.jansson@nokia.com | Rel-7 | Kimmo |  |  |
| 1043 | 336.3.1 | CT1 aspects for SMSIP | 527d? | 2005-06-08 A | 2007-06-14 A | 100% | 2005-06-08 | 2007-06-14 | 527d? | finish no earlier than 2007-06-15 | C1 | 4216h | 4216h | SMSIP | Nokia | jari.jansson@nokia.com | Rel-7 | Frederic | 23.040, 24.229 |  |
| 1044 | 336.3.2 | CT4 aspects for SMSIP | 518d? | 2005-06-08 A | 2007-06-01 A | 100% | 2005-06-08 | 2007-06-01 | 518d? | finish no earlier than 2007-06-01 | C4 | 4144h | 4144h | SMSIP-St3-c4 | Nokia | jari.jansson@nokia.com | Rel-7 | Kimmo | 23.008, 29.002 |  |
| 1045 | 337 | **Evolution of Policy Control and Charging** | 817d? | 2004-10-14 A | 2007-11-30 A | 100% | 2004-10-14 | 2007-11-30 | 817d? |  | S2,S5,C3,C1 | 30336h | 30336h | PCC | Nokia | balazs.bertenyi@nsn.com | Rel-7 | Maurice |  |  |
| 1046 | 337.1 | Deleted - TR for PCC | 315d? | 2004-10-14 A | 2005-12-29 A | 100% | 2004-10-14 | 2005-12-29 | 315d? | finish no earlier than 2005-12-28 | S2 | 2520h | 2520h | PCC | Nokia | balazs.bertenyi@nsn.com | Rel-7 | Maurice | 23.803 | SP-33 |
| 1047 | 337.2 | Stage 2 for PCC | 315d? | 2005-07-04 A | 2006-09-15 A | 100% | 2005-07-04 | 2006-09-15 | 315d? | finish no earlier than 2006-09-15 | S2 | 2520h | 2520h | PCC | Nokia | balazs.bertenyi@nsn.com | Rel-7 | Maurice | 23.203 |  |
| 1048 | 337.3 | Evolution of policy control and flow based bearer level charging | 109d? | 2006-08-01 A | 2006-12-29 A | 100% | 2006-08-01 | 2006-12-29 | 109d? | start no earlier than 2006-08-01 | S2 | 872h | 872h | PCC | Nokia | balazs.bertenyi@nsn.com | Rel-7 | Maurice | 23.207, 23.002, 23.228 |  |
| 1049 | 337.4 | SA5 Charging aspects of PCC | 316d? | 2006-03-31 A | 2007-06-15 A | 100% | 2006-03-31 | 2007-06-15 | 316d? | finish no earlier than 2007-06-15 | S5 | 2528h | 2528h | PCC-CH | Orange | alain.bibas@orange-ft.com | Rel-7 | Dionisio | 32.250, 32.251, 32.298, 32.299 |  |
| 1050 | 337.5 | Gx reference point for Policy and Charging Control | 521d? | 2005-12-02 A | 2007-11-30 A | 100% | 2005-12-02 | 2007-11-30 | 521d? | finish no earlier than 2007-09-14 | C3 | 4168h | 4168h | PCC-Gx | Siemens | Thomas.Belling@nsn.com | Rel-7 | Gwiho | 29.212 (not progressed to Rel-7: 29.210, 29.207, 29.208) |  |
| 1051 | 337.6 | **Rx reference point for PCC CT3 aspects** | 521d? | 2005-12-02 A | 2007-11-30 A | 100% | 2005-12-02 | 2007-11-30 | 521d? |  | C3,C1 | 11192h | 11192h | PCC-Rx | Ericsson | j.javier.pastor@ericsson.com | Rel-7 | Gwiho |  |  |
| 1052 | 337.6.1 | PCC-Rx CT3 aspects | 521d? | 2005-12-02 A | 2007-11-30 A | 100% | 2005-12-02 | 2007-11-30 | 521d? | finish no earlier than 2007-09-14 | C3 | 4168h | 4168h | PCC-Rx-c3 | Ericsson | j.javier.pastor@ericsson.com | Rel-7 | Gwiho | 29.213, 29.214 (not progressed to Rel-7: 29.209, 29.211) |  |
| 1053 | 337.6.2 | PCC-Rx CT1 aspects | 357d? | 2005-12-02 A | 2007-06-15 A | 100% | 2005-12-02 | 2007-06-15 | 357d? | finish no earlier than 2007-06-15 | C1 | 2856h | 2856h | PCC-Rx-Gx-c1 | Ericsson | j.javier.pastor@ericsson.com | Rel-7 | Frederic | 24.229 |  |

Notes:
- 1030: -
- 1031: end date updated by CT1-chairman after CP#33
- 1032: -
- 1033: CT4#32: a set of CRs on FBI for cable labs
- 1034: Duplicated entry ("ACCSEC2", "Access Security Enhancements", SP-040865) deleted by A.Sultan
- 1035: -
- 1036: -
- 1037: -
- 1038: 03/2006 SP#31 WID approved
- 1039: SP#33 updated WID (removed MMS)
- 1040: SP#33 updated WID
- 1041: SP#33 updated WID
- 1042: CP#34 updated WID
- 1043: CP#34 updated WID
- 1044: CP#34 updated WID
- 1045: SP-29 approved WID. SP-31 updated WID adding SA5 charging. 23.125 will be discontinued from Rel-7.
- 1046: SP-30: S2 has no intention for TR completion
- 1047: SP-29 approved WID. SP-31 updated WID. 23.125 will be discontinued from Rel-7.
- 1048: SP-29 approved WID. SP-31 updated WID. 23.125 will be discontinued from Rel-7.
- 1049: SP-31 updated WID with SA5 charging.
- 1050: -
- 1051: WID approved at CP#30, Revised at CP#31, Revised at CP#33
- 1052: -
- 1053: -

| ID | WBS | Task | Type | Duration | Start | Finish | Complete | Baseline start | Baseline finish | Baseline duration | Constraint | Resources | Work | Actual work | Text1 | Text4 | Text5 | Text6 | Text8 | Text3 | Text12 |
| --- | --- | --- | --- | --- | --- | --- | --- | --- | --- | --- | --- | --- | --- | --- | --- | --- | --- | --- | --- | --- | --- |
| 1054 | 338 | **Voice call continuity between CS and IMS (incl. I-WLAN)** |  | 641d? | 2004-12-31 A | 2007-06-15 A | 100% | 2004-12-31 | 2007-06-15 | 641d? |  | S2,S1,S5,C1,C4 | 12224h | 12224h | VCC | Alcatel-Lucent | Keith Drage (drage@alcatel-lucent.com) | Rel-7 | Maurice |  |  |
| 1055 | 338.1 | TR for VCC |  | 245d? | 2004-12-31 A | 2005-12-08 A | 100% | 2004-12-31 | 2005-12-08 | 245d? | finish no earlier than 2005-12-08 | S2 | 1960h | 1960h | VCC | Alcatel-Lucent | Andy Bennett (andybennett@alcatel-lucent.com) | Rel-7 | Maurice | 23.806 |  |
| 1056 | 338.2 | Stage 1 for VCC |  | 140d? | 2005-03-17 A | 2005-09-28 A | 100% | 2005-03-17 | 2005-09-28 | 140d? | finish no earlier than 2005-09-28 | S1 | 1120h | 1120h | VCC | Alcatel-Lucent | Andy Bennett (andybennett@alcatel-lucent.com) | Rel-7 | Alain | 22.101 |  |
| 1057 | 338.3 | Stage 2 for VCC |  | 264d? | 2005-09-06 A | 2006-09-08 A | 100% | 2005-09-06 | 2006-09-08 | 264d? | finish no earlier than 2006-09-08 | S2 | 2112h | 2112h | VCC | Alcatel-Lucent | Andy Bennett (andybennett@alcatel-lucent.com) | Rel-7 | Maurice | 23.206 |  |
| 1058 | 338.4 | SA5 Charging aspects of VCC |  | 325d? | 2006-03-17 A | 2007-06-14 A | 100% | 2006-03-17 | 2007-06-14 | 325d? | finish no earlier than 2007-06-14 | S5 | 2600h | 2600h | VCC-CH | Orange | alain.bibas@orange-ft.com | Rel-7 | Dionisio | 32.250, 32.260 |  |
| 1059 | 338.5 | **Stage 3 for VCC** |  | 358d? | 2006-02-01 A | 2007-06-15 A | 100% | 2006-02-01 | 2007-06-15 | 358d? |  | C1,C4 | 4432h | 4432h | VCC | Alcatel-Lucent | Keith Drage (drage@alcatel-lucent.com) | Rel-7 | Frederic |  |  |
| 1060 | 338.5.1 | CT1 aspects of VCC |  | 358d? | 2006-02-01 A | 2007-06-15 A | 100% | 2006-02-01 | 2007-06-15 | 358d? | finish no earlier than 2007-06-15 | C1 | 2864h | 2864h | VCC | Alcatel-Lucent | Keith Drage (drage@alcatel-lucent.com) | Rel-7 | Frederic | 24.206, 24.216 |  |
| 1061 | 338.5.2 | CT4 aspects of VCC |  | 196d? | 2006-06-09 A | 2007-03-09 A | 100% | 2006-06-09 | 2007-03-09 | 196d? | start no earlier than 2006-06-09 | C4 | 1568h | 1568h | VCC-St3-c4 | Alcatel-Lucent | Keith Drage (drage@alcatel-lucent.com) | Rel-7 | Kimmo | 23.003 |  |
| 1062 | 338.5.3 | Deleted - CT3 aspects of VCC | milestone | 0d? | 2006-11-02 A | 2006-11-02 A | 100% | 2006-11-02 | 2006-11-02 | 0d? | finish no earlier than 2006-11-02 | C3 |  |  | VCC | Alcatel-Lucent | Keith Drage (drage@alcatel-lucent.com) | Rel-7 | Gwiho | 29.163 | CP-33 |
| 1063 | 339 | **One Tunnel solution for optimization of Packet Data Traffic** |  | 418d? | 2006-03-27 A | 2007-10-31 A | 100% | 2006-03-27 | 2007-10-31 | 418d? |  | S2 | 7048h | 7048h | OPTUNEL | Nokia | antti.j.pasanen@nokia.com | Rel-7 | Maurice |  |  |
| 1064 | 339.1 | Deleted - Study on Stage 2 for One Tunnel solution |  | 125d? | 2006-03-27 A | 2006-09-15 A | 100% | 2006-03-27 | 2006-09-15 | 125d? | finish no earlier than 2005-09-12 | S2 | 1000h | 1000h | OPTUNEL-Study | Nokia | antti.j.pasanen@nokia.com | Rel-7 | Maurice | 23.809 | SP-34 |
| 1065 | 339.2 | One Tunnel Deployment Guideline |  | 268d? | 2006-10-23 A | 2007-10-31 A | 100% | 2006-10-23 | 2007-10-31 | 268d? | finish no earlier than 2007-10-31 | S2 | 2144h | 2144h | OPTUNEL-Guide | Huawei | lan.liu@huawei.com | Rel-7 | Maurice | 23.919 |  |
| 1066 | 339.3 | Stage 2 specification for One Tunnel solution |  | 70d? | 2006-09-11 A | 2006-12-15 A | 100% | 2006-09-11 | 2006-12-15 | 70d? | finish no earlier than 2006-12-15 | S2 | 560h | 560h | OPTUNEL-Stage2 | Nokia | antti.j.pasanen@nokia.com | Rel-7 | Maurice | 23.060 |  |
| 1067 | 340 | **CSI Terminating Session handling** |  | 267d? | 2006-06-08 A | 2007-06-15 A | 100% | 2006-06-08 | 2007-06-15 | 267d? |  | S2,C1 | 4728h | 4728h | CSItermS | Samsung | Osok Song | Rel-7 | Maurice |  |  |
| 1068 | 340.1 | Stage 2 of CStermS |  | 192d? | 2006-06-08 A | 2007-03-02 A | 100% | 2006-06-08 | 2007-03-02 | 192d? | start no earlier than 2006-06-08 | S2 | 1536h | 1536h | CSItermS | Samsung | Osok Song | Rel-7 | Maurice | 23.279 |  |
| 1069 | 340.2 | Stage 3 of CStermS |  | 132d? | 2006-12-14 A | 2007-06-15 A | 100% | 2006-12-14 | 2007-06-15 | 132d? | finish no earlier than 2007-06-15 | C1 | 1056h | 1056h | CSItermS | Samsung | chenho.chin@samsung.com | Rel-7 | Frederic | 24.229, 24.279 |  |
| 1070 | 340.3 | Deleted - duplicated with UID 340015 -Stage 3 CSI Terminating Session handling | milestone | 0d? | 2007-03-09 A | 2007-03-09 A | 100% | 2007-03-09 | 2007-03-09 | 0d? | start no earlier than 2007-03-09 | C1 |  |  | CSItermS | Samsung | chenho.chin@samsung.com | Rel-7 | Frederic | 24.229, 24.179, 24.279 | CP-34 |
| 1071 | 341 | Liberty Alliance and 3GPP Security Interworking |  | 451d? | 2005-03-10 A | 2006-11-30 A | 100% | 2005-03-10 | 2006-11-30 | 451d? | finish no earlier than 2006-11-30 | S3 | 3608h | 3608h | LibSec | Nokia | Silke.Holtmanns@NOKIA.COM | Rel-7 | Dionisio | 33.980 |  |
| 1072 | 342 | Trust Requirements for Open Platforms in 3GPP |  | 499d? | 2005-01-03 A | 2006-11-30 A | 100% | 2005-01-03 | 2006-11-30 | 499d? | finish no earlier than 2006-11-30 | S3 | 3992h | 3992h | TrustOP | Nokia | Silke.Holtmanns@NOKIA.COM | Rel-7 | Dionisio | 33.905 |  |
| 1073 | 343 | Development of UEA2 and UIA2 |  | 268d? | 2004-12-01 A | 2005-12-09 A | 100% | 2004-12-01 | 2005-12-09 | 268d? | finish no earlier than 2005-12-09 | S3 | 2144h | 2144h | AlgUEA2 | TeliaSonera | per.christoffersson@teliasonera.com | Rel-7 | Dionisio | 35.919, 35.215, 35.216, 35.217, 35.218 |  |
| 1074 | 344 | Lawful Interception in the 3GPP Rel-7 architecture |  | 118d? | 2005-06-28 A | 2005-12-08 A | 100% | 2005-06-28 | 2005-12-08 | 118d? | start no earlier than 2005-06-28 | S3 | 944h | 944h | LI-7A | BMWI | berthold.wilhelm@regtp.de | Rel-7 | Dionisio | 33.106, 33.107, 33.108 |  |
| 1075 | 345 | Key establishment between a UICC and a terminal |  | 201.45d? | 2005-12-07 A | 2006-09-28 A | 100% | 2005-12-07 | 2006-09-28 | 201.45d? | finish no earlier than 2006-09-28 | S3 | 1611.6h | 1611.6h | KeyEstUTerm | Gemalto | mireille.pauliac@gemplus.com | Rel-7 | Dionisio | 33.110 |  |
| 1076 | 346 | NDS Authentication Framework Extension for Transport Layer Security |  | 50d? | 2006-09-28 A | 2006-12-06 A | 100% | 2006-09-28 | 2006-12-06 | 50d? | finish no earlier than 2006-09-28 | S3 | 400h | 400h | NDSAFTLS | Nokia | tiina.s.koskinen@nokia.com | Rel-7 | Dionisio | 33.310 |  |
| 1077 | 347 | **Security enhancements** |  | 319d? | 2005-09-12 A | 2006-11-30 A | 100% | 2005-09-12 | 2006-11-30 | 319d? |  | S3,C1,C4 | 4856h | 4856h | SEC7 |  |  | Rel-7 | Dionisio |  |  |
| 1078 | 347.1 | HTTPS connection between a UICC and a NAF |  | 1d? | 2005-09-12 A | 2005-09-12 A | 100% | 2005-09-12 | 2005-09-12 | 1d? | start no earlier than 2005-09-12 | S3,C1 | 8h | 8h | SEC7-HSUN | Gemalto | JSeif@axalto.com, mireille.pauliac@gemplus.com | Rel-7 | Dionisio | 33.918, 33.222, 24.109 |  |
| 1079 | 347.2 | 2G GBA: 2G SIM usage in 3GPP GAA framework |  | 61d? | 2005-09-12 A | 2005-12-05 A | 100% | 2005-09-12 | 2005-12-05 | 61d? | finish no earlier than 2005-12-05 | S3 | 488h | 488h | SEC7-2GGBA | Nokia | Silke.Holtmanns@nokia.com | Rel-7 | Dionisio | 33.920, 33.220 |  |
| 1080 | 347.3 | Generic Authentication Architecture usage extensions and optimizations |  | 319d? | 2005-09-12 A | 2006-11-30 A | 100% | 2005-09-12 | 2006-11-30 | 319d? | finish no earlier than 2006-11-30 | S3 | 2552h | 2552h | SEC7-GAA2 | Nokia | Silke.Holtmanns@nokia.com | Rel-7 | Dionisio | 33.220, 29.109, 24.109, (33.223 goes to R8) |  |

Notes:
- 1054: WID approved SP#27; updated SP#28; updated SP#32
- 1055: -
- 1056: -
- 1057: -
- 1058: 03/2006 SP#31 WID approved
- 1059: -
- 1060: -
- 1061: -
- 1062: -
- 1063: -
- 1064: S2#52 CREATED. TR for Info SP-33. SP-34: S2 Report intention to discontinue TR
- 1065: -
- 1066: S2#52 CREATED
- 1067: Triggered by the abandoned Study UID_32117
- 1068: -
- 1069: CP-34 approved WID. CP-35 updated WID
- 1070: CP-34 approved WID
- 1071: WID approved SP#27.
- 1072: WID approved SP#26.
- 1073: WID approved SP#26, Dependant on Funding Availability.
- 1074: -
- 1075: -
- 1076: TLS profile is moved to Rel-8
- 1077: -
- 1078: -
- 1079: -
- 1080: 33.223 goes to R8

| ID | WBS | Task | Duration | Start | Finish | Complete | Baseline start | Baseline finish | Baseline duration | Constraint | Resources | Work | Actual work | Text1 | Text4 | Text5 | Text6 | Text8 | Text3 | Text12 | Text2 | Text7 |
| --- | --- | --- | --- | --- | --- | --- | --- | --- | --- | --- | --- | --- | --- | --- | --- | --- | --- | --- | --- | --- | --- | --- |
| 1081 | 347.4 | **SS7 TCAP security Gateway** | 241d? | 2005-09-12 A | 2006-08-14 A | 100% | 2005-09-12 | 2006-08-14 | 241d? |  | S3,C4 | 1808h | 1808h | SEC7-NDS-TCAPsec | Siemens | marc.blommaert.ext@nsn.com | Rel-7 | Dionisio |  |  |  |  |
| 1082 | 347.4.1 | SA3 aspects of SEC7-NDS-TCAPsec | 130d? | 2005-09-12 A | 2006-03-10 A | 100% | 2005-09-12 | 2006-03-10 | 130d? | finish no earlier than 2006-03-10 | S3 | 1040h | 1040h | SEC7-NDS-TCAPsec-SA3 | Siemens | marc.blommaert.ext@nsn.com | Rel-7 | Dionisio | 33.204 |  |  |  |
| 1083 | 347.4.2 | TCAPsec Gateway | 96d? | 2006-04-03 A | 2006-08-14 A | 100% | 2006-04-03 | 2006-08-14 | 96d? | start no earlier than 2006-04-01 | C4 | 768h | 768h | SEC7-TCAP | Siemens | Ulrich.wiehe@gksag.de | Rel-7 | Kimmo | 29.204, 29.002 |  |  |  |
| 1084 | 348 | IMS Stage 3 IETF Protocol alignment | 589d? | 2004-12-10 A | 2007-03-14 A | 100% | 2004-12-10 | 2007-03-14 | 589d? | finish no earlier than 2007-03-15 | C1 | 4712h | 4712h | IMSProtoc |  |  | Rel-7 | Frederic | 24.930 |  |  |  |
| 1085 | 349 | **Interoperability between VGCS/VBS and A/Gb flexibility** | 253d? | 2006-03-22 A | 2007-03-09 A | 100% | 2006-03-22 | 2007-03-09 | 253d? |  | C1,C4 | 3296h | 3296h | VGCSFlex | Siemens | robert.zaus@nsn.com | Rel-7 | Frederic |  |  |  |  |
| 1086 | 349.1 | CT1 aspects of VGCSFlex | 159d? | 2006-03-22 A | 2006-10-30 A | 100% | 2006-03-22 | 2006-10-30 | 159d? | finish no earlier than 2006-10-30 | C1 | 1272h | 1272h | VGCSFlex | Siemens | robert.zaus@nsn.com | Rel-7 | Frederic | 43.068, 43.069 |  |  |  |
| 1087 | 349.2 | CT4 aspects of VGCSFlex | 253d? | 2006-03-22 A | 2007-03-09 A | 100% | 2006-03-22 | 2007-03-09 | 253d? | finish no earlier than 2007-03-09 | C4 | 2024h | 2024h | VGCSFlex-c4 | Siemens | robert.zaus@nsn.com | Rel-7 | Kimmo | 29.002 |  |  |  |
| 1088 | 350 | DIAMETER on the GGSN Gi interface | 586d? | 2004-09-10 A | 2006-12-08 A | 100% | 2004-09-10 | 2006-12-08 | 586d? | finish no earlier than 2006-12-08 | C3 | 4688h | 4688h | DIAMGi | Vodafone | Nico.Gabriele@vodafone.com | Rel-7 | Gwiho | 29.061 |  |  |  |
| 1089 | 351 | DIAMETER on the PDG Wi interface | 586d? | 2004-09-10 A | 2006-12-08 A | 100% | 2004-09-10 | 2006-12-08 | 586d? | finish no earlier than 2006-12-08 | C3 | 4688h | 4688h | DIAMWi | Vodafone | Nico.Gabriele@vodafone.com | Rel-7 | Gwiho | 29.161 |  |  |  |
| 1090 | 352 | Interworking between the 3GPP CS domain with BICC or ISUP as signalling protocol and external SIP-I networks | 478d? | 2006-09-22 A | 2008-07-22 A | 100% | 2006-09-22 | 2008-07-22 | 478d? | finish no earlier than 2007-09-14 | C3 | 3824h | 3824h | ExtSIPI | Siemens | Thomas.Belling@nsn.com | Rel-7 | Gwiho | 29.164 |  |  |  |
| 1091 | 353 | PDU multiplexing at Nb Interface with IP transport | 427d? | 2006-12-04 A | 2008-07-22 A | 100% | 2006-12-04 | 2008-07-22 | 427d? | start no earlier than 2006-12-04 | C3 | 3416h | 3416h | NbIPMux | Alcatel-Lucent | Jean.Rzeznik@alcatel-lucent.fr | Rel-7 | Gwiho | 29.414 |  |  |  |
| 1092 | 354 | **Mp (MRFC - MRFP) interface** | 345d? | 2006-02-13 A | 2007-06-08 A | 100% | 2006-02-13 | 2007-06-08 | 345d? |  | C4,C1 | 4384h | 4384h | Mp | Ericsson | philip.hodges@ericsson.com | Rel-7 | Kimmo |  |  |  |  |
| 1093 | 354.1 | CT1 aspects of Mp | 1d | 2006-02-13 A | 2006-02-13 A | 100% | 2006-02-13 | 2006-02-13 | 1d | finish no earlier than 2006-02-13 | C1 | 8h | 8h | Mp | Ericsson | philip.hodges@ericsson.com | Rel-7 | Frederic | 24.229 |  |  |  |
| 1094 | 354.2 | Deleted - CT3 aspects of Mp | 1d | 2006-09-22 A | 2006-09-22 A | 100% | 2006-09-22 | 2006-09-22 | 1d | start no earlier than 2006-09-22 | C3 | 8h | 8h | Mp | Ericsson | philip.hodges@ericsson.com | Rel-7 | Gwiho | 29.162 | CP-33 |  |  |
| 1095 | 354.3 | Procedures description | 201d? | 2006-06-02 A | 2007-03-09 A | 100% | 2006-06-02 | 2007-03-09 | 201d? | finish no earlier than 2007-03-09 | C4 | 1608h | 1608h | Mp-PROCc4 | Huawei | Chencheng@huawei.com | Rel-7 | Kimmo | 23.333 |  |  |  |
| 1096 | 354.4 | Stage 3 | 345d | 2006-02-13 A | 2007-06-08 A | 100% | 2006-02-13 | 2007-06-08 | 345d | finish no earlier than 2007-06-08 | C4 | 2760h | 2760h | Mp-St3c4 | Ericsson | philip.hodges@ericsson.com | Rel-7 | Kimmo | 29.333 |  |  |  |
| 1097 | 355 | Routeing of MT-SMS via the HPLMN | 71d? | 2006-12-01 A | 2007-03-09 A | 100% | 2006-12-01 | 2007-03-09 | 71d? | finish no earlier than 2007-03-09 | C4,C1 | 568h | 568h | SMSviaH | Vodafone | Nick.Russell@vodafone.com | Rel-7 | Kimmo | 23.040, 29.002 |  |  |  |
| 1098 | 356 | Mobile Termination whilst the MS is moving to another MSC | 60d? | 2007-03-09 A | 2007-05-31 A | 100% | 2007-03-09 | 2007-05-31 | 60d? | start no earlier than 2007-03-09 | C4 | 480h | 480h | MTmovMS | Alcatel-Lucent | bruno.landais@alcatel-lucent.fr | Rel-7 | Kimmo | 23.008, 23.012, 23.018, 23.078, 23.079, 29.002 |  |  |  |
| 1099 | 357 | ISIM API for Java Card | 620d? | 2005-03-14 A | 2007-07-27 A | 100% | 2005-03-14 | 2007-07-27 | 620d? | finish no earlier than 2007-07-27 | C6 | 4960h | 4960h | APIJAVA | Sun | Sebastian Hans | Rel-7 | Xavier | 31.103, 102 241 |  |  |  |
| 1100 | 358 | Rel-7 (U)SIM API Testing (TS 31.213) | 211d? | 2009-05-30 A | 2010-03-19 A | 100% | 2009-05-30 | 2010-03-19 | 211d? | finish no earlier than 2010-03-12 | C6 | 1688h | 1688h | USIM_API_test | Sagem Orga | gerrit.hartbrod@sagem-orga.com | Rel-7 | Xavier | 31.213 |  | PCG-23 | CP-44 |
| 1101 | 359 | High speed interface between the UICC and the ME | 311d? | 2006-09-22 A | 2007-11-30 A | 100% | 2006-09-22 | 2007-11-30 | 311d? | finish no earlier than 2007-11-30 | C6 | 2488h | 2488h | HSI | Gemalto | jacques.seif@GEMALTO.COM | Rel-7 | Xavier | 31.101 |  |  |  |
| 1102 | 360 | Video Codec Performance Requirements | 634d? | 2005-01-03 A | 2007-06-07 A | 100% | 2005-01-03 | 2007-06-07 | 634d? | finish no earlier than 2007-06-07 | S4 | 5072h | 5072h | VICPer | Siemens | juergen.pandel@siemens.com | Rel-7 | Paolo | 26.234, 26.235, 26.346, 26.140, 26.902 |  |  |  |
| 1103 | 361 | Dynamic and Interactive Multimedia Scenes | 583d? | 2005-03-15 A | 2007-06-07 A | 100% | 2005-03-15 | 2007-06-07 | 583d? | finish no earlier than 2007-06-07 | S4 | 4664h | 4664h | DIMS | Streamezzo | gaelle.martin-cocher@streamezzo.com | Rel-7 | Paolo | 26.140, 26.142, 26.234, 26.244, 23.346 |  |  |  |
| 1104 | 362 | 3G-324M Video Telephony Call Setup Times Improvements | 341d? | 2005-06-08 A | 2006-09-27 A | 100% | 2005-06-08 | 2006-09-27 | 341d? | finish no earlier than 2006-09-27 | S4 | 2728h | 2728h | VTCSTI | Vodafone | edward.hall@vodafone.co.uk | Rel-7 | Paolo | 26.911 |  |  |  |

Notes:
- 1081: -
- 1082: -
- 1083: -
- 1084: TR 24.930: Signalling flows for the session setup in the IM CN subsystem based on Session Initiation Protocol (SIP)
- 1085: Voice Group Call Service
- 1086: -
- 1087: -
- 1088: -
- 1089: -
- 1090: -
- 1091: -
- 1092: -
- 1093: -
- 1094: CP#34: CT3 not involved in Mp interface definition
- 1095: -
- 1096: -
- 1097: WID approved in CP#34
- 1098: -
- 1099: -
- 1100: CP#47 completed. Update of Rel-6 (U)SIM API for Java Card Testing UID_43007 under Rel-6 UICC/USIM enhancements and interworking UID_1800
- 1101: Following ETSI publication of TS 102 600, expected to be completed at CT6 meeting 45
- 1102: -
- 1103: -
- 1104: -

| ID | WBS | Task | Type | Duration | Start | Finish | Complete | Baseline start | Baseline finish | Baseline duration | Constraint | Resources | Work | Actual work | Text1 | Text4 | Text5 | Text6 | Text8 | Text12 |
| --- | --- | --- | --- | --- | --- | --- | --- | --- | --- | --- | --- | --- | --- | --- | --- | --- | --- | --- | --- | --- |
| 1105 | 363 | **Optimizations for Multimedia Telephony over IMS** |  | 0d? | 2005-09-28 A | 2005-09-28 A | 100% | 2005-09-28 | 2005-09-28 | 0d? |  | S4 |  |  | OMTIMS | Ericsson | olle.franceschi@ericsson.com | Rel-7 | Paolo |  |
| 1106 | 363.1 | Deleted - Characterisation of Adaptive Jitter Management Performance for VoIP Services | milestone | 0d? | 2005-09-28 A | 2005-09-28 A | 100% | 2005-09-28 | 2005-09-28 | 0d? | start no earlier than 2007-03-15 | S4 |  |  | OMTIMS-CAJMP | Lucent | dhuo@lucent.com | Rel-7 | Paolo | SP-35 |
| 1107 | 364 | End-to-End Multimedia Services Performance Metrics |  | 382d? | 2005-09-28 A | 2007-03-15 A | 100% | 2005-09-28 | 2007-03-15 | 382d? | finish no earlier than 2007-03-15 | S4 | 3056h | 3056h | E2EMSPM | China Mobile | zhangyanyf@chinamobile.com | Rel-7 | Paolo |  |
| 1108 | 365 | Packet Switched Streaming Enhancements |  | 261d? | 2006-06-08 A | 2007-06-07 A | 100% | 2006-06-08 | 2007-06-07 | 261d? | finish no earlier than 2007-06-07 | S4 | 2088h | 2088h | PSSe | Ericsson | olle.franceschi@ericsson.com | Rel-7 | Paolo |  |
| 1109 | 366 | **OAM&P Rel-7** |  | 472.86d? | 2005-09-02 A | 2007-06-26 A | 100% | 2005-09-02 | 2007-06-26 | 472.86d? |  | S5 | 82725.8h | 82725.8h | OAM7 | Huawei | Christian.Toche@huawei.com | Rel-7 | Dionisio |  |
| 1110 | 366.1 | **Network Infrastructure Management** |  | 465d? | 2005-09-02 A | 2007-06-14 A | 100% | 2005-09-02 | 2007-06-14 | 465d? |  | S5 | 41800h | 41800h | OAM7-NIM |  |  | Rel-7 | Dionisio |  |
| 1111 | 366.1.1 | Enhance NRM to accommodate NGN (IMS as basis of the Next Generation Network) |  | 465d? | 2005-09-02 A | 2007-06-14 A | 100% | 2005-09-02 | 2007-06-14 | 465d? | finish no earlier than 2007-06-14 | S5 | 3720h | 3720h | OAM7-NIM | Motorola |  | Rel-7 | Dionisio |  |
| 1112 | 366.1.2 | Co-operative Element Management interface (CO-OP) (Study + Implementation) |  | 400d? | 2005-09-02 A | 2007-03-15 A | 100% | 2005-09-02 | 2007-03-15 | 400d? | finish no earlier than 2007-03-15 | S5 | 3200h | 3200h | OAM7-NIM | Motorola |  | Rel-7 | Dionisio |  |
| 1113 | 366.1.3 | Network Management (NM) Itf-N performance criteria |  | 465d? | 2005-09-02 A | 2007-06-14 A | 100% | 2005-09-02 | 2007-06-14 | 465d? | finish no earlier than 2007-06-14 | S5 | 3720h | 3720h | OAM7-NIM | China Mobile |  | Rel-7 | Dionisio |  |
| 1114 | 366.1.4 | Delta synchronization between IRP Manager and IRP Agent (Study + Implementation) |  | 465d? | 2005-09-02 A | 2007-06-14 A | 100% | 2005-09-02 | 2007-06-14 | 465d? | finish no earlier than 2007-06-14 | S5 | 3720h | 3720h | OAM7-NIM | Siemens |  | Rel-7 | Dionisio |  |
| 1115 | 366.1.5 | Subscription Management (SuM) IRP Solution Sets |  | 330d? | 2005-09-02 A | 2006-12-07 A | 100% | 2005-09-02 | 2006-12-07 | 330d? | finish no earlier than 2006-12-07 | S5 | 2640h | 2640h | OAM7-NIM | Ericsson |  | Rel-7 | Dionisio |  |
| 1116 | 366.1.6 | Integration Reference Point (IRP) Security Management |  | 400d? | 2005-09-02 A | 2007-03-15 A | 100% | 2005-09-02 | 2007-03-15 | 400d? | finish no earlier than 2007-03-15 | S5 | 3200h | 3200h | OAM7-NIM | Huawei | Christian.Toche@huawei.com | Rel-7 | Dionisio |  |
| 1117 | 366.1.7 | Partial suspension of Itf-N during maintenance/testing (Study + Implementation) |  | 465d? | 2005-09-02 A | 2007-06-14 A | 100% | 2005-09-02 | 2007-06-14 | 465d? | finish no earlier than 2007-06-14 | S5 | 3720h | 3720h | OAM7-NIM | Siemens |  | Rel-7 | Dionisio |  |
| 1118 | 366.1.8 | Deleted - Management of Legacy Equipment |  | 336d? | 2005-09-02 A | 2006-12-15 A | 100% | 2005-09-02 | 2006-12-15 | 336d? | finish no earlier than 2006-12-15 | S5 | 2688h | 2688h | OAM7-NIM | Siemens |  | Rel-7 | Dionisio | SP-35 |
| 1119 | 366.1.9 | Deleted - Rules for Vendor Specific Extensions |  | 400d? | 2005-09-02 A | 2007-03-15 A | 100% | 2005-09-02 | 2007-03-15 | 400d? | finish no earlier than 2007-03-15 | S5 | 3200h | 3200h | OAM7-NIM | Siemens |  | Rel-7 | Dionisio | SP-35 |
| 1120 | 366.1.10 | Backward and Forward Compatibility of IRP systems |  | 465d? | 2005-09-02 A | 2007-06-14 A | 100% | 2005-09-02 | 2007-06-14 | 465d? | finish no earlier than 2007-06-14 | S5 | 3720h | 3720h | OAM7-NIM | Ericsson |  | Rel-7 | Dionisio |  |
| 1121 | 366.1.11 | Repeater Network Resource Model (NRM) definition |  | 214d? | 2006-02-13 A | 2006-12-07 A | 100% | 2006-02-13 | 2006-12-07 | 214d? | finish no earlier than 2006-12-07 | S5 | 1712h | 1712h | OAM7-NIM | China Mobile |  | Rel-7 | Dionisio |  |
| 1122 | 366.1.12 | UTRAN radio channel power monitoring |  | 284d? | 2006-02-13 A | 2007-03-15 A | 100% | 2006-02-13 | 2007-03-15 | 284d? | finish no earlier than 2007-03-15 | S5 | 2272h | 2272h | OAM7-NIM | China Mobile |  | Rel-7 | Dionisio |  |
| 1123 | 366.1.13 | Notification XML Schema |  | 71d? | 2006-12-07 A | 2007-03-15 A | 100% | 2006-12-07 | 2007-03-15 | 71d? | finish no earlier than 2007-03-15 | S5 | 568h | 568h | OAM7-NIM | Huawei | Christian.Toche@huawei.com | Rel-7 | Dionisio |  |
| 1124 | 366.2 | **Performance Management** |  | 465d? | 2005-09-02 A | 2007-06-14 A | 100% | 2005-09-02 | 2007-06-14 | 465d? |  | S5 | 22992h | 22992h | OAM7-PM |  |  | Rel-7 | Dionisio |  |
| 1125 | 366.2.1 | Performance measurements definition for CN CS |  | 400d? | 2005-09-02 A | 2007-03-15 A | 100% | 2005-09-02 | 2007-03-15 | 400d? | finish no earlier than 2007-03-15 | S5 | 3200h | 3200h | OAM7-PM | China Mobile |  | Rel-7 | Dionisio |  |
| 1126 | 366.2.2 | Enhancement UTRAN performance measurements definition |  | 465d? | 2005-09-02 A | 2007-06-14 A | 100% | 2005-09-02 | 2007-06-14 | 465d? | finish no earlier than 2007-06-14 | S5 | 3720h | 3720h | OAM7-PM | China Mobile |  | Rel-7 | Dionisio |  |
| 1127 | 366.2.3 | Add TDD specific counters in Performance measurement |  | 330d? | 2005-09-02 A | 2006-12-07 A | 100% | 2005-09-02 | 2006-12-07 | 330d? | finish no earlier than 2006-12-15 | S5 | 2640h | 2640h | OAM7-PM | CATT |  | Rel-7 | Dionisio |  |
| 1128 | 366.2.4 | ATM bearer network Performance measurements |  | 400d? | 2005-09-02 A | 2007-03-15 A | 100% | 2005-09-02 | 2007-03-15 | 400d? | finish no earlier than 2007-03-15 | S5 | 3200h | 3200h | OAM7-PM | ZTE |  | Rel-7 | Dionisio |  |
| 1129 | 366.2.5 | Performance measurements definition for IMS |  | 465d? | 2005-09-02 A | 2007-06-14 A | 100% | 2005-09-02 | 2007-06-14 | 465d? | finish no earlier than 2007-06-14 | S5 | 3720h | 3720h | OAM7-PM | China Mobile |  | Rel-7 | Dionisio |  |
| 1130 | 366.2.6 | HSDPA performance measurements |  | 349d? | 2006-02-13 A | 2007-06-14 A | 100% | 2006-02-13 | 2007-06-14 | 349d? | finish no earlier than 2007-06-14 | S5 | 2792h | 2792h | OAM7-PM | China Mobile |  | Rel-7 | Dionisio |  |

Notes:
- 1105: - / Text3: 26.235, 26.236
- 1106: SP-35 stopped
- 1107: - / Text3: 26.944
- 1108: - / Text3: 26.234, 26.244
- 1109: -
- 1110: -
- 1111: - / Text3: 32.731/2/3/5, 32.631/2/3/5
- 1112: - / Text3: 32.806, 32.814, 32.101
- 1113: - / Text3: 32.811
- 1114: - / Text3: 32.391/2/3/5
- 1115: - / Text3: 32.307/317/607/667/665, 32.101, 32.175
- 1116: - / Text3: 32.372/3/5, 32.111,32.30x,32.32x,32.33x,32.34x,32.35x,32.36x,32.41x,32.60x,32.61x,32.66x
- 1117: - / Text3: 32.381/2/3/5
- 1118: Request to TSG#35 to STOP the WI / Text3: new 32.xxx
- 1119: Request to TSG#35 to STOP the WI / Text3: 32.62n; For n = 1 to 5
- 1120: - / Text3: 32.154
- 1121: - / Text3: 32.721/2/3/5
- 1122: - / Text3: 32.405, 32.64n; For n = 1 to 5
- 1123: 12/2006 SP#34 WID approved / Text3: New 32.325/345/365/415, CR to 32.335/615/665
- 1124: -
- 1125: - / Text3: 32.407, 32.408
- 1126: - / Text3: 32.405
- 1127: - / Text3: 32.405
- 1128: - / Text3: No impact on 32.404, 32.405, 32.406, 32.407
- 1129: - / Text3: 32.404,32.409,32.437, 32.632/3/4/5
- 1130: - / Text3: 32.405

| ID | WBS | Task | Type | Duration | Start | Finish | Complete | Baseline start | Baseline finish | Baseline duration | Constraint | Resources | Work | Actual work | Text1 | Text4 | Text6 | Text8 | Text12 | Text5 | Text11 | Text9 |
| --- | --- | --- | --- | --- | --- | --- | --- | --- | --- | --- | --- | --- | --- | --- | --- | --- | --- | --- | --- | --- | --- | --- |
| 1131 | 44.5 | **Trace Management** |  | 472.86d? | 2005-09-02 A | 2007-06-26 A | 100% | 2005-09-02 | 2007-06-26 | 472.86d? |  | S5 | 14150.9h | 14150.9h | OAM7-Trace | Vodafone | Rel-7 | Dionisio |  |  |  |  |
| 1132 | 366.3.1 | End-to-end Service Level tracing for IMS |  | 350d? | 2005-11-11 A | 2007-03-15 A | 100% | 2005-11-11 | 2007-03-15 | 350d? | finish no earlier than 2007-03-15 | S5 | 2800h | 2800h | OAM7-Trace | Vodafone | Rel-7 | Dionisio | SP-31 |  |  |  |
| 1133 | 366.3.2 | Trace record content for UTRAN TDD |  | 330d? | 2005-09-02 A | 2006-12-07 A | 100% | 2005-09-02 | 2006-12-07 | 330d? | finish no earlier than 2006-12-07 | S5 | 2640h | 2640h | OAM7-Trace | Nokia | Rel-7 | Dionisio |  |  |  |  |
| 1134 | 366.3.3 | IRP for Subscriber and Equipment Trace Management |  | 465d? | 2005-09-02 A | 2007-06-14 A | 100% | 2005-09-02 | 2007-06-14 | 465d? | finish no earlier than 2007-06-14 | S5 | 3720h | 3720h | OAM7-Trace | Nokia | Rel-7 | Dionisio |  |  |  |  |
| 1135 | 366.3.4 | Deleted - SIP enhancements for trace | milestone | 0d? | 2007-06-15 A | 2007-06-26 A | 100% | 2007-06-15 | 2007-06-26 | 0d? | start no earlier than 2007-06-15 | C1 |  |  | OAM7-Trace |  | Rel-7 | Frederic | CP-32 |  |  |  |
| 1136 | 366.3.5 | Deleted - duplicated with UID 35063 - IRP for Subscriber and Equipment Trace Management |  | 336d? | 2005-09-02 A | 2006-12-15 A | 100% | 2005-09-02 | 2006-12-15 | 336d? | finish no earlier than 2006-12-15 | S5 | 2688h | 2688h | OAM7-Trace | Nokia | Rel-7 | Dionisio | SP-33 |  |  |  |
| 1137 | 367 | **Charging Management small Enhancements Rel-7** |  | 279d? | 2006-05-22 A | 2007-06-14 A | 100% | 2006-05-22 | 2007-06-14 | 279d? |  | S5 | 5952h | 5952h | CH7 | Orange | Rel-7 | Dionisio |  | alain.bibas@orange-ft.com |  |  |
| 1138 | 367.1 | Alternate Charged Party (ACP) for IMS |  | 279d? | 2006-05-22 A | 2007-06-14 A | 100% | 2006-05-22 | 2007-06-14 | 279d? | finish no earlier than 2007-06-14 | S5 | 2232h | 2232h | CH7-IMS-ACP | Lucent | Rel-7 | Dionisio |  | njmazzarella@alcatel-lucent.com |  |  |
| 1139 | 367.2 | Align 3GPP Charging with OMA PoC Enabler Release 2.0 |  | 186d? | 2006-09-28 A | 2007-06-14 A | 100% | 2006-09-28 | 2007-06-14 | 186d? | finish no earlier than 2007-06-14 | S5 | 1488h | 1488h | CH7-PoC | Siemens | Rel-7 | Dionisio |  | Gerald GÖRMER |  |  |
| 1140 | 8.5 | **Multiple Input Multiple Output antennas (MIMO)** |  | 1177d? | 2003-03-14 A | 2007-09-17 A | 100% | 2003-03-14 | 2007-09-17 | 1177d? |  | R1 | 40272h | 40272h | MIMO | Alcatel-Lucent | Rel-7 | Patrick |  | hchuang@Alcatel-Lucent.com | RP-070037, RP-070531 |  |
| 1141 | 368.1 | MIMO - Physical layer |  | 915d? | 2003-09-12 A | 2007-03-15 A | 100% | 2003-09-12 | 2007-03-15 | 915d? | finish no earlier than 2007-03-15 | R1 | 7320h | 7320h | MIMO-Phys | Alcatel-Lucent | Rel-7 | Patrick |  | hchuang@Alcatel-Lucent.com | RP-070037 |  |
| 1142 | 368.2 | MIMO - Layer 2,3 aspects |  | 915d? | 2003-09-12 A | 2007-03-15 A | 100% | 2003-09-12 | 2007-03-15 | 915d? | finish no earlier than 2007-03-15 | R2 | 7320h | 7320h | MIMO-L23 | Alcatel-Lucent | Rel-7 | Joern |  | hchuang@Alcatel-Lucent.com | RP-070037 |  |
| 1143 | 368.3 | MIMO - Iub/Iur Protocol Aspects |  | 1045d? | 2003-03-14 A | 2007-03-15 A | 100% | 2003-03-14 | 2007-03-15 | 1045d? | finish no earlier than 2007-03-15 | R3 | 8360h | 8360h | MIMO-IurIub | Alcatel-Lucent | Rel-7 | Juha |  | hchuang@Alcatel-Lucent.com | RP-070037 |  |
| 1144 | 368.4 | MIMO - RF Radio Transmission/Reception, System Performance Requirements and Conformance Testing |  | 982d? | 2003-12-12 A | 2007-09-17 A | 100% | 2003-12-12 | 2007-09-17 | 982d? | finish no earlier than 2007-09-17 | R4 | 7856h | 7856h | MIMO-RF | Alcatel-Lucent | Rel-7 | Issam |  | ngm@Alcatel-Lucent.com | RP-070531 |  |
| 1145 | 369 | **Rel-7 Improvements of the Radio Interface** |  | 709d? | 2004-09-15 A | 2007-06-04 A | 100% | 2004-09-15 | 2007-06-04 | 709d? |  | RP | 29696h | 29696h | RInImp |  | Rel-7 | Issam |  |  |  |  |
| 1146 | 369.1 | Extended UMTS 1.7/2.1 GHz |  | 198d? | 2006-03-15 A | 2006-12-15 A | 100% | 2006-03-15 | 2006-12-15 | 198d? | finish no earlier than 2006-12-15 | R4 | 1584h | 1584h | RInImp-UMTS1721Ext | Ericsson | Rel-7 | Issam |  | Johan Sköld (johan.skold@ericsson.com) | RP-060681 |  |
| 1147 | 369.2 | UMTS 2.6 GHz 7.68 Mcps TDD |  | 67d? | 2006-06-15 A | 2006-09-15 A | 100% | 2006-06-15 | 2006-09-15 | 67d? | finish no earlier than 2006-09-15 | R4 | 536h | 536h | RInImp-UMTS26VHCRTDD | IPWireless | Rel-7 | Issam |  | Shin Horng Wong (shwong@ipwireless.com) | RP-060451 |  |
| 1148 | 369.3 | UMTS 2.6 GHz |  | 195d? | 2004-09-15 A | 2005-06-14 A | 100% | 2004-09-15 | 2005-06-14 | 195d? | finish no earlier than 2005-06-14 | R4 | 1560h | 1560h | RInImp-UMTS2600 | Nokia | Rel-7 | Issam |  | jussi.numminen@nokia.com | RP-050184 |  |
| 1149 | 369.4 | UMTS 2.6 GHz TDD |  | 261d? | 2004-12-15 A | 2005-12-14 A | 100% | 2004-12-15 | 2005-12-14 | 261d? | finish no earlier than 2005-12-15 | R4 | 2088h | 2088h | RInImp-UMTS2600TDD | IPWireless | Rel-7 | Issam |  | Shin Horng Wong (shwong@ipwireless.com) | RP-050661 |  |
| 1150 | 369.5 | UMTS 900 MHz |  | 261d? | 2004-12-15 A | 2005-12-14 A | 100% | 2004-12-15 | 2005-12-14 | 261d? | finish no earlier than 2005-12-15 | R4 | 2088h | 2088h | RInImp-UMTS900 | Nortel | Rel-7 | Issam |  | Yannick Li (yli@nortelnetworks.com) | RP-050662 |  |
| 1151 | 369.6 | UMTS 1700 MHz |  | 197d? | 2005-03-15 A | 2005-12-14 A | 100% | 2005-03-15 | 2005-12-14 | 197d? | finish no earlier than 2005-12-15 | R4 | 1576h | 1576h | RInImp-UMTS1700 | NTT DoCoMo | Rel-7 | Issam |  | Takehiro Nakamura (nakamurata@nttdocomo.co.jp) | RP-050824 |  |
| 1152 | 369.7 | UE Antenna Performance Evaluation Method and Requirements |  | 644d? | 2004-12-15 A | 2007-06-04 A | 100% | 2004-12-15 | 2007-06-04 | 644d? | finish no earlier than 2007-06-04 | R4 | 5152h | 5152h | RInImp-UEAnt | TeliaSonera | Rel-7 | Issam |  | Christian.Bergljung@TeliaSonera.com | RP-070281 |  |
| 1153 | 369.8 | Improved Performance Requirements for HSDPA UE based on Rx Diversity (type 1) & LMMSE equalizer (type 2) | milestone | 0d? | 2005-03-15 A | 2005-03-15 A | 100% | 2005-03-15 | 2005-03-15 | 0d? | finish no earlier than 2005-03-15 | R4 |  |  | RInImp-HSPerf-Type3 | Cingular | Rel-7 | Issam |  | Marc Grant | RP-060015 |  |
| 1154 | 369.9 | **Additional minimum UE performance requirement for non-HSDPA channels based on type 1 enhanced receiver (Rx Diversity)** |  | 327d? | 2005-09-15 A | 2006-12-15 A | 100% | 2005-09-15 | 2006-12-15 | 327d? |  | R4 | 7344h | 7344h | RInImp-RxDiv | Qualcomm | Rel-7 | Issam |  | Serge Willenegger (sergew@qualcomm.com) |  |  |
| 1155 | 369.9.1 | Additional minimum UE performance requirement for DL physical channels in support of DCH/HS-DSCH operation based on type 1 enhanced receiver (RX-Diversity) |  | 195d? | 2005-09-15 A | 2006-06-14 A | 100% | 2005-09-15 | 2006-06-14 | 195d? | finish no earlier than 2006-06-15 | R4 | 1560h | 1560h | RInImp-RxDiv-DCH | Cingular | Rel-7 | Issam |  | Marc Grant | RP-060235 |  |
| 1156 | 369.9.2 | Additional minimum UE performance requirement for downlink physical channels in support of MTCH and MCCH operation based on type 1 enhanced receiver (Rx-Diversity) |  | 198d? | 2006-03-15 A | 2006-12-15 A | 100% | 2006-03-15 | 2006-12-15 | 198d? | finish no earlier than 2006-12-15 | R4 | 1584h | 1584h | RInImp-RxDiv-MBMS | Qualcomm | Rel-7 | Issam |  | Serge Willenegger (sergew@qualcomm.com) | RP-060678 |  |
| 1157 | 369.9.3 | Additional minimum UE performance requirement for downlink physical channels in support of E-DCH operation based on type 1 enhanced receiver (Rx-Diversity) |  | 198d? | 2006-03-15 A | 2006-12-15 A | 100% | 2006-03-15 | 2006-12-15 | 198d? | finish no earlier than 2006-12-15 | R4 | 1584h | 1584h | RInImp-RxDiv-EDCH | Qualcomm | Rel-7 | Issam |  | Serge Willenegger (sergew@qualcomm.com) | RP-060679 |  |
| 1158 | 369.10 | Deleted Improved support of gaming over HSDPA/EDCH |  | 262d? | 2005-12-15 A | 2006-12-15 A | 100% | 2005-12-15 | 2006-12-15 | 262d? | finish no earlier than 2006-12-15 | R2 | 2096h | 2096h | RInImp-Gaming | Cingular | Rel-7 | Joern | RP-34 | Don Zelmer (dz1069@att.com) | RP-060680 |  |
| 1159 | 369.11 | Deleted (not approved at PCG) - UMTS 2.6 GHz FDD DL External | milestone | 0d? | 2005-09-15 A | 2005-09-15 A | 100% | 2005-09-15 | 2005-09-15 | 0d? | finish no earlier than 2005-09-15 | R4 |  |  | RInImp-UMTS2600Ext | T-mobile | Rel-7 | Issam | RP-31 | han.van.bussel@t-mobile.de |  | PCG-16 |

Notes:
- 1131: -
- 1132: 07/2005: OMA (Stage 1), Stage 2/3 SA5, CT1/3/4 / Text3: CR 32.101, 32.421/2/3.
- 1133: - / Text3: CR 32.421/2/3.
- 1134: - / Text3: 32.441/2/3/5, CRs 32.632/3/5
- 1135: combined with UID 11067
- 1136: - / Text3: 32.421,32.422,32.423. 3 new 32.4x1,2,3
- 1137: -
- 1138: - / Text3: 32.240, 32.260, 32.298, 32.299
- 1139: 09/2006 SP#33 WID approved / Text3: 32.240, 32.272, 32.299, 32.298
- 1140: Completed Sep 2007; SR in RP-070037and RP-070531 / Text3: 25.876, 25.996
- 1141: Completed Sep 2007; SR in RP-070037 / Text3: 25.211, 25.212, 25.213, 25.214, 25.215, 25.221
- 1142: Completed Sep 2007; SR in RP-070037 / Text3: 25.876
- 1143: Completed Sep 2007; SR in RP-070037
- 1144: Completed Sep 2007; SR in RP-070531
- 1145: Generic feature
- 1146: SR in RP-060681. Introduction of Band X (Extended UMTS 1.7/2.1 GHz) in 25.307 / Text3: 25.806, 25.101, 25.104, 25.133, 24.141, 25.331, 25.306, 25.307, 25.423, 25.461, 25.463, 34.121
- 1147: Completed Sep 2006; SR in RP-060451 / Text3: 25.102, 25.105, 25.123, 25.113, 25.142, 34.124
- 1148: SR in RP-050184. Introduction of UMTS2600 internal band, Band VII in 25.307 / Text3: 25.101, 25.104, 25.133, 25.141, 25.331, 25.942, 25.306, 25.307, 34.121
- 1149: SR in RP-050661 / Text3: 25.102, 25.105, 25.113, 25.123, 25.142, 25.331, 25.942, 25.306, 25.307, 34.122, 34.124
- 1150: SR in RP-050662. Introduction of UMTS 900 (Band VIII) in 25.307 / Text3: 25.101, 25.104, 25.113, 25.133, 25.141, 25.331, 25.942, 25.306, 25.307, 34.121
- 1151: SR in RP-050824 / Text3: 25.101, 25.104, 25.113, 25.133, 25.141, 25.306, 25.307, 25.331, 34.121
- 1152: RP#36 (May 2007) completed. SR in RP-070281 / Text3: 25.101, 25.963
- 1153: Completed Mar 2006, SR in RP-060015 / Text3: 25.101
- 1154: - / Text3: 25.101
- 1155: Completed Jun 2006, SR in RP-060235 / Text3: 25.101
- 1156: Completed Dec 2006, SR in RP-060678 / Text3: 25.101
- 1157: Completed Dec 2006, SR in RP-060679 / Text3: 25.101
- 1158: RP#34 (Dec 2006) stopped. SR in RP-060680
- 1159: This item was conditionnaly approved pending decision of PCG 16 who decided not to approve it / Text3: 25.101, 25.104, 25.133, 25.141, 25.331, 25.942, 25.306, 25.307, 34.121

| ID | WBS | Task | Duration | Start | Finish | Complete | Baseline start | Baseline finish | Baseline duration | Constraint | Deadline | Resources | Work | Actual work | Text1 | Text6 | Text8 | Text4 | Text5 | Text10 | Text11 |
| --- | --- | --- | --- | --- | --- | --- | --- | --- | --- | --- | --- | --- | --- | --- | --- | --- | --- | --- | --- | --- | --- |
| 1160 | 370 | **Rel-7 Improvements of the Radio Interface - UE Conformance Testing** | 741d? | 2005-11-11 A | 2008-09-12 A | 100% | 2005-11-11 | 2008-09-12 | 741d? |  |  | R5 | 17568h | 17568h | RInImp-UEConTest | Rel-7 | Ingbert |  |  |  |  |
| 1161 | 16.5.1 | UE Conformance Test for UMTS 2600 MHz | 146d | 2005-11-11 A | 2006-06-02 A | 100% | 2005-11-11 | 2006-06-02 | 146d | finish no earlier than 2006-06-02 | 2006-06-02 | R5 | 1168h | 1168h | RInImp-UMTS2600_Test | Rel-7 | Ingbert | Nokia | Aleksi.Heino@nokia.com | Fri 7/11/05 |  |
| 1162 | 16.5.1 | UE Conformance Test for UMTS 900 MHz (band VIII) | 146d | 2005-11-11 A | 2006-06-02 A | 100% | 2005-11-11 | 2006-06-02 | 146d | finish no earlier than 2006-06-02 | 2006-06-02 | R5 | 1168h | 1168h | RInImp-UMTS900_Test | Rel-7 | Ingbert | Qualcomm | hanye@qualcomm.com | Fri 11/03/05 |  |
| 1163 | 370.3 | Conformance Test Aspects – Improved Performance of HSDPA Receiver type 3 | 191d? | 2006-03-10 A | 2006-12-01 A | 100% | 2006-03-10 | 2006-12-01 | 191d? | finish no earlier than 2006-12-01 |  | R5 | 1528h | 1528h | RInImp-HSPerf-Type3_Test | Rel-7 | Ingbert | Motorola | carolyn.taylor@motorola.com |  |  |
| 1164 | 370.4 | UE antenna Over The Air (OTA) conformance testing | 518d? | 2006-09-20 A | 2008-09-12 A | 100% | 2006-09-20 | 2008-09-12 | 518d? | finish no earlier than 2008-09-12 |  | R5 | 4144h | 4144h | RInImp-UEAnt_Test | Rel-7 | Ingbert | Nokia | Aleksi.Heino@nokia.com |  | RP-080535 |
| 1165 | 370.5 | UE conformance testing for FDD Inter-Band Operation | 131d? | 2006-06-02 A | 2006-12-01 A | 100% | 2006-06-02 | 2006-12-01 | 131d? | finish no earlier than 2006-12-01 |  | R5 | 1048h | 1048h | RInImp-InterBand_Test | Rel-7 | Ingbert | NEC, Motorola | Jacob.John@motorola.com |  |  |
| 1166 | 370.6 | Conformance Test Aspects – Extended UMTS 1.7/2.1 GHz | 131d? | 2006-12-01 A | 2007-06-01 A | 100% | 2006-12-01 | 2007-06-01 | 131d? | finish no earlier than 2007-06-01 |  | R5 | 1048h | 1048h | RInImp-UEConTest_UMTS1721Ext | Rel-7 | Ingbert | Motorola | carolyn.taylor@motorola.com |  |  |
| 1167 | 370.7 | Conformance Test Aspects – Minimum UE performance requirement for downlink physical channels in support of E-DCH operation based on type 1 enhanced receiver (Rx-Diversity) | 136d? | 2007-06-01 A | 2007-12-07 A | 100% | 2007-06-01 | 2007-12-07 | 136d? | finish no earlier than 2007-12-07 |  | R5 | 1088h | 1088h | RInImp-UEConTest_RxDivEDCH | Rel-7 | Ingbert | Motorola | carolyn.taylor@motorola.com |  |  |
| 1168 | 370.8 | Conformance Test Aspects – Minimum UE performance requirement for downlink physical channels in support of MTCGH and MCCH operation based on type 1 enhanced receiver (Rx-Diversity) | 201d? | 2007-06-01 A | 2008-03-07 A | 100% | 2007-06-01 | 2008-03-07 | 201d? | finish no earlier than 2008-03-07 |  | R5 | 1608h | 1608h | RInImp-UEConTest_RxDivMBMS | Rel-7 | Ingbert | Ericsson | leif.mattisson@ericsson.com |  | RP-080056 |
| 1169 | 371 | **Rel-7 RAN improvements** | 653d? | 2004-12-15 A | 2007-06-15 A | 100% | 2004-12-15 | 2007-06-15 | 653d? |  |  | RP | 29920h | 29920h | RANimp | Rel-7 |  |  |  |  |  |
| 1170 | 371.1 | Optimization of channelisation code utilisation for 1.28 Mcps TDD | 523d? | 2004-12-15 A | 2006-12-15 A | 100% | 2004-12-15 | 2006-12-15 | 523d? | finish no earlier than 2006-12-15 |  | R1 | 4184h | 4184h | RANimp-RABSE-CodOptLCRTDD | Rel-7 | Patrick | UTStarcom | Ka Leong Lo (kaleong.lo@UTSTAR.COM) |  | RP-060682 |
| 1171 | 371.2 | Delay optimization for procedures applicable to CS and PS Connections | 394d? | 2005-03-15 A | 2006-09-15 A | 100% | 2005-03-15 | 2006-09-15 | 394d? | finish no earlier than 2006-09-15 |  | R2 | 3152h | 3152h | RANimp-DelayOpt | Rel-7 | Joern | Nokia | juho.pirskanen@nokia.com |  | RP-060453 |
| 1172 | 371.3 | Improved support of IMS Realtime Services using HSDPA/HSUPA | 197d? | 2005-03-15 A | 2005-12-14 A | 100% | 2005-03-15 | 2005-12-14 | 197d? | start no earlier than 2005-03-15 |  | R2 | 1576h | 1576h | RANimp-IMSRealTime | Rel-7 | Joern | Cingular | Don Zelmer (dz1069@att.com) |  | RP-050667 |
| 1173 | 371.4 | UE Performance Requirements for MBMS (TDD) | 328d? | 2005-03-15 A | 2006-06-15 A | 100% | 2005-03-15 | 2006-06-15 | 328d? | finish no earlier than 2006-06-15 |  | R4 | 2624h | 2624h | MBMS-RAN-RF-TDD | Rel-7 | Issam | IPwireless | shwong@ipwireless.com |  | RP-060477 |
| 1174 | 371.5 | Continuous connectivity for packet data users | 524d? | 2005-03-14 A | 2007-03-15 A | 100% | 2005-03-14 | 2007-03-15 | 524d? | finish no earlier than 2007-03-15 |  | R1 | 4192h | 4192h | RANimp-CPC | Rel-7 | Patrick | Siemens | Joern.Krause@siemens.com |  | RP-070033 |
| 1175 | 371.6 | Extended WCDMA Cell Range | 198d? | 2006-03-15 A | 2006-12-15 A | 100% | 2006-03-15 | 2006-12-15 | 198d? | finish no earlier than 2006-12-15 |  | R3 | 1584h | 1584h | RANimp-ExtCell | Rel-7 | Juha | Ericsson | Muhammad Kazmi |  | RP-060685 |
| 1176 | 371.7 | 7.68 Mcps TDD Enhanced Uplink | 198d? | 2006-03-15 A | 2006-12-15 A | 100% | 2006-03-15 | 2006-12-15 | 198d? | finish no earlier than 2006-12-15 |  | R1 | 1584h | 1584h | RANimp-VHCRTDD-EDCH | Rel-7 | Patrick | IPwireless | nanderson@ipwireless.com |  | RP-060684 |
| 1177 | 371.8 | Enhanced CELL_FACH State in FDD | 181d? | 2006-09-25 A | 2007-06-04 A | 100% | 2006-09-25 | 2007-06-04 | 181d? | finish no earlier than 2007-06-04 |  | R2 | 1448h | 1448h | RANimp-EnhState | Rel-7 | Joern | Nokia | juho.pirskanen@nokia.com |  | RP-070286 |
| 1178 | 371.9 | 64QAM for HSDPA (FDD) | 110d? | 2006-12-15 A | 2007-06-04 A | 100% | 2006-12-15 | 2007-06-04 | 110d? | finish no earlier than 2007-06-04 |  | R1 | 880h | 880h | RANimp-64QamDownlink | Rel-7 | Patrick | Ericsson | Johan.Bergman@ericsson.com |  | RP-070287 |
| 1179 | 371.10 | Improved L2 support for high data rates | 122d? | 2006-12-15 A | 2007-06-04 A | 100% | 2006-12-15 | 2007-06-04 | 122d? | finish no earlier than 2007-06-04 |  | R2 | 976h | 976h | RANimp-L2DataRates | Rel-7 | Joern | Ericsson | Janne.Peisa@ericsson.com |  | RP-070289 |
| 1180 | 371.11 | Introduction of 16QAM in HSUPA (FDD) | 110d? | 2006-12-15 A | 2007-06-04 A | 100% | 2006-12-15 | 2007-06-04 | 110d? | finish no earlier than 2007-06-04 |  | R1 | 880h | 880h | RANimp-16QamUplink | Rel-7 | Patrick | Nokia | Karri.Ranta-aho@nsn.com |  | RP-070288 |
| 1181 | 371.12 | **Interface to control Tower Mounted Amplifiers (TMAs)** | 101d? | 2007-01-26 A | 2007-06-15 A | 100% | 2007-01-26 | 2007-06-15 | 101d? |  |  | R3 | 1616h | 1616h | RANImp-TMA | Rel-7 | Juha | Vodafone | alexej.kulakov@vodafone.com |  | RP-070140 |
| 1182 | 371.12.1 | OAM aspects to Interface to control TMAs | 101d? | 2007-01-26 A | 2007-06-15 A | 100% | 2007-01-26 | 2007-06-15 | 101d? | finish no earlier than 2007-06-15 |  | S5 | 808h | 808h | RANImp-TMA-OAM | Rel-7 | Dionisio | Vodafone | Adrian.Neal@vodafone.com |  |  |
| 1183 | 372 | **Rel-7 RAN improvements - UE Conformance Testing** | 784d? | 2006-09-20 A | 2009-09-18 A | 100% | 2006-09-20 | 2009-09-18 | 784d? |  |  | R5 | 25472h | 25472h | RANimp-UEConTest | Rel-7 | Ingbert |  |  |  |  |
| 1184 | 372.1 | Conformance Test Aspects - 3.84 Mcps and 7.68 Mcps TDD Enhanced Uplink | 518d? | 2006-09-20 A | 2008-09-12 A | 100% | 2006-09-20 | 2008-09-12 | 518d? | finish no earlier than 2008-09-12 |  | R5 | 4144h | 4144h | RANimp-UEConTest_EDCHTDH | Rel-7 | Ingbert | IPWireless | tspeight@ipwireless.com |  | RP-080536 |
| 1185 | 372.2 | Conformance Test Aspects – 64QAM for HSDPA (FDD) | 257d? | 2007-03-09 A | 2008-03-03 A | 100% | 2007-03-09 | 2008-03-03 | 257d? | finish no earlier than 2008-03-03 |  | R5 | 2056h | 2056h | RANimp-UEConTest_64QamDownlink | Rel-7 | Ingbert | Ericsson | leif.mattisson@ericsson.com |  | RP-080059 |
| 1186 | 372.3 | Conformance Test Aspects – 16QAM for HSUPA (FDD) | 321d? | 2007-03-09 A | 2008-05-30 A | 100% | 2007-03-09 | 2008-05-30 | 321d? | finish no earlier than 2008-05-30 |  | R5 | 2568h | 2568h | RANimp-UEConTest_16QamUplink | Rel-7 | Ingbert | Motorola | carolyn.taylor@motorola.com |  | RP-080281 |
| 1187 | 372.4 | Conformance Test Aspects – Improved L2 support for high data rates | 321d? | 2007-03-09 A | 2008-05-30 A | 100% | 2007-03-09 | 2008-05-30 | 321d? | finish no earlier than 2008-05-30 |  | R5 | 2568h | 2568h | RANimp-UEConTest_L2DataRates | Rel-7 | Ingbert | Ericsson | leif.mattisson@ericsson.com |  | RP-080256 |
| 1188 | 372.5 | Conformance Test Aspects – Continuous connectivity for packet data users | 321d? | 2007-03-09 A | 2008-05-30 A | 100% | 2007-03-09 | 2008-05-30 | 321d? | finish no earlier than 2008-05-30 |  | R5 | 2568h | 2568h | RANimp-UEConTest_CPC | Rel-7 | Ingbert | Nokia | jarkko.hellsten@nokia.com |  | RP-080282 |
| 1189 | 372.6 | Conformance Test Aspects – Enhanced CELL_FACH state in FDD | 662d? | 2007-03-09 A | 2009-09-18 A | 100% | 2007-03-09 | 2009-09-18 | 662d? | finish no earlier than 2009-09-18 |  | R5 | 5296h | 5296h | RANimp-UEConTest_EnhancedCellFACHState | Rel-7 | Ingbert | Nokia | jarkko.hellsten@nokia.com |  | RP-090711 |

Notes:
- 1160: 05/08: Linked to Feature UID_20028 (RInImp)
- 1161: - / Text3: 34.108, 34.121
- 1162: - / Text3: 34.108, 34.121
- 1163: - / Text3: 34.121, 34.108
- 1164: SR in RP-080535. RP#41 completed (GERAN aspects might need to be included later) / Text3: 34.114
- 1165: - / Text3: 34.108, 34.123-1, 34.123-2, 34.123-3
- 1166: - / Text3: 34.108, 34.121-1, 34.121-2
- 1167: -
- 1168: SR in RP-080056
- 1169: Generic feature
- 1170: Completed Dec 2006; SR in RP-060682
- 1171: Completed Sep 2006; SR in RP-060453 / Text3: 25.815, 25.321, 25.322, 25.331
- 1172: Closed Dec 2005; SR in RP-050667
- 1173: Completed Sep 2006; SR in RP-060477 / Text3: 25.102, 25.123
- 1174: Completed at Mar 2007; SR in RP-070033 / Text3: 25.903, 25.201, 25.211, 25.212, 25.214, 25.308, 25.321, 25.331, 25.423, 25.433, 25.101, 25.133
- 1175: Completed Dec 2006; SR in RP-060685 / Text3: 25.133, 25.423, 25.425, 25.433, 25.435, 25.453, 25.331
- 1176: Completed Dec 2006; SR in RP-060684 / Text3: 25.201, 25.202, 25.221, 25.222, 25.223, 25.224, 25.225, 25.331, 23.321, 25.306, 25.302, 25.401, 25.420, 25.423, 25.427, 25.433, 25.102, 25.105, 25.142
- 1177: Completed May 2007; SR in RP-070286 / Text3: 25.308, 25.304, 25.306, 25.321, 25.331, 25.433, 25.435, 25.423, 25.425,
- 1178: Completed May 2007; SR in RP-070287 / Text3: 25.308, 25.211, 25.212, 25.213, 25.306, 25.331, 25.433, 25.435, 25.423, 25.425, 25.101, 25.104, 25.141
- 1179: Completed May 2007; SR in RP-070289 / Text3: 25.301, 25.308,25.306, 25.321, 25.322, 25.331, 25.433, 25.435, 25.423, 25.425, 25.999
- 1180: Completed May 2007; SR in RP-070288 / Text3: 25.319, 25.101, 25.104, 25.133, 25.141, 25.211, 25.212, 25.213, 25.214, 25.306, 25.321, 25.331, 25.423, 25.433
- 1181: Completed Mar 2007; SR in RP-070140
- 1182: SP#36 Jun 2007 completed / Text3: 32.642/3/5 – Align with RAN 25.466
- 1183: 05/08: Linked to Feature UID_20029 (RANimp)
- 1184: SR in RP-080536. RP#41 completed / Text3: 34.108, 34.122, 34.123-1, 34.123-2, 34.123-3
- 1185: SR in RP-080059. RP#39 completed. / Text3: 34.108, 34.121-1, 34.121-2, 34.123-1, 34.123-2, 34.123-3
- 1186: SR in RP-080281. RP#40 completed / Text3: 34.108, 34.121-1, 34.121-2, 34.123-1, 34.123-2, 34.123-3
- 1187: SR in RP-080256. RP#40 completed / Text3: 34.108, 34.123-1, 34.123-2, 34.123-3
- 1188: SR in RP-080282. RP#40 completed / Text3: 34.108, 34.121-1, 34.121-2, 34.123-1, 34.123-2, 34.123-3
- 1189: RP#45 completed / Text3: 34.108, 34.123-1, 34.123-2, 34.123-3

| ID | WBS | Task | Type | Duration | Start | Finish | Complete | Baseline start | Baseline finish | Baseline duration | Constraint | Resources | Work | Actual work | Text1 | Text4 | Text5 | Text6 | Text11 | Text8 | Text12 |
| --- | --- | --- | --- | --- | --- | --- | --- | --- | --- | --- | --- | --- | --- | --- | --- | --- | --- | --- | --- | --- | --- |
| 1190 | 373 | **7.68 Mcps TDD option** |  | 457d? | 2004-09-15 A | 2006-06-15 A | 100% | 2004-09-15 | 2006-06-15 | 457d? |  | RP | 19824h | 19824h | VHCRTDD | IPwireless | Martin Beale (mbeale@ipwireless.com) | Rel-7 | RP-060684 |  |  |
| 1191 | 373.1 | VHCRTDD: Stage 2 |  | 391d? | 2004-09-15 A | 2006-03-15 A | 100% | 2004-09-15 | 2006-03-15 | 391d? | finish no earlier than 2006-03-15 | R1 | 3128h | 3128h | VHCRTDD-Stage2 | IPwireless | Martin Beale (mbeale@ipwireless.com) | Rel-7 |  | Patrick |  |
| 1192 | 373.2 | VHCRTDD: Physical Layer |  | 391d? | 2004-09-15 A | 2006-03-15 A | 100% | 2004-09-15 | 2006-03-15 | 391d? | finish no earlier than 2006-03-15 | R1 | 3128h | 3128h | VHCRTDD-Phys | IPwireless | Martin Beale (mbeale@ipwireless.com) | Rel-7 |  | Patrick |  |
| 1193 | 373.3 | VHCRTDD: Layer 2 and layer 3 protocol aspects |  | 391d? | 2004-09-15 A | 2006-03-15 A | 100% | 2004-09-15 | 2006-03-15 | 391d? | finish no earlier than 2006-03-15 | R2 | 3128h | 3128h | VHCRTDD-L23 | IPwireless | drichards@ipwireless.com | Rel-7 |  | Joern |  |
| 1194 | 373.4 | VHCRTDD: UTRAN Iub/Iur Protocol Aspects |  | 391d? | 2004-09-15 A | 2006-03-15 A | 100% | 2004-09-15 | 2006-03-15 | 391d? | finish no earlier than 2006-03-15 | R3 | 3128h | 3128h | VHCRTDD-IurIub | IPwireless | Peter Legg (plegg@ipwireless.com) | Rel-7 |  | Juha |  |
| 1195 | 373.5 | VHCRTDD: RF Radio Transmission/ Reception, System Performance Requirements and Conformance Testing |  | 457d? | 2004-09-15 A | 2006-06-15 A | 100% | 2004-09-15 | 2006-06-15 | 457d? | finish no earlier than 2006-06-15 | R4 | 3656h | 3656h | VHCRTDD-RF | IPwireless | Shin Horng Wong (shwong@ipwireless.com) | Rel-7 |  | Issam |  |
| 1196 | 374 | **3.84 Mcps TDD Enhanced Uplink** |  | 394d? | 2005-03-15 A | 2006-09-15 A | 100% | 2005-03-15 | 2006-09-15 | 394d? |  | RP | 18384h | 18384h | EDCHTDD | IPwireless | nanderson@ipwireless.com | Rel-7 | RP-060684 |  |  |
| 1197 | 374.1 | EDCHTDD: Stage 2 |  | 328d? | 2005-03-15 A | 2006-06-15 A | 100% | 2005-03-15 | 2006-06-15 | 328d? | finish no earlier than 2006-06-15 | R2 | 2624h | 2624h | EDCHTDD-Stage2 | IPwireless | nanderson@ipwireless.com | Rel-7 |  | Joern |  |
| 1198 | 374.2 | EDCHTDD: Physical Layer |  | 394d? | 2005-03-15 A | 2006-09-15 A | 100% | 2005-03-15 | 2006-09-15 | 394d? | finish no earlier than 2006-09-15 | R1 | 3152h | 3152h | EDCHTDD-Phys | IPwireless | nanderson@ipwireless.com | Rel-7 |  | Patrick |  |
| 1199 | 374.3 | EDCHTDD: Layer 2 and 3 Protocol Aspects |  | 394d? | 2005-03-15 A | 2006-09-15 A | 100% | 2005-03-15 | 2006-09-15 | 394d? | finish no earlier than 2006-09-15 | R2 | 3152h | 3152h | EDCHTDD-L23 | IPwireless | drichards@ipwireless.com | Rel-7 |  | Joern |  |
| 1200 | 374.4 | EDCHTDD: UTRAN Iub/Iur Protocol Aspects |  | 394d? | 2005-03-15 A | 2006-09-15 A | 100% | 2005-03-15 | 2006-09-15 | 394d? | finish no earlier than 2006-09-15 | R3 | 3152h | 3152h | EDCHTDD-IurIub | Interdigital | jim.miller@interdigital.com | Rel-7 |  | Juha |  |
| 1201 | 374.5 | EDCHTDD: RF Radio Transmission/ Reception, System Performance Requirements and Conformance Testing |  | 394d? | 2005-03-15 A | 2006-09-15 A | 100% | 2005-03-15 | 2006-09-15 | 394d? | finish no earlier than 2006-09-15 | R4 | 3152h | 3152h | EDCHTDD-RF | IPwireless | Shin Horng Wong (shwong@ipwireless.com) | Rel-7 |  | Issam |  |
| 1202 | 375 | **1.28 Mcps TDD Enhanced Uplink** |  | 328d? | 2006-03-15 A | 2007-06-15 A | 100% | 2006-03-15 | 2007-06-15 | 328d? |  | RP | 11536h | 11536h | LCRTDD-EDCH | CATT | Haijing Hu | Rel-7 | RP-070296 |  |  |
| 1203 | 375.1 | 1.28 Mcps TDD Enhanced Uplink: Physical Layer |  | 262d? | 2006-03-15 A | 2007-03-15 A | 100% | 2006-03-15 | 2007-03-15 | 262d? | finish no earlier than 2007-03-15 | R1 | 2096h | 2096h | LCRTDD-EDCH-Phys | CATT | Ke Wang | Rel-7 |  | Patrick |  |
| 1204 | 375.2 | 1.28 Mcps TDD Enhanced Uplink: Layer 2 and 3 Protocol Aspects |  | 262d? | 2006-03-15 A | 2007-03-15 A | 100% | 2006-03-15 | 2007-03-15 | 262d? | finish no earlier than 2007-03-15 | R2 | 2096h | 2096h | LCRTDD-EDCH-L23 | CATT | Haiyang Quan | Rel-7 |  | Joern |  |
| 1205 | 375.3 | 1.28 Mcps TDD Enhanced Uplink: UTRAN Iub/Iur Protocol Aspects |  | 262d? | 2006-03-15 A | 2007-03-15 A | 100% | 2006-03-15 | 2007-03-15 | 262d? | finish no earlier than 2007-03-15 | R3 | 2096h | 2096h | LCRTDD-EDCH-IubIur | CATT | Yincheng Zhang | Rel-7 |  | Juha |  |
| 1206 | 375.4 | 1.28 Mcps TDD Enhanced Uplink: RF Radio Transmission/ Reception, System Performance Requirements and Conformance Testing |  | 328d? | 2006-03-15 A | 2007-06-15 A | 100% | 2006-03-15 | 2007-06-15 | 328d? | finish no earlier than 2007-06-15 | R4 | 2624h | 2624h | LCRTDD-EDCH-RF | CATT | Yuexia Song | Rel-7 |  | Issam |  |
| 1207 | 376 | 1.28 Mcps TDD Enhanced Uplink - UE Conformance Testing |  | 257d? | 2007-09-20 A | 2008-09-12 A | 100% | 2007-09-20 | 2008-09-12 | 257d? | finish no earlier than 2008-09-11 | R5 | 624h | 624h | LCRTDD-EDCH-UEConTest | CATT | chenxiaozhong@datangmobile.cn | Rel-7 | RP-080539 | Ingbert |  |
| 1208 | 377 | MS Antenna Performance Evaluation Method and Requirements |  | 731d? | 2005-01-28 A | 2007-11-16 A | 100% | 2005-01-28 | 2007-11-16 | 731d? | finish no earlier than 2007-11-16 | GP | 5848h | 5848h | APEMR | TeliaSonera | Ulf.Tegth@teliasonera.com | Rel-7 |  | Paolo |  |
| 1209 | 378 | **Lower 700 MHz Inclusion in the GERAN Specifications** |  | 390d? | 2005-01-03 A | 2006-06-30 A | 100% | 2005-01-03 | 2006-06-30 | 390d? |  | GP | 7632h | 7632h | GSM710 | UTC | dcotton@mtview.union-tel.com | Rel-7 |  | Paolo |  |
| 1210 | 378.1 | Inclusion of the 698 – 746 MHz band into GERAN core specifications |  | 129d? | 2005-01-03 A | 2005-06-30 A | 100% | 2005-01-03 | 2005-06-30 | 129d? | finish no earlier than 2005-06-30 | G1 | 1032h | 1032h | GSM710-core |  |  | Rel-7 |  | Paolo |  |
| 1211 | 378.2 | G1 aspects of GSM710 |  | 217.5d? | 2005-08-31 A | 2006-06-30 A | 100% | 2005-08-31 | 2006-06-30 | 217.5d? | finish no earlier than 2006-06-30 | G1 | 1740h | 1740h | GSM-710-test |  |  | Rel-7 |  | Paolo |  |
| 1212 | 378.3 | G3 aspects of GSM710 |  | 217.5d? | 2005-08-31 A | 2006-06-30 A | 100% | 2005-08-31 | 2006-06-30 | 217.5d? | finish no earlier than 2006-06-30 | G3new | 1740h | 1740h | GSM-710-test |  |  | Rel-7 |  | Ingbert |  |
| 1213 | 379 | **Support of Conversational Services in A/Gb mode via the PS domain** |  | 626d? | 2005-04-08 A | 2007-08-31 A | 100% | 2005-04-08 | 2007-08-31 | 626d? |  | GP | 15442.8h | 15442.8h | SCSAGB | Ericsson | gunnar.hedby@ericsson.com | Rel-7 |  | Paolo |  |
| 1214 | 379.1 | Minimise the transfer delay between the SGSN and the MS |  | 604.95d? | 2005-04-08 A | 2007-08-31 A | 100% | 2005-04-08 | 2007-08-31 | 604.95d? | finish no earlier than 2007-08-31 | GP | 4839.6h | 4839.6h | SCSAGB-MTD | Ericsson | gunnar.hedby@ericsson.com | Rel-7 |  | Paolo |  |
| 1215 | 379.2 | Definition of radio resource management functionality |  | 626d? | 2005-04-08 A | 2007-08-31 A | 100% | 2005-04-08 | 2007-08-31 | 626d? | finish no earlier than 2007-08-31 | G1 | 5008h | 5008h | SCSAGB-RRM | Ericsson | gunnar.hedby@ericsson.com | Rel-7 |  | Paolo |  |
| 1216 | 379.3 | Support of Conversational Services in A/Gb mode via the PS domain – RLC Non-Persistent mode |  | 101d? | 2006-06-30 A | 2006-11-17 A | 100% | 2006-06-30 | 2006-11-17 | 101d? | finish no earlier than 2006-11-17 | G2 | 808h | 808h | SCSAGB-RLCNP | Ericsson | gunnar.hedby@ericsson.com | Rel-7 |  | Gert |  |
| 1217 | 379.4 | Deleted- Radio Channel Support | milestone | 0d? | 2006-07-17 A | 2006-07-17 A | 100% | 2006-07-17 | 2006-07-17 | 0d? | start no earlier than 2006-07-17 | G2 |  |  | SCSAGB-RCHS | Ericsson | gunnar.hedby@ericsson.com | Rel-7 |  | Gert | SP-32 |
| 1218 | 379.5 | Deleted- Modifications to FLO | milestone | 0d? | 2006-07-17 A | 2006-07-17 A | 100% | 2006-07-17 | 2006-07-17 | 0d? | start no earlier than 2006-07-17 | G2 |  |  | SCSAGB-FLO | Ericsson | gunnar.hedby@ericsson.com | Rel-7 |  | Gert | SP-32 |

Notes:
- 1190: Completed Dec 2006, SR in RP-060684
- 1191: Feature completed and closed at RP#33 with the presentation of the test WI / Text3: 25.202
- 1192: Feature completed and closed at RP#33 with the presentation of the test WI / Text3: 25.221, 25.222, 25.223, 25.224,25.225
- 1193: Feature completed and closed at RP#33 with the presentation of the test WI / Text3: 25.301, 25.302, 25.305, 25.306, 25.321, 25.331
- 1194: Feature completed and closed at RP#33 with the presentation of the test WI / Text3: 25.401, 25.420, 25.423, 25.425, 25.427, 25.430, 25.433, 25.435
- 1195: Feature completed and closed at RP#33 with the presentation of the test WI / Text3: 25.102, 25.105, 25.123, 25.133, 25.142
- 1196: Completed Dec 2006, SR in RP-060684
- 1197: -
- 1198: - / Text3: 25.201, 25.221,25.222, 25.223, 25.224, 25.225
- 1199: - / Text3: 25.301, 25.302, 25.306, 25.321, 25.331
- 1200: - / Text3: 25.401, 25.420, 25.423, 25.427, 25.430, 25.433, 25.435
- 1201: - / Text3: 25.102, 25.105, 25.123, 25.142
- 1202: Completed May 2007; SR in RP-070038 and RP-070296
- 1203: - / Text3: 25.201, 25.221, 25.222, 25.223, 25.224, 25.225
- 1204: - / Text3: 25.301, 25.302, 25.306, 25.321, 25.331
- 1205: - / Text3: 25.401, 25.420, 25.423, 25.425, 25.427, 25.430, 25.433, 25.435
- 1206: - / Text3: 25.102, 25.105, 25.123, 25.142
- 1207: UID_350046->350146. 05/08: Linked to Feature UID_20055 (LCRTDD-EDCH). SR in RP-080539. RP#41 completed / Text3: 34.108, 34.122, 34.123-1/2/3
- 1208: GP#36 completed for R7 / Text3: 25.914, 25.144, 45.005
- 1209: - / Text3: 24.008, 43.022, 44.018, 44.118, 45, 001, 45.005, 51.010, 51.021
- 1210: Completed / Text3: 24.008, 43.022, 44.018, 44.118, 45, 001, 45.005,
- 1211: - / Text3: 51.021
- 1212: - / Text3: 51.010
- 1213: Originally started Nov. 2003 as GP-030443
- 1214: -
- 1215: -
- 1216: - / Text3: 43.955, 43.064, 44.060, 45.001, 45.002, 45.003, 45.005, 45.010, 51.010, 51.021
- 1217: -
- 1218: -

| ID | WBS | Task | Duration | Start | Finish | Complete | Baseline start | Baseline finish | Baseline duration | Constraint | Resources | Work | Actual work | Text1 | Text4 | Text5 | Text6 | Text8 | Text12 |
| --- | --- | --- | --- | --- | --- | --- | --- | --- | --- | --- | --- | --- | --- | --- | --- | --- | --- | --- | --- |
| 1219 | 380 | **Addition of new frequency band to GSM (T-GSM810)** | 626d? | 2005-04-08 A | 2007-08-31 A | 100% | 2005-04-08 | 2007-08-31 | 626d? |  | GP | 12112h | 12112h | TGSM810 | Huawei | chende@huawei.com | Rel-7 | Paolo |  |
| 1220 | 380.1 | Changes to core specification | 106d? | 2005-04-08 A | 2005-09-02 A | 100% | 2005-04-08 | 2005-09-02 | 106d? | finish no earlier than 2005-09-02 | GP | 848h | 848h | TGSM810-Core | Huawei | chende@huawei.com | Rel-7 | Paolo |  |
| 1221 | 380.2 | Changes to MS testing specification | 626d? | 2005-04-08 A | 2007-08-31 A | 100% | 2005-04-08 | 2007-08-31 | 626d? | finish no earlier than 2007-08-31 | G3new | 5008h | 5008h | TGSM810-MStest | Huawei | chende@huawei.com | Rel-7 | Ingbert |  |
| 1222 | 380.3 | Changes to BTS testing specification | 156d? | 2005-04-08 A | 2005-11-11 A | 100% | 2005-04-08 | 2005-11-11 | 156d? | finish no earlier than 2005-11-11 | G1 | 1248h | 1248h | TGSM810-BTStest | Huawei | chende@huawei.com | Rel-7 | Paolo |  |
| 1223 | 381 | **Handover of dedicated and shared resources while in Dual Transfer Mode** | 421d? | 2005-04-08 A | 2006-11-17 A | 100% | 2005-04-08 | 2006-11-17 | 421d? |  | GP | 12672h | 12672h | HODSRDTM | Nokia | rami.vaittinen@nokia.com | Rel-7 | Paolo |  |
| 1224 | 381.1 | Handover of dedicated and shared resources while in Dual Transfer Mode | 321d? | 2005-04-08 A | 2006-06-30 A | 100% | 2005-04-08 | 2006-06-30 | 321d? | finish no earlier than 2006-06-30 | G2 | 2568h | 2568h | HODSRDTM-G2 | Nokia | rami.vaittinen@nokia.com | Rel-7 | Gert |  |
| 1225 | 381.2 | Deleted - MS Conformance Testing | 421d? | 2005-04-08 A | 2006-11-17 A | 100% | 2005-04-08 | 2006-11-17 | 421d? | finish no earlier than 2006-11-17 | G3new | 3368h | 3368h | HODSRDTM-Mstest | Nokia | rami.vaittinen@nokia.com | Rel-7 | Ingbert | GP-32 |
| 1226 | 381.3 | Deleted - BTS conformance testing | 421d? | 2005-04-08 A | 2006-11-17 A | 100% | 2005-04-08 | 2006-11-17 | 421d? | finish no earlier than 2006-11-17 | G1 | 3368h | 3368h | HODSRDTM-BTStest | Nokia | rami.vaittinen@nokia.com | Rel-7 | Paolo | GP-32 |
| 1227 | 382 | **Mobile Station Receive Diversity (DARP Phase II)** | 526d? | 2005-11-11 A | 2007-11-16 A | 100% | 2005-11-11 | 2007-11-16 | 526d? |  | GP | 16360h | 16360h | MSRD2 | Nokia | kent.pedersen@nokia.com | Rel-7 | Paolo |  |
| 1228 | 382.1 | Performance Requirements for Mobile Station Receive Diversity, DARP Phase II | 331d? | 2005-11-11 A | 2007-02-16 A | 100% | 2005-11-11 | 2007-02-16 | 331d? | finish no earlier than 2007-02-16 | GP | 2648h | 2648h | MSRD2-PerfReq | Nokia | kent.pedersen@nokia.com | Rel-7 | Paolo |  |
| 1229 | 382.2 | Capability signalling of Mobile Station Receive Diversity, DARP Phase II | 331d? | 2005-11-11 A | 2007-02-16 A | 100% | 2005-11-11 | 2007-02-16 | 331d? | finish no earlier than 2007-02-16 | GP | 2648h | 2648h | MSRD2-CapSig | Nokia | kent.pedersen@nokia.com | Rel-7 | Paolo |  |
| 1230 | 382.3 | Test Scenarios for Mobile Station Receive Diversity, DARP Phase II | 331d? | 2005-11-11 A | 2007-02-16 A | 100% | 2005-11-11 | 2007-02-16 | 331d? | finish no earlier than 2007-02-16 | GP | 2648h | 2648h | MSRD2-TestSc | Nokia | kent.pedersen@nokia.com | Rel-7 | Paolo |  |
| 1231 | 382.4 | MS conformance test of DARP Phase II (MSRD) | 526d? | 2005-11-11 A | 2007-11-16 A | 100% | 2005-11-11 | 2007-11-16 | 526d? | finish no earlier than 2007-11-16 | GP | 4208h | 4208h | MSRD2-Msconf | Nokia | kent.pedersen@nokia.com | Rel-7 | Ingbert |  |
| 1232 | 383 | **Downlink Dual Carrier** | 421d? | 2006-01-20 A | 2007-08-31 A | 100% | 2006-01-20 | 2007-08-31 | 421d? |  | GP | 7664h | 7664h | GDCDL | Nokia Siemens Networks | leonardo.provvedi@roke.co.uk | Rel-7 | Paolo |  |
| 1233 | 383.1 | Downlink Dual Carrier Stage 2 | 116d? | 2006-01-20 A | 2006-06-30 A | 100% | 2006-01-20 | 2006-06-30 | 116d? | finish no earlier than 2006-06-30 | G1 | 928h | 928h | GDCDL-Stage2 | Nokia Siemens Networks | leonardo.provvedi@roke.co.uk | Rel-7 | Paolo |  |
| 1234 | 383.2 | Downlink Dual Carrier Stage 3 | 421d? | 2006-01-20 A | 2007-08-31 A | 100% | 2006-01-20 | 2007-08-31 | 421d? | finish no earlier than 2007-08-31 | G1 | 3368h | 3368h | GDCDL-Stage2 | Nokia Siemens Networks | leonardo.provvedi@roke.co.uk | Rel-7 | Paolo |  |
| 1235 | 384 | **Downlink Dual Carrier – MS Conformance Test** | 947d? | 2006-01-20 A | 2009-09-04 A | 100% | 2006-01-20 | 2009-09-04 | 947d? |  | G3new | 11150.6h | 11150.6h | GDCDL-Stage3 | Nokia Siemens Networks | leonardo.provvedi@roke.co.uk | Rel-7 | Ingbert |  |
| 1236 | 384.1 | Downlink Dual Carrier – MS Conformance Test | 446.82d? | 2006-01-20 A | 2009-09-04 A | 100% | 2006-01-20 | 2009-09-04 | 446.82d? | finish no earlier than 2009-09-04 | G3new | 3574.6h | 3574.6h | GDCDL-Stage3 | Nokia Siemens Networks | leonardo.provvedi@roke.co.uk | Rel-7 | Ingbert |  |
| 1237 | 385 | Support of SIGTRAN in GERAN | 116d? | 2006-01-20 A | 2006-06-30 A | 100% | 2006-01-20 | 2006-06-30 | 116d? | finish no earlier than 2006-06-30 | G3new | 928h | 928h | GDCDL-MStest | Ericsson | peter.ostrup@ericsson.com | Rel-7 | Ingbert |  |
| 1238 | 386 | **Latency Reductions** | 306d? | 2006-06-30 A | 2007-08-31 A | 100% | 2006-06-30 | 2007-08-31 | 306d? |  | GP | 7344h | 7344h | LATRED | Ericsson | Hakan.Persson@Ericsson.com | Rel-7 | Paolo |  |
| 1239 | 386.1 | Improved Ack/Nack reporting | 306d? | 2006-06-30 A | 2007-08-31 A | 100% | 2006-06-30 | 2007-08-31 | 306d? | finish no earlier than 2007-08-31 | G2 | 2448h | 2448h | LATRED-ACKNAR | Ericsson | Hakan.Persson@Ericsson.com | Rel-7 | Gert |  |
| 1240 | 386.2 | Reduced TTI | 306d? | 2006-06-30 A | 2007-08-31 A | 100% | 2006-06-30 | 2007-08-31 | 306d? | finish no earlier than 2007-08-31 | G2 | 2448h | 2448h | LATRED-REDTTI | Ericsson | Hakan.Persson@Ericsson.com | Rel-7 | Gert |  |
| 1241 | 387 | PS Handover between GERAN/UTRAN mode and GAN Mode | 166d? | 2006-06-30 A | 2007-02-16 A | 100% | 2006-06-30 | 2007-02-16 | 166d? | finish no earlier than 2007-02-16 | G2 | 1328h | 1328h | GUGAN | Ericsson | John.Diachina@Ericsson.com | Rel-7 | Gert |  |
| 1242 | 388 | **Higher Uplink performance for GERAN Evolution** | 516d? | 2006-09-08 A | 2008-08-29 A | 100% | 2006-09-08 | 2008-08-29 | 516d? |  | GP | 15440h | 15440h | HUGE | Nokia Siemens Networks, Ericsson | eddie.riddington@nokia.com, stefan.g.eriksson@ericsson.com | Rel-7 | Paolo |  |
| 1243 | 388.1 | Stage 2 of HUGE | 261d? | 2006-09-08 A | 2007-09-07 A | 100% | 2006-09-08 | 2007-09-07 | 261d? | finish no earlier than 2007-09-07 | G1 | 2088h | 2088h | HUGE-Stage2 | Nokia Siemens Networks, Ericsson | eddie.riddington@nokia.com, stefan.g.eriksson@ericsson.com | Rel-7 | Paolo |  |
| 1244 | 388.2 | Layer 1 Support of HUGE | 381d? | 2006-09-08 A | 2008-02-22 A | 100% | 2006-09-08 | 2008-02-22 | 381d? | finish no earlier than 2008-02-22 | G1 | 3048h | 3048h | HUGE-Layer1 | Nokia Siemens Networks, Ericsson | eddie.riddington@nokia.com, stefan.g.eriksson@ericsson.com | Rel-7 | Paolo |  |
| 1245 | 388.3 | Layer 2/3 Support of HUGE | 256d? | 2006-09-08 A | 2007-08-31 A | 100% | 2006-09-08 | 2007-08-31 | 256d? | finish no earlier than 2007-08-31 | G2 | 2048h | 2048h | HUGE-Layer23 | Nokia Siemens Networks, Ericsson | eddie.riddington@nokia.com, stefan.g.eriksson@ericsson.com | Rel-7 | Gert |  |
| 1246 | 388.4 | Performance requirements | 516d? | 2006-09-08 A | 2008-08-29 A | 100% | 2006-09-08 | 2008-08-29 | 516d? | finish no earlier than 2008-08-29 | G1 | 4128h | 4128h | HUGE-Perfreq | Nokia Siemens Networks, Ericsson | eddie.riddington@nokia.com, stefan.g.eriksson@ericsson.com | Rel-7 | Paolo |  |

Notes:
- 1219: - / Text3: 45.005, 45.050, 24.008, 45.008, 45.001, 43.022, 43.030, 44.018, 44.060, 51.010-1, 51.021
- 1220: - / Text3: 45.005, 45.050, 24.008, 45.008, 45.001, 43.022, 43.030, 44.018, 44.060
- 1221: - / Text3: 51010-1
- 1222: - / Text3: 51021
- 1223: GP#30 completed. Started at GP#24
- 1224: GP#30 completed / Text3: 43.055, 44.018, 44.060
- 1225: Stopped, no work done. 12/2008 Marked as stopped ("deleted") / Text3: 51-010
- 1226: Stopped, no work done. 12/2008 Marked as stopped ("deleted") / Text3: 51.026
- 1227: GP#36 completed / Text3: 24.008, 45.005, 51.010
- 1228: GP#33 completed / Text3: 45.005
- 1229: GP#33 completed / Text3: 24.008
- 1230: GP#33 completed / Text3: 45.005
- 1231: GP#36 completed / Text3: 51.010
- 1232: GP#35 completed
- 1233: GP#30 completed / Text3: 43.055, 43.064
- 1234: GP#35 completed / Text3: 24.008, 44.018, 44.060, 45.001, 45.002, 45.005, 45.008
- 1235: GP#43 completed / Text3: 51.010
- 1236: GP#43 completed / Text3: 51.010
- 1237: GP#30 completed / Text3: 48.001, 48.006, 43.059, 49.031
- 1238: GP#35 completed / Text3: 45.001, 45.002, 45.003, 45.005, 45.010, 43.055, 43.064, 44.060, 51.010-1, 51.021
- 1239: GP#35 completed / Text3: 45.001, 45.002, 45.003, 45.005, 45.010, 43.055, 43.064, 44.060, 51.010-1, 51.021
- 1240: GP#35 completed / Text3: 45.001, 45.002, 45.003, 45.005, 45.010, 43.055, 43.064, 44.060, 51.010-1, 51.021
- 1241: GP#33 completed / Text3: 43.318, 44.318, 43.129, 25.306, 24.008, 44.060, 25.331, 51.010
- 1242: GP#39 completed. SP#42 split core from testing specification work.
- 1243: GP#35 completed / Text3: 43.055, 43.064
- 1244: GP#37 completed / Text3: 45.001, 45.002, 45.003, 45.004, 45.008
- 1245: GP#35 completed / Text3: 24.008, 44.018, 44.060
- 1246: GP#39 completed / Text3: 45.005

| ID | WBS | Task | Type | Duration | Start | Finish | Complete | Remaining | Baseline start | Baseline finish | Baseline duration | Total slack | Constraint | Resources | Work | Actual work | Text1 | Text4 | Text5 | Text6 | Text8 | Text12 |
| --- | --- | --- | --- | --- | --- | --- | --- | --- | --- | --- | --- | --- | --- | --- | --- | --- | --- | --- | --- | --- | --- | --- |
| 1247 | 389 | **HUGE Conformance Testing** |  | 1047d? | 2006-09-08 A | 2010-09-10 | 66% | 359.46d? | 2006-09-08 | 2010-09-10 | 1047d? | 265d |  | G1,G3new | 22992h | 9955.6h | HUGE | Nokia Siemens Networks, Ericsson | eddie.riddington@nokia.com, stefan.g.eriksson@ericsson.com | Rel-7 | Paolo |  |
| 1248 | 389.1 | HUGE - MS Conformance Test |  | 1046d? | 2006-09-08 A | 2010-09-10 | 40% | 627.6d? | 2006-09-08 | 2010-09-10 | 1046d? | 265d | finish no earlier than 2010-09-10 | G3new | 8368h | 3347.2h | HUGE-Mstest | Nokia Siemens Networks, Ericsson | eddie.riddington@nokia.com, stefan.g.eriksson@ericsson.com | Rel-7 | Ingbert |  |
| 1249 | 389.2 | HUGE - BTS Conformance Test |  | 782d? | 2006-09-08 A | 2009-09-04 A | 100% |  | 2006-09-08 | 2009-09-04 | 782d? |  | finish no earlier than 2009-09-04 | G1 | 6248h | 6248h | HUGE-BTStest | Nokia Siemens Networks, Ericsson | eddie.riddington@nokia.com, stefan.g.eriksson@ericsson.com | Rel-7 | Paolo |  |
| 1250 | 390 | **REduced symbol Duration, Higher Order modulation and Turbo coding (RED HOT) for downlink** |  | 391d? | 2006-11-17 A | 2008-05-16 A | 100% |  | 2006-11-17 | 2008-05-16 | 391d? |  |  | GP | 7904h | 7904h | REDHOT | Ericsson, Nokia Siemens Networks, Marvell | stefan.g.eriksson@ericsson.com | Rel-7 | Paolo |  |
| 1251 | 390.1 | Stage 2 for REDHOT |  | 206d? | 2006-11-17 A | 2007-08-31 A | 100% |  | 2006-11-17 | 2007-08-31 | 206d? |  | finish no earlier than 2007-08-31 | G1 | 1648h | 1648h | REDHOT-Stage2 | Ericsson, Nokia Siemens Networks, Marvell | stefan.g.eriksson@ericsson.com | Rel-7 | Paolo |  |
| 1252 | 390.2 | Stage 3 for REDHOT |  | 391d? | 2006-11-17 A | 2008-05-16 A | 100% |  | 2006-11-17 | 2008-05-16 | 391d? |  | finish no earlier than 2008-05-16 | G1 | 3128h | 3128h | REDHOT-Stage3 | Ericsson, Nokia Siemens Networks, Marvell | stefan.g.eriksson@ericsson.com | Rel-7 | Paolo |  |
| 1253 | 391 | **REDHOT Conformance Testing** |  | 997d? | 2006-11-17 A | 2010-09-10 | 64% | 361.75d? | 2006-11-17 | 2010-09-10 | 997d? | 265d |  | G1,G3new | 21152h | 8735.6h | REDHOT | Ericsson, Nokia Siemens Networks, Marvell | stefan.g.eriksson@ericsson.com | Rel-7 | Paolo |  |
| 1254 | 391.1 | REDHOT - MS Conformance Tests |  | 996d? | 2006-11-17 A | 2010-09-10 | 40% | 597.6d? | 2006-11-17 | 2010-09-10 | 996d? | 265d | finish no earlier than 2010-09-10 | G3new | 7968h | 3187.2h | REDHOT-Mstest | Ericsson | stefan.g.eriksson@ericsson.com | Rel-7 | Ingbert |  |
| 1255 | 391.2 | BTS Conformance Tests |  | 651d? | 2006-11-17 A | 2009-05-15 A | 100% |  | 2006-11-17 | 2009-05-15 | 651d? |  | finish no earlier than 2009-05-15 | G1 | 5208h | 5208h | REDHOT-BTStest | Ericsson, Nokia Siemens Networks, Marvell | stefan.g.eriksson@ericsson.com | Rel-7 | Paolo |  |
| 1256 | 392 | (Small) Technical Enhancements and Improvements for Rel-7 | milestone | 0d? | 2007-03-26 A | 2007-03-26 A | 100% |  | 2007-03-26 | 2007-03-26 | 0d? |  | start no earlier than 2007-03-26 | All |  |  | TEI7 |  |  | Rel-7 |  |  |
| 1257 | 393 | **Deleted - PS domain and IMS support for IMS Emergency sessions** |  | 63.69d? | 2006-06-23 A | 2006-09-21 A | 100% |  | 2006-06-23 | 2006-09-21 | 63.69d? |  |  | S2 |  |  | IMS-EMER | Nokia | curt.c.wong@nokia.com | Rel-7 | Maurice | SP-30 |
| 1258 | 393.1 | Deleted - IMS aspects to support IMS Emergency sessions | milestone | 0d? | 2006-06-23 A | 2006-09-21 A | 100% |  | 2006-06-23 | 2006-09-21 | 0d? |  | start no earlier than 2006-06-23 | S2 |  |  | IMS-EMER | Nokia | curt.c.wong@nokia.com | Rel-7 | Maurice | SP-30 |
| 1259 | 393.2 | Deleted - PS domain aspects to support IMS Emergency sessions | milestone | 0d? | 2006-06-23 A | 2006-09-21 A | 100% |  | 2006-06-23 | 2006-09-21 | 0d? |  | start no earlier than 2006-06-23 | S2 |  |  | IMS-EMER | Nokia | curt.c.wong@nokia.com | Rel-7 | Maurice | SP-30 |
| 1260 | 394 | Deleted - Covered by SI - Personal Network (PN) and Personal Area Network (PAN) | milestone | 0d? | 2005-12-08 A | 2005-12-20 A | 100% |  | 2005-12-08 | 2005-12-20 | 0d? |  | start no earlier than 2005-12-08 | S1 |  |  | PNPAN | Vodafone | armin.toepfer@vodafone.com | Rel-7 | Alain | SP-30 |
| 1261 | 395 | Deleted - Covered by SI - Multimedia Telephony Capabilities for IMS | milestone | 0d? | 2005-12-08 A | 2005-12-20 A | 100% |  | 2005-12-08 | 2005-12-20 | 0d? |  | start no earlier than 2005-12-08 | S1 |  |  | MITE | Ericsson | peter.bleckert@ericsson.com | Rel-7 | Alain | SP-30 |
| 1262 | 396 | Deleted - Covered by SI - Transferring of emergency Call data | milestone | 0d? | 2005-12-08 A | 2005-12-08 A | 100% |  | 2005-12-08 | 2005-12-08 | 0d? |  | start no earlier than 2005-12-08 | S1 |  |  | eCALL | Motorola | steven.vardy@motorola.com | Rel-7 | Alain | SP-30 |
| 1263 | 397 | Deleted - Covered by SI - MBMS Enhancements | milestone | 0d? | 2005-12-08 A | 2005-12-08 A | 100% |  | 2005-12-08 | 2005-12-08 | 0d? |  | start no earlier than 2005-12-08 | S1 |  |  | MBMSE | China Mobile | liuhongyfw@chinamobile.com | Rel-7 | Alain | SP-30 |
| 1264 | 398 | **Deleted - VoIMS bearer related enhancements** |  | 0d? | 2006-07-21 A | 2006-07-21 A | 100% |  | 2006-07-21 | 2006-07-21 | 0d? |  |  | S2 |  |  | VoIMS |  |  | Rel-7 | Maurice | SP-32 |
| 1265 | 398.1 | Deleted - FS on enhancement of radio performance for VoIMS | milestone | 0d? | 2006-07-21 A | 2006-07-21 A | 100% |  | 2006-07-21 | 2006-07-21 | 0d? |  | start no earlier than 2006-07-21 | S2 |  |  | VoIMS | Nortel | Laurence Lautier (lautierl@nortel.com) | Rel-7 | Maurice | SP-32 |
| 1266 | 399 | Release 7 Studies |  | 1d? | 2000-01-03 | 2000-01-03 |  |  | 2000-01-03 | 2000-01-03 | 1d? | 3056d |  | CP,GP,RP,SP | 8h |  |  |  |  | Rel-7 |  |  |
| 1267 | 400 | **Study on Multimedia Telephony Capabilities for IMS** |  | 276d? | 2005-07-11 A | 2006-07-31 A | 100% |  | 2005-07-11 | 2006-07-31 | 276d? |  |  | S1 | 4353.6h | 4353.6h | MITE | Ericsson | peter.bleckert@ericsson.com | Rel-7 | Alain |  |
| 1268 | 400.1 | Deleted covered by UID_31082 - Study of (MITe) - IMS Multimedia Telephony Communication Enabler and supplementary services |  | 276d? | 2005-07-11 A | 2006-07-31 A | 100% |  | 2005-07-11 | 2006-07-31 | 276d? |  | start no earlier than 2005-07-11 | S1 | 2208h | 2208h | MITE | Ericsson | peter.bleckert@ericsson.com | Rel-7 | Alain | SP-28 |
| 1269 | 401 | Study on Behaviour of Multi system UEs |  | 384d? | 2004-06-28 A | 2005-12-15 A | 100% |  | 2004-06-28 | 2005-12-15 | 384d? |  | start no earlier than 2004-06-28 | S1 | 3072h | 3072h | BMSU | Qualcomm | dwilliams@qualcomm.com | Rel-7 | Alain |  |
| 1270 | 402 | Study on Combining CS calls and IMS sessions |  | 189d? | 2004-06-28 A | 2005-03-17 A | 100% |  | 2004-06-28 | 2005-03-17 | 189d? |  | start no earlier than 2004-06-28 | S1 | 1512h | 1512h | IRTSD-CS_IMS |  | Robert Frank | Rel-7 | Alain |  |
| 1271 | 403 | Study on All-IP Network |  | 188d? | 2004-06-28 A | 2005-03-16 A | 100% |  | 2004-06-28 | 2005-03-16 | 188d? |  | start no earlier than 2004-06-28 | S1 | 1504h | 1504h | FS_AIPN | NTT DoCoMo | c.masyu@nttdocomo.co.jp | Rel-7 | Alain |  |
| 1272 | 404 | Study on Videotelephony teleservice |  | 231d? | 2005-03-01 A | 2006-01-17 A | 100% |  | 2005-03-01 | 2006-01-17 | 231d? |  |  | S1 | 1848h | 1848h | VidTel | T-Mobile | kurt.bischinger@t-mobile.at | Rel-7 | Alain |  |
| 1273 | 405 | Study on Network Selection Principles |  | 193d? | 2005-03-15 A | 2005-12-08 A | 100% |  | 2005-03-15 | 2005-12-08 | 193d? |  |  | S1 | 1544h | 1544h | NetSel | O2 | chris.friel@o2.com | Rel-7 | Alain |  |
| 1274 | 406 | Study on Multimedia Priority Service |  | 851d? | 2003-03-28 A | 2006-06-30 A | 100% |  | 2003-03-28 | 2006-06-30 | 851d? |  | finish no earlier than 2005-12-16 | S1 | 6808h | 6808h | PRIOR-MM | Telcordia | jgarraha@telcordia.com | Rel-7 | Alain |  |
| 1275 | 407 | Study on Transferring of emergency Call data |  | 190d? | 2005-07-11 A | 2006-03-31 A | 100% |  | 2005-07-11 | 2006-03-31 | 190d? |  | finish no earlier than 2005-12-08 | S1 | 1520h | 1520h | eCALL | Motorola | steven.vardy@motorola.com | Rel-7 | Alain |  |
| 1276 | 408 | Study on Enhancement of E2E QoS |  | 281.4d? | 2004-06-28 A | 2005-09-15 A | 100% |  | 2004-06-28 | 2005-09-15 | 281.4d? |  | finish no earlier than 2005-12-01 | S2 | 2251.2h | 2251.2h | QoS7 | Huawei | Robert Jaksa | Rel-7 | Maurice |  |
| 1277 | 409 | Study on Bandwidth Saving at Nb Interface with IP transport |  | 261d? | 2006-03-10 A | 2007-03-09 A | 100% |  | 2006-03-10 | 2007-03-09 | 261d? |  | finish no earlier than 2007-03-09 | C3 | 2088h | 2088h | BSNbIP | Siemens | Thomas.Belling@nsn.com | Rel-7 | Gwiho |  |
| 1278 | 410 | Study on Routeing of MT-SMS via the HPLMN |  | 301d? | 2005-10-07 A | 2006-12-01 A | 100% |  | 2005-10-07 | 2006-12-01 | 301d? |  | finish no earlier than 2006-12-01 | C4 | 2408h | 2408h | SMS7 | Vodafone | Nick.Russell@vodafone.com | Rel-7 | Kimmo |  |
| 1279 | 411 | Study on the TCAPsec Gateway concept |  | 96d? | 2005-10-28 A | 2006-03-10 A | 100% |  | 2005-10-28 | 2006-03-10 | 96d? |  | finish no earlier than 2006-03-10 | C4 | 768h | 768h | SEC7-TCAP | Siemens | Ulrich.wiehe@gksag.de | Rel-7 | Kimmo |  |
| 1280 | 412 | Study on using M2PA in 3GPP network |  | 318d? | 2006-03-22 A | 2007-06-08 A | 100% |  | 2006-03-22 | 2007-06-08 | 318d? |  | finish no earlier than 2007-06-08 | C4 | 2544h | 2544h | FS-M2PA | China Mobile | zhaoyuyi@chinamobile.com | Rel-7 | Kimmo |  |

Notes:
- 1247: SP#42 split core from testing specification work
- 1248: GP#45 completion 03/10=>09/10 (was 02/10=>03/10) / Text3: 51.010
- 1249: GP#43 completed / Text3: 51.021
- 1250: GP#38 completed. SP#42 split core from testing specification work.
- 1251: GP#35 completed / Text3: 43.055, 43.064
- 1252: GP#38 completed / Text3: 24.008, 44.018, 44.060, 45.001, 45.002, 45.003, 45.004, 45.005, 45.008
- 1253: SP#42 split core from testing specification work
- 1254: GP#45 completion 03/10=>09/10 (was 02/10=>03/10) / Text3: 51.010
- 1255: GP#42 completed / Text3: 51.021
- 1256: - / Text3: CP-070260
- 1257: Approved at SP#29 / Text3: 23.867, 23.abc, 23.060, 23.002, 23.271
- 1258: Approved at SP#29 / Text3: 23.867, 23.abc, 23.060, 23.002, 23.271
- 1259: Approved at SP#29 / Text3: 23.867, 23.abc, 23.060, 23.002, 23.271
- 1260: -
- 1261: -
- 1262: -
- 1263: -
- 1264: Created by MCC to group all VoIMS related items, after consultation of chairs
- 1265: WID approved SP#28: SA2#52: CLOSED - To be removed from the work plan / Text3: 23.807
- 1266: -
- 1267: Spin-off Feature UID_7038 (MTSI) / Text3: 22.973
- 1268: Duplicate entry with 31082 / Text3: 22.973
- 1269: - / Text3: 22.936
- 1270: - / Text3: 22.979
- 1271: 07/08 Moved to Rel-7 as Study out of stopped Rel-8 Feature UID_31067 All-IP Network (AIPN) / Text3: 22.978
- 1272: - / Text3: 22.903
- 1273: Spin-off Feature Network selection enhancements (NSP-CR) UID_7041 / Text3: 22.811
- 1274: Spin-off Feature PRIOR UID_340044 / Text3: 22.953
- 1275: - / Text3: 22.967
- 1276: - / Text3: 23.802
- 1277: Moved to FS at CT32 (in line with slides) / Text3: 29.814
- 1278: Previously known as "Study of a SMS Centre for MT SMS" / Text3: 23.840
- 1279: TR 29.800 content moved to TS 29.204 under implementation WI UID_310005 TCAPsec Gateway / Text3: 29.800
- 1280: - / Text3: 29.801

| ID | WBS | Task | Type | Duration | Start | Finish | Complete | Baseline start | Baseline finish | Baseline duration | Total slack | Constraint | Resources | Work | Actual work | Text1 | Text3 | Text4 | Text5 | Text6 | Text8 | Text11 | Text12 |
| --- | --- | --- | --- | --- | --- | --- | --- | --- | --- | --- | --- | --- | --- | --- | --- | --- | --- | --- | --- | --- | --- | --- | --- |
| 1281 | 413 | **Study on Support of (G)MSC-S - (G)MSC-S Nc Interface based on the SIP-I protocol** |  | 350d? | 2006-05-15 A | 2007-09-14 A | 100% | 2006-05-15 | 2007-09-14 | 350d? |  |  | C4 | 7800h | 7800h | NcSIP | 29.802 | Vodafone | david.hutton@vodafone.com | Rel-7 | Kimmo |  |  |
| 1282 | 413.1 | CT4 aspects of NcSIP |  | 275d? | 2006-05-15 A | 2007-06-01 A | 100% | 2006-05-15 | 2007-06-01 | 275d? |  | finish no earlier than 2007-06-01 | C4 | 2200h | 2200h | NcSIP | 29.802 | Vodafone | david.hutton@vodafone.com | Rel-7 | Kimmo |  |  |
| 1283 | 413.2 | CT3 aspects of NcSIP |  | 350d? | 2006-05-15 A | 2007-09-14 A | 100% | 2006-05-15 | 2007-09-14 | 350d? |  | finish no earlier than 2007-09-14 | C3 | 2800h | 2800h | NcSIP | 29.802 | Ericsson | ragnar.huslende@ericsson.com | Rel-7 | Gwiho |  |  |
| 1284 | 414 | Study on SOAP/HTTP IRP Solution Sets |  | 330d? | 2005-09-02 A | 2006-12-07 A | 100% | 2005-09-02 | 2006-12-07 | 330d? |  | finish no earlier than 2006-12-07 | S5 | 2640h | 2640h | OAM7-NIM-XML | 32.809 | Nortel |  | Rel-7 | Dionisio |  |  |
| 1285 | 415 | Study on Itf-N Implementation Conformance Statement (ICS) template |  | 400d? | 2005-09-02 A | 2007-03-15 A | 100% | 2005-09-02 | 2007-03-15 | 400d? |  | finish no earlier than 2007-03-15 | S5 | 3200h | 3200h | OAM7-NIM-ICS | 32.812 | China Mobile |  | Rel-7 | Dionisio |  |  |
| 1286 | 416 | Study on IRP Information Model |  | 400d? | 2005-09-02 A | 2007-03-15 A | 100% | 2005-09-02 | 2007-03-15 | 400d? |  | finish no earlier than 2007-03-15 | S5 | 3200h | 3200h | OAM7-NIM-IM | 32.810 | Motorola |  | Rel-7 | Dionisio |  |  |
| 1287 | 417 | Study on Evolved UTRA and UTRAN |  | 458d? | 2004-12-15 A | 2006-09-15 A | 100% | 2004-12-15 | 2006-09-15 | 458d? |  | finish no earlier than 2006-09-15 | RP | 3664h | 3664h | RANFS-Evo | 25.912 | NTT DoCoMo | nakamurata@NTTDOCOMO.CO.JP | Rel-7 | Issam | RP-060472 |  |
| 1288 | 418 | Study on Performance Evaluation of the UE behaviour in high speed trains with speeds up to 350 kmph |  | 328d? | 2005-03-15 A | 2006-06-15 A | 100% | 2005-03-15 | 2006-06-15 | 328d? |  | finish no earlier than 2006-06-15 | R4 | 2624h | 2624h | RANFS-HSTrains | none | Vodafone | Mike.vogel@vodafone.com,tim.frost@vodafone.com | Rel-7 | Issam | RP-060412 |  |
| 1289 | 419 | Study on UTRA Tower Mounted Amplifier (FDD) |  | 195d? | 2005-06-15 A | 2006-03-14 A | 100% | 2005-06-15 | 2006-03-14 | 195d? |  | finish no earlier than 2006-03-15 | R4 | 1560h | 1560h | RANFS-TMA | 25.818 | Ericsson | Klas.Sjerling@ericsson.com | Rel-7 | Issam | RP-060035 |  |
| 1290 | 420 | Study on Continuous connectivity for packet data users |  | 132d? | 2005-03-15 A | 2005-09-14 A | 100% | 2005-03-15 | 2005-09-14 | 132d? |  | finish no earlier than 2005-09-15 | R1 | 1056h | 1056h | RANFS-cont-packet | none | Siemens | joerg.gustrau@siemens.com | Rel-7 | Patrick | RP-050427 |  |
| 1291 | 421 | Study on Improvement of the Multimedia Broadcast Multicast Service (MBMS) in UTRAN |  | 262d? | 2005-12-15 A | 2006-12-15 A | 100% | 2005-12-15 | 2006-12-15 | 262d? |  | finish no earlier than 2006-12-15 | R2 | 2096h | 2096h | RANFS-MBMSImp | 25.905 | LG Electronics | leego@lge.com | Rel-7 | Joern | RP-060692 |  |
| 1292 | 422 | Study on Performance Improvements in Small Cells using HSDPA/EDCH |  | 131d? | 2005-12-15 A | 2006-06-15 A | 100% | 2005-12-15 | 2006-06-15 | 131d? |  | finish no earlier than 2006-06-15 | R4 | 1048h | 1048h | SMALLCELLS | none | Cingular | Marc Grant | Rel-7 | Issam | RP-060263 |  |
| 1293 | 423 | Study on Further Improved Performance Requirements for UMTS/HSDPA UE (FDD) |  | 383d? | 2005-12-15 A | 2007-06-04 A | 100% | 2005-12-15 | 2007-06-04 | 383d? |  | finish no earlier than 2007-06-04 | R4 | 3064h | 3064h | RANFS-IC | 25.963 | Cingular | Marc Grant | Rel-7 | Issam | RP-070499 |  |
| 1294 | 424 | Study on Scope of future FDD HSPA Evolution |  | 394d? | 2006-03-15 A | 2007-09-17 A | 100% | 2006-03-15 | 2007-09-17 | 394d? |  | finish no earlier than 2007-09-17 | RP | 3152h | 3152h | RANFS-HSPAEvo | 25.999 | Cingular | Don Zelmer (dz1069@att.com) | Rel-7 | Issam | RP-070533 |  |
| 1295 | 425 | Study on Dynamically reconfiguring a FDD UE receiver to reduce power consumption when desired Quality of Service is met | milestone | 0d? | 2007-06-22 A | 2007-06-22 A | 100% | 2007-06-22 | 2007-06-22 | 0d? |  |  | R4 |  |  | FSUEPow | 25.906 | Nokia | Chris.callender@nokia.com, tiina.s.koskinen@nokia.com | Rel-7 | Issam | RP-070534 |  |
| 1296 | 426 | Study on Future GERAN Evolution |  | 486d? | 2005-04-08 A | 2007-02-16 A | 100% | 2005-04-08 | 2007-02-16 | 486d? |  | finish no earlier than 2007-02-16 | GP | 3888h | 3888h | FGE | 45.912 | Nokia | eddie.riddington@nokia.com | Rel-7 | Paolo |  |  |
| 1297 | 427 | Study on GAN Enhancements | milestone | 0d? | 2007-08-31 A | 2007-08-31 A | 100% | 2007-08-31 | 2007-08-31 | 0d? |  | start no earlier than 2007-08-31 | GP |  |  | EGAN | 43.902 | T-Mobile | janne.linkola@t-mobile.com | Rel-7 | Paolo |  |  |
| 1298 | 428 | Deleted - covered by UID33027 - IMS security extensions | milestone | 0d? | 2005-12-08 A | 2005-12-08 A | 100% | 2005-12-08 | 2005-12-08 | 0d? |  | start no earlier than 2005-12-08 | S3 |  |  | IMS-SE |  | Ericsson | Bengt.Sahlin@ericsson.com | Rel-7 | Dionisio |  | SP-30 |
| 1299 | 429 | Deleted - covered by 32108 - Study of work on an LCS architecture for I-WLAN | milestone | 0d? | 2006-12-08 A | 2006-12-08 A | 100% | 2006-12-08 | 2006-12-08 | 0d? |  | start no earlier than 2006-12-08 | S2 |  |  | IMS-SE |  | LG Electronics | Donghee Shim dhshim@lge.com ; phede@lge.com | Rel-7 | Maurice |  | SP-33 |
| 1300 | 430 | **Deleted: Study on applicability of GALILEO for LCS** |  | 0d? | 2005-06-30 A | 2005-06-30 A | 100% | 2005-06-30 | 2005-06-30 | 0d? |  |  | S2 |  |  | Galileo |  |  |  | Rel-7 | Maurice |  | SP-25 |
| 1301 | 430.1 | Deleted - TR on Stage 2 | milestone | 0d? | 2005-06-30 A | 2005-06-30 A | 100% | 2005-06-30 | 2005-06-30 | 0d? |  | finish no earlier than 2005-06-30 | S2 |  |  | Galileo |  |  |  | Rel-7 | Maurice |  | SP-25 |
| 1302 | 430.2 | Deleted - GERAN review of the TR | milestone | 0d? | 2005-06-30 A | 2005-06-30 A | 100% | 2005-06-30 | 2005-06-30 | 0d? |  | start no earlier than 2005-06-30 | GP |  |  | Galileo |  |  |  | Rel-7 | Paolo |  | SP-26 |
| 1303 | 16.7 | **Deleted - IMS Local services** |  | 0d? | 2006-01-06 A | 2006-01-06 A | 100% | 2006-01-06 | 2006-01-06 | 0d? |  |  | S2 |  |  | IMSLocal | 23.228 |  |  | Rel-7 | Maurice |  | SP-28 |
| 1304 | 16.7.1 | Deleted - Stage 2 | milestone | 0d | 2006-01-06 A | 2006-01-06 A | 100% | 2006-01-06 | 2006-01-06 | 0d |  | start no earlier than 2006-01-06 | S2 |  |  | IMSLocal |  |  |  | Rel-7 | Maurice |  | SP-26 |
| 1305 | 431.2 | Deleted - Stage 3 for IMS Local services | milestone | 0d? | 2006-01-06 A | 2006-01-06 A | 100% | 2006-01-06 | 2006-01-06 | 0d? |  | finish no earlier than 2006-01-06 | C1 |  |  | IMSLocal |  | Lucent | Keith Drage (drage@alcatel-lucent.com) | Rel-7 | Frederic |  | SP-25 |
| 1306 | 432 | Deleted - IMS Phase 3 | milestone | 0d? | 2006-01-06 A | 2006-01-06 A | 100% | 2006-01-06 | 2006-01-06 | 0d? |  | start no earlier than 2006-01-06 | S2 |  |  |  |  |  |  | Rel-7 | Maurice |  | SP-25 |
| 1307 | 433 | Deleted - Improvements of Radio Interface | milestone | 0d? | 2004-09-15 A | 2004-09-15 A | 100% | 2004-09-15 | 2004-09-15 | 0d? |  | start no earlier than 2004-09-15 | RP |  |  | RInImp |  |  |  | Rel-7 | Issam |  | SP-24 |
| 1308 | 434 | Deleted: Generic User Profile Phase 2 | milestone | 0d | 2005-08-08 A | 2006-06-30 A | 100% | 2005-08-08 | 2006-06-30 | 0d |  |  | C4 |  |  |  |  |  |  | Rel-7 | Kimmo |  | SP-27 |
| 1309 | 30.4 | Deleted - Stage 3 - Common objects | milestone | 0d | 2005-08-08 A | 2006-06-30 A | 100% | 2005-08-08 | 2006-06-30 | 0d |  | finish no earlier than 2006-06-30 | C4 |  |  |  | 24.241 |  |  | Rel-7 | Kimmo |  | SP-27 |
| 1310 | 436 | Deleted was duplicated- Study of Customised Alerting Tone (CAT) Requirements | milestone | 0d? | 2006-06-30 A | 2006-06-30 A | 100% | 2006-06-30 | 2006-06-30 | 0d? |  | start no earlier than 2006-06-30 | S1 |  |  | CAT |  |  |  | Rel-7 | Alain |  | SP-31 |
| 1311 | 437 | Deleted - FS of enhanced support of Video Telephony | milestone | 0d? | 2006-06-30 A | 2006-06-30 A | 100% | 2006-06-30 | 2006-06-30 | 0d? |  | start no earlier than 2006-06-30 | GP |  |  | VIDGER |  | Ericsson | stefan.g.eriksson@ericsson.com | Rel-7 | Paolo |  | SP-32 |
| 1312 | 438 | Deleted (moved to Rel8) - Study on Transferring of emergency call data – in-band modem solution | milestone | 0d? | 2007-06-22 A | 2007-06-22 A | 100% | 2007-06-22 | 2007-06-22 | 0d? |  | start no earlier than 2007-06-22 | S4 |  |  | eCALLIBMS | 26.967 | Airbiquity | lhong@airbiquity.com | Rel-7 | Paolo |  | SP-38 |
| 1313 | 439 | Deleted - covered by UID 20053 - Study on Interference Cancellation for UTRA FDD UE |  | 1d? | 2007-03-28 A | 2007-03-28 A | 100% | 2007-03-28 | 2007-03-28 | 1d? |  | start no earlier than 2007-03-28 | R4 | 8h | 8h | RANFS-InterfCanc |  |  |  | Rel-7 | Issam |  | SP-38 |
| 1314 | 440 | Deleted - Study of Personal Network and Personal Area Network | milestone | 0d? | 2006-10-20 A | 2006-10-20 A | 100% | 2006-10-20 | 2006-10-20 | 0d? |  | finish no earlier than 2006-10-20 | S1 |  |  | PNPAN |  |  |  | Rel-7 | Alain |  | SP-31 |
| 1315 | 441 | Deleted - Study on IMS with real time services deployment |  | 316d? | 2004-06-28 A | 2005-09-12 A | 100% | 2004-06-28 | 2005-09-12 | 316d? |  |  | S1 | 2528h | 2528h | IRTSD |  |  |  | Rel-7 | Alain |  | SP-30 |
| 1316 | 442 | Deleted - Study on Stage 2 (IMS services using CS bearers) |  | 316d? | 2004-06-28 A | 2005-09-12 A | 100% | 2004-06-28 | 2005-09-12 | 316d? |  | finish no earlier than 2005-09-12 | S2 | 2528h | 2528h | IRTSD-IMSCS | 23.899 | Nortel | Mark Watson | Rel-7 | Maurice |  | SP-30 |
| 1317 | 443 | Deleted - Study on IMS enhancements and optimizations for real time communication. |  | 430d? | 2005-10-10 A | 2007-06-01 A | 100% | 2005-10-10 | 2007-06-01 | 430d? |  | finish no earlier than 2007-06-01 | S2 | 3440h | 3440h | IMS-RT | 23.818 | Ericsson | stephen.terrill@ericsson.com | Rel-7 | Maurice |  | SP-35 |
| 1318 | 444 | Deleted - Study on Terminating Session handling |  | 255d? | 2006-01-09 A | 2006-12-29 A | 100% | 2006-01-09 | 2006-12-29 | 255d? |  | finish no earlier than 2006-12-29 | S2 | 2040h | 2040h | CSIterm | 23.819 | Samsung |  | Rel-7 | Maurice |  | SP-32 |
| 1319 | 445 | Deleted - Study on IRP usage scenarios |  | 330d? | 2005-09-02 A | 2006-12-07 A | 100% | 2005-09-02 | 2006-12-07 | 330d? |  | finish no earlier than 2006-12-07 | S5 | 2640h | 2640h | OAM-Study | 32.8xy | Lucent |  | Rel-7 | Dionisio |  | SP-32 |
| 1320 | 446 | Release 6 Features |  | 1d? | 2000-01-03 | 2000-01-03 |  | 2000-01-03 | 2000-01-03 | 1d? | 3056d |  | NP,GP, RP,SP,TP | 8h |  |  |  |  |  | Rel-6 |  |  |  |

Notes:
- 1281: -
- 1282: -
- 1283: -
- 1284: SP#34 completed
- 1285: SP#35 completed
- 1286: SP#35 completed
- 1287: RP#33 (Sep 2006) completed. SR in RP-060472
- 1288: RP#32 (Jun 2006) completed. SR in RP-060412
- 1289: RP#31 (Mar 2006) completed. SR in RP-060035
- 1290: RP#29 (Sep 2006) completed. SR in RP-050427
- 1291: RP#34 (Dec 2006) completed. SR in RP-060692
- 1292: RP#32 (Jun 2006) closed (no progress). SR in RP-060263
- 1293: RP#36 (May 2007) completed. SR in RP-070499
- 1294: RP#37 (Sep 2007) completed. SR in RP-070533
- 1295: RP#37 (Sep 2007) completed. SR in RP-070534
- 1296: GP#33 completed
- 1297: GP#35 completed
- 1298: -
- 1299: S2#52: Entry created
- 1300: -
- 1301: -
- 1302: -
- 1303: -
- 1304: DAB - Not yet required in SA2 as it exists in previous releases
- 1305: -
- 1306: -
- 1307: Stage 2 description of Interim conclusion
- 1308: Created at TSG#27 by A. Sultan because of the move to Rel-7 of "Common Objects".
- 1309: No progress in CN4#26. This have to be moved to Rel-7. It was deleted from WID
- 1310: Awaiting MCC SA3 input
- 1311: FS CLOSED at G#28 (no input)
- 1312: SP-38 stopped
- 1313: Deleted. Same as FS on Further Improved Performance Requirements for UMTS/HSDPA UE (FDD)
- 1314: Moved from FS section Feb 06
- 1315: -
- 1316: SP-30: S2 has no intention for TR completion
- 1317: abandoned at 65%
- 1318: SP#32 Jun 2006 Study abandoned => spin-off Implementation work UID_320029
- 1319: -
- 1320: -

| ID | WBS | Task | Duration | Start | Finish | Complete | Baseline start | Baseline finish | Baseline duration | Constraint | Resources | Work | Actual work | Text1 | Text6 | Text8 | Text4 | Text5 | Text3 | Text10 | Text12 |
| --- | --- | --- | --- | --- | --- | --- | --- | --- | --- | --- | --- | --- | --- | --- | --- | --- | --- | --- | --- | --- | --- |
| 1321 | 8 | **Rel-6 Improvements of Radio Interface** | 1393d? | 2000-08-14 A | 2005-12-14 A | 100% | 2000-08-14 | 2005-12-14 | 1393d? |  | RP | 38664h | 38664h | RInImp | Rel-6 | Issam |  |  |  |  |  |
| 1322 | 447.1 | Improved support of IMS Realtime Services using HSDPA/EDCH | 197d? | 2005-03-15 A | 2005-12-14 A | 100% | 2005-03-15 | 2005-12-14 | 197d? | finish no earlier than 2005-12-14 | R2 | 1576h | 1576h | RInImp-IMSRealTime | Rel-6 | Joern | Cingular | Don Zelmer (dz1069@att.com) |  |  |  |
| 1323 | 447.2 | Improving Receiver Performance Requirements for the FDD UE | 401d | 2002-03-08 A | 2003-09-19 A | 100% | 2002-03-08 | 2003-09-19 | 401d | start no earlier than 2002-03-08 | R4 | 3208h | 3208h | RInImp-UERecPerf | Rel-6 | Issam | Intel | shimon.moshavi@INTEL.COM | 25.101 |  |  |
| 1324 | 8.2 | **Base station classification** | 603d | 2000-08-14 A | 2002-12-04 A | 100% | 2000-08-14 | 2002-12-04 | 603d |  | R4 | 9648h | 9648h | RInImp-BSClass | Rel-6 | Issam |  |  |  |  |  |
| 1325 | 8.2.1 | FDD Base station classification | 603d | 2000-08-14 A | 2002-12-04 A | 100% | 2000-08-14 | 2002-12-04 | 603d | finish no earlier than 2002-12-04 | R4 | 4824h | 4824h | RInImp-BSClass-FDD | Rel-6 | Issam | Nokia | antti.toskala@nokia.com | 25.104, 25.141 |  |  |
| 1326 | 447.4 | UMTS-850 | 266d | 2002-12-06 A | 2003-12-12 A | 100% | 2002-12-06 | 2003-12-12 | 266d | finish no earlier than 2003-12-15 | R4 | 2128h | 2128h | RInImp-UMTS850 | Rel-6 | Issam | Cingular | Don Zelmer (dz1069@att.com) | 25.101, 25.104, 25.133, 25.141, 25.307, 25.331, 25.942 |  |  |
| 1327 | 447.5 | DS-CDMA introduction in the 800 MHz band | 196d | 2003-03-14 A | 2003-12-12 A | 100% | 2003-03-14 | 2003-12-12 | 196d | finish no earlier than 2003-12-15 | R4 | 1568h | 1568h | RInImp-UMTS800 | Rel-6 | Issam | NTT DoCoMo | Takehiro Nakamura (nakamurata@nttdocomo.co.jp) | 25.101, 25.104, 25.133, 25.141, 25.307, 25.331 |  |  |
| 1328 | 447.6 | UMTS 1.7/2.1 GHz | 261d | 2003-03-14 A | 2004-03-12 A | 100% | 2003-03-14 | 2004-03-12 | 261d | finish no earlier than 2004-03-15 | R4 | 2088h | 2088h | RInImp-UMTS1721 | Rel-6 | Issam | Nokia | jussi.numminen@NOKIA.COM | 25.101, 25.104, 25.133, 25.141, 25.307, 25.331 |  |  |
| 1329 | 447.7 | **Improved Receiver Performance Requirements for HSDPA** | 392d? | 2003-12-15 A | 2005-06-14 A | 100% | 2003-12-15 | 2005-06-14 | 392d? |  | R4 | 7304h | 7304h | RInImp-HSPerf | Rel-6 | Issam | Nokia | jussi.numminen@NOKIA.COM |  |  |  |
| 1330 | 447.7.1 | Improved Minimum Performance Requirements for HSDPA UE categories 7 and 8 | 195d? | 2004-09-15 A | 2005-06-14 A | 100% | 2004-09-15 | 2005-06-14 | 195d? | finish no earlier than 2005-06-14 | R4 | 1560h | 1560h | RInImp-HSPerf-10code | Rel-6 | Issam | Nokia | jussi.numminen@nokia.com | 25.101 |  |  |
| 1331 | 447.7.2 | Performance Requirements of Receive Diversity for HSDPA | 326d | 2003-12-15 A | 2005-03-14 A | 100% | 2003-12-15 | 2005-03-14 | 326d | finish no earlier than 2005-03-14 | R4 | 2608h | 2608h | RInImp-HSPerf-RxDiv | Rel-6 | Issam | NTT DoCoMo | Takehiro Nakamura (nakamurata@nttdocomo.co.jp) | 25.101 |  |  |
| 1332 | 448 | **Rel-6 RAN Feasibility Studies** | 1196d? | 2000-08-14 A | 2005-03-14 A | 100% | 2000-08-14 | 2005-03-14 | 1196d? |  | RP | 43048h | 43048h |  | Rel-6 |  |  |  |  |  |  |
| 1333 | 448.1 | FS of the improved access to UE measurement data for CRNC to support TDD RRM | 270d? | 2002-12-06 A | 2003-12-18 A | 100% | 2002-12-06 | 2003-12-18 | 270d? | finish no earlier than 2003-09-19 | R3 | 2160h | 2160h | RANimp-RRMopt-FSUEMsD | Rel-6 | Juha | Interdigital | jim.miller@interdigital.com | 25.801, 25.423 | SP-24 |  |
| 1334 | 448.2 | FS on Radio link performance enhancements | 1067d | 2000-08-14 A | 2004-09-14 A | 100% | 2000-08-14 | 2004-09-14 | 1067d | finish no earlier than 2004-09-14 | R1 | 8536h | 8536h | RInImp-Rlperf | Rel-6 | Patrick | Nokia | antti.toskala@nokia.com | 25.899 |  |  |
| 1335 | 448.3 | FS on Improvement of inter-frequency and inter-system measurements for 1.28 Mcps TDD | 461d | 2001-12-14 A | 2003-09-19 A | 100% | 2001-12-14 | 2003-09-19 | 461d | start no earlier than 2001-12-14 | R1 | 3688h | 3688h | RInImp-IfIsMLCR | Rel-6 | Patrick | Samsung | Li Xiao Qiang (xqli@samsung.co.kr) | 25.888 |  |  |
| 1336 | 448.4 | FS for the analysis of OFDM for UTRAN enhancement | 526d | 2002-06-10 A | 2004-06-14 A | 100% | 2002-06-10 | 2004-06-14 | 526d | start no earlier than 2002-06-10 | R1 | 4208h | 4208h | RInImp-FSOFDM | Rel-6 | Patrick | Nortel | Sarah Boumendil | 25.892 |  |  |
| 1337 | 448.5 | FS on Uplink Enhancements for Dedicated Transport Channels | 396d | 2002-09-06 A | 2004-03-12 A | 100% | 2002-09-06 | 2004-03-12 | 396d | finish no earlier than 2004-03-12 | R1 | 3168h | 3168h | RInImp-FSUpDTrCh | Rel-6 | Patrick | Nokia | Karri.Ranta-aho@nsn.com | 25.896 |  |  |
| 1338 | 448.6 | FS on Analysis on Higher Chip Rates for UTRA TDD evolutions | 528d | 2002-09-06 A | 2004-09-14 A | 100% | 2002-09-06 | 2004-09-14 | 528d | finish no earlier than 2004-09-14 | R1 | 4224h | 4224h | RInImp-FSVHCRTDD | Rel-6 | Patrick | IPWireless | mbeale@ipwireless.com | 25.895 |  |  |
| 1339 | 448.7 | FS on Low Output Powers for general purpose FDD BSs | 128d | 2003-06-13 A | 2004-03-12 A | 100% | 2003-06-13 | 2004-03-12 | 128d | finish no earlier than 2004-03-12 | R3 | 1024h | 1024h | RInImp-FSLoPw | Rel-6 | Juha | Telefonica | Ana Burgos (burgos_a@tsm.es) | 25.807 |  |  |
| 1340 | 448.8 | FS on Uplink enhancements for UTRA TDD | 462d | 2003-06-06 A | 2005-03-14 A | 100% | 2003-06-06 | 2005-03-14 | 462d | finish no earlier than 2005-03-14 | R1 | 3696h | 3696h | RInImp-FSUpEnhTDD | Rel-6 | Patrick | Interdigital | Marian.Rudolf@InterDigital.com | 25.804 |  |  |
| 1341 | 8.8 | FS on UE antenna efficiency test methods performance requirements (2) | 131d | 2002-03-08 A | 2002-09-06 A | 100% | 2002-03-08 | 2002-09-06 | 131d | finish no earlier than 2002-09-06 | R4 | 1048h | 1048h | RInImp-UEAnTM2 | Rel-6 | Issam | Allgon | Alf Ahlström |  |  |  |
| 1342 | 9.4 | Deleted - FS on the evolution of the UTRAN architecture | 592d | 2002-09-09 A | 2004-12-14 A | 100% | 2002-09-09 | 2004-12-14 | 592d | finish no earlier than 2004-12-15 | R3 | 4736h | 4736h | RANimp-FSEvo | Rel-6 | Juha | Nokia | woonhee.hwang@nsn.com, Antti.Toskala@nokia.com |  |  | RP-26 |
| 1343 | 449 | **FDD Enhanced Uplink** | 393d | 2004-03-15 A | 2005-09-14 A | 100% | 2004-03-15 | 2005-09-14 | 393d |  | RP | 14128h | 14128h | EDCH | Rel-6 |  | Ericsson | Joakim Bergström |  |  |  |
| 1344 | 449.1 | FDD Enhanced Uplink - Stage 2 | 197d | 2004-03-15 A | 2004-12-14 A | 100% | 2004-03-15 | 2004-12-14 | 197d | finish no earlier than 2004-12-14 | R2 | 1576h | 1576h | EDCH-Stage2 | Rel-6 | Joern |  |  | 25.309 |  |  |
| 1345 | 449.2 | FDD Enhanced Uplink - Physical Layer | 261d | 2004-03-15 A | 2005-03-14 A | 100% | 2004-03-15 | 2005-03-14 | 261d | finish no earlier than 2005-03-14 | R1 | 2088h | 2088h | EDCH-Phys | Rel-6 | Patrick | Nokia | Karri.Ranta-aho@nsn.com | 25.211, 25.212, 25.213, 25.214, 25.215 |  |  |
| 1346 | 449.3 | FDD Enhanced Uplink - Layer 2 and 3 Protocol Aspects | 261d | 2004-03-15 A | 2005-03-14 A | 100% | 2004-03-15 | 2005-03-14 | 261d | finish no earlier than 2005-03-14 | R2 | 2088h | 2088h | EDCH-L23 | Rel-6 | Joern | Ericsson | Joakim Bergström | 25.301, 25.302, 25.306, 25.321, 25.331 |  |  |
| 1347 | 449.4 | FDD Enhanced Uplink - UTRAN Iub/Iur Protocol Aspects | 261d | 2004-03-15 A | 2005-03-14 A | 100% | 2004-03-15 | 2005-03-14 | 261d | finish no earlier than 2005-03-14 | R3 | 2088h | 2088h | EDCH-IurIub | Rel-6 | Juha | Nortel | Saso Stojanovski | 25.401, 25.420, 25.423, 25.430, 25.433 |  |  |
| 1348 | 449.5 | FDD Enhanced Uplink - RF Radio Transmission/ Reception, System Performance Requirements and Conformance Testing | 393d | 2004-03-15 A | 2005-09-14 A | 100% | 2004-03-15 | 2005-09-14 | 393d | finish no earlier than 2005-09-15 | R4 | 3144h | 3144h | EDCH-RF | Rel-6 | Issam | Ericsson | thomas.unshelm@ERICSSON.COM | 25.101, 25.104, 25.133, 25.141 |  |  |

Notes:
- 1321: This is a generic feature without particular end date
- 1322: -
- 1323: -
- 1324: -
- 1325: -
- 1326: Introduction of UMTS850 (Band V) in 25.307
- 1327: Introduction of UMTS800 in 25.307
- 1328: Introduction of UMTS1700/2100 (Band IV)
- 1329: -
- 1330: Approved at RP#25 as RP-040375
- 1331: -
- 1332: -
- 1333: -
- 1334: Study finished at RP#25
- 1335: -
- 1336: -
- 1337: -
- 1338: Study finished at RP#25
- 1339: -
- 1340: -
- 1341: The RInImp-UEAnTM FS was re-opened at TSG RP#15 upon request from WG4
- 1342: Study Closed, work will continue within the FS on evolved UTRA and UTRAN
- 1343: -
- 1344: -
- 1345: -
- 1346: -
- 1347: -
- 1348: -

| ID | WBS | Task | Type | Duration | Start | Finish | Complete | Baseline start | Baseline finish | Baseline duration | Constraint | Resources | Work | Actual work | Text1 | Text6 | Text3 | Text4 | Text5 | Text8 | Text12 | Text10 |
| --- | --- | --- | --- | --- | --- | --- | --- | --- | --- | --- | --- | --- | --- | --- | --- | --- | --- | --- | --- | --- | --- | --- |
| 1349 | 450 | **Rel-6 RAN improvements** |  | 656d? | 2002-09-09 A | 2005-03-14 A | 100% | 2002-09-09 | 2005-03-14 | 656d? |  | RP | 28312h | 28312h | RANimp | Rel-6 |  |  |  |  |  |  |
| 1350 | 9.2 | **RAB support enhancement** |  | 522d? | 2003-03-14 A | 2005-03-14 A | 100% | 2003-03-14 | 2005-03-14 | 522d? |  | R2 | 9360h | 9360h | RANimp-RABSE | Rel-6 | 25.862 | Nokia | Jussi Kähtävä (juha.mikola@nokia.com) | Joern |  |  |
| 1351 | 450.1.1 | Optimization of downlink channelisation code utilisation |  | 262d | 2004-03-12 A | 2005-03-14 A | 100% | 2004-03-12 | 2005-03-14 | 262d | finish no earlier than 2005-03-14 | R1 | 2096h | 2096h | RANimp-RABSE-CodeOptFDD | Rel-6 |  | Nortel | Sarah Boumendil | Patrick |  |  |
| 1352 | 450.1.2 | optimization of channelisation code utilisation for 3.84 Mcps TDD |  | 261d | 2004-03-15 A | 2005-03-14 A | 100% | 2004-03-15 | 2005-03-14 | 261d | finish no earlier than 2005-03-15 | R1 | 2088h | 2088h | RANimp-RABSE-CodOptTDD | Rel-6 |  | IPWireless | Nicholas Anderson | Patrick |  |  |
| 1353 | 450.1.3 | HS-DPCCH ACK/NACK Enhancement |  | 65d? | 2004-09-15 A | 2004-12-14 A | 100% | 2004-09-15 | 2004-12-14 | 65d? | finish no earlier than 2004-12-15 | R1 | 520h | 520h | RANimp-RABSE-ACKNACK | Rel-6 | 25.212, 25.214, 24.331, 25.433 | Nokia | Jussi Kähtävä (juha.mikola@nokia.com) | Patrick |  |  |
| 1354 | 450.1.4 | Deleted - Iu enhancements for IMS support in RAN |  | 320d? | 2003-03-14 A | 2004-06-03 A | 100% | 2003-03-14 | 2004-06-03 | 320d? | start no earlier than 2003-03-14 | R3 | 2560h | 2560h | RANimp-RABSE-IuEnhIMS | Rel-6 |  | Nortel | Philippe.Godin@nortelnetworks.com | Juha | RP-24 |  |
| 1355 | 450.1.5 | Deleted - Improvement of RRM across RNS and RNS/BSS | milestone | 0d? | 2003-12-05 A | 2003-12-05 A | 100% | 2003-12-05 | 2003-12-05 | 0d? | finish no earlier than 2003-12-05 | R3 |  |  | RANimp-RRM1 | Rel-6 |  | Nokia | antti.toskala@nokia.com | Juha | RP-23 |  |
| 1356 | 9.1 | Beamforming Enhancements |  | 66d | 2003-09-19 A | 2003-12-19 A | 100% | 2003-09-19 | 2003-12-19 | 66d | finish no earlier than 2004-03-12 | R1 | 528h | 528h | RANimp-BFE | Rel-6 | 24.215, 25.423, 25.425, 25.433, 25.435 | Nokia | Jussi Kähtävä (juha.mikola@nokia.com) | Patrick |  |  |
| 1357 | 450.3 | **Rel6 RRM optimization for Iur and Iub** |  | 126d | 2003-09-19 A | 2004-03-12 A | 100% | 2003-09-19 | 2004-03-12 | 126d |  | R3 | 2016h | 2016h | RANimp-RRMopt | Rel-6 |  | Ericsson | Gert-Jan.van.Lieshout@eln.ericsson.se | Juha |  |  |
| 1358 | 450.3.1 | Improved access to UE measurement data for CRNC to support TDD RRM |  | 126d | 2003-09-19 A | 2004-03-12 A | 100% | 2003-09-19 | 2004-03-12 | 126d | finish no earlier than 2004-03-15 | R3 | 1008h | 1008h | RANimp-RRMopt-UEMsD | Rel-6 | 25.423 | Interdigital | jim.miller@interdigital.com | Juha | RP-22 |  |
| 1359 | 450.4 | **Remote Control of Electrical Tilting Antennas** |  | 395d? | 2003-03-14 A | 2004-09-16 A | 100% | 2003-03-14 | 2004-09-16 | 395d? |  | R3 | 7464h | 7464h | RANimp-TiltAnt | Rel-6 |  | Vodafone | Andreas.Hauser@vodafone.com | Juha |  |  |
| 1360 | 450.4.1 | Tilting Antenna - RAN aspects |  | 393d? | 2003-03-14 A | 2004-09-14 A | 100% | 2003-03-14 | 2004-09-14 | 393d? | finish no earlier than 2004-09-14 | R3 | 3144h | 3144h | RANimp-TiltAnt | Rel-6 | 25.460, 25.461, 25.462, 25.463 | Vodafone | Andreas.Hauser@vodafone.com | Juha |  |  |
| 1361 | 450.4.2 | OAM&P impacts |  | 145d | 2004-02-27 A | 2004-09-16 A | 100% | 2004-02-27 | 2004-09-16 | 145d | finish no earlier than 2004-09-16 | S5 | 1160h | 1160h | RANimp-TiltAnt-OAM | Rel-6 | 32.804, 32.64x | Vodafone | Adrian.Neal@vodafone.com | Dionisio |  | SP-24 |
| 1362 | 450.5 | Network Assisted Cell Change (NACC) from UTRAN to GERAN - network-side aspects |  | 462d? | 2002-09-09 A | 2004-06-15 A | 100% | 2002-09-09 | 2004-06-15 | 462d? | finish no earlier than 2004-06-15 | R3 | 3696h | 3696h | RANimp-NACC | Rel-6 |  | Vodafone | Brendan.McWilliams@gb.vodafone.co.uk | Juha |  |  |
| 1363 | 12 | **Location Services enhancements 2** |  | 1024d? | 2001-01-15 A | 2004-12-16 A | 100% | 2001-01-15 | 2004-12-16 | 1024d? |  | S2,S5,N4,RP | 78152h | 78152h | LCS2 | Rel-6 | 23.271 |  |  | Maurice |  |  |
| 1364 | 12.1 | **Improvement on Le interface** |  | 653d? | 2002-06-17 A | 2004-12-15 A | 100% | 2002-06-17 | 2004-12-15 | 653d? |  | S2 | 9872h | 9872h | LCS2 | Rel-6 |  |  |  | Maurice |  |  |
| 1365 | 451.1.1 | Stage 2 |  | 331d? | 2002-06-17 A | 2003-09-22 A | 100% | 2002-06-17 | 2003-09-22 | 331d? | start no earlier than 2002-06-17 | S2 | 2648h | 2648h | LCS2 | Rel-6 |  |  |  | Maurice |  |  |
| 1366 | 451.1.2 | Stage 3 - impacts MLP (Mobile Location Protocol) |  | 250d? | 2004-01-01 A | 2004-12-15 A | 100% | 2004-01-01 | 2004-12-15 | 250d? | finish no earlier than 2004-12-15 | OMA | 2000h | 2000h | LCS2 | Rel-6 |  |  | OMA-LIAISON@mail.openmobilealliance.org |  |  |  |
| 1367 | 12.2 | **Enhanced support for anonymity and user privacy** |  | 638d? | 2002-07-08 A | 2004-12-15 A | 100% | 2002-07-08 | 2004-12-15 | 638d? |  | S2 | 9144h | 9144h | LCS2 | Rel-6 |  |  |  | Maurice |  |  |
| 1368 | 451.2.1 | Stage 2 |  | 255d? | 2002-07-08 A | 2003-06-27 A | 100% | 2002-07-08 | 2003-06-27 | 255d? | finish no earlier than 2003-06-27 | S2 | 2040h | 2040h | LCS2 | Rel-6 |  |  |  | Maurice |  |  |
| 1369 | 451.2.2 | Stage 3 - impacts MLP and RLP |  | 250d? | 2004-01-01 A | 2004-12-15 A | 100% | 2004-01-01 | 2004-12-15 | 250d? | finish no earlier than 2004-12-15 | OMA | 2000h | 2000h | LCS2 | Rel-6 |  |  | OMA-LIAISON@mail.openmobilealliance.org |  |  |  |
| 1370 | 12.3 | **Enhanced inter-GMLC interface** |  | 648d? | 2002-06-24 A | 2004-12-15 A | 100% | 2002-06-24 | 2004-12-15 | 648d? |  | S2 | 9704h | 9704h | LCS2 | Rel-6 |  |  |  | Maurice |  |  |
| 1371 | 451.3.1 | Stage 2 |  | 315d? | 2002-06-24 A | 2003-09-05 A | 100% | 2002-06-24 | 2003-09-05 | 315d? | finish no earlier than 2003-09-05 | S2 | 2520h | 2520h | LCS2 | Rel-6 |  |  |  | Maurice |  |  |
| 1372 | 451.3.2 | Stage 3 - definition of RLP and PCP |  | 250d? | 2004-01-01 A | 2004-12-15 A | 100% | 2004-01-01 | 2004-12-15 | 250d? | finish no earlier than 2004-12-15 | OMA | 2000h | 2000h | LCS2 | Rel-6 |  |  | OMA-LIAISON@mail.openmobilealliance.org |  |  |  |

Notes:
- 1349: Generic feature
- 1350: building block without particular end date
- 1351: -
- 1352: WIDS modified in RP#26, RP-040551
- 1353: Approved at RP#25 as RP-040390
- 1354: Closed RP#24 due to the lack of progress
- 1355: abandoned RP-23
- 1356: -
- 1357: -
- 1358: -
- 1359: -
- 1360: Finished at RP#25
- 1361: SP#25 09/2004 completed
- 1362: -
- 1363: -
- 1364: -
- 1365: -
- 1366: Updated according to SP-040232
- 1367: -
- 1368: -
- 1369: Updated according to SP-040232
- 1370: -
- 1371: -
- 1372: Updated according to SP-040232

| ID | WBS | Task | Type | Duration | Start | Finish | Complete | Baseline start | Baseline finish | Baseline duration | Constraint | Resources | Work | Actual work | Text1 | Text6 | Text8 | Text5 | Text4 | Text12 |
| --- | --- | --- | --- | --- | --- | --- | --- | --- | --- | --- | --- | --- | --- | --- | --- | --- | --- | --- | --- | --- |
| 1373 | 12.4 | **Location Services support for IMS public identities** |  | 473d? | 2003-02-24 A | 2004-12-15 A | 100% | 2003-02-24 | 2004-12-15 | 473d? |  | S2 | 7704h | 7704h | LCS2 | Rel-6 | Maurice |  |  |  |
| 1374 | 451.4.1 | Stage 2 |  | 240d? | 2003-02-24 A | 2004-01-23 A | 100% | 2003-02-24 | 2004-01-23 | 240d? | finish no earlier than 2004-01-23 | S2 | 1920h | 1920h | LCS2 | Rel-6 | Maurice |  |  |  |
| 1375 | 451.4.2 | Stage 3 - impacts MLP, RLP and PCP |  | 250d? | 2004-01-01 A | 2004-12-15 A | 100% | 2004-01-01 | 2004-12-15 | 250d? | finish no earlier than 2004-12-15 | OMA | 2000h | 2000h | LCS2 | Rel-6 |  | OMA-LIAISON@mail.openmobilealliance.org |  |  |
| 1376 | 12.5 | **New area event for location service triggering reports** |  | 663d? | 2002-06-03 A | 2004-12-15 A | 100% | 2002-06-03 | 2004-12-15 | 663d? |  | S2 | 11416h | 11416h | LCS2 | Rel-6 | Maurice |  |  |  |
| 1377 | 451.5.1 | Stage 2 |  | 280d? | 2002-06-03 A | 2003-06-27 A | 100% | 2002-06-03 | 2003-06-27 | 280d? | finish no earlier than 2003-06-27 | S2 | 2240h | 2240h | LCS2 | Rel-6 | Maurice |  |  |  |
| 1378 | 451.5.2 | Stage 3 for UE-CN signalling |  | 234d? | 2003-10-09 A | 2004-08-31 A | 100% | 2003-10-09 | 2004-08-31 | 234d? | start no earlier than 2003-10-09 | N4 | 1872h | 1872h | LCS2 | Rel-6 | Kimmo |  |  |  |
| 1379 | 451.5.3 | Stage 3 - impacts MLP, RLP and PCP |  | 250d? | 2004-01-01 A | 2004-12-15 A | 100% | 2004-01-01 | 2004-12-15 | 250d? | finish no earlier than 2004-12-15 | OMA | 2000h | 2000h | LCS2 | Rel-6 |  | OMA-LIAISON@mail.openmobilealliance.org |  |  |
| 1380 | 12.7 | **UE positioning** |  | 957d? | 2001-01-15 A | 2004-09-14 A | 100% | 2001-01-15 | 2004-09-14 | 957d? |  | RP | 18480h | 18480h | LCS2-UEpos | Rel-6 | Issam |  |  |  |
| 1381 | 12.8 | Open SMLC-SRNC Interface within the UTRAN to support UTRAN Rel4 positioning methods |  | 700d? | 2001-01-15 A | 2003-09-19 A | 100% | 2001-01-15 | 2003-09-19 | 700d? | finish no earlier than 2003-09-19 | R2 | 5600h | 5600h | LCS-Rel4Pos | Rel-6 | Joern | Meik.Kottkamp@siemens.com | Siemens |  |
| 1382 | 451.6.2 | A-GPS minimum performance specification |  | 333d? | 2003-06-06 A | 2004-09-14 A | 100% | 2003-06-06 | 2004-09-14 | 333d? | finish no earlier than 2004-09-14 | R4 | 2664h | 2664h | LCS-UEPos-AGPSPerf | Rel-6 | Issam | donglin.shen@attws.com | AT&T Wireless |  |
| 1383 | 12.7.2 | FS on Enhancements to OTDOA Positioning using advanced blanking methods |  | 320d | 2002-07-01 A | 2003-09-19 A | 100% | 2002-07-01 | 2003-09-19 | 320d | finish no earlier than 2003-09-19 | R2 | 2560h | 2560h | LCS2-UEpos-FSBlank | Rel-6 | Joern | david.bartlett@cursor-system.com | Cambridge Positioning Systems |  |
| 1384 | 451.6.4 | Deleted - UE positioning enhancements - other methods | milestone | 0d? | 2003-09-26 A | 2003-09-26 A | 100% | 2003-09-26 | 2003-09-26 | 0d? | finish no earlier than 2003-09-26 | R2 |  |  | LCS2-UEpos-enh | Rel-6 | Joern | Meik.Kottkamp@siemens.com | Siemens | RP-24 |
| 1385 | 451.7 | LCS charging |  | 455d? | 2003-03-21 A | 2004-12-16 A | 100% | 2003-03-21 | 2004-12-16 | 455d? | start no earlier than 2003-03-21 | S5 | 3640h | 3640h | LCS2-CH | Rel-6 | Dionisio | alain.bibas@orange-ft.com | France Telecom |  |
| 1386 | 14 | **Rel-6 Security enhancements** |  | 1018d? | 2001-01-03 A | 2004-11-26 A | 100% | 2001-01-03 | 2004-11-26 | 1018d? |  | S3 | 28824h | 28824h | SEC1 | Rel-6 | Dionisio | Peter.Howard@vodafone.com | Vodafone |  |
| 1387 | 14.1 | **Enhanced HE control of security (including positive authentication reporting)** |  | 712d | 2001-01-03 A | 2003-09-25 A | 100% | 2001-01-03 | 2003-09-25 | 712d |  | S3 | 14064h | 14064h | SEC1 | Rel-6 | Dionisio | Peter.Howard@vodafone.com | Vodafone |  |
| 1388 | 14.1.1 | Deleted - SEC1 Stage 2 (Enhanced HE control of security) |  | 378d | 2001-01-03 A | 2002-06-14 A | 100% | 2001-01-03 | 2002-06-14 | 378d | finish no earlier than 2002-06-14 | S3 | 3024h | 3024h | SEC1 | Rel-6 | Dionisio |  |  | SP-16 |
| 1389 | 14.1.3 | **Network domain security** |  | 334d | 2002-06-17 A | 2003-09-25 A | 100% | 2002-06-17 | 2003-09-25 | 334d |  | S3 | 5344h | 5344h | SEC1-NDS | Rel-6 | Dionisio | Geir-myrdahl.koien@telenor.com | Telenor |  |
| 1390 | 14.1.3.1 | IP network layer security (NDS/IP) |  | 334d | 2002-06-17 A | 2003-09-25 A | 100% | 2002-06-17 | 2003-09-25 | 334d | finish no earlier than 2003-09-25 | S3 | 2672h | 2672h | SEC1-NDS-IP | Rel-6 | Dionisio |  |  |  |
| 1391 | 452.2 | Network Domain Security; Authentication Framework (NDS/AF) |  | 521d? | 2002-02-15 A | 2004-02-13 A | 100% | 2002-02-15 | 2004-02-13 | 521d? | finish no earlier than 2004-02-13 | S3 | 4168h | 4168h | SEC1-NDS-AF | Rel-6 | Dionisio | tommi.viitanen@nokia.com | Nokia |  |
| 1392 | 452.3 | Key Management of group keys for Voice Group Call Services |  | 306d | 2003-09-26 A | 2004-11-26 A | 100% | 2003-09-26 | 2004-11-26 | 306d | finish no earlier than 2004-11-26 | S3 | 2448h | 2448h | SECGKYV | Rel-6 | Dionisio | benno.tietz@vodafone.com | Vodafone |  |
| 1393 | 16 | **IMS Phase 2** |  | 1395d? | 2000-08-28 A | 2005-12-30 A | 100% | 2000-08-28 | 2005-12-30 | 1395d? |  | S1,S2,S3,S5,NP | 130248h | 130248h | IMS2 | Rel-6 | Alain |  |  |  |
| 1394 | 453.1 | Enhancements to the Cx and Sh interfaces |  | 323d? | 2003-06-06 A | 2004-08-31 A | 100% | 2003-06-06 | 2004-08-31 | 323d? | finish no earlier than 2004-08-31 | N4 | 2584h | 2584h | IMS2-CCR | Rel-6 | Kimmo |  |  |  |
| 1395 | 16.12 | **IMS Group Management** |  | 715d? | 2002-03-14 A | 2004-12-08 A | 100% | 2002-03-14 | 2004-12-08 | 715d? |  | S1 | 12680h | 12680h | IMSGM | Rel-6 | Alain | juha.kalliokulju@nokia.com | Nokia |  |
| 1396 | 16.12.1 | Stage 1 - TS on IMS group management |  | 193d | 2002-03-14 A | 2002-12-09 A | 100% | 2002-03-14 | 2002-12-09 | 193d | finish no earlier than 2002-12-09 | S1 | 1544h | 1544h | IMSGM | Rel-6 | Alain | juha.kalliokulju@nokia.com | Nokia |  |
| 1397 | 453.2.2 | Stage 2 |  | 158d? | 2003-05-26 A | 2003-12-31 A | 100% | 2003-05-26 | 2003-12-31 | 158d? | finish no earlier than 2003-12-31 | S2 | 1264h | 1264h | IMSGM | Rel-6 | Maurice |  |  |  |
| 1398 | 453.2.3 | Stage 3 for IMS Group management (e.g. chat) |  | 519d? | 2002-12-13 A | 2004-12-08 A | 100% | 2002-12-13 | 2004-12-08 | 519d? | finish no earlier than 2004-12-08 | N1 | 4152h | 4152h | IMSGM | Rel-6 | Frederic | Keith Drage (drage@alcatel-lucent.com) | Lucent |  |

Notes:
- 1373: -
- 1374: -
- 1375: Updated according to SP-040232
- 1376: -
- 1377: -
- 1378: 31/10/2003 work has started. Current stage 3 fullfills the requirements of stage 2. ......
- 1379: Updated according to SP-040232
- 1380: -
- 1381: - / Text3: 25.305, 25.401, 25.450, 25.452, 25.453
- 1382: Finished at RP#25 / Text3: 25.171
- 1383: -
- 1384: building block without particular end date
- 1385: SP#26 12/2004 completed / Text3: 32.271
- 1386: Added BB UE authentication and rapporteur added.
- 1387: Added by SP-000575 without any dates. 18/10/00: Change of WI title, added hyperlink rapporteur new end date 03/01. New end date and correct Release to be decided S3#18
- 1388: New end date and correct Release to be decided S3#18. Marked as stopped 12/2008
- 1389: WID approved for Rel-6 at SP#17. Completed 2004-12
- 1390: Should be complete after SA3#27. Completed 2004-12 / Text3: 33.210
- 1391: WID approved SP#19. Work started after FS approved SP#18
- 1392: Approved TSG#21. Completed 2004-12 / Text3: 42.068, 43.068, 44.068, 42.069, 43.069, 44.069, 31.102, 24.008, 48.008, 42.009, 43.020
- 1393: Not yet available: verbally approved at SA15, actual WID to be provided at SA16 by Lucent / Text3: 23.228
- 1394: Shared public user identities need to be solved. If email approval CR is accepted. Work 100% done....
- 1395: -
- 1396: -
- 1397: -
- 1398: Depends on CN decision on CPCP in Rel-6. Complete, if unresolved IETF dependencies are dropped (-> LS to CN plenary)

| ID | WBS | Task | Type | Duration | Start | Finish | Complete | Baseline start | Baseline finish | Baseline duration | Constraint | Resources | Work | Actual work | Text6 | Text8 | Text4 | Text5 | Text1 | Text3 | Text12 |
| --- | --- | --- | --- | --- | --- | --- | --- | --- | --- | --- | --- | --- | --- | --- | --- | --- | --- | --- | --- | --- | --- |
| 1399 | 453.3 | **IMS Conferencing** |  | 548d? | 2002-11-04 A | 2004-12-08 A | 100% | 2002-11-04 | 2004-12-08 | 548d? |  | N1 | 10960h | 10960h | Rel-6 | Frederic |  |  |  |  |  |
| 1400 | 453.3.1 | Stage 2 |  | 303d? | 2002-11-04 A | 2003-12-31 A | 100% | 2002-11-04 | 2003-12-31 | 303d? | finish no earlier than 2003-12-31 | S2 | 2424h | 2424h | Rel-6 | Maurice |  |  |  |  |  |
| 1401 | 453.3.2 | Stage 3 |  | 519d? | 2002-12-13 A | 2004-12-08 A | 100% | 2002-12-13 | 2004-12-08 | 519d? | finish no earlier than 2004-12-08 | N1 | 4152h | 4152h | Rel-6 | Frederic | Lucent | Keith Drage (drage@alcatel-lucent.com) |  |  |  |
| 1402 | 16.11 | **IMS Messaging** |  | 992d? | 2002-03-14 A | 2005-12-30 A | 100% | 2002-03-14 | 2005-12-30 | 992d? |  | S1 | 23912h | 23912h | Rel-6 | Alain | Nokia | juha.kalliokulju@nokia.com | IMSM |  |  |
| 1403 | 16.11.1 | TR on support of messaging in the IMS |  | 193d | 2002-03-14 A | 2002-12-09 A | 100% | 2002-03-14 | 2002-12-09 | 193d | finish no earlier than 2002-12-09 | S1 | 1544h | 1544h | Rel-6 | Alain | Nokia | juha.kalliokulju@nokia.com | IMSM-TR |  |  |
| 1404 | 453.4.2 | Stage 1 22.340 |  | 23d? | 2002-11-11 A | 2002-12-11 A | 100% | 2002-11-11 | 2002-12-11 | 23d? | finish no earlier than 2002-12-11 | S1 | 184h | 184h | Rel-6 | Alain | Nokia | juha.kalliokulju@nokia.com | IMSM-TS | 22.340 |  |
| 1405 | 453.4.3 | CRs to 22.140 & 22.228 |  | 263d? | 2002-03-14 A | 2003-03-17 A | 100% | 2002-03-14 | 2003-03-17 | 263d? | finish no earlier than 2003-03-17 | S1 | 2104h | 2104h | Rel-6 | Alain | Nokia | juha.kalliokulju@nokia.com | IMSM-CR | 22.140,22.228 |  |
| 1406 | 16.11.3 | Stage 2 |  | 477d | 2002-11-04 A | 2004-08-31 A | 100% | 2002-11-04 | 2004-08-31 | 477d | finish no earlier than 2004-08-31 | S2 | 3816h | 3816h | Rel-6 | Maurice |  |  |  |  |  |
| 1407 | 453.4.5 | Stage 3 for IMS Messaging |  | 519d? | 2002-12-13 A | 2004-12-08 A | 100% | 2002-12-13 | 2004-12-08 | 519d? | finish no earlier than 2004-12-08 | N1 | 4152h | 4152h | Rel-6 | Frederic | Lucent | Keith Drage (drage@alcatel-lucent.com) |  |  |  |
| 1408 | 453.4.6 | SIP/SIMPLE Instant messaging |  | 522d? | 2004-01-01 A | 2005-12-30 A | 100% | 2004-01-01 | 2005-12-30 | 522d? | finish no earlier than 2005-06-30 | OMA | 4176h | 4176h | Rel-6 |  |  | OMA-LIAISON@mail.openmobilealliance.org |  |  |  |
| 1409 | 453.5 | **Additional SIP Capabilities support not covered by Rel-5** |  | 680d? | 2002-11-11 A | 2005-06-17 A | 100% | 2002-11-11 | 2005-06-17 | 680d? |  | N1 | 13392h | 13392h | Rel-6 | Frederic |  |  |  |  |  |
| 1410 | 453.5.1 | Stage 2 for add SIP cap (e.g. forking) |  | 335d? | 2002-11-11 A | 2004-02-20 A | 100% | 2002-11-11 | 2004-02-20 | 335d? | finish no earlier than 2004-02-20 | S2 | 2680h | 2680h | Rel-6 | Maurice |  |  |  |  |  |
| 1411 | 453.5.2 | Stage 3 for Additional SIP Capabilities |  | 454d? | 2002-12-13 A | 2004-09-08 A | 100% | 2002-12-13 | 2004-09-08 | 454d? | finish no earlier than 2004-09-08 | N1 | 3632h | 3632h | Rel-6 | Frederic | Lucent | Keith Drage (drage@alcatel-lucent.com) |  |  |  |
| 1412 | 453.5.3 | Procedured associated with IMS-ALG |  | 205d? | 2004-09-06 A | 2005-06-17 A | 100% | 2004-09-06 | 2005-06-17 | 205d? | start no earlier than 2004-09-06 | N1 | 1640h | 1640h | Rel-6 | Frederic |  |  |  |  |  |
| 1413 | 453.6 | Review additional SIP Capabilities against IMS |  | 454d? | 2002-12-13 A | 2004-09-08 A | 100% | 2002-12-13 | 2004-09-08 | 454d? | finish no earlier than 2004-09-08 | N1 | 3632h | 3632h | Rel-6 | Frederic | Lucent | Keith Drage (drage@alcatel-lucent.com) |  |  |  |
| 1414 | 16.5 | **Interworking between IMS and IP networks** |  | 1118d? | 2000-08-28 A | 2004-12-08 A | 100% | 2000-08-28 | 2004-12-08 | 1118d? |  | N3 | 31712h | 31712h | Rel-6 | Gwiho | BT | nigel.holland@bt.com | IMS-CCR-IWIP | 23.821, 29.061, 29.162 |  |
| 1415 | 16.5.1 | Interworking for 3GPP_SIP and IETF_SIP |  | 730d | 2000-08-28 A | 2003-06-13 A | 100% | 2000-08-28 | 2003-06-13 | 730d | finish no earlier than 2003-06-13 | N3 | 5840h | 5840h | Rel-6 | Gwiho | Siemens | Thomas.Belling@nsn.com |  | New 29.962 |  |
| 1416 | 16.5.2 | Interworking for IPv6 to IPv4 |  | 1118d | 2000-08-28 A | 2004-12-08 A | 100% | 2000-08-28 | 2004-12-08 | 1118d | finish no earlier than 2004-12-08 | N3 | 8944h | 8944h | Rel-6 | Gwiho |  |  |  | 29.163 |  |
| 1417 | 453.7.3 | Interworking for IPv6 to IPv4 (SIP / SDP aspects) |  | 87d? | 2004-05-11 A | 2004-09-08 A | 100% | 2004-05-11 | 2004-09-08 | 87d? | finish no earlier than 2004-09-08 | N1 | 696h | 696h | Rel-6 | Frederic |  |  |  |  |  |
| 1418 | 16.8.1 | stage 3 of interworking with non-IMS IP networks |  | 911d | 2001-03-14 A | 2004-09-08 A | 100% | 2001-03-14 | 2004-09-08 | 911d | finish no earlier than 2004-09-08 | N1 | 7288h | 7288h | Rel-6 | Frederic |  |  |  |  |  |
| 1419 | 16.6.1 | Interworking between IMS and CS networks |  | 929d? | 2000-08-28 A | 2004-03-18 A | 100% | 2000-08-28 | 2004-03-18 | 929d? | finish no earlier than 2004-03-18 | N3 | 7432h | 7432h | Rel-6 | Gwiho | Vodafone | Brendan.McWilliams@gb.vodafone.co.uk | IMS-CCR-IWCS | 29.163, 29.061, 24.228, and new CN4 specification |  |
| 1420 | 16.10 | Mn interface (IM-MGW to MGCF) enhancements (CN4 Part) |  | 418d | 2001-08-07 A | 2004-09-01 A | 100% | 2001-08-07 | 2004-09-01 | 418d | finish no earlier than 2004-09-01 | N4 | 3344h | 3344h | Rel-6 | Kimmo |  |  | IMS-CCR-Mn |  |  |
| 1421 | 453.10 | Study of subscriber and operators relationship in IMS and related ISIM requirements for Rel 6” |  | 20d? | 2002-11-15 A | 2002-12-12 A | 100% | 2002-11-15 | 2002-12-12 | 20d? | finish no earlier than 2002-12-12 | S1 | 160h | 160h | Rel-6 | Alain | Nokia | juha.kalliokulju@nokia.com |  |  |  |
| 1422 | 453.11 | Lawful Interception in the 3GPP Rel-6 architecture |  | 269d? | 2002-12-09 A | 2003-12-18 A | 100% | 2002-12-09 | 2003-12-18 | 269d? | finish no earlier than 2003-12-18 | S3 | 2152h | 2152h | Rel-6 | Dionisio | Reg TP | berthold.wilhelm@regtp.de | SEC1-LI | 33.106, 33.107, 33.108 |  |
| 1423 | 453.12 | IMS Subscription and access scenarios |  | 130d? | 2002-12-16 A | 2003-06-13 A | 100% | 2002-12-16 | 2003-06-13 | 130d? | start no earlier than 2002-12-16 | S1 | 1040h | 1040h | Rel-6 | Alain |  |  |  | 22.800 |  |
| 1424 | 453.13 | IMS charging |  | 455d? | 2003-03-21 A | 2004-12-16 A | 100% | 2003-03-21 | 2004-12-16 | 455d? | finish no earlier than 2004-12-16 | S5 | 3640h | 3640h | Rel-6 | Dionisio | Ericsson | Patrik TEPPO | IMS2-CH | 32.260 |  |
| 1425 | 453.14 | IMS Management objects |  | 306d? | 2004-09-03 A | 2005-11-04 A | 100% | 2004-09-03 | 2005-11-04 | 306d? | finish no earlier than 2005-03-04 | N1 | 2448h | 2448h | Rel-6 | Frederic |  |  |  | 24.167 |  |
| 1426 | 453.15 | Deleted - Stage 2 of IMS Phase 2 | milestone | 0d? | 2003-09-19 A | 2003-09-19 A | 100% | 2003-09-19 | 2003-09-19 | 0d? | finish no earlier than 2003-09-19 | S2 |  |  | Rel-6 | Maurice |  |  | IMS2 |  | SP-21 |

Notes:
- 1399: -
- 1400: -
- 1401: Depends on CN decision on IETF dependencies in Rel-6. Higher figure if CPCP is dropped (-> LS to CN plenary)
- 1402: -
- 1403: -
- 1404: -
- 1405: -
- 1406: -
- 1407: -
- 1408: Updated according to SP-040232
- 1409: -
- 1410: -
- 1411: -
- 1412: -
- 1413: -
- 1414: [DAB 14.02.02] - end date pushed back to March 2003
- 1415: [DAB - 20.08.03] - CN Part of TR Complete @ CN#20
- 1416: -
- 1417: -
- 1418: -
- 1419: [DAB - 25.05.04] - CN3 consider this work to be complete
- 1420: TISPAN issue is open
- 1421: -
- 1422: -
- 1423: -
- 1424: SP#26 12/2004 completed
- 1425: -
- 1426: -

| ID | WBS | Task | Type | Duration | Start | Finish | Complete | Baseline start | Baseline finish | Baseline duration | Constraint | Resources | Work | Actual work | Text1 | Text4 | Text5 | Text6 | Text8 | Text3 | Text10 | Text12 |
| --- | --- | --- | --- | --- | --- | --- | --- | --- | --- | --- | --- | --- | --- | --- | --- | --- | --- | --- | --- | --- | --- | --- |
| 1427 | 454 | **3GPP Enablers for services like Push to Talk over Cellular (PoC)** |  | 459d? | 2003-09-08 A | 2005-06-09 A | 100% | 2003-09-08 | 2005-06-09 | 459d? |  | S2,S4,S5 | 10696h | 10696h | PoC | Ericsson | Shabnam Sultana | Rel-6 | Maurice |  |  |  |
| 1428 | 454.1 | Feasibility Study |  | 322d? | 2003-09-08 A | 2004-11-30 A | 100% | 2003-09-08 | 2004-11-30 | 322d? | finish no earlier than 2004-11-30 | S2 | 2576h | 2576h | PoC | Ericsson | Shabnam Sultana | Rel-6 | Maurice | 23.979 | SP-24 |  |
| 1429 | 454.2 | Dependencies on OMA PoC |  | 303d? | 2004-01-01 A | 2005-02-28 A | 100% | 2004-01-01 | 2005-02-28 | 303d? | finish no earlier than 2004-12-30 | OMA | 2424h | 2424h | PoC |  | OMA-LIAISON@mail.openmobilealliance.org | Rel-6 |  |  | SP-24 |  |
| 1430 | 454.3 | Selection of one or more PoC codec(s) for PoC |  | 69d? | 2004-09-13 A | 2004-12-16 A | 100% | 2004-09-13 | 2004-12-16 | 69d? | start no earlier than 2004-09-13 | S4 | 552h | 552h | PoC |  |  | Rel-6 | Paolo | 26.235, 26.236 | SP-25 |  |
| 1431 | 454.4 | PoC charging |  | 184d? | 2004-09-27 A | 2005-06-09 A | 100% | 2004-09-27 | 2005-06-09 | 184d? | finish no earlier than 2005-06-09 | S5 | 1472h | 1472h | PoC-CH | Siemens | Gerald GÖRMER | Rel-6 | Dionisio | 32.272 |  |  |
| 1432 | 455 | Study on Interworking aspects and migration scenarios for IPv4 based IMS Implementations |  | 210d? | 2003-09-08 A | 2004-06-25 A | 100% | 2003-09-08 | 2004-06-25 | 210d? | finish no earlier than 2004-06-25 | S2 | 1680h | 1680h | IPv4IMS | Siemens | Alexander Milinski | Rel-6 | Maurice | 23.981 |  |  |
| 1433 | 16.3 | **Interoperability and Commonality between IMS using different IP-connectivity Networks** |  | 325d? | 2002-09-16 A | 2003-12-12 A | 100% | 2002-09-16 | 2003-12-12 | 325d? |  | S2 | 9176h | 9176h | IMSCOOP |  |  | Rel-6 | Maurice | 23.864 |  |  |
| 1434 | 16.3.1 | Stage 2 for Interoperability |  | 272d | 2002-09-16 A | 2003-09-30 A | 100% | 2002-09-16 | 2003-09-30 | 272d | finish no earlier than 2003-09-30 | S2 | 2176h | 2176h | IMSCOOP | Nokia | balazs.bertenyi@nsn.com | Rel-6 | Maurice | 23.864 |  |  |
| 1435 | 456.2 | Stage 2 for commonality |  | 265d? | 2002-09-16 A | 2003-09-19 A | 100% | 2002-09-16 | 2003-09-19 | 265d? | start no earlier than 2002-09-16 | S2 | 2120h | 2120h | IMSCOOP | Nokia | balazs.bertenyi@nsn.com | Rel-6 | Maurice | 23.864 |  |  |
| 1436 | 16.3.2 | Stage 3 |  | 305d | 2002-10-14 A | 2003-12-12 A | 100% | 2002-10-14 | 2003-12-12 | 305d | finish no earlier than 2003-12-12 | N1 | 2440h | 2440h | IMSCOOP | Lucent | Keith Drage (drage@alcatel-lucent.com) | Rel-6 | Frederic |  |  |  |
| 1437 | 17 | **Support of Push Services** |  | 823d | 2001-01-03 A | 2004-02-27 A | 100% | 2001-01-03 | 2004-02-27 | 823d |  | S1 | 11390.6h | 11390.6h | PUSH | NTT Comware | Yoshinori Kitada | Rel-6 | Alain | 23.976 |  |  |
| 1438 | 17.1 | Stage 1 |  | 378d | 2001-01-03 A | 2002-06-14 A | 100% | 2001-01-03 | 2002-06-14 | 378d | finish no earlier than 2002-06-14 | S1 | 3024h | 3024h | PUSH |  |  | Rel-6 | Alain |  |  |  |
| 1439 | 17.3 | TR 23.976 on Push Architecture |  | 340d | 2002-11-11 A | 2004-02-27 A | 100% | 2002-11-11 | 2004-02-27 | 340d | finish no earlier than 2004-02-27 | S2 | 2720h | 2720h | PUSH | RIM | Nick Alfano | Rel-6 | Maurice | 23.976 |  |  |
| 1440 | 18 | **Multimedia Messaging (MMS) enhancements** |  | 865d? | 2002-08-15 A | 2005-12-07 A | 100% | 2002-08-15 | 2005-12-07 | 865d? |  | T2,S1,S4,S5,OMA | 31936h | 31936h | MMS6 | Siemens | Josef.Laumen@SAL.SIEMENS.DE | Rel-6 | Kimmo |  |  |  |
| 1441 | 18.1 | **Definition of service requirements** |  | 286d? | 2002-11-15 A | 2003-12-19 A | 100% | 2002-11-15 | 2003-12-19 | 286d? |  | S1 | 4576h | 4576h | MMS6-SR |  |  | Rel-6 | Alain | 22.140 |  |  |
| 1442 | 458.1.1 | Definition of service requirements charging |  | 286d? | 2002-11-15 A | 2003-12-19 A | 100% | 2002-11-15 | 2003-12-19 | 286d? | finish no earlier than 2003-12-20 | S1 | 2288h | 2288h | MMS6-SR | Siemens | Josef.Laumen@SAL.SIEMENS.DE | Rel-6 | Alain | 22.140 |  |  |
| 1443 | 18.2 | Technical realization |  | 591d | 2002-09-06 A | 2004-12-10 A | 100% | 2002-09-06 | 2004-12-10 | 591d | finish no earlier than 2004-12-10 | T2 | 4728h | 4728h | MMS6 | Siemens | Josef.Laumen@SAL.SIEMENS.DE | Rel-6 | Kimmo | 23.140 |  |  |
| 1444 | 18.3 | OMA dependencies |  | 446d | 2003-08-15 A | 2005-04-29 A | 100% | 2003-08-15 | 2005-04-29 | 446d | finish no earlier than 2004-12-10 | OMA | 3568h | 3568h | MMS6 |  |  | Rel-6 | Kimmo | OMA specs |  |  |
| 1445 | 18.4 | MMS formats and codecs |  | 865d | 2002-08-15 A | 2005-12-07 A | 100% | 2002-08-15 | 2005-12-07 | 865d | finish no earlier than 2005-12-07 | S4 | 6920h | 6920h | MMS6-Codec | Nokia | roberto.castagno@nokia.com | Rel-6 | Paolo | 26.140, 26.936 |  |  |
| 1446 | 458.5 | Handling of private addressing schemes in MMS |  | 263d | 2003-12-10 A | 2004-12-10 A | 100% | 2003-12-10 | 2004-12-10 | 263d | finish no earlier than 2004-12-10 | T2 | 2104h | 2104h | MMS6 | T-Mobile | Steffen.Habermann@T-MOBILE.DE | Rel-6 | Kimmo | 23.140 |  |  |
| 1447 | 458.6 | MMS charging |  | 390d? | 2003-03-21 A | 2004-09-16 A | 100% | 2003-03-21 | 2004-09-16 | 390d? | start no earlier than 2003-03-21 | S5 | 3120h | 3120h | MMS6-CH |  |  | Rel-6 | Dionisio | 32.270 |  |  |
| 1448 | 458.7 | Deleted - FS Multiple MMS Relay/Server Architecture | milestone | 0d | 2004-12-10 A | 2004-12-10 A | 100% | 2004-12-10 | 2004-12-10 | 0d | finish no earlier than 2004-12-10 | T2 |  |  | MMS6 | Telefónica Móviles | Juan Gorospe (gorospe_j@tsm.es) | Rel-6 | Kimmo | probably Annex to 23.140 |  | TP-26 |
| 1449 | 19 | **Rel-6 MExE enhancements** |  | 326d | 2002-03-08 A | 2003-06-06 A | 100% | 2002-03-08 | 2003-06-06 | 326d |  | T2 | 7328h | 7328h | MEXE6 |  |  | Rel-6 | Kimmo |  |  |  |
| 1450 | 19.1 | MExE Rel-6 Improvements and Investigations |  | 264d | 2002-03-08 A | 2003-03-12 A | 100% | 2002-03-08 | 2003-03-12 | 264d | finish no earlier than 2003-03-12 | T2 | 2112h | 2112h | MEXE6-ENHANC | TTPCom | Lars Brenk ( (lsb_ttpcom@HOTMAIL.COM) | Rel-6 |  |  |  |  |
| 1451 | 19.2 | MExE Run-Time Independent Framework Feasibility Study |  | 326d | 2002-03-08 A | 2003-06-06 A | 100% | 2002-03-08 | 2003-06-06 | 326d | finish no earlier than 2003-06-06 | T2 | 2608h | 2608h | MEXE6-RTIF | Intel | Aaron.Cohen@intel.com | Rel-6 |  | 22.857 |  |  |
| 1452 | 21 | Subscription Management |  | 650d | 2002-09-20 A | 2005-03-17 A | 100% | 2002-09-20 | 2005-03-17 | 650d | finish no earlier than 2005-03-17 | S5 | 5200h | 5200h | SuM | T-Mobile | istvan.aba@t-mobile.at | Rel-6 | Dionisio | 32.140/1, 32.171/2/5, 32.803 |  |  |

Notes:
- 1427: -
- 1428: -
- 1429: Updated according to SP-040232
- 1430: Completed
- 1431: SP#28 06/2005 completed
- 1432: -
- 1433: -
- 1434: No contributions assumed that no more will be done in 3GPP hence work may need to be done in 3GPP2
- 1435: -
- 1436: -
- 1437: Changed from FS to actual support of Push
- 1438: -
- 1439: -
- 1440: -
- 1441: -
- 1442: -
- 1443: -
- 1444: -
- 1445: -
- 1446: -
- 1447: SP#25 09/2004 completed
- 1448: originally it was intended to create a FS TR but most likely the work will become an Annex of 23.140
- 1449: -
- 1450: -
- 1451: -
- 1452: SP#27 03/2005 completed

| ID | WBS | Task | Duration | Start | Finish | Complete | Baseline start | Baseline finish | Baseline duration | Constraint | Resources | Work | Actual work | Text1 | Text4 | Text5 | Text6 | Text8 | Text3 |
| --- | --- | --- | --- | --- | --- | --- | --- | --- | --- | --- | --- | --- | --- | --- | --- | --- | --- | --- | --- |
| 1453 | 22 | **Presence Capability** | 1233d? | 2001-03-19 A | 2005-12-07 A | 100% | 2001-03-19 | 2005-12-07 | 1233d? |  | S1 | 37112h | 37112h | PRESNC | Motorola | Mark Cataldo | Rel-6 | Alain |  |
| 1454 | 22.1 | Stage 1 | 610d | 2001-03-19 A | 2003-07-18 A | 100% | 2001-03-19 | 2003-07-18 | 610d | finish no earlier than 2003-07-18 | S1 | 4880h | 4880h | PRESNC |  |  | Rel-6 | Alain | 22.141 |
| 1455 | 22.2 | Stage 2 | 268d | 2001-09-12 A | 2002-09-20 A | 100% | 2001-09-12 | 2002-09-20 | 268d | finish no earlier than 2002-09-20 | S2 | 2144h | 2144h | PRESNC | Nokia | balazs.bertenyi@nsn.com | Rel-6 | Maurice |  |
| 1456 | 22.3 | Stage 3 | 703d | 2002-04-01 A | 2004-12-08 A | 100% | 2002-04-01 | 2004-12-08 | 703d | finish no earlier than 2004-12-08 | N1 | 5624h | 5624h | PRESNC | Lucent | Keith Drage (drage@alcatel-lucent.com) | Rel-6 | Frederic |  |
| 1457 | 461.4 | Stage 3 (CN3 Part Pk interface) | 770d? | 2002-04-01 A | 2005-03-11 A | 100% | 2002-04-01 | 2005-03-11 | 770d? | finish no earlier than 2005-03-11 | N3 | 6160h | 6160h | PRESNC |  |  | Rel-6 | Gwiho |  |
| 1458 | 461.5 | Media Codecs and Formats for IMS Messaging and Presence | 650d? | 2003-06-12 A | 2005-12-07 A | 100% | 2003-06-12 | 2005-12-07 | 650d? | finish no earlier than 2005-12-07 | S4 | 5200h | 5200h | PRESNC-COFIMP | Nokia | harri.honko@nokia.com | Rel-6 | Paolo | 26.141, 26.936 |
| 1459 | 22.4 | Security issues | 79d | 2002-08-26 A | 2002-12-12 A | 100% | 2002-08-26 | 2002-12-12 | 79d | finish no earlier than 2002-12-12 | S3 | 632h | 632h | PRESNC |  |  | Rel-6 | Dionisio |  |
| 1460 | 461.7 | SIMPLE Presence | 326d? | 2004-01-01 A | 2005-03-31 A | 100% | 2004-01-01 | 2005-03-31 | 326d? | finish no earlier than 2004-12-30 | OMA | 2608h | 2608h | PRESNC |  | OMA-LIAISON@mail.openmobilealliance.org | Rel-6 |  |  |
| 1461 | 25 | **Enhanced A/Gb feasibility study** | 51d? | 2002-08-30 A | 2002-11-08 A | 100% | 2002-08-30 | 2002-11-08 | 51d? |  | GP | 3264h | 3264h | AGbEnFS | Vodafone | jose-luis.carrizo@vodafone.co.uk | Rel-6 | Paolo | None |
| 1462 | 25.1 | **Feasibility study on A/Gb enhancements** | 51d? | 2002-08-30 A | 2002-11-08 A | 100% | 2002-08-30 | 2002-11-08 | 51d? |  | G2 | 2856h | 2856h | AGbEnFS-FS | Vodafone | jose-luis.carrizo@vodafone.co.uk | Rel-6 | Gert | None |
| 1463 | 25.1.1 | Requirements for the support of conversational services | 51d | 2002-08-30 A | 2002-11-08 A | 100% | 2002-08-30 | 2002-11-08 | 51d | finish no earlier than 2002-11-08 | GP | 408h | 408h | AGbEnFS-FS |  |  | Rel-6 | Paolo | None |
| 1464 | 462.1.2 | Identification of the different building blocks for the provision of conversational services on the existing A/Gb protocol stack | 51d? | 2002-08-30 A | 2002-11-08 A | 100% | 2002-08-30 | 2002-11-08 | 51d? | finish no earlier than 2002-11-08 | GP | 408h | 408h | AGbEnFS-FS |  |  | Rel-6 | Paolo | None |
| 1465 | 462.1.3 | Outline of impact and feasibility of these building blocks and their different solutions | 51d? | 2002-08-30 A | 2002-11-08 A | 100% | 2002-08-30 | 2002-11-08 | 51d? | finish no earlier than 2002-11-08 | GP | 408h | 408h | AGbEnFS-FS |  |  | Rel-6 | Paolo | None |
| 1466 | 25.1.4 | Impact on 3GPP architecture and requirement to co-ordinatge with other TSGs (CN, SA) | 51d | 2002-08-30 A | 2002-11-08 A | 100% | 2002-08-30 | 2002-11-08 | 51d | finish no earlier than 2002-11-08 | GP | 408h | 408h | AGbEnFS-FS |  |  | Rel-6 | Paolo | None |
| 1467 | 25.1.5 | Standardisation effort | 51d | 2002-08-30 A | 2002-11-08 A | 100% | 2002-08-30 | 2002-11-08 | 51d | finish no earlier than 2002-11-08 | GP | 408h | 408h | AGbEnFS-FS |  |  | Rel-6 | Paolo | None |
| 1468 | 25.1.6 | Dependency to other features | 51d | 2002-08-30 A | 2002-11-08 A | 100% | 2002-08-30 | 2002-11-08 | 51d | finish no earlier than 2002-11-08 | GP | 408h | 408h | AGbEnFS-FS |  |  | Rel-6 | Paolo | None |
| 1469 | 26 | **Flexible Layer One for GERAN** | 1171d | 2000-01-03 A | 2004-06-25 A | 100% | 2000-01-03 | 2004-06-25 | 1171d |  | GP | 71551h | 71551h | FLOGER | Nokia | benoist.sebire@nokia.com | Rel-6 | Paolo |  |
| 1470 | 26.1 | **Realisation of a Flexible Layer One** | 1126d | 2000-01-03 A | 2004-04-23 A | 100% | 2000-01-03 | 2004-04-23 | 1126d |  | GP | 42816h | 42816h | FLOGER-Real | Nokia | benoist.sebire@nokia.com | Rel-6 | Paolo |  |
| 1471 | 26.1.1 | Technical Report | 471d | 2002-04-19 A | 2004-02-06 A | 100% | 2002-04-19 | 2004-02-06 | 471d | finish no earlier than 2004-02-06 | GP | 3768h | 3768h | FLOGER-Real |  |  | Rel-6 | Paolo |  |
| 1472 | 26.1.2 | Architecture in 45.001 and 43.051 | 526d | 2002-04-19 A | 2004-04-23 A | 100% | 2002-04-19 | 2004-04-23 | 526d | finish no earlier than 2004-04-23 | G1 | 4208h | 4208h | FLOGER-Real |  |  | Rel-6 |  |  |
| 1473 | 26.1.3 | Multiplexing in 45.002 | 526d | 2002-04-19 A | 2004-04-23 A | 100% | 2002-04-19 | 2004-04-23 | 526d | finish no earlier than 2004-04-23 | G1 | 4208h | 4208h | FLOGER-Real |  |  | Rel-6 |  |  |
| 1474 | 26.1.4 | Channel Coding in 45.003 | 526d | 2002-04-19 A | 2004-04-23 A | 100% | 2002-04-19 | 2004-04-23 | 526d | finish no earlier than 2004-04-23 | G1 | 4208h | 4208h | FLOGER-Real |  |  | Rel-6 |  |  |
| 1475 | 26.1.5 | Performance Requirements in 45.005 | 1126d | 2000-01-03 A | 2004-04-23 A | 100% | 2000-01-03 | 2004-04-23 | 1126d | finish no earlier than 2004-04-23 | G1 | 9000h | 9000h | FLOGER-Real |  |  | Rel-6 |  |  |
| 1476 | 26.1.6 | Radio subsystem link control in 45.008 | 526d | 2002-04-19 A | 2004-04-23 A | 100% | 2002-04-19 | 2004-04-23 | 526d | finish no earlier than 2004-04-23 | G1 | 4208h | 4208h | FLOGER-Real |  |  | Rel-6 |  |  |
| 1477 | 26.1.7 | Requirements in 44.004 | 526d | 2002-04-19 A | 2004-04-23 A | 100% | 2002-04-19 | 2004-04-23 | 526d | finish no earlier than 2004-04-23 | G2 | 4208h | 4208h | FLOGER-Real |  |  | Rel-6 | Gert |  |

Notes:
- 1453: merged "Presence Service Enhancements" (UID31028, PRES1) to this feature as no answer was provided on why Presence and Presence Encmts had same target completion date
- 1454: -
- 1455: -
- 1456: Dependency to 2 IETF drafts, no known work at the moment
- 1457: No Contributions so far - only requires a little work
- 1458: -
- 1459: LSs handled in SA3. WID approved SP#17 Contribution at S3#25 & following e-mail discussion. Marked as closed 12/2008 (was marked 90% complete)
- 1460: Updated according to SP-040232
- 1461: -
- 1462: -
- 1463: -
- 1464: -
- 1465: -
- 1466: -
- 1467: -
- 1468: -
- 1469: -
- 1470: -
- 1471: -
- 1472: -
- 1473: -
- 1474: -
- 1475: -
- 1476: -
- 1477: -

| ID | WBS | Task | Type | Duration | Start | Finish | Complete | Baseline start | Baseline finish | Baseline duration | Constraint | Resources | Work | Actual work | Text1 | Text4 | Text5 | Text6 | Text8 | Text12 | Text3 |
| --- | --- | --- | --- | --- | --- | --- | --- | --- | --- | --- | --- | --- | --- | --- | --- | --- | --- | --- | --- | --- | --- |
| 1478 | 26.2 | **Signalling and protocol support for a Flexible Layer One** |  | 571d | 2002-04-19 A | 2004-06-25 A | 100% | 2002-04-19 | 2004-06-25 | 571d |  | G2 | 13704h | 13704h | FLOGER-SigPro | Nokia | benoist.sebire@nokia.com | Rel-6 | Gert |  |  |
| 1479 | 26.2.1 | Modifications to RLC/MAC in 44.060 and 44.160 |  | 571d | 2002-04-19 A | 2004-06-25 A | 100% | 2002-04-19 | 2004-06-25 | 571d | finish no earlier than 2004-06-25 | G2 | 4568h | 4568h | FLOGER-SigPro |  |  | Rel-6 | Gert |  |  |
| 1480 | 26.2.2 | Modifications to RRC in 44.118 and 44.018 |  | 571d | 2002-04-19 A | 2004-06-25 A | 100% | 2002-04-19 | 2004-06-25 | 571d | finish no earlier than 2004-06-25 | G2 | 4568h | 4568h | FLOGER-SigPro |  |  | Rel-6 | Gert |  |  |
| 1481 | 26.3 | **Security for a Flexible Layer One** |  | 356d | 2002-04-19 A | 2003-08-29 A | 100% | 2002-04-19 | 2003-08-29 | 356d |  | S3, G2 | 5663.03h | 5663.03h | FLOGER-SecFLO | Nokia | benoist.sebire@nokia.com | Rel-6 | Dionisio |  |  |
| 1482 | 26.3.1 | Ciphering in 44.160,44.118, 44.060 and 44.018 |  | 356d | 2002-04-19 A | 2003-08-29 A | 100% | 2002-04-19 | 2003-08-29 | 356d | finish no earlier than 2003-08-29 | S3, G2 | 2848h | 2848h | FLOGER-SecFLO |  |  | Rel-6 | Dionisio |  |  |
| 1483 | 26.4 | **Deleted - GERAN MS Conformance test for the Flexible Layer One - DELETE** |  | 0d | 2004-02-06 A | 2004-02-06 A | 100% | 2004-02-06 | 2004-02-06 | 0d |  | G4,G5 |  |  | FLOGER-Msconf | Nokia | benoist.sebire@nokia.com | Rel-6 | Paolo | GP-27 |  |
| 1484 | 26.4.1 | Deleted at TSG #27 - MS Test in 51.010 | milestone | 0d | 2004-02-06 A | 2004-02-06 A | 100% | 2004-02-06 | 2004-02-06 | 0d | finish no earlier than 2004-02-06 | G4,G5 |  |  | FLOGER-Msconf |  |  | Rel-6 | Paolo | GP-22 |  |
| 1485 | 26.5 | **Deleted - GERAN BTS Conformance test for the Flexible Layer One - DELETE** |  | 0d | 2004-02-06 A | 2004-02-06 A | 100% | 2004-02-06 | 2004-02-06 | 0d |  | G3new |  |  | FLOGER-BTSconf | Nokia | benoist.sebire@nokia.com | Rel-6 | Ingbert | GP-27 |  |
| 1486 | 26.5.1 | Deleted at TGS #27 - BTS Test in 51.021 - DELETE | milestone | 0d | 2004-02-06 A | 2004-02-06 A | 100% | 2004-02-06 | 2004-02-06 | 0d | finish no earlier than 2004-02-06 | G3new |  |  | FLOGER-BTSconf |  |  | Rel-6 | Ingbert | GP-22 |  |
| 1487 | 27 | Uplink TDOA feasibility study |  | 151d | 2001-11-30 A | 2002-06-28 A | 100% | 2001-11-30 | 2002-06-28 | 151d | finish no earlier than 2002-06-28 | GP | 1208h | 1208h | TDOAF | TruePosition | Bob Gross (rlgross@trueposition.com) | Rel-6 | Paolo |  | 45.811 |
| 1488 | 28 | **Multimedia Broadcast and Multicast Service** |  | 1781d? | 2001-05-11 A | 2008-03-07 A | 100% | 2001-05-11 | 2008-03-07 | 1781d? |  | S1,S2,S4,S5,T1,RP,GP | 158712h | 158712h | MBMS |  |  | Rel-6 | Alain |  |  |
| 1489 | 28.1 | Stage 1 |  | 232d | 2001-05-11 A | 2002-04-01 A | 100% | 2001-05-11 | 2002-04-01 | 232d | finish no earlier than 2002-04-01 | S1 | 1856h | 1856h | MBMS |  |  | Rel-6 | Alain |  | 22.146, 22.101 |
| 1490 | 28.2 | **Stage 2** |  | 648d | 2001-09-24 A | 2004-03-17 A | 100% | 2001-09-24 | 2004-03-17 | 648d |  | S2 | 10408h | 10408h | MBMS |  |  | Rel-6 | Maurice |  |  |
| 1491 | 28.2.1 | TR on Architectural Study |  | 240d | 2001-09-24 A | 2002-08-23 A | 100% | 2001-09-24 | 2002-08-23 | 240d | finish no earlier than 2002-08-23 | S2 | 1920h | 1920h | MBMS |  |  | Rel-6 | Maurice |  | 23.846 |
| 1492 | 28.2.2 | Stage 2 Specification Work |  | 413d | 2002-08-19 A | 2004-03-17 A | 100% | 2002-08-19 | 2004-03-17 | 413d | finish no earlier than 2004-03-17 | S2 | 3304h | 3304h | MBMS |  |  | Rel-6 | Maurice |  | 23.246 |
| 1493 | 28.3 | **Introduction of MBMS in RAN** |  | 967d? | 2002-01-01 A | 2005-09-14 A | 100% | 2002-01-01 | 2005-09-14 | 967d? |  | R2 | 15992h | 15992h | MBMS-RAN | Nokia | juho.pirskanen@nokia.com | Rel-6 | Joern |  | 25.346, 25.304, 25.321, 25.322, 25.323, 25.331 |
| 1494 | 465.3.1 | Introduction of MBMS in RAN (physical & upper layers, access network interfaces) |  | 771d? | 2002-01-01 A | 2004-12-14 A | 100% | 2002-01-01 | 2004-12-14 | 771d? | finish no earlier than 2004-12-14 | R2 | 6168h | 6168h | MBMS-RAN | Nokia | juho.pirskanen@nokia.com | Rel-6 | Joern |  | 25.346, 25.304, 25.321, 25.322, 25.323 |
| 1495 | 465.3.2 | UE Performance Requirements for MBMS |  | 261d? | 2004-09-15 A | 2005-09-14 A | 100% | 2004-09-15 | 2005-09-14 | 261d? | finish no earlier than 2005-09-15 | R4 | 2088h | 2088h | MBMS-RAN-RF | Ericsson | Torgny.Palenius@ericsson.com | Rel-6 | Issam |  | 25.101, 25.133 |
| 1496 | 28.4 | Support of the MBMS in CN protocols |  | 647d | 2002-06-18 A | 2004-12-08 A | 100% | 2002-06-18 | 2004-12-08 | 647d | finish no earlier than 2004-12-08 | N1 | 5176h | 5176h | MBMS |  |  | Rel-6 | Frederic |  |  |
| 1497 | 465.5 | Gmb interface for MBMS (CN3 part) |  | 334d | 2003-08-29 A | 2004-12-08 A | 100% | 2003-08-29 | 2004-12-08 | 334d | finish no earlier than 2004-12-08 | N3 | 2672h | 2672h | MBMS |  |  | Rel-6 | Gwiho |  | 29.061 |
| 1498 | 28.5 | Security Aspects of MBMS |  | 710d | 2002-07-01 A | 2005-03-18 A | 100% | 2002-07-01 | 2005-03-18 | 710d | finish no earlier than 2005-03-18 | S3 | 5680h | 5680h | MBMS |  | adrian.escott@three.co.uk | Rel-6 | Dionisio |  |  |
| 1499 | 28.6 | **Support of MBMS in GERAN** |  | 892d? | 2001-08-30 A | 2005-01-28 A | 100% | 2001-08-30 | 2005-01-28 | 892d? |  | GP | 71040h | 71040h | MBMS-GERAN |  |  | Rel-6 | Paolo |  |  |
| 1500 | 28.6.1 | Impact on the logical and physical channels |  | 631d | 2002-08-30 A | 2005-01-28 A | 100% | 2002-08-30 | 2005-01-28 | 631d | finish no earlier than 2005-01-28 | GP | 5048h | 5048h | MBMS-GERAN |  |  | Rel-6 | Paolo |  |  |
| 1501 | 28.6.4 | Re-synchronisation at cell change |  | 631d | 2002-08-30 A | 2005-01-28 A | 100% | 2002-08-30 | 2005-01-28 | 631d | finish no earlier than 2005-01-28 | G2 | 5048h | 5048h | MBMS-GERAN |  |  | Rel-6 | Gert |  |  |
| 1502 | 465.7.3 | Simultaneous support of MBMS services |  | 631d? | 2002-08-30 A | 2005-01-28 A | 100% | 2002-08-30 | 2005-01-28 | 631d? | finish no earlier than 2005-01-28 | GP | 5048h | 5048h | MBMS-GERAN |  |  | Rel-6 | Paolo |  |  |
| 1503 | 465.7.4 | Simultaneous support of MBMS and non-MBMS services |  | 892d? | 2001-08-30 A | 2005-01-28 A | 100% | 2001-08-30 | 2005-01-28 | 892d? | finish no earlier than 2005-01-28 | GP | 7136h | 7136h | MBMS-GERAN |  |  | Rel-6 | Paolo |  |  |
| 1504 | 465.7.5 | Resynchronisation at cell change |  | 892d? | 2001-08-30 A | 2005-01-28 A | 100% | 2001-08-30 | 2005-01-28 | 892d? | finish no earlier than 2005-01-28 | GP | 7136h | 7136h | MBMS-GERAN |  |  | Rel-6 | Paolo |  |  |
| 1505 | 28.6.5 | Decision making process between point-to-point or pont-to-multipoint configurations |  | 631d | 2002-08-30 A | 2005-01-28 A | 100% | 2002-08-30 | 2005-01-28 | 631d | finish no earlier than 2005-01-28 | GP | 5048h | 5048h | MBMS-GERAN |  |  | Rel-6 | Paolo |  |  |
| 1506 | 28.6.6 | MBMS channel allocations procedures to multiple MSs |  | 631d | 2002-08-30 A | 2005-01-28 A | 100% | 2002-08-30 | 2005-01-28 | 631d | finish no earlier than 2005-01-28 | GP | 5048h | 5048h | MBMS-GERAN |  |  | Rel-6 | Paolo |  |  |
| 1507 | 28.6.7 | Changes to the Gb interface |  | 631d | 2002-08-30 A | 2005-01-28 A | 100% | 2002-08-30 | 2005-01-28 | 631d | finish no earlier than 2005-01-28 | GP | 5048h | 5048h | MBMS-GERAN |  |  | Rel-6 | Paolo |  |  |
| 1508 | 28.6.8 | GERAN specific changes to the Iu-ps interface |  | 631d | 2002-08-30 A | 2005-01-28 A | 100% | 2002-08-30 | 2005-01-28 | 631d | finish no earlier than 2005-01-28 | GP | 5048h | 5048h | MBMS-GERAN |  |  | Rel-6 | Paolo |  |  |
| 1509 | 28.6.9 | Interaction between MBMS and Iu-flex |  | 631d | 2002-08-30 A | 2005-01-28 A | 100% | 2002-08-30 | 2005-01-28 | 631d | finish no earlier than 2005-01-28 | GP | 5048h | 5048h | MBMS-GERAN |  |  | Rel-6 | Paolo |  |  |
| 1510 | 28.6.10 | Security aspects |  | 631d | 2002-08-30 A | 2005-01-28 A | 100% | 2002-08-30 | 2005-01-28 | 631d | finish no earlier than 2005-01-28 | GP | 5048h | 5048h | MBMS-GERAN |  |  | Rel-6 | Paolo |  |  |
| 1511 | 465.7.12 | MBMS-GERAN - MS conformance tests |  | 786d? | 2002-01-25 A | 2005-01-28 A | 100% | 2002-01-25 | 2005-01-28 | 786d? | finish no earlier than 2005-01-28 | G3new | 6288h | 6288h | MBMS-GERAN |  |  | Rel-6 | Ingbert |  |  |
| 1512 | 465.7.13 | Deleted - MS conformance tests - G5 | milestone | 0d? | 2003-06-27 A | 2003-06-27 A | 100% | 2003-06-27 | 2003-06-27 | 0d? | start no earlier than 2003-06-27 | G5 |  |  | MBMS-GERAN |  |  | Rel-6 | Paolo | GP-19 |  |

Notes:
- 1478: -
- 1479: -
- 1480: -
- 1481: -
- 1482: -
- 1483: -
- 1484: -
- 1485: -
- 1486: -
- 1487: -
- 1488: Title renamed at SP#13
- 1489: This may or may not be a separate stage 1. In the meantime, CRs are proposed for 22.101
- 1490: -
- 1491: -
- 1492: -
- 1493: -
- 1494: Was "Introduction of MBMS in RAN" before RP#25. Created w/o WIDS after RAN approved the WT for RF aspects.Take WIDS from the parent BB
- 1495: Approved at RP#25 as RP-040370
- 1496: -
- 1497: -
- 1498: WID approved SP#17. 2004-12: Expected completion March 2005
- 1499: -
- 1500: -
- 1501: -
- 1502: -
- 1503: -
- 1504: -
- 1505: -
- 1506: -
- 1507: -
- 1508: -
- 1509: -
- 1510: -
- 1511: -
- 1512: -

| ID | WBS | Task | Type | Duration | Start | Finish | Complete | Baseline start | Baseline finish | Baseline duration | Constraint | Deadline | Resources | Work | Actual work | Text1 | Text6 | Text8 | Text4 | Text5 | Text10 | Text12 |
| --- | --- | --- | --- | --- | --- | --- | --- | --- | --- | --- | --- | --- | --- | --- | --- | --- | --- | --- | --- | --- | --- | --- |
| 1513 | 28.1 | **MBMS User Services** |  | 743d? | 2003-05-13 A | 2006-03-16 A | 100% | 2003-05-13 | 2006-03-16 | 743d? |  |  | S1 | 13576h | 13576h | MBMS | Rel-6 | Alain |  |  |  |  |
| 1514 | 28.1 | MBMS User Services Stage 1 |  | 233d | 2003-05-13 A | 2004-04-01 A | 100% | 2003-05-13 | 2004-04-01 | 233d | start no earlier than 2003-05-13 |  | S1 | 1864h | 1864h | MBMS | Rel-6 | Alain |  |  |  |  |
| 1515 | 465.8.2 | Definition of MBMS user services, media codecs, formats and transport/application protocols using MBMS |  | 721d? | 2003-06-12 A | 2006-03-16 A | 100% | 2003-06-12 | 2006-03-16 | 721d? | finish no earlier than 2006-03-16 |  | S4 | 5768h | 5768h | MBMS-TSMBMS | Rel-6 | Paolo | Nokia | igor.curcio@nokia.com |  |  |
| 1516 | 465.9 | MBMS charging |  | 108d? | 2005-01-11 A | 2005-06-09 A | 100% | 2005-01-11 | 2005-06-09 | 108d? | start no earlier than 2005-01-11 |  | S5 | 864h | 864h | MBMS-CH | Rel-6 | Dionisio |  |  |  |  |
| 1517 | 465.10 | **MBMS UE Conformance Testing** |  | 521d? | 2006-03-10 A | 2008-03-07 A | 100% | 2006-03-10 | 2008-03-07 | 521d? |  |  | R5,T1 | 17200h | 17200h | MBMS-UEConTest | Rel-6 | Ingbert |  |  |  |  |
| 1518 | 16.5.1 | RF/RRM Conformance Test Aspects – MBMS (FDD) |  | 461d | 2006-06-02 A | 2008-03-07 A | 100% | 2006-06-02 | 2008-03-07 | 461d | finish no earlier than 2008-03-07 | 2006-06-02 | R5,T1 | 3688h | 3688h | MBMS-RAN-RF_Test | Rel-6 | Ingbert | Ericsson | leif.mattisson@ericsson.com | Fri 11/03/05 |  |
| 1519 | 465.10.2 | Conformance Test Aspects - MBMS for 3.84 Mcps and 7.68 Mcps TDD |  | 318d? | 2006-09-20 A | 2007-12-07 A | 100% | 2006-09-20 | 2007-12-07 | 318d? | finish no earlier than 2007-12-07 |  | R5,T1 | 2544h | 2544h | MBMS-UEConTest_TDH | Rel-6 | Ingbert | IPWireless | Timothy Speight (tspeight@ipwireless.com) |  |  |
| 1520 | 465.10.3 | Signalling Conformance Test Aspects – MBMS for LCR TDD |  | 318d? | 2006-09-20 A | 2007-12-07 A | 100% | 2006-09-20 | 2007-12-07 | 318d? | finish no earlier than 2007-12-07 |  | R5,T1 | 2544h | 2544h | MBMS-UEConTest_SIGTDL | Rel-6 | Ingbert | DATANG | zhaojian@datangmobile.cn |  |  |
| 1521 | 465.10.4 | Conformance Test Aspects – MBMS |  | 396d? | 2006-03-10 A | 2007-09-14 A | 100% | 2006-03-10 | 2007-09-14 | 396d? | finish no earlier than 2007-09-14 |  | R5,T1 | 3168h | 3168h | MBMS_Test | Rel-6 | Ingbert | Qualcomm | Shubhang Vora (svora@qualcomm.com) |  |  |
| 1522 | 16.5.1 | Conformance Test Aspects - 1.28 Mcps TDD MBMS RF/RRM |  | 136d | 2007-06-01 A | 2007-12-07 A | 100% | 2007-06-01 | 2007-12-07 | 136d | finish no earlier than 2007-12-07 | 2006-06-02 | R5,T1 | 1088h | 1088h | MBMS-UEConTest_RFTDL | Rel-6 | Ingbert | Datang Mobile | chenxiaozhong@datangmobile.cn | Fri 11/03/05 |  |
| 1523 | 29 | **Speech Recognition and Speech Enabled Services** |  | 1105d? | 2001-10-08 A | 2005-12-30 A | 100% | 2001-10-08 | 2005-12-30 | 1105d? |  |  | S1 | 20176h | 20176h | SRSES | Rel-6 | Alain |  |  |  |  |
| 1524 | 29.1 | Speech Enabled Services Based on Distributed Speech Recognition (DSR) |  | 115d | 2001-10-08 A | 2002-03-15 A | 100% | 2001-10-08 | 2002-03-15 | 115d | finish no earlier than 2002-03-15 |  | S1 | 920h | 920h | DSR | Rel-6 | Alain | Qualcomm | Dwilliams@qualcomm.com |  |  |
| 1525 | 29.2 | TR on Architectural impacts |  | 212d | 2003-05-12 A | 2004-03-02 A | 100% | 2003-05-12 | 2004-03-02 | 212d | finish no earlier than 2004-03-02 |  | S2 | 1696h | 1696h | SRSES | Rel-6 |  |  |  |  |  |
| 1526 | 466.3 | Codec Work to Support Speech Recognition Framework for Automated Voice Services |  | 568d? | 2002-10-15 A | 2004-12-16 A | 100% | 2002-10-15 | 2004-12-16 | 568d? | finish no earlier than 2004-12-16 |  | S4 | 4544h | 4544h | SRSES-Codec | Rel-6 | Paolo | Motorola | David Pearce (bdp003@motorola.com) |  |  |
| 1527 | 466.4 | Multimodal support |  | 522d? | 2004-01-01 A | 2005-12-30 A | 100% | 2004-01-01 | 2005-12-30 | 522d? | finish no earlier than 2005-06-30 |  | OMA | 4176h | 4176h | SRSES | Rel-6 |  |  | OMA-LIAISON@mail.openmobilealliance.org | SP-24 |  |
| 1528 | 466.5 | Deleted - SES codec negotiation at Session Description Protocol (SDP) | milestone | 0d? | 2003-06-04 A | 2003-06-04 A | 100% | 2003-06-04 | 2003-06-04 | 0d? | start no earlier than 2003-06-04 |  | N1 |  |  | SRSES | Rel-6 | Frederic |  |  |  | NP-23 |
| 1529 | 30 | **Generic User Profile Rel-6** |  | 889d | 2001-10-08 A | 2005-03-03 A | 100% | 2001-10-08 | 2005-03-03 | 889d |  |  | S1 | 24295.8h | 24295.8h | GUP | Rel-6 | Alain |  |  |  |  |
| 1530 | 30.1 | Stage 1 - Requirements |  | 430d | 2001-10-08 A | 2003-05-30 A | 100% | 2001-10-08 | 2003-05-30 | 430d | finish no earlier than 2002-12-09 |  | S1 | 3440h | 3440h | GUP | Rel-6 | Alain | T-Mobile | kurt.bischinger@t-mobile.at |  |  |
| 1531 | 30.3 | Stage 2 - Architecture |  | 355d | 2002-01-28 A | 2003-06-06 A | 100% | 2002-01-28 | 2003-06-06 | 355d | finish no earlier than 2003-06-06 |  | S2 | 2840h | 2840h | GUP | Rel-6 | Maurice | Nokia | harri.o.koskinen@nokia.com |  |  |
| 1532 | 30.2 | Stage 2 - Data Description Method |  | 586d | 2002-12-05 A | 2005-03-03 A | 100% | 2002-12-05 | 2005-03-03 | 586d | finish no earlier than 2005-03-03 |  | N4 | 4688h | 4688h | GUP | Rel-6 | Kimmo | T-Mobile | kurt.bischinger@t-mobile.at |  |  |
| 1533 | 30.5 | Stage 3 - Network |  | 468.98d | 2003-05-19 A | 2005-03-03 A | 100% | 2003-05-19 | 2005-03-03 | 468.98d | finish no earlier than 2005-03-03 |  | N4 | 3751.83h | 3751.83h | GUP | Rel-6 | Kimmo |  |  |  |  |
| 1534 | 30.6 | Security Aspects |  | 308d | 2002-07-16 A | 2003-09-18 A | 100% | 2002-07-16 | 2003-09-18 | 308d | finish no earlier than 2003-09-18 |  | S3 | 2464h | 2464h | GUP | Rel-6 | Dionisio | Lucent | Owen, Bradley (bvowen@lucent.com) |  |  |
| 1535 | 31 | **Digital Rights Management** |  | 690d? | 2001-10-08 A | 2004-05-28 A | 100% | 2001-10-08 | 2004-05-28 | 690d? |  |  | S1 | 10152h | 10152h | DRM | Rel-6 | Alain |  |  |  |  |
| 1536 | 31.1 | Requirements |  | 179d | 2001-10-08 A | 2002-06-13 A | 100% | 2001-10-08 | 2002-06-13 | 179d | finish no earlier than 2002-06-13 |  | S1 | 1432h | 1432h | DRM | Rel-6 | Alain | Openwave | nicholas.wood@openwave.com |  |  |
| 1537 | 468.2 | Stage 2 |  | 107d? | 2004-01-01 A | 2004-05-28 A | 100% | 2004-01-01 | 2004-05-28 | 107d? | finish no earlier than 2004-05-28 |  | OMA | 856h | 856h | DRM | Rel-6 |  |  | OMA-LIAISON@mail.openmobilealliance.org | SP-24 |  |
| 1538 | 468.3 | Stage 3 |  | 107d? | 2004-01-01 A | 2004-05-28 A | 100% | 2004-01-01 | 2004-05-28 | 107d? | finish no earlier than 2004-05-28 |  | OMA | 856h | 856h | DRM | Rel-6 |  |  | OMA-LIAISON@mail.openmobilealliance.org | SP-24 |  |
| 1539 | 31.3 | Security |  | 186d | 2002-06-17 A | 2003-03-03 A | 100% | 2002-06-17 | 2003-03-03 | 186d | finish no earlier than 2003-03-03 |  | OMA | 1488h | 1488h | DRM | Rel-6 |  |  |  |  |  |
| 1540 | 468.5 | Deleted - Monitoring of Stages 2 and 3 progress (actual work to be done by OMA) | milestone | 0d? | 2003-03-21 A | 2003-03-21 A | 100% | 2003-03-21 | 2003-03-21 | 0d? | start no earlier than 2002-08-19 |  | S1 |  |  | DRM | Rel-6 | Alain |  |  |  | SP-19 |

Notes:
- 1513: - / Text3: 22.246
- 1514: - / Text3: 22.246
- 1515: TR26.946 tbc by March 06 / Text3: 26.346, 26.936, 26.946
- 1516: SP#28 06/2005 completed / Text3: 32.273
- 1517: BB place holder for a number of RAN5 Tasks. Moved in from the Stoyan/Testing WP / Text3: 34.108, 34.109, 34.121-1, 34.121-2, 34.122, 34.123-1, 34.123-2, 34.123-3
- 1518: TS 34.109 is under RAN2; RAN5 need to identify possible new requirements on UE test loop functionality to enable testing / Text3: 34.108, 34.109, 34.121-1, 34.121-2
- 1519: - / Text3: 34.108, 34.122, 34.123-1, 34.123-2, 34.123-3
- 1520: - / Text3: 34.108, 34.123-1, 34.123-2, 34.123-3
- 1521: - / Text3: 34.108, 34.123-1, 34.123-2, 34.123-3
- 1522: - / Text3: 34.108, 34.109, 34.122
- 1523: -
- 1524: - / Text3: 22.941, 23.207, 22.243
- 1525: - / Text3: 23.877
- 1526: - / Text3: 26.235, 26.236, 26.243, 26.177, 26.943
- 1527: -
- 1528: Abandoned NP-23
- 1529: -
- 1530: - / Text3: 22.240, 22.228
- 1531: - / Text3: 23.240
- 1532: TR approved in CN#26 / Text3: 23.241
- 1533: - / Text3: 29.240
- 1534: WID approved SP#17. SA WG3 progress slow, depends on progress in other groups. / Text3: 33.102, 33.203, 33.210
- 1535: Foreseen start and completion dates introduced by MCC (no indication at all on the WID)
- 1536: -
- 1537: -
- 1538: -
- 1539: SA3 acknowledge role in WI at SA3#20. Active contribution S3#24, S3#25. S3 WID approved SP#17
- 1540: Replaced by UID 60005 and 60006

| ID | WBS | Task | Duration | Start | Finish | Complete | Baseline start | Baseline finish | Baseline duration | Constraint | Resources | Work | Actual work | Text1 | Text4 | Text5 | Text6 | Text8 | Text3 | Text10 |
| --- | --- | --- | --- | --- | --- | --- | --- | --- | --- | --- | --- | --- | --- | --- | --- | --- | --- | --- | --- | --- |
| 1541 | 32 | **WLAN-UMTS Interworking Rel-6** | 1495d? | 2000-01-03 A | 2005-09-22 A | 100% | 2000-01-03 | 2005-09-22 | 1495d? |  | S1 | 48472h | 48472h | WLAN | Telenor | frederic.paint@telenor.com | Rel-6 | Alain |  |  |
| 1542 | 32.1 | Technical Report | 901d? | 2000-01-03 A | 2003-06-13 A | 100% | 2000-01-03 | 2003-06-13 | 901d? | finish no earlier than 2003-06-13 | S1 | 7200h | 7200h | WLAN-TR | Telenor | frederic.paint@telenor.com | Rel-6 | Alain | 22.934, 22.101, 22.105 |  |
| 1543 | 469.2 | **Stage 1** | 375d? | 2003-01-06 A | 2004-06-11 A | 100% | 2003-01-06 | 2004-06-11 | 375d? |  | S1 | 3920h | 3920h | WLAN-TS | Telenor | frederic.paint@telenor.com | Rel-6 | Alain | 22.234 | SP-24 |
| 1544 | 469.2.1 | Global stage 1 | 375d? | 2003-01-06 A | 2004-06-11 A | 100% | 2003-01-06 | 2004-06-11 | 375d? | finish no earlier than 2004-06-11 | S1 | 3000h | 3000h | WLAN-TS | Telenor | frederic.paint@telenor.com | Rel-6 | Alain | 22.234 | SP-24 |
| 1545 | 32.2 | Architecture Definition for scenarii 2 and 3 | 571d | 2002-03-25 A | 2004-05-31 A | 100% | 2002-03-25 | 2004-05-31 | 571d | finish no earlier than 2004-05-31 | S2 | 4568h | 4568h | WLAN |  |  | Rel-6 | Maurice | 23.234 |  |
| 1546 | 32.3 | Security | 125d | 2002-09-30 A | 2003-03-21 A | 100% | 2002-09-30 | 2003-03-21 | 125d | finish no earlier than 2003-03-21 | S3 | 1000h | 1000h | WLAN | Ericsson | luis.lopez-soria@ece.ericsson.se | Rel-6 | Dionisio | 21.133, 33.106, 33.107, 33.108, 33.200, 33.203, 33.210 |  |
| 1547 | 469.5 | Stage 3 - CN4 aspects | 334d? | 2003-05-23 A | 2004-09-01 A | 100% | 2003-05-23 | 2004-09-01 | 334d? | finish no earlier than 2004-09-01 | N4 | 2672h | 2672h | WLAN-IW | Nokia | raquel.rodriguez@nokia.com | Rel-6 | Kimmo | 29.234, 29.061 |  |
| 1548 | 469.6 | Stage 3 - CN3 aspects (Wi Interface for Scenario 3) | 355d? | 2003-05-23 A | 2004-09-30 A | 100% | 2003-05-23 | 2004-09-30 | 355d? | start no earlier than 2003-05-23 | N3 | 2840h | 2840h | WLAN |  |  | Rel-6 | Gwiho | 29.161 | SP-24 |
| 1549 | 469.7 | Stage 3 for scenario 2 | 339d? | 2003-05-23 A | 2004-09-08 A | 100% | 2003-05-23 | 2004-09-08 | 339d? | finish no earlier than 2004-09-08 | N1 | 2712h | 2712h | WLAN |  |  | Rel-6 | Frederic |  |  |
| 1550 | 469.8 | Stage 3 for scenario 3 | 404d? | 2003-05-23 A | 2004-12-08 A | 100% | 2003-05-23 | 2004-12-08 | 404d? | finish no earlier than 2004-12-08 | N1 | 3232h | 3232h | WLAN |  |  | Rel-6 | Frederic |  | SP-24 |
| 1551 | 469.9 | WLAN charging | 655d? | 2003-03-21 A | 2005-09-22 A | 100% | 2003-03-21 | 2005-09-22 | 655d? | finish no earlier than 2005-09-22 | S5 | 5240h | 5240h | WLAN-CH | Nokia | Benni ALEXANDER | Rel-6 | Dionisio | 32.252 |  |
| 1552 | 469.10 | USIM enhancements for WLAN Interworking | 391d? | 2003-09-05 A | 2005-03-04 A | 100% | 2003-09-05 | 2005-03-04 | 391d? | finish no earlier than 2005-03-04 | T3 | 3128h | 3128h | WLAN | Axalto | Jabellan@axalto.com | Rel-6 |  |  |  |
| 1553 | 33 | **Priority Service** | 347d? | 2002-05-30 A | 2003-09-26 A | 100% | 2002-05-30 | 2003-09-26 | 347d? |  | S1 | 6464h | 6464h | PRIOR1 | Telcordia | Biplab K. Pramanik (bpramani@telcordia.com) | Rel-6 | Alain |  |  |
| 1554 | 33.1 | Feasibility Study | 1d | 2002-06-14 A | 2002-06-14 A | 100% | 2002-06-14 | 2002-06-14 | 1d | finish no earlier than 2002-06-14 | S1 | 8h | 8h | PRIOR-FS | Telcordia | Biplab K. Pramanik (bpramani@telcordia.com) | Rel-6 | Alain | 22.950 |  |
| 1555 | 33.2 | Stage 1 - Requirements | 340d | 2002-05-30 A | 2003-09-17 A | 100% | 2002-05-30 | 2003-09-17 | 340d | finish no earlier than 2003-09-17 | S1 | 2720h | 2720h | PRIOR-SR | Telcordia | James J. Garrahan (bpramani@telcordia.com) | Rel-6 | Alain |  |  |
| 1556 | 470.3 | Priority service implementation guide | 131d? | 2003-03-28 A | 2003-09-26 A | 100% | 2003-03-28 | 2003-09-26 | 131d? | finish no earlier than 2003-09-26 | S1 | 1048h | 1048h | PRIOR1 | Telcordia | Biplab K. Pramanik (bpramani@telcordia.com) | Rel-6 | Alain | 22.952 |  |
| 1557 | 34 | **Network Sharing** | 498d? | 2003-01-20 A | 2004-12-15 A | 100% | 2003-01-20 | 2004-12-15 | 498d? |  | S1 | 16608h | 16608h | NTShar | T-Mobile | michele.zarri@t-mobile.co.uk | Rel-6 | Alain |  |  |
| 1558 | 34.1 | Technical Report | 240d? | 2003-01-20 A | 2003-12-19 A | 100% | 2003-01-20 | 2003-12-19 | 240d? |  | S1 | 1920h | 1920h | NTShar-TR | T-Mobile | michele.zarri@t-mobile.co.uk | Rel-6 | Alain | 22.951 |  |
| 1559 | 471.2 | Stage 1 - CRs to implement Network Sharing | 240d? | 2003-01-20 A | 2003-12-19 A | 100% | 2003-01-20 | 2003-12-19 | 240d? | finish no earlier than 2003-12-19 | S1 | 1920h | 1920h | NTSharCR | T-Mobile | michele.zarri@t-mobile.co.uk | Rel-6 | Alain | 22.011, 22.101, 22.115, 22.129 |  |
| 1560 | 471.3 | Stage 2 | 372d? | 2003-02-27 A | 2004-07-30 A | 100% | 2003-02-27 | 2004-07-30 | 372d? | finish no earlier than 2004-07-30 | S2 | 2976h | 2976h | NTShar | T-Mobile | michele.zarri@t-mobile.co.uk | Rel-6 | Maurice | 23.002, 23.060, 23.221, 23.236, new 23.251 |  |
| 1561 | 471.4 | Network sharing - stage 3 | 404d? | 2003-05-23 A | 2004-12-08 A | 100% | 2003-05-23 | 2004-12-08 | 404d? | finish no earlier than 2004-12-08 | N1 | 3232h | 3232h | NTShar | T-Mobile | michele.zarri@t-mobile.co.uk | Rel-6 | Frederic | 23.008, 23.122, 24.007, 24.008, 29.018 |  |
| 1562 | 471.5 | Enhancement of the support of network sharing in the UTRAN | 324d | 2003-09-19 A | 2004-12-15 A | 100% | 2003-09-19 | 2004-12-15 | 324d | finish no earlier than 2004-12-15 | R2 | 2592h | 2592h | NTShar-UTRANEnh | TeliaSonera | Anders.Dahlen@TeliaSonera.com | Rel-6 | Joern | 25.401, 25.413, 25.331, 25.304 |  |
| 1563 | 35 | **QoS Improvements** | 628d? | 2002-07-15 A | 2004-12-08 A | 100% | 2002-07-15 | 2004-12-08 | 628d? |  | S2,N3 | 13128h | 13128h | QoS1 | Nokia |  | Rel-6 | Maurice | 23.107, 23.207, 23.221 |  |
| 1564 | 35.1 | FS on Dynamic Policy control enhancements for end-to-end QoS | 465d | 2002-07-15 A | 2004-04-23 A | 100% | 2002-07-15 | 2004-04-23 | 465d | finish no earlier than 2004-04-23 | S2 | 3720h | 3720h | QoS1 | Nortel | Claire Mousset | Rel-6 | Maurice | 23.917 withdrawn (Contents all in 23.207) |  |
| 1565 | 472.2 | Definition of the Gq interface | 214d? | 2003-07-01 A | 2004-04-23 A | 100% | 2003-07-01 | 2004-04-23 | 214d? | finish no earlier than 2004-04-23 | S2 | 1712h | 1712h | QoS1 |  | Janne Rinne | Rel-6 |  | 23.207 |  |
| 1566 | 472.3 | Gq interface specification for Dynamic Policy control enhancements – Stage 3 | 334d | 2003-08-29 A | 2004-12-08 A | 100% | 2003-08-29 | 2004-12-08 | 334d | finish no earlier than 2004-12-08 | N3 | 2672h | 2672h | QoS1 | Nokia | Anna.Sillanpaai@nokia.com | Rel-6 | Gwiho | 29.207, 29.208, 29.209 |  |

Notes:
- 1541: -
- 1542: -
- 1543: -
- 1544: -
- 1545: -
- 1546: Active contribution S3#24, S3#25. WID approved SP#17
- 1547: WID approved at CN#19
- 1548: -
- 1549: -
- 1550: -
- 1551: SP#28: delayed 09/2005. WT also under SA5 BB 35017 Charging Management for Bearer level
- 1552: -
- 1553: -
- 1554: -
- 1555: -
- 1556: -
- 1557: -
- 1558: -
- 1559: -
- 1560: -
- 1561: -
- 1562: -
- 1563: -
- 1564: -
- 1565: -
- 1566: [DAB - 25.05.04] - Delayed to Sept - possibly Dec 2004

| ID | WBS | Task | Type | Duration | Start | Finish | Complete | Baseline start | Baseline finish | Baseline duration | Constraint | Resources | Work | Actual work | Text1 | Text4 | Text5 | Text6 | Text8 | Text10 | Text12 |
| --- | --- | --- | --- | --- | --- | --- | --- | --- | --- | --- | --- | --- | --- | --- | --- | --- | --- | --- | --- | --- | --- |
| 1567 | 36 | **Subscriber certificates** |  | 728d? | 2002-02-25 A | 2004-12-08 A | 100% | 2002-02-25 | 2004-12-08 | 728d? |  | S3,S2,N1,N4,T3,OMA | 12888h | 12888h | SEC1-SC | Nokia | valtteri.niemi@nokia.com | Rel-6 | Dionisio |  |  |
| 1568 | 36.1 | Stage 1 |  | 144d | 2002-02-25 A | 2002-09-12 A | 100% | 2002-02-25 | 2002-09-12 | 144d | finish no earlier than 2002-09-12 | S3 | 1152h | 1152h | SEC1-SC | Nokia | valtteri.niemi@nokia.com | Rel-6 | Dionisio |  |  |
| 1569 | 36.2 | Architecture review |  | 24d | 2002-10-14 A | 2002-11-14 A | 100% | 2002-10-14 | 2002-11-14 | 24d | finish no earlier than 2002-11-14 | S2 | 192h | 192h | SEC1-SC | Nokia |  | Rel-6 | Maurice |  |  |
| 1570 | 473.3 | Stage 3 |  | 313d? | 2003-09-19 A | 2004-11-30 A | 100% | 2003-09-19 | 2004-11-30 | 313d? | finish no earlier than 2004-11-30 | N4,T3 | 2504h | 2504h | SEC1-SC | Nokia | Lauri Laitinen | Rel-6 | Kimmo |  |  |
| 1571 | 473.4 | Stage 3 Ua & Ub interfaces |  | 288d? | 2003-11-03 A | 2004-12-08 A | 100% | 2003-11-03 | 2004-12-08 | 288d? | finish no earlier than 2004-12-08 | N1 | 2304h | 2304h | SEC1-SC | Nokia |  | Rel-6 | Frederic |  |  |
| 1572 | 473.5 | OMA dependencies on Subscriber certificates |  | 114d? | 2004-01-01 A | 2004-06-08 A | 100% | 2004-01-01 | 2004-06-08 | 114d? | finish no earlier than 2004-06-08 | OMA | 912h | 912h | SEC1-SC | Nokia | OMA-LIAISON@mail.openmobilealliance.org | Rel-6 |  | SP-24 |  |
| 1573 | 474 | **Rel-6 OSA enhancements** |  | 616d? | 2002-10-31 A | 2005-03-10 A | 100% | 2002-10-31 | 2005-03-10 | 616d? |  | N5 | 22576h | 22576h | OSA3 | Alcatel | Chelo.Abarca@alcatel.fr | Rel-6 | Kimmo |  |  |
| 1574 | 474.1 | Scope of the Open Service Access Release 6 |  | 66d? | 2003-03-28 A | 2003-06-27 A | 100% | 2003-03-28 | 2003-06-27 | 66d? | finish no earlier than 2003-06-27 | S1 | 528h | 528h | OSA3 |  |  | Rel-6 | Alain |  |  |
| 1575 | 474.2 | OSA Stage 2 |  | 150d? | 2004-08-13 A | 2005-03-10 A | 100% | 2004-08-13 | 2005-03-10 | 150d? | finish no earlier than 2005-03-10 | N5 | 1200h | 1200h | OSA3 |  |  | Rel-6 | Kimmo |  |  |
| 1576 | 474.3 | Multi Media Messaging function |  | 487d? | 2002-10-31 A | 2004-09-10 A | 100% | 2002-10-31 | 2004-09-10 | 487d? | finish no earlier than 2004-09-10 | N5 | 3896h | 3896h | OSA3 |  |  | Rel-6 | Kimmo |  |  |
| 1577 | 474.4 | Policy management extensions |  | 292d? | 2002-10-31 A | 2003-12-12 A | 100% | 2002-10-31 | 2003-12-12 | 292d? | finish no earlier than 2003-12-12 | N5 | 2336h | 2336h | OSA3 |  |  | Rel-6 | Kimmo |  |  |
| 1578 | 474.5 | TS on Presence and Availability Management (from the PRESNC WI) |  | 367d? | 2002-10-31 A | 2004-03-26 A | 100% | 2002-10-31 | 2004-03-26 | 367d? | finish no earlier than 2004-03-26 | N5 | 2936h | 2936h | OSA3 |  |  | Rel-6 | Kimmo |  |  |
| 1579 | 474.6 | OSA interfaces at different levels of abstractions (Parlay X, Web services) |  | 305d? | 2003-07-14 A | 2004-09-10 A | 100% | 2003-07-14 | 2004-09-10 | 305d? | finish no earlier than 2004-09-10 | N5 | 2440h | 2440h | OSA3 |  |  | Rel-6 | Kimmo |  |  |
| 1580 | 474.7 | Introduction of migration support mechanism |  | 290d? | 2002-10-31 A | 2003-12-10 A | 100% | 2002-10-31 | 2003-12-10 | 290d? | finish no earlier than 2003-12-12 | N5 | 2320h | 2320h | OSA3 |  |  | Rel-6 | Kimmo |  |  |
| 1581 | 474.8 | Framework Function for Federation |  | 225d? | 2003-02-03 A | 2003-12-12 A | 100% | 2003-02-03 | 2003-12-12 | 225d? | finish no earlier than 2003-12-12 | N5 | 1800h | 1800h | OSA3 |  |  | Rel-6 | Kimmo |  |  |
| 1582 | 474.9 | OMA potential overlaps with 3GPP OSA Stage 3 (Web services) |  | 196d? | 2003-12-18 A | 2004-09-16 A | 100% | 2003-12-18 | 2004-09-16 | 196d? | start no earlier than 2003-12-18 | OMA | 1568h | 1568h | OSA3 |  |  | Rel-6 |  | SP-24 |  |
| 1583 | 474.10 | Deleted - TR on Presence and Availability Management (from the PRESNC WI) | milestone | 0d? | 2004-09-17 A | 2004-09-17 A | 100% | 2004-09-17 | 2004-09-17 | 0d? | start no earlier than 2004-09-17 | N5 |  |  | OSA3 |  |  | Rel-6 | Kimmo |  | NP-24 |
| 1584 | 39 | **Addition of frequency bands to GSM (TAPS)** |  | 676d | 2002-06-28 A | 2005-01-28 A | 100% | 2002-06-28 | 2005-01-28 | 676d |  | GP | 16640h | 16640h | TAPS | Nokia | Torben Themsen | Rel-6 | Paolo |  |  |
| 1585 | 39.1 | **Addition of frequency bands to GSM – Changes to core specs** |  | 26d | 2002-11-15 A | 2002-12-20 A | 100% | 2002-11-15 | 2002-12-20 | 26d |  | G1 | 416h | 416h | TAPS-Specs | Nokia | Torben Themsen | Rel-6 | Paolo |  |  |
| 1586 | 39.1.1 | Changes to core specs |  | 26d | 2002-11-15 A | 2002-12-20 A | 100% | 2002-11-15 | 2002-12-20 | 26d | finish no earlier than 2002-12-20 | G1 | 208h | 208h | TAPS-Specs | Nokia | Torben Themsen | Rel-6 | Paolo |  |  |
| 1587 | 39.2 | **Deleted - Addition of frequency bands to GSM – Changes for conformance tests** |  | 676d | 2002-06-28 A | 2005-01-28 A | 100% | 2002-06-28 | 2005-01-28 | 676d |  | G4 | 10816h | 10816h | TAPS-Conf | Nokia | Torben Themsen | Rel-6 | Paolo |  | GP-23 |
| 1588 | 39.2.1 | Deleted - 51.010-1 Add testing |  | 676d | 2002-06-28 A | 2005-01-28 A | 100% | 2002-06-28 | 2005-01-28 | 676d | finish no earlier than 2005-01-28 | G4 | 5408h | 5408h | TAPS-Conf | Nokia | Torben Themsen | Rel-6 | Paolo |  | GP-23 |
| 1589 | 40 | **Seamless support of streaming services in A/Gb mode** |  | 1426d? | 2000-01-03 A | 2005-06-17 A | 100% | 2000-01-03 | 2005-06-17 | 1426d? |  | GP | 53096h | 53096h | SSStrea | Vodafone | José Luis Carrizo Martínez | Rel-6 | Paolo |  |  |
| 1590 | 40.1 | **Identification of requirements for streaming** |  | 46d? | 2003-06-27 A | 2003-08-29 A | 100% | 2003-06-27 | 2003-08-29 | 46d? |  | G1 | 736h | 736h | SSStrea | Vodafone | José Luis Carrizo Martínez | Rel-6 | Paolo |  |  |
| 1591 | 476.1.1 | Requirements |  | 46d? | 2003-06-27 A | 2003-08-29 A | 100% | 2003-06-27 | 2003-08-29 | 46d? | finish no earlier than 2003-08-29 | G1 | 368h | 368h | SSStrea | Vodafone | José Luis Carrizo Martínez | Rel-6 | Paolo |  |  |

Notes:
- 1567: Approved at SP#14. May require BBs from CN1, CN4, SA5 and T3
- 1568: Contribution received S3#24, S3#25 / Text3: 33.220, 33.221, 33.222, 33.246
- 1569: -
- 1570: Finished in CN4#26 / Text3: 23.003, 23.008, 29.109, 29.230, T3 31.102, 31.103, 31.111
- 1571: - / Text3: 24.109
- 1572: Updated according to SP-040420
- 1573: CN#25: Updated WID NP-040351 replaces NP-040144. / Text3: 22.127, 23.198, 29.198, 29.199, 29.998
- 1574: -
- 1575: Inherited by CN5 from SA2 at TSG#25 Sep 2004. SA2's 23.127 (OSA/VHE Stage 2) replaced from Rel-6 onwards by a new CN5 TS 23.198 (Stage 2 OSA-only). / Text3: 23.198 OSA Stage 2-ONLY replaces 23.127 (OSA/VHE) from Rel-6 onwards
- 1576: - / Text3: 29.198-15
- 1577: - / Text3: 29.198, 29.998
- 1578: N5#26: Split WI into TS & TR. / Text3: 29.198-14
- 1579: - / Text3: 29.199
- 1580: - / Text3: 29.198, 29.998
- 1581: - / Text3: 29.198, 29.998
- 1582: TSG#25 Approved CN5 29.199 Parlay X Web services. Ongoing 3GPP/OMA co-ordination to avoid OMA producing conflicting/OVERLAPING specs (NP-040283/SP-040493).
- 1583: N5#26:TR Completion 09/04; consistent with CN1 delayed Rel-6 completion.
- 1584: -
- 1585: -
- 1586: -
- 1587: -
- 1588: -
- 1589: -
- 1590: -
- 1591: -

| ID | WBS | Task | Duration | Start | Finish | Complete | Baseline start | Baseline finish | Baseline duration | Constraint | Resources | Work | Actual work | Text1 | Text4 | Text5 | Text6 | Text8 | Text12 | Text3 |
| --- | --- | --- | --- | --- | --- | --- | --- | --- | --- | --- | --- | --- | --- | --- | --- | --- | --- | --- | --- | --- |
| 1592 | 40.2 | **Performance study of cell change mechanisms** | 956d? | 2000-01-03 A | 2003-08-29 A | 100% | 2000-01-03 | 2003-08-29 | 956d? |  | G1 | 30568h | 30568h | SSStrea | Vodafone | José Luis Carrizo Martínez | Rel-6 | Paolo |  |  |
| 1593 | 476.2.1 | Performance of NACC | 956d? | 2000-01-03 A | 2003-08-29 A | 100% | 2000-01-03 | 2003-08-29 | 956d? | finish no earlier than 2003-08-29 | G1 | 7640h | 7640h | SSStrea | Vodafone | José Luis Carrizo Martínez | Rel-6 | Paolo |  |  |
| 1594 | 476.2.2 | Performance of cell change in DTM for the PS domain | 956d? | 2000-01-03 A | 2003-08-29 A | 100% | 2000-01-03 | 2003-08-29 | 956d? | finish no earlier than 2003-08-29 | G1 | 7640h | 7640h | SSStrea | Vodafone | José Luis Carrizo Martínez | Rel-6 | Paolo |  |  |
| 1595 | 476.2.3 | Handover | 956d? | 2000-01-03 A | 2003-08-29 A | 100% | 2000-01-03 | 2003-08-29 | 956d? | finish no earlier than 2003-08-29 | G1 | 7640h | 7640h | SSStrea | Vodafone | José Luis Carrizo Martínez | Rel-6 | Paolo |  |  |
| 1596 | 40.3 | **Reduction of service interruption times and packet loss during mobility procedures** | 516d? | 2003-06-27 A | 2005-06-17 A | 100% | 2003-06-27 | 2005-06-17 | 516d? |  | G2 | 10800h | 10800h | SSStrea | Vodafone | José Luis Carrizo Martínez | Rel-6 | Gert |  |  |
| 1597 | 476.3.1 | optimizations of existing mechanisms/procedures | 106d? | 2003-06-27 A | 2003-11-21 A | 100% | 2003-06-27 | 2003-11-21 | 106d? | finish no earlier than 2003-11-21 | G2 | 848h | 848h | SSStrea | Vodafone | José Luis Carrizo Martínez | Rel-6 | Gert |  |  |
| 1598 | 476.3.2 | Inter-system NACC | 106d? | 2003-06-27 A | 2003-11-21 A | 100% | 2003-06-27 | 2003-11-21 | 106d? | finish no earlier than 2003-11-21 | G2 | 848h | 848h | SSStrea | Vodafone | José Luis Carrizo Martínez | Rel-6 | Gert |  |  |
| 1599 | 476.3.3 | PS Handover (within GERAN and between GERAN and UTRAN) | 516d? | 2003-06-27 A | 2005-06-17 A | 100% | 2003-06-27 | 2005-06-17 | 516d? | finish no earlier than 2003-11-21 | G2 | 4128h | 4128h | SSStrea | Vodafone | José Luis Carrizo Martínez | Rel-6 | Gert |  |  |
| 1600 | 476.3.4 | Dependency to other features | 106d? | 2003-06-27 A | 2003-11-21 A | 100% | 2003-06-27 | 2003-11-21 | 106d? | finish no earlier than 2003-11-21 | G2 | 848h | 848h | SSStrea | Vodafone | José Luis Carrizo Martínez | Rel-6 | Gert |  |  |
| 1601 | 40.5 | **Deleted - MS conformance testing** | 31d? | 2003-12-19 A | 2004-01-30 A | 100% | 2003-12-19 | 2004-01-30 | 31d? |  | G3new | 248h | 248h | SSStrea | Vodafone | José Luis Carrizo Martínez | Rel-6 | Ingbert | GP-27 |  |
| 1602 | 476.4.1 | Deleted - MS conformance tests | 31d? | 2003-12-19 A | 2004-01-30 A | 100% | 2003-12-19 | 2004-01-30 | 31d? | finish no earlier than 2004-01-30 | G4,G5 | 248h | 248h | SSStrea | Vodafone | José Luis Carrizo Martínez | Rel-6 | Ingbert | GP-27 |  |
| 1603 | 476.5 | GERAN A/Gb mode security enhancements | 612d? | 2002-09-26 A | 2005-01-28 A | 100% | 2002-09-26 | 2005-01-28 | 612d? | finish no earlier than 2005-01-28 | S3 | 4896h | 4896h | SSStrea | Vodafone | peter.howard@vodafone.com | Rel-6 | Dionisio |  | 33.102 |
| 1604 | 41 | Performance characterisation of default codecs for PS conversational multimedia application | 455d | 2002-09-13 A | 2004-06-10 A | 100% | 2002-09-13 | 2004-06-10 | 455d | finish no earlier than 2004-06-10 | S4 | 3640h | 3640h | CODCAR | Nokia | pasi.s.ojala@nokia.com | Rel-6 | Paolo |  | 26.935 |
| 1605 | 43 | Study on Privacy Capability | 83d | 2003-11-10 A | 2004-03-03 A | 100% | 2003-11-10 | 2004-03-03 | 83d | start no earlier than 2003-11-10 | S1 | 664h | 664h | PrivCap | Lucent | Liz Daniel | Rel-6 | Alain |  | 22.949 |
| 1606 | 44 | **OAM&P Rel-6** | 652d? | 2002-09-12 A | 2005-03-11 A | 100% | 2002-09-12 | 2005-03-11 | 652d? |  | S5 | 30819.5h | 30819.5h | OAM | Motorola |  | Rel-6 | Dionisio |  |  |
| 1607 | 44.1 | Principles, high level Requirements and Architecture | 526d | 2002-09-12 A | 2004-09-16 A | 100% | 2002-09-12 | 2004-09-16 | 526d | finish no earlier than 2004-09-16 | S5 | 4208h | 4208h | OAM-AR | Motorola |  | Rel-6 | Dionisio |  | 32.101, 32.102 |
| 1608 | 44.2 | Performance Management | 591d | 2002-09-12 A | 2004-12-16 A | 100% | 2002-09-12 | 2004-12-16 | 591d | finish no earlier than 2004-12-16 | S5 | 4728h | 4728h | OAM-PM | Nortel |  | Rel-6 | Dionisio |  | 32.401/3, 52.402, 32.411/2/3, 32.432/5/6 |
| 1609 | 44.4 | Network Infrastructure Management | 591d | 2002-09-12 A | 2004-12-16 A | 100% | 2002-09-12 | 2004-12-16 | 591d | finish no earlier than 2004-12-16 | S5 | 4728h | 4728h | OAM-NIM | Ericsson | thomas.tovinger@ericsson.com | Rel-6 | Dionisio |  | 32.15x, 32.3/6/7xy |
| 1610 | 44.5 | **Trace Management Rel-6** | 646d? | 2002-09-20 A | 2005-03-11 A | 100% | 2002-09-20 | 2005-03-11 | 646d? |  | S5 | 12061.9h | 12061.9h | OAM-Trace | Nokia | kari.t.ronka@nokia.com | Rel-6 | Dionisio |  | 32.42x, 52.008 |
| 1611 | 479.4.1 | Subscriber and UE trace management | 585d | 2002-09-20 A | 2004-12-16 A | 100% | 2002-09-20 | 2004-12-16 | 585d | finish no earlier than 2004-12-16 | S5 | 4680h | 4680h | OAM-Trace | Nokia | kari.t.ronka@nokia.com | Rel-6 | Dionisio |  | 32.421/2/3, 52.008 |
| 1612 | 479.4.2 | Subscriber and equipment trace in UTRAN | 268d? | 2003-06-06 A | 2004-06-15 A | 100% | 2003-06-06 | 2004-06-15 | 268d? | finish no earlier than 2004-06-15 | R3 | 2144h | 2144h | OAM-Trace-RAN | Nortel | Yann Sehedi (sehedic@nortelnetworks.com) | Rel-6 | Juha |  | 25.413, 25.420, 25.423 |
| 1613 | 479.4.3 | Trace Management, Stage3 | 193.74d? | 2004-06-09 A | 2005-03-11 A | 100% | 2004-06-09 | 2005-03-11 | 193.74d? | finish no earlier than 2005-03-11 | N4 | 1549.92h | 1549.92h | OAM-Trace | Nokia | seppo.kauntola@nokia.com | Rel-6 | Kimmo |  | 23.205, 29.232, 29.060, 29.002, 29.228 |
| 1614 | 480 | **Charging Management** | 666d? | 2002-11-21 A | 2005-06-09 A | 100% | 2002-11-21 | 2005-06-09 | 666d? |  | S5 | 55320h | 55320h | CH | T-Mobile | karl-heinz.nenner@t-mobile.de | Rel-6 | Dionisio |  | 32.2xy |
| 1615 | 480.1 | Charging architecture and principles | 390d? | 2003-03-21 A | 2004-09-16 A | 100% | 2003-03-21 | 2004-09-16 | 390d? | start no earlier than 2003-03-21 | S5 | 3120h | 3120h | CH |  |  | Rel-6 | Dionisio |  | 32.240 |
| 1616 | 480.2 | Charging Data Record (CDR) file format and transfer | 260d? | 2003-03-21 A | 2004-03-18 A | 100% | 2003-03-21 | 2004-03-18 | 260d? | start no earlier than 2003-03-21 | S5 | 2080h | 2080h | CH |  |  | Rel-6 | Dionisio |  | 32.297 |
| 1617 | 480.3 | CDR parameter description | 580d? | 2003-03-21 A | 2005-06-09 A | 100% | 2003-03-21 | 2005-06-09 | 580d? | finish no earlier than 2005-06-09 | S5 | 4640h | 4640h | CH |  |  | Rel-6 | Dionisio |  | 32.298 |
| 1618 | 480.4 | Diameter charging applications | 390d? | 2003-03-21 A | 2004-09-16 A | 100% | 2003-03-21 | 2004-09-16 | 390d? | start no earlier than 2003-03-21 | S5 | 3120h | 3120h | CH |  |  | Rel-6 | Dionisio |  | 32.299 |
| 1619 | 480.5 | Online Charging System (OCS) architecture study | 130d? | 2003-03-21 A | 2003-09-18 A | 100% | 2003-03-21 | 2003-09-18 | 130d? | start no earlier than 2003-03-21 | S5 | 1040h | 1040h | CH |  |  | Rel-6 | Dionisio |  | 32.815 |
| 1620 | 480.6 | OCS: Applications and interfaces | 455d? | 2003-03-21 A | 2004-12-16 A | 100% | 2003-03-21 | 2004-12-16 | 455d? | start no earlier than 2003-03-21 | S5 | 3640h | 3640h | CH |  |  | Rel-6 | Dionisio |  | 32.296 |

Notes:
- 1592: -
- 1593: -
- 1594: -
- 1595: -
- 1596: Completed at GERP#17
- 1597: -
- 1598: -
- 1599: -
- 1600: -
- 1601: Marked as stopped 10/2009
- 1602: Marked as stopped 10/2009
- 1603: Possible changes to 33.102 or new specification needed
- 1604: -
- 1605: -
- 1606: SP#26: Updated WID SP-040766 was SP-020445. Completion delayed 12/04->03/05 due to OAM-Trace in CN1/4.
- 1607: SP#25 09/2004 completed
- 1608: SP#26 12/2004 completed
- 1609: SP#26 12/2004 completed
- 1610: SP#26 12/2004 SA5 completed 12/04. Signalling Based Trace Activation for IMS (SIP) moved to Rel-7. Reason: CN1 cannot complete 24.229 trace without IETF dependency => estimate 05/2005.
- 1611: SP#26 12/2004 completed
- 1612: -
- 1613: -
- 1614: SP#28 Target 09/2005 for WLAN Charging 32.252
- 1615: SP#25 09/2004 completed
- 1616: SP#23 03/2004 completed
- 1617: SP#28 06/2005 completed
- 1618: SP#25 09/2004 completed
- 1619: SP#21 09/2003 completed
- 1620: SP#26 12/2004 completed

| ID | WBS | Task | Duration | Start | Finish | Complete | Baseline start | Baseline finish | Baseline duration | Constraint | Resources | Work | Actual work | Text1 | Text4 | Text5 | Text6 | Text8 | Text10 | Text12 |
| --- | --- | --- | --- | --- | --- | --- | --- | --- | --- | --- | --- | --- | --- | --- | --- | --- | --- | --- | --- | --- |
| 1621 | 480.7 | **Charging Management for Bearer level** | 390d? | 2003-03-21 A | 2004-09-16 A | 100% | 2003-03-21 | 2004-09-16 | 390d? |  | S5 | 11440h | 11440h | CH-BC | Nokia | Benni ALEXANDER | Rel-6 | Dionisio |  |  |
| 1622 | 480.7.1 | CS domain charging | 260d? | 2003-03-21 A | 2004-03-18 A | 100% | 2003-03-21 | 2004-03-18 | 260d? | start no earlier than 2003-03-21 | S5 | 2080h | 2080h | CH |  |  | Rel-6 | Dionisio |  |  |
| 1623 | 480.7.2 | PS domain charging | 390d? | 2003-03-21 A | 2004-09-16 A | 100% | 2003-03-21 | 2004-09-16 | 390d? | start no earlier than 2003-03-21 | S5 | 3120h | 3120h | CH |  |  | Rel-6 | Dionisio |  |  |
| 1624 | 480.7.3 | CDR transfer | 390d? | 2003-03-21 A | 2004-09-16 A | 100% | 2003-03-21 | 2004-09-16 | 390d? | start no earlier than 2003-03-21 | S5 | 3120h | 3120h | CH |  |  | Rel-6 | Dionisio |  |  |
| 1625 | 480.8 | Charging Management for the IMS | 455d? | 2003-03-21 A | 2004-12-16 A | 100% | 2003-03-21 | 2004-12-16 | 455d? | finish no earlier than 2004-12-16 | S5 | 3640h | 3640h | IMS2-CH | Ericsson | Patrik TEPPO | Rel-6 | Dionisio |  |  |
| 1626 | 480.9 | Charging Management for the Service domain | 580d? | 2003-03-21 A | 2005-06-09 A | 100% | 2003-03-21 | 2005-06-09 | 580d? | finish no earlier than 2005-06-09 | S5 | 4640h | 4640h | CH | Siemens | Gerald GÖRMER | Rel-6 | Dionisio |  |  |
| 1627 | 480.10 | **Overall architectural aspects of IP flow based bearer level charging** | 602d? | 2002-11-21 A | 2005-03-11 A | 100% | 2002-11-21 | 2005-03-11 | 602d? |  | S2 | 12632h | 12632h | CH-FBC |  |  | Rel-6 | Maurice |  |  |
| 1628 | 480.10.1 | Overall definition of FBC architecture | 334d? | 2002-11-21 A | 2004-03-02 A | 100% | 2002-11-21 | 2004-03-02 | 334d? | start no earlier than 2002-11-21 | S2 | 2672h | 2672h | CH-FBC |  |  | Rel-6 | Maurice | SP-24 |  |
| 1629 | 480.10.2 | Study on providing policy control with FBC | 130d? | 2004-02-02 A | 2004-07-30 A | 100% | 2004-02-02 | 2004-07-30 | 130d? | start no earlier than 2004-02-01 | S2 | 1040h | 1040h | CH-FBC |  |  | Rel-6 | Maurice | SP-24 |  |
| 1630 | 480.10.3 | Gx interface for flow based charging | 223d? | 2004-02-02 A | 2004-12-08 A | 100% | 2004-02-02 | 2004-12-08 | 223d? | start no earlier than 2004-02-01 | N3 | 1784h | 1784h | CH-FBC | Nokia | juha.a.rasanen@nokia.com | Rel-6 | Gwiho | SP-25 |  |
| 1631 | 480.10.4 | Rx interface for flow based charging | 290d? | 2004-02-02 A | 2005-03-11 A | 100% | 2004-02-02 | 2005-03-11 | 290d? | finish no earlier than 2005-03-11 | N3 | 2320h | 2320h | CH-FBC | Nortel | Javier Gonzalez Gallego | Rel-6 | Gwiho | SP-25 |  |
| 1632 | 13 | **Rel-6 UICC/USIM enhancements and interworking** | 1164d? | 2000-09-25 A | 2005-03-10 A | 100% | 2000-09-25 | 2005-03-10 | 1164d? |  | T3 | 43088h | 43088h | USAT1 |  |  | Rel-6 | Xavier |  |  |
| 1633 | 13.1 | **UICC API** | 777d | 2002-03-20 A | 2005-03-10 A | 100% | 2002-03-20 | 2005-03-10 | 777d |  | T3 | 15024h | 15024h | USAT1-API |  |  | Rel-6 | Xavier |  |  |
| 1634 | 13.1.1 | Java API Test specification | 59d | 2002-03-20 A | 2002-06-10 A | 100% | 2002-03-20 | 2002-06-10 | 59d | finish no earlier than 2002-09-20 | T3 | 472h | 472h | USAT1-API | Microelectrónica Española | Mario Pérez | Rel-6 | Xavier |  |  |
| 1635 | 481.1.2 | 2G/3G Java Card™ API based applet interworking | 255d | 2003-03-17 A | 2004-03-05 A | 100% | 2003-03-17 | 2004-03-05 | 255d | finish no earlier than 2004-02-19 | T3 | 2040h | 2040h | USAT1-API | Oberthur Card Systems | Stéphane Andrau | Rel-6 | Xavier |  |  |
| 1636 | 481.1.3 | (U)SIM API for Java Card Testing | 519d | 2003-03-17 A | 2005-03-10 A | 100% | 2003-03-17 | 2005-03-10 | 519d | finish no earlier than 2005-03-10 | T3 | 4152h | 4152h | USAT1-API | Axalto | Christophe Begassat (cbegassat@axalto.com) | Rel-6 | Xavier |  |  |
| 1637 | 13.1.2 | Deleted - Java API Test specification (TS 43.019 Rel-5) | 268d | 2002-05-30 A | 2003-06-09 A | 100% | 2002-05-30 | 2003-06-09 | 268d | finish no earlier than 2003-09-17 | T3 | 2144h | 2144h | USAT1-API | Microelectrónica Española | Mario Pérez | Rel-6 | Xavier |  | TP-20 |
| 1638 | 481.2 | **Rel-6 USIM toolkit enhancements** | 1160d? | 2000-09-25 A | 2005-03-04 A | 100% | 2000-09-25 | 2005-03-04 | 1160d? |  | T3 | 21848h | 21848h | USAT1-API-MULTOS | Aspects Software | Neil Livingston | Rel-6 | Xavier |  |  |
| 1639 | 481.2.1 | **C SIM API** | 525d | 2000-09-25 A | 2002-09-27 A | 100% | 2000-09-25 | 2002-09-27 | 525d |  | T3 | 9960h | 9960h | USAT1-API-MULTOS | Aspects Software | Neil Livingston | Rel-6 | Xavier |  |  |
| 1640 | 481.2.1.1 | Specification | 525d | 2000-09-25 A | 2002-09-27 A | 100% | 2000-09-25 | 2002-09-27 | 525d | finish no earlier than 2002-09-27 | T3 | 4200h | 4200h | USAT1-API-MULTOS | Aspects Software | Neil Livingston | Rel-6 | Xavier |  |  |
| 1641 | 481.2.1.2 | Test specification | 195d | 2001-01-01 A | 2001-09-28 A | 100% | 2001-01-01 | 2001-09-28 | 195d | finish no earlier than 2001-09-28 | T3 | 1560h | 1560h | USAT1-API-MULTOS | Aspects Software | Neil Livingston | Rel-6 | Xavier |  |  |
| 1642 | 481.2.2 | USIM application toolkit Conformance Test Specification for Mobile Equipments | 326d? | 2003-12-05 A | 2005-03-04 A | 100% | 2003-12-05 | 2005-03-04 | 326d? | start no earlier than 2003-12-05 | T3 | 2608h | 2608h | USAT1-API-MULTOS | Gemplus | Eric.laffont@gemplus.com | Rel-6 | Xavier |  |  |
| 1643 | 482 | **Packet Switched Streaming Services Rel-6** | 798d? | 2002-11-18 A | 2005-12-07 A | 100% | 2002-11-18 | 2005-12-07 | 798d? |  | S4,S1 | 13304h | 13304h | PSSrel6 | Ericsson | olle.franceschi@ericsson.com | Rel-6 | Paolo |  |  |
| 1644 | 482.1 | Stage 1 | 86d? | 2002-11-18 A | 2003-03-17 A | 100% | 2002-11-18 | 2003-03-17 | 86d? | finish no earlier than 2003-03-17 | S1 | 688h | 688h | PSSrel6 | Ericsson |  | Rel-6 | Alain |  |  |
| 1645 | 482.2 | Stage 3 | 779d? | 2002-12-13 A | 2005-12-07 A | 100% | 2002-12-13 | 2005-12-07 | 779d? | finish no earlier than 2005-12-07 | S4 | 6232h | 6232h | PSSrel6-Stage3 | Ericsson | olle.franceschi@ericsson.com | Rel-6 | Paolo |  |  |
| 1646 | 483 | AMR-WB extension for high audio quality | 779d | 2002-12-13 A | 2005-12-07 A | 100% | 2002-12-13 | 2005-12-07 | 779d | finish no earlier than 2005-12-07 | S4 | 6232h | 6232h | AMRWB+ | Nokia | janne.m.vainio@nokia.com | Rel-6 | Paolo |  |  |
| 1647 | 484 | Codec Enhancements for Packet Switched Conversational Multimedia Applications | 198d? | 2004-03-16 A | 2004-12-16 A | 100% | 2004-03-16 | 2004-12-16 | 198d? | finish no earlier than 2004-12-16 | S4 | 1584h | 1584h | CEPSCM | Nokia | miska.hannuksela@nokia.com | Rel-6 | Paolo |  |  |
| 1648 | 485 | 3G-324M Improvements | 198d? | 2004-03-16 A | 2004-12-16 A | 100% | 2004-03-16 | 2004-12-16 | 198d? | finish no earlier than 2004-12-16 | S4 | 1584h | 1584h | 3G-324MI | Ericsson | bo.burman@ericsson.com | Rel-6 | Paolo |  |  |
| 1649 | 486 | Single Antenna Receiver Interference Cancellation (SAIC) | 420.92d? | 2002-11-15 A | 2004-06-25 A | 100% | 2002-11-15 | 2004-06-25 | 420.92d? | finish no earlier than 2004-08-27 | GP,G1 | 3367.36h | 3367.36h | SAIC | Cingular | Marc Grant | Rel-6 | Paolo |  |  |

Notes:
- 1621: SP#28 Target 09/2005 for WLAN Charging 32.252
- 1622: SP#23 03/2004 completed / Text3: 32.250
- 1623: SP#25 09/2004 completed / Text3: 32.251
- 1624: SP#25 09/2004 completed / Text3: 32.295
- 1625: SP#26 12/2004 completed / Text3: 32.260
- 1626: SP#26: Updated WID SP-040778 was SP-030050. Target completion 06/2005. Consisting of MMS-CH, LCS-CH, WLAN-CH, POC-CH, MBMS-CH / Text3: 32.252, 32.270, 32.271, 32.272
- 1627: - / Text3: 23.125
- 1628: -
- 1629: -
- 1630: - / Text3: 29.210
- 1631: - / Text3: 29.209
- 1632: -
- 1633: 8/3/2001: test spec is based on R99 core spec, so deleted from Workplan
- 1634: -
- 1635: -
- 1636: - / Text3: 31.213
- 1637: MOVED to Rel-5 WP
- 1638: -
- 1639: - / Text3: 31.101, 31.102, 31.103, 31.111, 31.113, new 31.115, 31.116
- 1640: -
- 1641: -
- 1642: - / Text3: 31.124
- 1643: -
- 1644: 2nd resp SA4 / Text3: 22.233
- 1645: TR tbc by Sept. 05 / Text3: 26.233, 26.234, 26.244, 26.245, 26.246, 26.401, 26.402, 26.403, 26.404, 26.405, 26.406, 26.410, 26.411, 26.412, 26.273, 26.290, 26.304, 26.412, 26.274, 26.936
- 1646: TR tbc by Sept. 05 / Text3: 26.290, 26.304, 26.273, 26.274, 26.412, 26.936
- 1647: - / Text3: 26.235, 26.236
- 1648: - / Text3: 26.111, 26.911
- 1649: - / Text3: 45.903

| ID | WBS | Task | Type | Duration | Start | Finish | Complete | Baseline start | Baseline finish | Baseline duration | Constraint | Resources | Work | Actual work | Text1 | Text3 | Text4 | Text5 | Text6 | Text8 | Text12 |
| --- | --- | --- | --- | --- | --- | --- | --- | --- | --- | --- | --- | --- | --- | --- | --- | --- | --- | --- | --- | --- | --- |
| 1650 | 487 | **Enhancement of dialled service for CAMEL** |  | 199d | 2003-03-28 A | 2003-12-31 A | 100% | 2003-03-28 | 2003-12-31 | 199d |  | S1,N2,N4 | 3184h | 3184h | EDCAMEL | 22.078 | Samsung | Craig Bishop | Rel-6 | Alain |  |
| 1651 | 487.1 | Stages 2 and 3 |  | 199d | 2003-03-28 A | 2003-12-31 A | 100% | 2003-03-28 | 2003-12-31 | 199d | finish no earlier than 2003-09-19 | N2,N4 | 1592h | 1592h | EDCAMEL | 23.008, 23.016, 23.018, 23.078, 29.002, 29.078 | Samsung | Richard Brook | Rel-6 | Kimmo |  |
| 1652 | 488 | Study on Bandwidth and resource savings in CS networks |  | 273d? | 2003-06-01 A | 2004-06-16 A | 100% | 2003-06-01 | 2004-06-16 | 273d? | finish no earlier than 2004-06-16 | S2 | 2184h | 2184h | BARS | 23.977 |  |  | Rel-6 | Maurice |  |
| 1653 | 489 | FS on (U)SIM Security Reuse by Peripheral Devices on Local Interfaces |  | 127d? | 2003-07-03 A | 2003-12-26 A | 100% | 2003-07-03 | 2003-12-26 | 127d? | finish no earlier than 2003-12-26 | S3 | 1016h | 1016h |  | 33.817 | Toshiba | Raziq Yaqub (ryaqub@tari.toshiba.com) | Rel-6 | Dionisio |  |
| 1654 | 490 | **Multiple TBF in A/Gb mode** |  | 736d? | 2002-04-05 A | 2005-01-28 A | 100% | 2002-04-05 | 2005-01-28 | 736d? |  | GP,G2 | 17600h | 17600h | MULTBF |  | Ericsson | gunnar.mildh@era.ericsson.se | Rel-6 | Paolo |  |
| 1655 | 490.1 | **Multiple TBF in A/Gb mode** |  | 366d? | 2002-04-05 A | 2003-08-29 A | 100% | 2002-04-05 | 2003-08-29 | 366d? |  | GP,G2 | 11712h | 11712h | MULTBF-Agbmode |  | Ericsson | gunnar.mildh@era.ericsson.se | Rel-6 | Paolo |  |
| 1656 | 490.1.1 | Multiple TBF Concept paper |  | 366d? | 2002-04-05 A | 2003-08-29 A | 100% | 2002-04-05 | 2003-08-29 | 366d? | finish no earlier than 2003-08-29 | GP,G2 | 2928h | 2928h | MULTBF-Agbmode |  |  |  | Rel-6 | Paolo |  |
| 1657 | 490.1.2 | Multiple TBF Stage 2 (43.064) CRs |  | 366d? | 2002-04-05 A | 2003-08-29 A | 100% | 2002-04-05 | 2003-08-29 | 366d? | finish no earlier than 2003-08-29 | GP,G2 | 2928h | 2928h | MULTBF-Agbmode |  |  |  | Rel-6 | Paolo |  |
| 1658 | 490.1.3 | Multiple TBF Stage 3 (44.060) CRs |  | 366d? | 2002-04-05 A | 2003-08-29 A | 100% | 2002-04-05 | 2003-08-29 | 366d? | finish no earlier than 2003-08-29 | GP,G2 | 2928h | 2928h | MULTBF-Agbmode |  |  |  | Rel-6 | Paolo |  |
| 1659 | 490.2 | Deleted - Multiple TBF in A/Gb mode – MS testing | milestone | 0d? | 2005-01-28 A | 2005-01-28 A | 100% | 2005-01-28 | 2005-01-28 | 0d? | start no earlier than 2005-01-28 | G3new |  |  | MULTBF-Testing |  | Ericsson | gunnar.mildh@era.ericsson.se | Rel-6 | Paolo | GP-27 |
| 1660 | 491 | **Alignment between the test-regimes for GERAN capable MS** |  | 526d? | 2003-08-29 A | 2005-09-02 A | 100% | 2003-08-29 | 2005-09-02 | 526d? |  | G3new | 4208h | 4208h | ALTERE |  | Ericsson | Toubassi | Rel-6 | Ingbert |  |
| 1661 | 491.1 | Determine the controversial test cases in the different test regimes and align them with 3GPP GERAN test specifications. Such test cases to be added to TS 51.010. |  | 526d? | 2003-08-29 A | 2005-09-02 A | 100% | 2003-08-29 | 2005-09-02 | 526d? | finish no earlier than 2005-09-02 | G3new | 4208h | 4208h | ALTERE-TC |  |  |  | Rel-6 | Ingbert |  |
| 1662 | 492 | Addition of U-TDOA in the CS domain |  | 111d? | 2003-11-21 A | 2004-04-23 A | 100% | 2003-11-21 | 2004-04-23 | 111d? | finish no earlier than 2004-04-23 | GP | 888h | 888h | UTDOACS |  | TruePosition | Bob Gross, Rhys Robinson (rlgross@trueposition.com) | Rel-6 | Paolo |  |
| 1663 | 493 | Addition of U-TDOA in the PS domain |  | 361d? | 2003-06-27 A | 2004-11-12 A | 100% | 2003-06-27 | 2004-11-12 | 361d? | finish no earlier than 2004-11-12 | GP | 2888h | 2888h | UTDOAPS |  | TruePosition | Bob Gross, Rhys Robinson (rlgross@trueposition.com) | Rel-6 | Paolo |  |
| 1664 | 494 | **Downlink Advanced Receiver Performance** |  | 466d? | 2003-11-21 A | 2005-09-02 A | 100% | 2003-11-21 | 2005-09-02 | 466d? |  | GP | 19160h | 19160h | DARP |  | Nokia | tommy.bysted@nokia.com | Rel-6 | Paolo |  |
| 1665 | 494.1 | DARP test scenarios |  | 201d? | 2003-11-21 A | 2004-08-27 A | 100% | 2003-11-21 | 2004-08-27 | 201d? | finish no earlier than 2004-08-27 | GP | 1608h | 1608h | DARP-TS |  | Nokia | tommy.bysted@nokia.com | Rel-6 | Paolo |  |
| 1666 | 494.2 | **DARP for GMSK modulated voice services** |  | 201d? | 2004-02-06 A | 2004-11-12 A | 100% | 2004-02-06 | 2004-11-12 | 201d? |  | GP | 4824h | 4824h | DARP-GMSK |  | Nokia | tommy.bysted@nokia.com | Rel-6 | Paolo |  |
| 1667 | 494.2.1 | Performance requirements in 45.005 |  | 201d? | 2004-02-06 A | 2004-11-12 A | 100% | 2004-02-06 | 2004-11-12 | 201d? | finish no earlier than 2004-11-12 | GP | 1608h | 1608h | DARP-GMSK-Perf |  |  |  | Rel-6 | Paolo |  |
| 1668 | 494.2.2 | Radio subsystem link control in 45.008 |  | 201d? | 2004-02-06 A | 2004-11-12 A | 100% | 2004-02-06 | 2004-11-12 | 201d? | finish no earlier than 2004-11-12 | GP | 1608h | 1608h | DARP-GMSK-LC |  |  |  | Rel-6 | Paolo |  |
| 1669 | 494.3 | **DARP for GPRS and EGPRS MCS1-MCS4** |  | 201d? | 2004-02-06 A | 2004-11-12 A | 100% | 2004-02-06 | 2004-11-12 | 201d? |  | GP | 4824h | 4824h | DARP-GPRSE |  | Nokia | tommy.bysted@nokia.com | Rel-6 | Paolo |  |
| 1670 | 494.3.1 | Performance requirements in 45.005 |  | 201d? | 2004-02-06 A | 2004-11-12 A | 100% | 2004-02-06 | 2004-11-12 | 201d? | finish no earlier than 2004-11-12 | GP | 1608h | 1608h | DARP-GPRSE-Perf |  |  |  | Rel-6 | Paolo |  |
| 1671 | 494.3.2 | Radio subsystem link control in 45.008 |  | 201d? | 2004-02-06 A | 2004-11-12 A | 100% | 2004-02-06 | 2004-11-12 | 201d? | finish no earlier than 2004-11-12 | GP | 1608h | 1608h | DARP-GPRSE-LC |  |  |  | Rel-6 | Paolo |  |
| 1672 | 494.4 | DARP Capability signalling |  | 256d? | 2003-11-21 A | 2004-11-12 A | 100% | 2003-11-21 | 2004-11-12 | 256d? | finish no earlier than 2004-11-12 | GP | 2048h | 2048h | DARP-CAPSIG |  | Nokia | tommy.bysted@nokia.com | Rel-6 | Paolo |  |
| 1673 | 494.5 | GERAN MS Conformance test for DARP |  | 266d? | 2004-08-27 A | 2005-09-02 A | 100% | 2004-08-27 | 2005-09-02 | 266d? | finish no earlier than 2005-06-24 | G3new | 2128h | 2128h | ARP-ConfTest |  | Nokia | tommy.bysted@nokia.com | Rel-6 | Ingbert |  |

Notes:
- 1650: -
- 1651: -
- 1652: -
- 1653: Approved TSG#20
- 1654: GP#17 Nov 2003 Moved from Rel-5 UID_50058 MULTBF (Only Multiple TBF Concept paper produced in Rel-5)
- 1655: -
- 1656: -
- 1657: -
- 1658: -
- 1659: -
- 1660: -
- 1661: -
- 1662: Completed, except for potential LMU performance specs
- 1663: -
- 1664: -
- 1665: -
- 1666: -
- 1667: -
- 1668: -
- 1669: -
- 1670: -
- 1671: -
- 1672: -
- 1673: -

| ID | WBS | Task | Type | Duration | Start | Finish | Complete | Baseline start | Baseline finish | Baseline duration | Constraint | Resources | Work | Actual work | Text1 | Text4 | Text5 | Text6 | Text8 | Text12 | Text3 | Text10 |
| --- | --- | --- | --- | --- | --- | --- | --- | --- | --- | --- | --- | --- | --- | --- | --- | --- | --- | --- | --- | --- | --- | --- |
| 1674 | 495 | **Reduction of PS service interruption in Dual Transfer Mode** |  | 416d? | 2003-11-21 A | 2005-06-24 A | 100% | 2003-11-21 | 2005-06-24 | 416d? |  | G2 | 8360h | 8360h | PSintDTM | Siemens | toby.proctor@roke.co.uk | Rel-6 | Gert |  |  |  |
| 1675 | 495.1 | Use case and requirement definition |  | 111d? | 2003-11-21 A | 2004-04-23 A | 100% | 2003-11-21 | 2004-04-23 | 111d? | finish no earlier than 2004-04-23 | G2 | 888h | 888h | PSintDTM-Req | Siemens | toby.proctor@roke.co.uk | Rel-6 | Gert |  |  |  |
| 1676 | 495.2 | Performance Study of Current Procedures |  | 111d? | 2003-11-21 A | 2004-04-23 A | 100% | 2003-11-21 | 2004-04-23 | 111d? | start no earlier than 2003-11-21 | G2 | 888h | 888h | PSintDTM-Perf | Siemens | toby.proctor@roke.co.uk | Rel-6 | Gert |  |  |  |
| 1677 | 495.3 | Reduction of service interruption times and packet loss during Dual Transfer Mode and mobility procedures |  | 146d? | 2004-04-23 A | 2004-11-12 A | 100% | 2004-04-23 | 2004-11-12 | 146d? | finish no earlier than 2004-11-12 | G2 | 1168h | 1168h | PSintDTM-Reduct | Siemens | toby.proctor@roke.co.uk | Rel-6 | Gert |  |  |  |
| 1678 | 495.4 | Deleted - MS Conformance testing - Reduction of PS service interruption in DTM |  | 261d? | 2004-06-25 A | 2005-06-24 A | 100% | 2004-06-25 | 2005-06-24 | 261d? | finish no earlier than 2005-06-24 | G3new | 2088h | 2088h | PSintDTM-ConfMS |  |  | Rel-6 | Ingbert | GP-25 |  |  |
| 1679 | 495.5 | Deleted - BTS Conformance testing - Reduction of PS service interruption in DTM | milestone | 0d? | 2005-06-24 A | 2005-06-24 A | 100% | 2005-06-24 | 2005-06-24 | 0d? | finish no earlier than 2005-06-24 | G3new |  |  | PSintDTM-ConfBTS |  |  | Rel-6 | Ingbert | GP-25 |  |  |
| 1680 | 496 | CAMEL prepay interworking with SCUDIF |  | 216.3d | 2003-12-08 A | 2004-10-05 A | 100% | 2003-12-08 | 2004-10-05 | 216.3d |  | N4,N3,S1 | 1730.4h | 1730.4h | SCCAMEL | Nokia | Keijo.Palviainen@Nokia.Com | Rel-6 | Kimmo |  | 22.078, 23.078, 29.078, 29.002, 23.172 |  |
| 1681 | 497 | **Circuit Switched Video and Voice Service Improvements** |  | 430d? | 2004-01-12 A | 2005-09-02 A | 100% | 2004-01-12 | 2005-09-02 | 430d? |  | S2,C1 | 9256h | 9256h | CS_VSS | Vodafone | John Watson | Rel-6 | Alain |  |  |  |
| 1682 | 497.1 | Deleted - Stage 1 - Requirements |  | 199d | 2004-01-12 A | 2004-10-14 A | 100% | 2004-01-12 | 2004-10-14 | 199d | finish no earlier than 2004-10-14 | S1 | 1592h | 1592h | CS_VSS | Vodafone | John Watson | Rel-6 | Alain | SP-26 | 22.101 |  |
| 1683 | 497.2 | Stage 2 Study on architecture alternatives |  | 244d? | 2004-01-12 A | 2004-12-16 A | 100% | 2004-01-12 | 2004-12-16 | 244d? | finish no earlier than 2004-08-13 | S2 | 1952h | 1952h | CS_VSS | Vodafone | Chris Pudney | Rel-6 | Maurice |  | 23.903 | SP-24 |
| 1684 | 497.3 | Deleted - Stage 2 description on Redial |  | 164d? | 2004-05-03 A | 2004-12-16 A | 100% | 2004-05-03 | 2004-12-16 | 164d? | finish no earlier than 2004-12-16 | S2 | 1312h | 1312h | CS_VSS | Vodafone | Chris Pudney | Rel-6 | Maurice | SP-26 |  | SP-24 |
| 1685 | 497.4 | Switching between voice and video call - Redial solution |  | 120d? | 2005-01-03 A | 2005-06-17 A | 100% | 2005-01-03 | 2005-06-17 | 120d? | start no earlier than 2005-01-03 | C1 | 960h | 960h | CS_VSS | Vodafone |  | Rel-6 | Frederic |  | 23.009, 24.008 |  |
| 1686 | 497.5 | Deleted - CS_VSS - GERAN2 Part | milestone | 0d | 2005-09-02 A | 2005-09-02 A | 100% | 2005-09-02 | 2005-09-02 | 0d | start no earlier than 2005-09-02 | G2 |  |  | CS_VSS | Vodafone |  | Rel-6 | Gert | GP-26 |  |  |
| 1687 | 497.6 | Deleted - CS_VSS - CN3 Part | milestone | 0d? | 2004-10-14 A | 2004-10-14 A | 100% | 2004-10-14 | 2004-10-14 | 0d? | start no earlier than 2004-10-14 | N3 |  |  | CS_VSS | Vodafone |  | Rel-6 | Gwiho | TP-26 |  |  |
| 1688 | 498 | Network Domain Security; MAP application layer security (NDS/MAPsec) |  | 127d? | 2004-07-06 A | 2004-12-29 A | 100% | 2004-07-06 | 2004-12-29 | 127d? | finish no earlier than 2003-12-26 | S3 | 1016h | 1016h | MAPSEC | Vodafone | Peter.Howard@vodafone.com | Rel-6 | Dionisio |  |  |  |
| 1689 | 499 | FS on Security for early IMS |  | 127d? | 2004-10-01 A | 2005-03-28 A | 100% | 2004-10-01 | 2005-03-28 | 127d? | finish no earlier than 2003-12-26 | S3 | 1016h | 1016h | SEC-IMS | Vodafone | Peter.Howard@vodafone.com | Rel-6 | Dionisio |  | 33.978 |  |
| 1690 | 500 | Reorganisation of CS Data Specifications |  | 14d? | 2004-11-19 A | 2004-12-08 A | 100% | 2004-11-19 | 2004-12-08 | 14d? | finish no earlier than 2004-12-24 | N3 | 112h | 112h | CS Data | Siemens | Thomas.Belling@nsn.com | Rel-6 | Gwiho |  | 23.910, 29.007, new 23.202 |  |
| 1691 | 501 | **Generic Access to A/Gb Interface (GAAI)** |  | 411d? | 2004-06-25 A | 2006-01-20 A | 100% | 2004-06-25 | 2006-01-20 | 411d? |  | GP | 9160h | 9160h | GAAI | Motorola |  | Rel-6 | Paolo |  |  |  |
| 1692 | 501.1 | FS on GAAI |  | 46d? | 2004-06-25 A | 2004-08-27 A | 100% | 2004-06-25 | 2004-08-27 | 46d? | finish no earlier than 2004-08-27 | GP | 368h | 368h | GAAG | Motorola |  | Rel-6 | Paolo |  | 43.901 |  |
| 1693 | 501.2 | GAAI – Stage 2 |  | 161d? | 2004-08-27 A | 2005-04-08 A | 100% | 2004-08-27 | 2005-04-08 | 161d? | finish no earlier than 2005-04-08 | GP | 1288h | 1288h | GAAI-Stage2 | Ericsson | jari.vikberg@ericsson.com | Rel-6 | Paolo |  | 43.318 |  |
| 1694 | 501.3 | GAAI – Stage 3 |  | 161d? | 2004-08-27 A | 2005-04-08 A | 100% | 2004-08-27 | 2005-04-08 | 161d? | finish no earlier than 2005-04-08 | GP | 1288h | 1288h | GAAI-Stage3 |  |  | Rel-6 | Paolo |  | 44.318 |  |
| 1695 | 501.4 | MS Conformance Test for GAAI |  | 366d? | 2004-08-27 A | 2006-01-20 A | 100% | 2004-08-27 | 2006-01-20 | 366d? | finish no earlier than 2006-01-20 | GP | 2928h | 2928h | GAAI-CT |  |  | Rel-6 | Ingbert |  |  |  |
| 1696 | 502 | **Support of PS Handover for GERAN A/Gb mode** |  | 473d? | 2003-11-03 A | 2005-08-24 A | 100% | 2003-11-03 | 2005-08-24 | 473d? |  | GP,G2 | 11352h | 11352h | SPSHAGB | Ericsson | gunnar.hedby@ericsson.com | Rel-6 | Paolo |  |  |  |
| 1697 | 502.1 | Stage 2 |  | 473d? | 2003-11-03 A | 2005-08-24 A | 100% | 2003-11-03 | 2005-08-24 | 473d? | finish no earlier than 2005-09-02 | GP,G2 | 3784h | 3784h | SPSHAGB-Stage2 | Ericsson | gunnar.hedby@ericsson.com | Rel-6 | Paolo |  | 43.129 |  |
| 1698 | 502.2 | PS handover |  | 473d? | 2003-11-03 A | 2005-08-24 A | 100% | 2003-11-03 | 2005-08-24 | 473d? | finish no earlier than 2005-09-02 | GP,G2 | 3784h | 3784h | SPSHAGB-PSHO | Ericsson | gunnar.hedby@ericsson.com | Rel-6 | Paolo |  |  |  |
| 1699 | 502.3 | Definition of radio resource management functionality |  | 473d? | 2003-11-03 A | 2005-08-24 A | 100% | 2003-11-03 | 2005-08-24 | 473d? | finish no earlier than 2005-09-02 | GP,G2 | 3784h | 3784h | SPSHAGB-RRM | Ericsson | gunnar.hedby@ericsson.com | Rel-6 | Paolo |  |  |  |

Notes:
- 1674: -
- 1675: -
- 1676: -
- 1677: -
- 1678: -
- 1679: -
- 1680: -
- 1681: -
- 1682: -
- 1683: -
- 1684: -
- 1685: -
- 1686: -
- 1687: -
- 1688: Approved TSG#24. Marked as closed 12/2008 (was marked 20% complete)
- 1689: SP#24 approved WID. SP#27 completed. SP#46 TR 33.978 withdrawn from Rel-8 onwards
- 1690: Created at TSG#27 as 100 % complete
- 1691: -
- 1692: Feasibility Study
- 1693: -
- 1694: -
- 1695: Marked as closed 12/2008 (was marked 90% complete)
- 1696: Replaces SCSAGB- Originally Started Nov 2003 as GP-030443
- 1697: Replaces SCSAGB-Stage2
- 1698: Replaces SCSAGB-PSH
- 1699: Replaces SCSAGB-RRM

| ID | WBS | Task | Type | Duration | Start | Finish | Complete | Baseline start | Baseline finish | Baseline duration | Total slack | Constraint | Resources | Work | Actual work | Text1 | Text6 | Text8 | Text3 | Text12 | Text4 | Text5 |
| --- | --- | --- | --- | --- | --- | --- | --- | --- | --- | --- | --- | --- | --- | --- | --- | --- | --- | --- | --- | --- | --- | --- |
| 1700 | 503 | **small Technical Enhancements and Improvements for Rel-6** |  | 503d? | 2006-06-02 A | 2008-05-06 A | 100% | 2006-06-02 | 2008-05-06 | 503d? |  |  | All | 4024h | 4024h | TEI6 | Rel-6 | all |  |  |  |  |
| 1701 | 503.1 | Small Technical Enhancements and Improvements for Rel-6 Conformance Testing |  | 503d? | 2006-06-02 A | 2008-05-06 A | 100% | 2006-06-02 | 2008-05-06 | 503d? |  | start no earlier than 2006-06-02 | R5,T1 | 4024h | 4024h | TEI6_Test | Rel-6 | Ingbert | 34.108,34.121-1/2,34.122,34.123-1/2/3 |  |  |  |
| 1702 | 504 | Deleted - Study of Feature Interactions Requirements | milestone | 0d? | 2004-09-16 A | 2004-09-16 A | 100% | 2004-09-16 | 2004-09-16 | 0d? |  | finish no earlier than 2004-10-01 | S1 |  |  | FINTER | Rel-6 | Alain |  | SP-25 |  |  |
| 1703 | 505 | Deleted - Enhancements of VGCS in public networks for communication of public authority officials |  | 7d? | 2005-08-24 A | 2005-09-02 A | 100% | 2005-08-24 | 2005-09-02 | 7d? |  | start no earlier than 2005-08-24 | GP,G2 | 56h | 56h | EVGCS | Rel-6 | Paolo | 44.018, 44.068, 48.008 | GP-26 | Siemens | kenneth.isaacs@roke.co.uk |
| 1704 | 506 | **Deleted - Support of Conversational Services in A/Gb mode via the PS domain** |  | 64d? | 2003-11-21 A | 2004-02-19 A | 100% | 2003-11-21 | 2004-02-19 | 64d? |  |  | GP,N1 | 1024h | 1024h | SCSAGB | Rel-6 | Paolo |  | GP-18 | Ericsson | David Bladsjö (david.bladsjo@ericsson.com) |
| 1705 | 506.1 | Deleted - Creation of a TR | milestone | 0d? | 2003-11-21 A | 2003-11-21 A | 100% | 2003-11-21 | 2003-11-21 | 0d? |  | start no earlier than 2003-11-21 | GP |  |  | SCSAGB-TR | Rel-6 | Paolo |  | GP-17 | Ericsson | David Bladsjö (david.bladsjo@ericsson.com) |
| 1706 | 506.2 | Deleted - Stage 2 | milestone | 0d? | 2003-11-21 A | 2003-11-21 A | 100% | 2003-11-21 | 2003-11-21 | 0d? |  | finish no earlier than 2003-11-21 | GP |  |  | SCSAGB-Stage2 | Rel-6 | Paolo |  | GP-17 | Ericsson | David Bladsjö (david.bladsjo@ericsson.com) |
| 1707 | 506.3 | Deleted - Radio Channel Support | milestone | 0d? | 2003-11-21 A | 2003-11-21 A | 100% | 2003-11-21 | 2003-11-21 | 0d? |  | finish no earlier than 2003-11-21 | GP |  |  | SCSAGB-RCS | Rel-6 | Paolo |  | GP-17 | Ericsson | David Bladsjö (david.bladsjo@ericsson.com) |
| 1708 | 506.4 | Deleted - Definition of radio resource management functionality | milestone | 0d? | 2003-11-21 A | 2003-11-21 A | 100% | 2003-11-21 | 2003-11-21 | 0d? |  | finish no earlier than 2003-11-21 | GP |  |  | SCSAGB-RRM | Rel-6 | Paolo |  | GP-17 | Ericsson | David Bladsjö (david.bladsjo@ericsson.com) |
| 1709 | 506.5 | Deleted - replaced by 50561 - PS Handover |  | 64d | 2003-11-21 A | 2004-02-19 A | 100% | 2003-11-21 | 2004-02-19 | 64d |  | start no earlier than 2003-11-21 | GP,N1 | 512h | 512h | SCSAGB-PSH | Rel-6 | Paolo |  | GP-18 | Ericsson | David Bladsjö (david.bladsjo@ericsson.com) |
| 1710 | 506.6 | Deleted - Modifications to FLO | milestone | 0d? | 2003-11-21 A | 2003-11-21 A | 100% | 2003-11-21 | 2003-11-21 | 0d? |  | finish no earlier than 2003-11-21 | GP |  |  | SCSAGB-FLO | Rel-6 | Paolo |  | RP-29 | Ericsson | David Bladsjö (david.bladsjo@ericsson.com) |
| 1711 | 507 | Deleted - Rel-6 Evolutions of the transport in the UTRAN | milestone | 0d | 2003-12-31 A | 2003-12-31 A | 100% | 2003-12-31 | 2003-12-31 | 0d |  | start no earlier than 2003-12-31 | RP |  |  | ETRAN | Rel-6 | Issam |  | RP-22 | Alcatel | Francois Courau |
| 1712 | 508 | Release 5 Features |  | 1d? | 2000-01-03 | 2000-01-03 |  | 2000-01-03 | 2000-01-03 | 1d? | 3056d |  | NP,GP, RP,SP,TP | 8h |  |  | Rel-5 |  |  |  |  |  |
| 1713 | 75 | IP transport in the UTRAN |  | 445d | 2000-07-17 A | 2002-03-29 A | 100% | 2000-07-17 | 2002-03-29 | 445d |  | finish no earlier than 2002-03-29 | R3 | 3560h | 3560h | ETRAN-IPtrans | Rel-5 | Juha |  |  | Alcatel | Nicolas Drevon |
| 1714 | 76 | FS on Usage of SUA |  | 205d | 2001-03-12 A | 2001-12-21 A | 100% | 2001-03-12 | 2001-12-21 | 205d |  | finish no earlier than 2001-12-21 | N4 | 1640h | 1640h | SS7IP | Rel-5 | Kimmo |  |  |  |  |
| 1715 | 77 | **High Speed Downlink Packet Access** |  | 570d | 2001-04-02 A | 2003-06-06 A | 100% | 2001-04-02 | 2003-06-06 | 570d |  |  | R2 | 15272h | 15272h | HSDPA | Rel-5 | Joern |  |  | Motorola | Ravi Kuchibhotla |
| 1716 | 77.1 | Physical Layer |  | 257d | 2001-04-05 A | 2002-03-29 A | 100% | 2001-04-05 | 2002-03-29 | 257d |  | finish no earlier than 2002-03-29 | R1 | 2056h | 2056h | HSDPA-Phys | Rel-5 | Patrick |  |  | Motorola | Amitava Ghosh |
| 1717 | 77.2 | Layer 2 and 3 aspects |  | 257d | 2001-04-05 A | 2002-03-29 A | 100% | 2001-04-05 | 2002-03-29 | 257d |  | finish no earlier than 2002-03-29 | R2 | 2056h | 2056h | HSDPA-L23 | Rel-5 | Joern |  |  | Motorola | Ravi Kuchibhotla |
| 1718 | 77.3 | Iub/Iur protocol aspects |  | 260d | 2001-04-02 A | 2002-03-29 A | 100% | 2001-04-02 | 2002-03-29 | 260d |  | finish no earlier than 2002-03-29 | R3 | 2080h | 2080h | HSDPA-IubIur | Rel-5 | Juha |  |  | Motorola | Mike Diesen |
| 1719 | 77.4 | RF Radio Transmission/ Reception, System Performance Requirements and Conformance Testing |  | 565d | 2001-04-09 A | 2003-06-06 A | 100% | 2001-04-09 | 2003-06-06 | 565d |  | finish no earlier than 2003-06-06 | R4 | 4520h | 4520h | HSDPA-RF | Rel-5 | Issam |  |  | Motorola | Howard Benn |
| 1720 | 78 | **Rel-5 Improvements of Radio Interface** |  | 535d | 2000-08-14 A | 2002-08-30 A | 100% | 2000-08-14 | 2002-08-30 | 535d |  |  | RP | 30376h | 30376h | RInImp | Rel-5 |  |  |  |  |  |
| 1721 | 78.1 | **Base station classification** |  | 480d | 2000-08-14 A | 2002-06-14 A | 100% | 2000-08-14 | 2002-06-14 | 480d |  |  | R4 | 9208h | 9208h | RInImp-BSClass | Rel-5 | Issam |  |  | Nokia | antti.toskala@nokia.com |
| 1722 | 78.1.1 | TDD Base station classification |  | 410d | 2000-08-14 A | 2002-03-08 A | 100% | 2000-08-14 | 2002-03-08 | 410d |  | finish no earlier than 2002-03-08 | R4 | 3280h | 3280h | RInImp-BSClass-TDD | Rel-5 | Issam |  |  | Nokia | antti.toskala@nokia.com |
| 1723 | 78.1.2 | Base Station Classification for 1.28 Mcps TDD option |  | 261d | 2001-06-15 A | 2002-06-14 A | 100% | 2001-06-15 | 2002-06-14 | 261d |  | finish no earlier than 2002-06-14 | R4 | 2088h | 2088h | RInImp-BSClass-LCRTDD | Rel-5 | Issam |  |  | Siemens | Meik.Kottkamp@siemens.com |
| 1724 | 78.2 | Enhancement on the DSCH hard split mode |  | 271d | 2001-03-16 A | 2002-03-29 A | 100% | 2001-03-16 | 2002-03-29 | 271d |  | finish no earlier than 2002-03-29 | R1 | 2168h | 2168h | RInImp-DSCHhsp | Rel-5 | Patrick |  |  | Samsung | Jaeyoel KIM |
| 1725 | 78.3 | Hybrid ARQ II/III |  | 355d | 2000-08-21 A | 2001-12-28 A | 100% | 2000-08-21 | 2001-12-28 | 355d |  | finish no earlier than 2001-12-28 | R2 | 2840h | 2840h | RInImp-HARQ | Rel-5 | Joern |  | RP-14 | Siemens | A. Sitte |
| 1726 | 78.4 | FS on USTS |  | 355d | 2000-08-14 A | 2001-12-21 A | 100% | 2000-08-14 | 2001-12-21 | 355d |  | finish no earlier than 2001-12-21 | R1 | 2840h | 2840h | RInImp-USTS | Rel-5 | Patrick |  |  | SK Telecom | D. Kim |
| 1727 | 78.5 | FS on UE antenna efficiency test method performance requirements |  | 255d | 2000-09-25 A | 2001-09-14 A | 100% | 2000-09-25 | 2001-09-14 | 255d |  | finish no earlier than 2001-09-14 | R4 | 2040h | 2040h | RInImp-UEAnTM | Rel-5 | Issam |  |  | Allgon | O. Edvardsson |
| 1728 | 78.6 | FS on the re-introduction of the downlink SIR measurement |  | 200d | 2001-03-12 A | 2001-12-14 A | 100% | 2001-03-12 | 2001-12-14 | 200d |  | finish no earlier than 2001-12-14 | R4 | 1600h | 1600h | RInImp-SIR | Rel-5 | Issam |  |  | Ericsson | Torgny.Palenius@ericsson.com |
| 1729 | 78.7 | FS on mitigating the effect of CPICH interference at the UE |  | 255d | 2001-03-19 A | 2002-03-08 A | 100% | 2001-03-19 | 2002-03-08 | 255d |  | finish no earlier than 2002-03-08 | R4 | 2040h | 2040h | RInImp-CPICH_Intf | Rel-5 | Issam |  |  | Intel | shimon.moshavi@INTEL.COM |

Notes:
- 1700: "Joker" WI, to be used for a Rel 6 CR not related to any feature and with very limited impact on the system. Moved in from Stoyan/Testing WP
- 1701: "Joker" WI, to be used for small modifications applicable to Rel 4 conformance testing
- 1702: SP#25 stopped
- 1703: GP#26 moved to Rel-7 as UID_11045 Enhancements of VGCS in public networks for communication of public authority officials
- 1704: -
- 1705: -
- 1706: Started
- 1707: Not started
- 1708: Not started
- 1709: Started
- 1710: Not started
- 1711: Generic feature
- 1712: -
- 1713: -
- 1714: -
- 1715: -
- 1716: -
- 1717: -
- 1718: -
- 1719: -
- 1720: -
- 1721: -
- 1722: -
- 1723: -
- 1724: -
- 1725: Stopped at RP#14; work on this task was performed as part of High Speed Downlink Packet Access feature
- 1726: -
- 1727: -
- 1728: -
- 1729: -

| ID | WBS | Task | Duration | Start | Finish | Complete | Baseline start | Baseline finish | Baseline duration | Constraint | Resources | Work | Actual work | Text6 | Text8 | Text12 | Text1 | Text4 | Text5 | Text3 |
| --- | --- | --- | --- | --- | --- | --- | --- | --- | --- | --- | --- | --- | --- | --- | --- | --- | --- | --- | --- | --- |
| 1730 | 78.8 | **Deleted - Conformance Test Spec. improvements in Radio Interface** | 140d | 2002-02-18 A | 2002-08-30 A | 100% | 2002-02-18 | 2002-08-30 | 140d |  | T1 | 3360h | 3360h | Rel-5 | Ingbert | TP-17 |  |  |  |  |
| 1731 | 78.8.1 | Deleted - Testing improvement of inter-frequency and inter-system measurement | 140d | 2002-02-18 A | 2002-08-30 A | 100% | 2002-02-18 | 2002-08-30 | 140d | finish no earlier than 2002-08-30 | T1 | 1120h | 1120h | Rel-5 | Ingbert | TP-17 |  |  |  |  |
| 1732 | 78.8.2 | Deleted - Testing Hybrid ARQ II/III | 140d | 2002-02-18 A | 2002-08-30 A | 100% | 2002-02-18 | 2002-08-30 | 140d | finish no earlier than 2002-08-30 | T1 | 1120h | 1120h | Rel-5 | Ingbert | TP-17 |  |  |  |  |
| 1733 | 79 | **Rel-5 RAN improvements** | 772d? | 2001-03-16 A | 2004-03-01 A | 100% | 2001-03-16 | 2004-03-01 | 772d? |  | RP | 39984h | 39984h | Rel-5 |  |  | RANimp |  |  |  |
| 1734 | 79.1 | **RRM optimization for Iur and Iub** | 318d | 2001-03-16 A | 2002-06-04 A | 100% | 2001-03-16 | 2002-06-04 | 318d |  | R3 | 8904h | 8904h | Rel-5 | Juha |  | RANimp-RRMopt | Ericsson | Gert-Jan.van.Lieshout@eln.ericsson.se |  |
| 1735 | 79.1.1 | Iur common transport channel efficiency optimization | 271d | 2001-03-16 A | 2002-03-29 A | 100% | 2001-03-16 | 2002-03-29 | 271d | finish no earlier than 2002-03-29 | R3 | 2168h | 2168h | Rel-5 | Juha |  | RANimp-RRMopt-ctc | Ericsson | Shahrokh Amirijoo |  |
| 1736 | 79.1.2 | Iur neighbouring cell reporting efficiency optimization | 271d | 2001-03-16 A | 2002-03-29 A | 100% | 2001-03-16 | 2002-03-29 | 271d | finish no earlier than 2002-03-29 | R3 | 2168h | 2168h | Rel-5 | Juha |  | RANimp-RRMopt-ncr | Ericsson | Shahrokh Amirijoo |  |
| 1737 | 79.1.3 | FS Introduction of direct transport bearers between SRNC and Node-B | 253d | 2001-06-15 A | 2002-06-04 A | 100% | 2001-06-15 | 2002-06-04 | 253d | finish no earlier than 2002-06-28 | R3 | 2024h | 2024h | Rel-5 | Juha |  | RAN-imp-RRMopt-DTB | Ericsson | Risto Sepponen |  |
| 1738 | 79.2 | RL Timing Adjustment | 271d | 2001-03-16 A | 2002-03-29 A | 100% | 2001-03-16 | 2002-03-29 | 271d | finish no earlier than 2002-03-29 | R3 | 2168h | 2168h | Rel-5 | Juha |  | RANimp-RLTA | Ericsson | Elena Voltolina |  |
| 1739 | 79.3 | Separation of resource reservation and radio link activation | 271d | 2001-03-16 A | 2002-03-29 A | 100% | 2001-03-16 | 2002-03-29 | 271d | finish no earlier than 2002-03-29 | R3 | 2168h | 2168h | Rel-5 | Juha |  | RANimp-SepRR | Ericsson | Gert-Jan.van.Lieshout@eln.ericsson.se |  |
| 1740 | 79.4 | FS SRNS Relocation Procedure Enhancement | 318d | 2001-06-15 A | 2002-09-03 A | 100% | 2001-06-15 | 2002-09-03 | 318d | finish no earlier than 2002-09-06 | R3 | 2544h | 2544h | Rel-5 | Juha |  | RANimp-SRNS | Nokia | Olivier Guyot |  |
| 1741 | 79.5 | FS Improvement of Radio Resource Management across RNS and RNS/PSS | 201d | 2001-03-16 A | 2001-12-21 A | 100% | 2001-03-16 | 2001-12-21 | 201d | finish no earlier than 2001-12-21 | R3 | 1608h | 1608h | Rel-5 | Juha |  | RANimp-ImpRRM | Nokia | antti.toskala@nokia.com |  |
| 1742 | 79.6 | Re-arrangements of Iub transport bearers | 271d | 2001-03-16 A | 2002-03-29 A | 100% | 2001-03-16 | 2002-03-29 | 271d | finish no earlier than 2002-03-29 | R3 | 2168h | 2168h | Rel-5 | Juha |  | RANimp-TTPS | Nokia | antti.toskala@nokia.com |  |
| 1743 | 79.7 | RAB support enhancement for Rel-5 | 325d | 2001-04-02 A | 2002-06-28 A | 100% | 2001-04-02 | 2002-06-28 | 325d | finish no earlier than 2002-06-28 | R2 | 2600h | 2600h | Rel-5 | Joern |  | RANimp-RABSE5 | Nokia | Juha Mikola |  |
| 1744 | 79.8 | Beamforming requirements for UE | 61d | 2001-09-21 A | 2001-12-14 A | 100% | 2001-09-21 | 2001-12-14 | 61d | finish no earlier than 2001-12-14 | R1 | 488h | 488h | Rel-5 | Patrick |  | RANimp-BFR-UE | Nokia | Jussi Kähtävä (juha.mikola@nokia.com) |  |
| 1745 | 79.9 | Support of Site Selection Diversity Transmission in UTRAN | 123d | 2001-12-14 A | 2002-06-04 A | 100% | 2001-12-14 | 2002-06-04 | 123d | finish no earlier than 2002-06-04 | R1 | 984h | 984h | Rel-5 | Patrick |  | RANimp-SSDT | NEC |  |  |
| 1746 | 79.10 | Node B Synchronisation for 1.28 Mcps TDD | 271d | 2001-03-16 A | 2002-03-29 A | 100% | 2001-03-16 | 2002-03-29 | 271d | finish no earlier than 2002-03-29 | R1 | 2168h | 2168h | Rel-5 | Patrick |  | RANimp-NBSLCR | CATT | Jinling HU |  |
| 1747 | 79.12 | **Deleted - Conformance Test Aspects - RAN Improvements** | 565d? | 2002-01-01 A | 2004-03-01 A | 100% | 2002-01-01 | 2004-03-01 | 565d? |  | T1 | 8008h | 8008h | Rel-5 | Ingbert | TP-23 |  |  |  | 0% |
| 1748 | 79.12.1 | Deleted - Testing Radio access bearer support enhancements | 175d | 2002-01-01 A | 2002-09-02 A | 100% | 2002-01-01 | 2002-09-02 | 175d | finish no earlier than 2002-09-02 | T1 | 1400h | 1400h | Rel-5 | Ingbert | TP-17 |  |  |  |  |
| 1749 | 513.11.2 | Deleted - General changes to TS34.121 and TS34.122 corresponding to release 5 | 261d? | 2003-03-03 A | 2004-03-01 A | 100% | 2003-03-03 | 2004-03-01 | 261d? | finish no earlier than 2004-03-01 | T1 | 2088h | 2088h | Rel-5 | Ingbert | TP-23 | RANimp-test |  |  | 34.108, 34.121, 34.122 |
| 1750 | 80 | UTRAN Sharing in Connected Mode | 197d | 2001-12-03 A | 2002-09-03 A | 100% | 2001-12-03 | 2002-09-03 | 197d | finish no earlier than 2002-09-06 | R3 | 1576h | 1576h | Rel-5 | Juha |  | NETSHARE | Ericsson | Martin Israelsson |  |
| 1751 | 81 | **Provisioning of IP-based multimedia services** | 1089d | 2000-01-03 A | 2004-03-03 A | 100% | 2000-01-03 | 2004-03-03 | 1089d |  | S1,S2,S5 | 187156h | 187156h | Rel-5 | Alain |  | IMS | Openwave | Mark Cataldo |  |
| 1752 | 81.1 | **Call control and roaming to support IMS in UMTS** | 641d | 2000-01-03 A | 2002-06-14 A | 100% | 2000-01-03 | 2002-06-14 | 641d |  | S2 | 82528h | 82528h | Rel-5 | Maurice |  | IMS-CCR | Lucent | Liz Daniel |  |
| 1753 | 81.1.1 | Stage 1 | 215d | 2000-02-21 A | 2000-12-15 A | 100% | 2000-02-21 | 2000-12-15 | 215d | finish no earlier than 2000-09-21 | S1 | 1720h | 1720h | Rel-5 | Alain |  | IMS-CCR | Motorola | Mark Cataldo | 22.228 |
| 1754 | 81.1.2 | Stage 2 (Architecture and Main flows) | 246d | 2000-04-14 A | 2001-03-23 A | 100% | 2000-04-14 | 2001-03-23 | 246d | finish no earlier than 2001-03-23 | S2 | 1968h | 1968h | Rel-5 | Maurice |  | IMS-CCR | Lucent | Liz Daniel | 23.228 |
| 1755 | 81.1.3 | Impact on MM/CC/SM | 400d | 2000-08-28 A | 2002-03-08 A | 100% | 2000-08-28 | 2002-03-08 | 400d | finish no earlier than 2002-03-08 | N1 | 3200h | 3200h | Rel-5 | Frederic |  | IMS-CCR-IWMM | Lucent | Keith Drage (drage@alcatel-lucent.com) |  |

Notes:
- 1730: Marked as stopped 12/2008
- 1731: Marked as stopped 12/2008
- 1732: Marked as stopped 12/2008
- 1733: -
- 1734: -
- 1735: -
- 1736: -
- 1737: FS was closed and introduction of WI not agreed at RAN #16
- 1738: -
- 1739: -
- 1740: -
- 1741: FS was closed and WI was introduced at RAN #14
- 1742: -
- 1743: RFC 3095 context relocation
- 1744: -
- 1745: RP-020356
- 1746: -
- 1747: Marked as stopped 12/2008
- 1748: Marked as stopped 12/2008
- 1749: Marked as stopped 12/2008
- 1750: Formerly 'Shared Network support in connected mode', renamed at RAN #16.
- 1751: -
- 1752: -
- 1753: Issues include e.g.: Roaming requirements, Requirements on supplementary services, Interworking requirements
- 1754: Issues include e.g.: Mobile IP, RAB selection principles, Optimized VoIP bearer mechanisms, SIP multimedia protocol
- 1755: Per 26/2-02: This is understood to be the PCO & TFT CRs which CN1 provides to TSGN #15 for approval. If this is correct understanding, then the task is 100 % complete.

| ID | WBS | Task | Duration | Start | Finish | Complete | Baseline start | Baseline finish | Baseline duration | Constraint | Resources | Work | Actual work | Text1 | Text3 | Text4 | Text5 | Text6 | Text8 |
| --- | --- | --- | --- | --- | --- | --- | --- | --- | --- | --- | --- | --- | --- | --- | --- | --- | --- | --- | --- |
| 1756 | 81.1.4 | **SIP Call Control protocol for the IMS** | 641d | 2000-01-03 A | 2002-06-14 A | 100% | 2000-01-03 | 2002-06-14 | 641d |  | N1 | 70808h | 70808h | IMS-CCR | 24.228, 24.229, 23.218 | Lucent | Keith Drage (drage@alcatel-lucent.com) | Rel-5 | Frederic |
| 1757 | 81.1.4.1 | IMS signalling flows | 385d | 2000-10-02 A | 2002-03-22 A | 100% | 2000-10-02 | 2002-03-22 | 385d | finish no earlier than 2002-03-22 | N1 | 3080h | 3080h | IMS-CCR | 24.228 |  |  | Rel-5 | Frederic |
| 1758 | 81.1.4.2 | IMS stage 3 | 385d | 2000-10-02 A | 2002-03-22 A | 100% | 2000-10-02 | 2002-03-22 | 385d | finish no earlier than 2002-03-22 | N1 | 3080h | 3080h | IMS-CCR | 24.229 |  |  | Rel-5 | Frederic |
| 1759 | 81.1.4.3 | IMS Session Handling; stage 2 | 385d | 2000-10-02 A | 2002-03-22 A | 100% | 2000-10-02 | 2002-03-22 | 385d | finish no earlier than 2002-03-22 | N1 | 3080h | 3080h | IMS-CCR | 23.218 |  |  | Rel-5 | Frederic |
| 1760 | 81.1.4.4 | **Main IETF dependencies** | 636d | 2000-01-03 A | 2002-06-07 A | 100% | 2000-01-03 | 2002-06-07 | 636d |  | NP | 45400h | 45400h | IMS |  |  |  | Rel-5 | Kimmo |
| 1761 | 81.1.4.4.1 | IETF: RFC 3261 (Session Initiation Protocol) | 346d | 2000-11-24 A | 2002-03-22 A | 100% | 2000-11-24 | 2002-03-22 | 346d | finish no earlier than 2002-03-22 | N1 | 2768h | 2768h | IMS |  |  |  | Rel-5 | Frederic |
| 1762 | 81.1.4.4.2 | IETF: RFC 3262 (Reliability of provisional responses) | 346d | 2000-11-24 A | 2002-03-22 A | 100% | 2000-11-24 | 2002-03-22 | 346d | finish no earlier than 2002-03-22 | N1 | 2768h | 2768h | IMS |  |  |  | Rel-5 | Frederic |
| 1763 | 81.1.4.4.3 | IETF: RFC 3312 (Without COMET)(Integration of resource management and SIP) | 382d | 2000-11-24 A | 2002-05-13 A | 100% | 2000-11-24 | 2002-05-13 | 382d | finish no earlier than 2002-05-13 | N1 | 3056h | 3056h | IMS |  |  |  | Rel-5 | Frederic |
| 1764 | 81.1.4.4.4 | IETF: RFC 3323 (SIP extensions for caller identity and privacy) | 382d | 2000-11-24 A | 2002-05-13 A | 100% | 2000-11-24 | 2002-05-13 | 382d | finish no earlier than 2002-05-13 | N1 | 3056h | 3056h | IMS |  |  |  | Rel-5 | Frederic |
| 1765 | 81.1.4.4.5 | IETF: RFC 3313 (SIP extensions for media authorization) | 382d | 2000-11-24 A | 2002-05-13 A | 100% | 2000-11-24 | 2002-05-13 | 382d | finish no earlier than 2002-05-13 | N1 | 3056h | 3056h | IMS |  |  |  | Rel-5 | Frederic |
| 1766 | 81.1.4.4.6 | IETF: RFC 3265 (specific event notification) | 346d | 2000-11-24 A | 2002-03-22 A | 100% | 2000-11-24 | 2002-03-22 | 346d | finish no earlier than 2002-03-22 | N1 | 2768h | 2768h | IMS |  |  |  | Rel-5 | Frederic |
| 1767 | 81.1.4.4.7 | IETF: RFC editor Queue (refer method) | 401d | 2000-11-24 A | 2002-06-07 A | 100% | 2000-11-24 | 2002-06-07 | 401d | finish no earlier than 2002-06-07 | N1 | 3208h | 3208h | IMS |  |  |  | Rel-5 | Frederic |
| 1768 | 81.1.4.4.8 | IETF: RFC editor Queue (DHCP options for SIP servers) | 382d | 2000-11-24 A | 2002-05-13 A | 100% | 2000-11-24 | 2002-05-13 | 382d | finish no earlier than 2002-05-13 | N1 | 3056h | 3056h | IMS |  |  |  | Rel-5 | Frederic |
| 1769 | 81.1.4.4.10 | IETF: RFC 3267 (AMR and AMR WB RTP and SDP) | 346d | 2000-11-24 A | 2002-03-22 A | 100% | 2000-11-24 | 2002-03-22 | 346d | finish no earlier than 2002-03-22 | N1 | 2768h | 2768h | IMS |  |  |  | Rel-5 | Frederic |
| 1770 | 81.1.4.4.11 | IETF: RFC 3266 (IPv6 support within SDP) | 581d | 2000-01-03 A | 2002-03-22 A | 100% | 2000-01-03 | 2002-03-22 | 581d | finish no earlier than 2002-03-22 | N1 | 4640h | 4640h | IMS |  |  |  | Rel-5 | Frederic |
| 1771 | 81.1.4.4.12 | IETF: RFC 3311 (The Update method) | 382d | 2000-11-24 A | 2002-05-13 A | 100% | 2000-11-24 | 2002-05-13 | 382d | finish no earlier than 2002-05-13 | N1 | 3056h | 3056h | IMS |  |  |  | Rel-5 | Frederic |
| 1772 | 81.1.4.4.13 | IETF: RFC 3324 (Network Asserted Identity) | 382d | 2000-11-24 A | 2002-05-13 A | 100% | 2000-11-24 | 2002-05-13 | 382d | finish no earlier than 2002-05-13 | N1 | 3056h | 3056h | IMS |  |  |  | Rel-5 | Frederic |
| 1773 | 81.1.4.4.14 | IETF: RFC editor Queue (Various 3GPP Private Extensions) | 382d | 2000-11-24 A | 2002-05-13 A | 100% | 2000-11-24 | 2002-05-13 | 382d | finish no earlier than 2002-05-13 | N1 | 3056h | 3056h | IMS |  |  |  | Rel-5 | Frederic |
| 1774 | 81.1.4.5 | **Addressing** | 380d | 2000-10-09 A | 2002-03-22 A | 100% | 2000-10-09 | 2002-03-22 | 380d |  | S2 | 7744h | 7744h | IMS |  |  |  | Rel-5 | Maurice |
| 1775 | 81.1.4.5.1 | Architectural issues | 235d | 2000-10-09 A | 2001-08-31 A | 100% | 2000-10-09 | 2001-08-31 | 235d | finish no earlier than 2001-03-16 | S2 | 1880h | 1880h | IMS |  |  |  | Rel-5 | Maurice |
| 1776 | 81.1.4.5.2 | Impact on HSS | 353d | 2000-11-15 A | 2002-03-22 A | 100% | 2000-11-15 | 2002-03-22 | 353d | finish no earlier than 2002-03-22 | N4 | 2824h | 2824h | IMS |  |  |  | Rel-5 | Kimmo |
| 1777 | 81.1.4.6 | **Service Examples (Work stopped)** | 304d | 2001-04-17 A | 2002-06-14 A | 100% | 2001-04-17 | 2002-06-14 | 304d |  | S1 | 4864h | 4864h | IMS-Sex | 22.928 | Motorola | Mark Cataldo | Rel-5 | Alain |
| 1778 | 81.1.4.6.1 | IMS Framework Report (work stopped) | 304d | 2001-04-17 A | 2002-06-14 A | 100% | 2001-04-17 | 2002-06-14 | 304d | finish no earlier than 2002-06-14 | S1 | 2432h | 2432h | IMS-FrWk | 22.941 | SBC | Randolph Wohlert (rwohlert@tri.sbc.com) | Rel-5 | Alain |
| 1779 | 81.2 | **Access Security for IMS** | 190d | 2001-10-08 A | 2002-06-28 A | 100% | 2001-10-08 | 2002-06-28 | 190d |  | S3 | 4120h | 4120h | IMS-ASEC |  | Ericsson | krister.boman@emw.ericsson.se | Rel-5 | Dionisio |
| 1780 | 81.2.2 | IMS impacts on UICC (ISIM application) | 185d | 2001-10-08 A | 2002-06-21 A | 100% | 2001-10-08 | 2002-06-21 | 185d | finish no earlier than 2002-06-21 | T3 | 1480h | 1480h |  |  | Vodafone | Jeremy Norris | Rel-5 |  |
| 1781 | 81.2.3 | SIP extensions for Integrity protection | 140d | 2001-12-17 A | 2002-06-28 A | 100% | 2001-12-17 | 2002-06-28 | 140d | finish no earlier than 2002-06-28 | N1 | 1120h | 1120h |  |  |  |  | Rel-5 | Frederic |
| 1782 | 81.3 | Security Aspects of Requirement for Network Configuration Independence | 130d | 2001-07-02 A | 2001-12-28 A | 100% | 2001-07-02 | 2001-12-28 | 130d | finish no earlier than 2001-12-28 | S3 | 1040h | 1040h | SEC1-NCI |  | AT&T Wireless | hugh.shieh@attws.com | Rel-5 | Dionisio |
| 1783 | 81.4 | Lawful interception | 410d | 2000-09-04 A | 2002-03-29 A | 100% | 2000-09-04 | 2002-03-29 | 410d | finish no earlier than 2002-03-29 | S3 | 3280h | 3280h | IMS-LI | 33.106, 33.107, new 33.108 | Reg TP | berthold.wilhelm@regtp.de | Rel-5 | Dionisio |
| 1784 | 81.5 | Charging and OAM&P for IMS | 383d | 2000-12-25 A | 2002-06-12 A | 100% | 2000-12-25 | 2002-06-12 | 383d | finish no earlier than 2002-06-12 | S5 | 3064h | 3064h | IMS-OAM | 32-series | VoiceStream, Motorola |  | Rel-5 | Dionisio |

Notes:
- 1756: TSGN_10 approved the change:CN1 - SA2 SIP joint meeting spotted one more place for improvement: work tasks with ID 1998 and 1278 are actually subtasks under of single CN1 WT. One WI has been approved for the CN1 WT with title "SIP Call Control protocol
- 1757: 24.228
- 1758: 24.229
- 1759: 23.218
- 1760: -
- 1761: -
- 1762: -
- 1763: -
- 1764: -
- 1765: -
- 1766: -
- 1767: -
- 1768: -
- 1769: -
- 1770: -
- 1771: -
- 1772: -
- 1773: -
- 1774: -
- 1775: -
- 1776: Covered by 29.228 & 29228
- 1777: -
- 1778: -
- 1779: TS33.203 will be presented for info at SP#14 and is scheduled for approval at SP#15. Dependencies on IETF exist. Approved SP#15
- 1780: -
- 1781: Per 26/2-02: CN1 is not aware of any requirements and is not doing anything on this task.
- 1782: Incorporated into IMS access security TS (33.203) which will be presented for info at SP#14 and is scheduled for approval at SP#15.Editors notes removed SP#16&17
- 1783: SA#17 completed
- 1784: -

| ID | WBS | Task | Duration | Start | Finish | Complete | Baseline start | Baseline finish | Baseline duration | Constraint | Resources | Work | Actual work | Text1 | Text3 | Text4 | Text5 | Text6 | Text8 |
| --- | --- | --- | --- | --- | --- | --- | --- | --- | --- | --- | --- | --- | --- | --- | --- | --- | --- | --- | --- |
| 1785 | 81.6 | **Multimedia codecs and protocols for conversational PS services** | 568d | 2000-07-26 A | 2002-09-27 A | 100% | 2000-07-26 | 2002-09-27 | 568d |  | S4 | 15640h | 15640h | IMS-CODEC | 26.235, 26.236 | Toshiba, Nokia | B. Aronson (Toshiba), pasi.s.ojala@nokia.com | Rel-5 | Paolo |
| 1786 | 81.6.1 | Codecs | 427d | 2000-07-26 A | 2002-03-14 A | 100% | 2000-07-26 | 2002-03-14 | 427d | finish no earlier than 2001-03-21 | S4 | 3416h | 3416h |  | 26.235, 26.236 |  |  | Rel-5 | Paolo |
| 1787 | 81.6.2 | Transport protocols | 1d | 2002-03-12 A | 2002-03-12 A | 100% | 2002-03-12 | 2002-03-12 | 1d | finish no earlier than 2002-03-12 | S4 | 8h | 8h | IMS-CODEC | 26.236 | Nokia | P. Ojala | Rel-5 | Paolo |
| 1788 | 81.6.4 | recommendation for QoS parameter values for various media types | 195d | 2001-12-31 A | 2002-09-27 A | 100% | 2001-12-31 | 2002-09-27 | 195d | finish no earlier than 2002-09-27 | S4 | 1560h | 1560h |  |  |  |  | Rel-5 | Paolo |
| 1789 | 81.6.5 | IETF: RFC 3310 (HTTP Digest Authentication using AKA) | 382d | 2000-11-24 A | 2002-05-13 A | 100% | 2000-11-24 | 2002-05-13 | 382d | finish no earlier than 2002-05-13 | N1 | 3056h | 3056h |  |  |  |  | Rel-5 | Frederic |
| 1790 | 81.6.6 | IETF: RFC 3329 (Security mechanism agreement for SIP connections) | 382d | 2000-11-24 A | 2002-05-13 A | 100% | 2000-11-24 | 2002-05-13 | 382d | finish no earlier than 2002-05-13 | N1 | 3056h | 3056h |  |  |  |  | Rel-5 | Frederic |
| 1791 | 81.7 | **SIP message compression** | 185d | 2001-09-24 A | 2002-06-07 A | 100% | 2001-09-24 | 2002-06-07 | 185d |  | S2 | 3128h | 3128h |  |  |  |  | Rel-5 | Maurice |
| 1792 | 81.7.1 | Stage 2 | 25d | 2001-09-24 A | 2001-10-26 A | 100% | 2001-09-24 | 2001-10-26 | 25d | finish no earlier than 2001-10-26 | S2 | 200h | 200h |  |  |  |  | Rel-5 | Maurice |
| 1793 | 81.7.2 | Compression signalling | 181d | 2001-09-28 A | 2002-06-07 A | 100% | 2001-09-28 | 2002-06-07 | 181d | finish no earlier than 2002-06-07 | N1 | 1448h | 1448h |  |  |  |  | Rel-5 | Frederic |
| 1794 | 81.8 | **Stage 3 description of IMS interfaces** | 383d | 2001-03-14 A | 2002-08-30 A | 100% | 2001-03-14 | 2002-08-30 | 383d |  | NP | 29531.6h | 29531.6h |  |  |  |  | Rel-5 | Kimmo |
| 1795 | 81.8.1 | Cx interface (HSS to CSCF) | 135.95d | 2001-03-14 A | 2002-06-07 A | 100% | 2001-03-14 | 2002-06-07 | 135.95d | finish no earlier than 2002-06-07 | N4 | 1087.58h | 1087.58h |  |  |  |  | Rel-5 | Kimmo |
| 1796 | 81.8.2 | Mp interface (MRFC - MRFP) enhancements | 258d | 2001-03-14 A | 2002-03-08 A | 100% | 2001-03-14 | 2002-03-08 | 258d | finish no earlier than 2002-06-07 | N4 | 2064h | 2064h |  |  |  |  | Rel-5 | Kimmo |
| 1797 | 81.8.3 | Mw interface (CSCF to P-CSCF) | 323d | 2001-03-14 A | 2002-06-07 A | 100% | 2001-03-14 | 2002-06-07 | 323d | finish no earlier than 2002-06-07 | N1 | 2584h | 2584h |  |  |  |  | Rel-5 | Frederic |
| 1798 | 81.8.4 | Mr interface (CSCF to MRF) | 273d | 2001-03-14 A | 2002-03-29 A | 100% | 2001-03-14 | 2002-03-29 | 273d | finish no earlier than 2002-03-29 | N1 | 2184h | 2184h |  |  |  |  | Rel-5 | Frederic |
| 1799 | 81.8.5 | Dx interface (I-CSCF to SLF) | 323d | 2001-03-14 A | 2002-06-07 A | 100% | 2001-03-14 | 2002-06-07 | 323d | finish no earlier than 2002-06-07 | N4 | 2584h | 2584h |  |  |  |  | Rel-5 | Kimmo |
| 1800 | 81.8.6 | Go interface (GGSN to PCF) | 323d | 2001-03-14 A | 2002-06-07 A | 100% | 2001-03-14 | 2002-06-07 | 323d | finish no earlier than 2002-06-07 | N3 | 2584h | 2584h |  |  |  |  | Rel-5 | Gwiho |
| 1801 | 81.8.7 | ISC (IMS Service Control) Interface | 323d | 2001-03-14 A | 2002-06-07 A | 100% | 2001-03-14 | 2002-06-07 | 323d | finish no earlier than 2002-06-07 | N1 | 2584h | 2584h |  |  |  |  | Rel-5 | Frederic |
| 1802 | 81.8.8 | Sh interface (HSS to AS) | 82d | 2002-02-14 A | 2002-06-07 A | 100% | 2002-02-14 | 2002-06-07 | 82d | finish no earlier than 2002-06-07 | N4 | 656h | 656h |  |  |  |  | Rel-5 | Kimmo |
| 1803 | 81.8.9 | Si interface (HSS to IM-SSF) | 162.5d | 2002-01-16 A | 2002-08-30 A | 100% | 2002-01-16 | 2002-08-30 | 162.5d | finish no earlier than 2002-06-07 | N4 | 1300h | 1300h |  |  |  |  | Rel-5 | Kimmo |
| 1804 | 81.8.10 | Gm interface (UE to CSCF) | 323d | 2001-03-14 A | 2002-06-07 A | 100% | 2001-03-14 | 2002-06-07 | 323d | finish no earlier than 2002-06-07 | N1 | 2584h | 2584h |  |  |  |  | Rel-5 | Frederic |
| 1805 | 81.8.11 | Mi interface (CSCF to BGCF) | 323d | 2001-03-14 A | 2002-06-07 A | 100% | 2001-03-14 | 2002-06-07 | 323d | finish no earlier than 2002-06-07 | N1 | 2584h | 2584h |  |  |  |  | Rel-5 | Frederic |
| 1806 | 81.8.12 | Mj interface (BGCF to MGCF) | 323d | 2001-03-14 A | 2002-06-07 A | 100% | 2001-03-14 | 2002-06-07 | 323d | finish no earlier than 2002-06-07 | N1 | 2584h | 2584h |  |  |  |  | Rel-5 | Frederic |
| 1807 | 81.8.13 | Mk interface (BGCF to BGCF) | 323d | 2001-03-14 A | 2002-06-07 A | 100% | 2001-03-14 | 2002-06-07 | 323d | finish no earlier than 2002-06-07 | N1 | 2584h | 2584h |  |  |  |  | Rel-5 | Frederic |
| 1808 | 81.9 | Support of VHE/OSA by entities and protocols of the IMS (e.g. CSCF) | 186d | 2001-09-21 A | 2002-06-07 A | 100% | 2001-09-21 | 2002-06-07 | 186d | finish no earlier than 2002-06-07 | N5 | 1488h | 1488h | IMS-ONOSA | 29.198, 29.998 | Ericsson | Ard.Jan.Moerdijk@eln.ericsson.se | Rel-5 | Kimmo |

Notes:
- 1785: -
- 1786: -
- 1787: -
- 1788: -
- 1789: -
- 1790: -
- 1791: -
- 1792: -
- 1793: -
- 1794: -
- 1795: -
- 1796: [DAB 08-03-02] - No work required in CN4
- 1797: -
- 1798: -
- 1799: CN4#11 30/11/01: No inputs received in CN4 / 14/02/02 Completed(introduced in 29.228)
- 1800: [DAB - 23/05/03] - 100 % complete
- 1801: -
- 1802: CN4#11 30/11/01: No inputs received in CN4 / CN4#12bis 14/02/02: WID approved / 17th May 100% complete. 3GPP TS 29.329 will be sent for approval in CN#16
- 1803: SA16: Part of Rel5 only if completed in September 02. Marked as closed 12/2008 (was marked 72% complete)
- 1804: -
- 1805: -
- 1806: -
- 1807: -
- 1808: -

| ID | WBS | Task | Duration | Start | Finish | Predecessors | Complete | Baseline start | Baseline finish | Baseline duration | Constraint | Resources | Work | Actual work | Text1 | Text4 | Text5 | Text6 | Text8 | Text12 | Text3 |
| --- | --- | --- | --- | --- | --- | --- | --- | --- | --- | --- | --- | --- | --- | --- | --- | --- | --- | --- | --- | --- | --- |
| 1809 | 81.10 | **CAMEL control of IMS services** | 365d | 2001-04-16 A | 2002-09-06 A |  | 100% | 2001-04-16 | 2002-09-06 | 365d |  | N2 | 9952h | 9952h | IMS-CAMEL | Lucent | Angelica Remoquillo | Rel-5 | Kimmo |  |  |
| 1810 | 81.10.1 | Stage2 work 'general' | 365d | 2001-04-16 A | 2002-09-06 A |  | 100% | 2001-04-16 | 2002-09-06 | 365d | finish no earlier than 2002-09-06 | N2 | 2920h | 2920h |  |  |  | Rel-5 | Kimmo |  |  |
| 1811 | 81.10.2 | Stage3 work 'CAP' | 175d | 2002-01-07 A | 2002-09-06 A |  | 100% | 2002-01-07 | 2002-09-06 | 175d | finish no earlier than 2002-09-06 | N2 | 1400h | 1400h |  |  |  | Rel-5 | Kimmo |  |  |
| 1812 | 81.10.3 | Stage2 work 'Si interface' | 175d | 2002-01-07 A | 2002-09-06 A |  | 100% | 2002-01-07 | 2002-09-06 | 175d | finish no earlier than 2002-09-06 | N2 | 1400h | 1400h |  |  |  | Rel-5 | Kimmo |  |  |
| 1813 | 81.10.4 | Stage3 work 'Si interface' | 82d | 2002-02-14 A | 2002-06-07 A |  | 100% | 2002-02-14 | 2002-06-07 | 82d | finish no earlier than 2002-06-07 | N4 | 656h | 656h |  |  |  | Rel-5 | Kimmo |  |  |
| 1814 | 81.10.5 | Deleted - SDM issues for CAMEL control of IMS | 82d | 2002-02-14 A | 2002-06-07 A |  | 100% | 2002-02-14 | 2002-06-07 | 82d | finish no earlier than 2002-06-07 | N4 | 656h | 656h |  |  |  | Rel-5 | Kimmo | NP-17 |  |
| 1815 | 81.11 | Pre-pay/real-time charging in IMS | 196d | 2001-06-15 A | 2002-03-15 A |  | 100% | 2001-06-15 | 2002-03-15 | 196d | finish no earlier than 2002-03-15 | S1 | 1568h | 1568h |  |  |  | Rel-5 | Alain |  |  |
| 1816 | 81.12 | **Charging** | 289d | 2001-08-06 A | 2002-09-12 A |  | 100% | 2001-08-06 | 2002-09-12 | 289d |  | S2,S5 | 6632h | 6632h | OAM-CH | T-Mobile | karl-heinz.nenner@t-mobile.de | Rel-5 | Dionisio |  | 32.225 |
| 1817 | 81.12.1 | Charging Implications of IMS architecture | 75d | 2001-08-06 A | 2001-11-16 A |  | 100% | 2001-08-06 | 2001-11-16 | 75d | finish no earlier than 2001-11-16 | S2 | 600h | 600h |  |  |  | Rel-5 | Maurice |  |  |
| 1818 | 81.12.2 | Charging management for IMS (off-line & on-line) | 214d | 2001-11-19 A | 2002-09-12 A | 1817 | 100% | 2001-11-19 | 2002-09-12 | 214d | finish no earlier than 2002-09-12 | S5 | 1712h | 1712h | OAM-CH |  |  | Rel-5 | Dionisio |  | 32.225 |
| 1819 | 86.1.6.10 | Billing, accounting and call detail record aspects | 251d | 2001-09-27 A | 2002-09-12 A |  | 100% | 2001-09-27 | 2002-09-12 | 251d | finish no earlier than 2002-09-12 | S5 | 2008h | 2008h | OAM-CH | T-Mobile | Karl-Heinz.Nenner@T-MOBILE.DE | Rel-5 | Dionisio |  | 32.225 |
| 1820 | 81.13 | **Other IETF dependencies** | 401d | 2000-11-24 A | 2002-06-07 A |  | 100% | 2000-11-24 | 2002-06-07 | 401d |  | NP | 9624h | 9624h |  |  |  | Rel-5 |  |  |  |
| 1821 | 81.13.1 | IETF: draft-ietf-aaa-diameter - should be CN4 | 401d | 2000-11-24 A | 2002-06-07 A |  | 100% | 2000-11-24 | 2002-06-07 | 401d | finish no earlier than 2002-06-07 | NP | 3208h | 3208h |  |  |  | Rel-5 |  |  |  |
| 1822 | 81.13.2 | IETF: draft-johansson-aaa-diameter-mm-app - should be CN4 | 401d | 2000-11-24 A | 2002-06-07 A |  | 100% | 2000-11-24 | 2002-06-07 | 401d | finish no earlier than 2002-06-07 | NP | 3208h | 3208h |  |  |  | Rel-5 |  |  |  |
| 1823 | 81.15 | Conformance Test Aspects - Provisioning of IMS | 205d | 2002-03-18 A | 2002-12-27 A |  | 100% | 2002-03-18 | 2002-12-27 | 205d | finish no earlier than 2002-12-27 | T1 | 1640h | 1640h | IMS-TEST |  |  | Rel-5 | Ingbert |  |  |
| 1824 | 81.16 | Testing of support for IMS - prose | 270d | 2002-09-18 A | 2003-09-30 A |  | 100% | 2002-09-18 | 2003-09-30 | 270d | finish no earlier than 2003-09-30 | T1 | 2160h | 2160h |  | Anritsu | dan.fox@eu.anritsu.com | Rel-5 | Ingbert |  | 34.108, 34.123 |
| 1825 | 81.17 | Testing of support for IMS - TTCN | 381d | 2002-09-18 A | 2004-03-03 A |  | 100% | 2002-09-18 | 2004-03-03 | 381d | finish no earlier than 2004-03-03 | T1 | 3048h | 3048h |  | Anritsu | dan.fox@eu.anritsu.com | Rel-5 | Ingbert |  | 34.108, 34.123 |
| 1826 | 82 | **Extended Transparent End-to-End PS Streaming Service** | 313d? | 2002-01-03 A | 2003-03-17 A |  | 100% | 2002-01-03 | 2003-03-17 | 313d? |  | S4 | 6224h | 6224h | PSS-E | Ericsson | olle.franceschi@ericsson.com | Rel-5 | Paolo |  | 26.233, 26.234 |
| 1827 | 82.1 | **Stage 1** | 86d? | 2002-11-18 A | 2003-03-17 A |  | 100% | 2002-11-18 | 2003-03-17 | 86d? |  | S1 | 1376h | 1376h |  | Vodafone | stephen.wolak@vodafone.com | Rel-5 | Alain |  | 22.233 |
| 1828 | 516.1.1 | Interaction with other services | 86d? | 2002-11-18 A | 2003-03-17 A |  | 100% | 2002-11-18 | 2003-03-17 | 86d? | finish no earlier than 2003-03-17 | S1 | 688h | 688h |  | Vodafone | stephen.wolak@vodafone.com | Rel-5 | Alain |  | 22.233 |
| 1829 | 82.2 | Stage 2 (version Rel5 of TS 26.234) | 51d | 2002-01-03 A | 2002-03-14 A |  | 100% | 2002-01-03 | 2002-03-14 | 51d | finish no earlier than 2002-03-26 | S4 | 408h | 408h |  |  |  | Rel-5 | Paolo |  | 26.234 |
| 1830 | 82.3 | RTP usage model | 242d | 2002-01-03 A | 2002-12-06 A |  | 100% | 2002-01-03 | 2002-12-06 | 242d | finish no earlier than 2002-12-06 | S4 | 1936h | 1936h |  |  |  | Rel-5 | Paolo |  | 26.937 |
| 1831 | 83 | **Rel-5 OSA enhancements** | 955d | 1999-04-27 A | 2002-12-20 A |  | 100% | 1999-04-27 | 2002-12-20 | 955d |  | S1 | 62480h | 62480h | OSA1 | Siemens | Joerg Swetina (joerg.swetina@nw.neclab.eu) | Rel-5 | Alain |  | 22.127, 23.127, 29.198-x, 29.998-x |
| 1832 | 83.1 | General Stage 2 for Rel5 | 194d | 2001-09-11 A | 2002-06-07 A |  | 100% | 2001-09-11 | 2002-06-07 | 194d |  | S2 | 1232h | 1232h |  |  |  | Rel-5 | Maurice |  |  |

Notes:
- 1809: -
- 1810: DAB 12.12.01 split into cn4 and cn2 parts
- 1811: DAB 12.12.01 split into cn4 and cn2 parts
- 1812: DAB 12.12.01 split into cn4 and cn2 parts
- 1813: [DAB 08-03-02] - UID 12004 is MASTER of UID 14998 / 17 May need to be recearch possible impact on 23.008 & 23.016, changes to 29.002 are done.
- 1814: Marked as stopped 12/2008
- 1815: Marked as closed 12/2008 (was marked 60% complete)
- 1816: -
- 1817: -
- 1818: -
- 1819: -
- 1820: Was introduced at SP#13 by Ileana Leuca (exact position in the WP and related WG have to be defined)
- 1821: Marked as closed 12/2008 (was marked 90% complete)
- 1822: Marked as closed 12/2008 (was marked 50% complete)
- 1823: The task is a building block, individual work items are being considered but are constrained by lack of supporting companies. Marked as stopped 12/2008
- 1824: Marked as stopped 12/2008
- 1825: Marked as stopped 12/2008
- 1826: -
- 1827: 2nd resp SA4
- 1828: 2nd resp SA4. Marked as closed 12/2008 (was marked 65% complete)
- 1829: 2nd resp SA2
- 1830: Marked as closed 12/2008 (was marked 90% complete)
- 1831: -
- 1832: Marked as closed 12/2008 (was marked 47% complete)

| ID | WBS | Task | Duration | Start | Finish | Predecessors | Complete | Baseline start | Baseline finish | Baseline duration | Constraint | Resources | Work | Actual work | Text1 | Text6 | Text8 | Text3 | Text4 | Text5 |
| --- | --- | --- | --- | --- | --- | --- | --- | --- | --- | --- | --- | --- | --- | --- | --- | --- | --- | --- | --- | --- |
| 1833 | 83.2 | **OSA APIs for Multimedia Call Control** | 499d | 2000-07-11 A | 2002-06-07 A |  | 100% | 2000-07-11 | 2002-06-07 | 499d |  | S2 | 5960h | 5960h | OSA1-CSCF | Rel-5 | Maurice |  |  |  |
| 1834 | 83.2.1 | Stage 1 | 438d | 2000-07-11 A | 2002-03-14 A |  | 100% | 2000-07-11 | 2002-03-14 | 438d | finish no earlier than 2002-03-14 | S1 | 3504h | 3504h |  | Rel-5 | Alain | 22.127 | Siemens | Manfred.leitgeb@siemens.at |
| 1835 | 83.2.2 | (Multimedia) Call Control - Stages 2 and 3 | 194d | 2001-09-11 A | 2002-06-07 A |  | 100% | 2001-09-11 | 2002-06-07 | 194d | finish no earlier than 2002-06-07 | N5 | 1552h | 1552h |  | Rel-5 | Kimmo | 29.198-04 |  |  |
| 1836 | 83.3 | Generic user interaction - Stage 3 | 194d | 2001-09-11 A | 2002-06-07 A |  | 100% | 2001-09-11 | 2002-06-07 | 194d | finish no earlier than 2002-06-07 | N5 | 1552h | 1552h |  | Rel-5 | Kimmo | 29.198-05 |  |  |
| 1837 | 83.4 | Charging - Stage 3 | 194d | 2001-09-11 A | 2002-06-07 A |  | 100% | 2001-09-11 | 2002-06-07 | 194d | finish no earlier than 2002-06-07 | N5 | 1552h | 1552h |  | Rel-5 | Kimmo | 29.198-12 |  |  |
| 1838 | 83.5 | Call Control Service Mapping; Multiparty Call Control SIP - Stage 3 | 194d | 2001-09-11 A | 2002-06-07 A |  | 100% | 2001-09-11 | 2002-06-07 | 194d | finish no earlier than 2002-06-07 | N5 | 1552h | 1552h |  | Rel-5 | Kimmo | 29.998-04-4 |  |  |
| 1839 | 83.6 | WSDL APIs for SOAP/HTTP - Stage 3 | 455d | 2000-09-11 A | 2002-06-07 A |  | 100% | 2000-09-11 | 2002-06-07 | 455d | finish no earlier than 2002-06-07 | N5 | 3640h | 3640h |  | Rel-5 | Kimmo | 29.198, 29.998 |  |  |
| 1840 | 83.7 | **OSA security** | 639d | 2000-07-11 A | 2002-12-20 A |  | 100% | 2000-07-11 | 2002-12-20 | 639d |  | S3 | 15000h | 15000h | OSA1-SEC | Rel-5 | Dionisio |  | BT | colin.blanchard@bt.com |
| 1841 | 83.7.1 | Stage 1 | 349d | 2000-07-11 A | 2001-11-09 A |  | 100% | 2000-07-11 | 2001-11-09 | 349d | finish no earlier than 2001-11-09 | S1 | 2792h | 2792h |  | Rel-5 | Alain | 22.127 | Siemens | Manfred.leitgeb@siemens.at |
| 1842 | 83.7.2 | Stage 3 | 430d | 2000-10-23 A | 2002-06-14 A |  | 100% | 2000-10-23 | 2002-06-14 | 430d | finish no earlier than 2002-06-14 | S3 | 3440h | 3440h |  | Rel-5 | Dionisio |  |  |  |
| 1843 | 83.7.3 | security related SCF(s) definition | 186d | 2001-09-21 A | 2002-06-07 A |  | 100% | 2001-09-21 | 2002-06-07 | 186d | finish no earlier than 2002-06-07 | N5 | 1488h | 1488h |  | Rel-5 | Kimmo | 29.198, 29.998 | Ericsson | Ard.Jan.Moerdijk@eln.ericsson.se |
| 1844 | 83.7.4 | (possibly) changes required from supporting platforms, e.g. gsmSCF, HLR | 69d | 2000-09-11 A | 2000-12-14 A |  | 100% | 2000-09-11 | 2000-12-14 | 69d | finish no earlier than 2000-12-14 | S3 | 552h | 552h |  | Rel-5 | Dionisio |  |  |  |
| 1845 | 517.7.5 | Security (moved from Rel-6) | 202d | 2002-03-14 A | 2002-12-20 A |  | 100% | 2002-03-14 | 2002-12-20 | 202d | finish no earlier than 2002-12-20 | S3 | 1616h | 1616h |  | Rel-5 | Dionisio |  |  |  |
| 1846 | 83.8 | **Interactions OSA - e-commerce** | 815d | 1999-04-27 A | 2002-06-07 A |  | 100% | 1999-04-27 | 2002-06-07 | 815d |  | S2 | 6152h | 6152h | OSA1-ECOM | Rel-5 | Maurice |  |  |  |
| 1847 | 83.8.1 | Stage 1 | 439d | 1999-04-27 A | 2000-12-28 A |  | 100% | 1999-04-27 | 2000-12-28 | 439d | finish no earlier than 2000-12-28 | S1 | 3504h | 3504h |  | Rel-5 | Alain | 22.127 | Siemens | Joerg Swetina (joerg.swetina@nw.neclab.eu) |
| 1848 | 83.8.2 | Stages 2 and 3 | 186d | 2001-09-21 A | 2002-06-07 A |  | 100% | 2001-09-21 | 2002-06-07 | 186d | finish no earlier than 2002-06-07 | N5 | 1488h | 1488h |  | Rel-5 | Kimmo | 29.198, 29.998 | Ericsson | Ard.Jan.Moerdijk@eln.ericsson.se |
| 1849 | 83.9 | Policy Management - Stage 3 | 194d | 2001-09-11 A | 2002-06-07 A |  | 100% | 2001-09-11 | 2002-06-07 | 194d | finish no earlier than 2002-06-07 | N5 | 1552h | 1552h |  | Rel-5 | Kimmo | 29.198-13 |  |  |
| 1850 | 83.10 | Presence and Availability Management (PAM) - Stage 3 | 194d | 2001-09-11 A | 2002-06-07 A |  | 100% | 2001-09-11 | 2002-06-07 | 194d | finish no earlier than 2002-06-07 | N5 | 1552h | 1552h |  | Rel-5 | Kimmo | 29.198-14 |  |  |
| 1851 | 83.11 | **CHECK STATUS - LCS - OSA interfaces** | 455d | 2000-09-11 A | 2002-06-07 A |  | 100% | 2000-09-11 | 2002-06-07 | 455d |  | S1 | 5656h | 5656h | OSA1-LCSI | Rel-5 | Alain |  | Siemens | Joerg Swetina (joerg.swetina@nw.neclab.eu) |
| 1852 | 83.11.1 | Stage 1 | 65d | 2000-09-11 A | 2000-12-08 A |  | 100% | 2000-09-11 | 2000-12-08 | 65d | finish no earlier than 2000-12-08 | S1 | 520h | 520h |  | Rel-5 | Alain | 22.127 | Siemens | Joerg Swetina (joerg.swetina@nw.neclab.eu) |
| 1853 | 83.11.2 | Stage 2 | 1d | 2000-12-11 A | 2000-12-11 A | 1852 | 100% | 2000-12-11 | 2000-12-11 | 1d | finish no earlier than 2000-12-11 | S2 | 8h | 8h |  | Rel-5 | Maurice | 23.127 | Ericsson | Christophe GOURRAUD |
| 1854 | 83.11.3 | Stage 3 | 186d | 2001-09-21 A | 2002-06-07 A | 1853 | 100% | 2001-09-21 | 2002-06-07 | 186d | finish no earlier than 2002-06-07 | N5 | 1488h | 1488h |  | Rel-5 | Kimmo | 29.198, 29.998 | Ericsson | Ard.Jan.Moerdijk@eln.ericsson.se |
| 1855 | 517.12 | Access to User Profile | 145d | 2001-06-01 A | 2001-12-20 A |  | 100% | 2001-06-01 | 2001-12-20 | 145d | finish no earlier than 2001-12-20 | S1 | 1160h | 1160h | OSA2-UP | Rel-5 | Alain |  |  |  |
| 1856 | 517.13 | **Retrieval of Terminal capabilities** | 634d | 2000-07-11 A | 2002-12-13 A |  | 100% | 2000-07-11 | 2002-12-13 | 634d |  | S2 | 10808h | 10808h | OSA2-TC | Rel-5 | Maurice |  |  |  |
| 1857 | 517.13.1 | Stage 1 | 132d | 2000-07-11 A | 2001-01-10 A |  | 100% | 2000-07-11 | 2001-01-10 | 132d | finish no earlier than 2001-01-10 | S1 | 1056h | 1056h |  | Rel-5 | Alain | 22.127 | Siemens | Joerg Swetina (joerg.swetina@nw.neclab.eu) |
| 1858 | 517.13.2 | Stages 2 and 3 | 321d | 2001-09-21 A | 2002-12-13 A | 1857 | 100% | 2001-09-21 | 2002-12-13 | 321d | finish no earlier than 2002-12-13 | N5 | 2568h | 2568h |  | Rel-5 | Kimmo | 29.198, 29.998 | Ericsson | Ard.Jan.Moerdijk@eln.ericsson.se |
| 1859 | 517.13.3 | Provisioning of the terminal capabilities | 445d | 2001-04-02 A | 2002-12-13 A |  | 100% | 2001-04-02 | 2002-12-13 | 445d | finish no earlier than 2002-12-13 | T2 | 3560h | 3560h |  | Rel-5 |  | 23.057 |  |  |

Notes:
- 1833: For Rel5 even if completed by March
- 1834: -
- 1835: -
- 1836: -
- 1837: -
- 1838: -
- 1839: -
- 1840: CR to correct security specifications in 29.198 scheduled for approval at CN#15
- 1841: -
- 1842: Marked as closed 12/2008 (was marked 80% complete)
- 1843: -
- 1844: -
- 1845: Contribution at S3#25
- 1846: -
- 1847: Marked as closed 12/2008 (was marked 95% complete)
- 1848: -
- 1849: -
- 1850: -
- 1851: az: CN#13 - changed to Rel5
- 1852: -
- 1853: az 24/05/01: Rel4 completion 90->100%.
- 1854: -
- 1855: -
- 1856: -
- 1857: -
- 1858: -
- 1859: According to T2 SWG1 M. Cataldo this is automatically supported by the MExE support of UAProf therefore 100% complete

| ID | WBS | Task | Duration | Start | Finish | Predecessors | Complete | Baseline start | Baseline finish | Baseline duration | Constraint | Resources | Work | Actual work | Text1 | Text4 | Text5 | Text6 | Text8 | Text3 |
| --- | --- | --- | --- | --- | --- | --- | --- | --- | --- | --- | --- | --- | --- | --- | --- | --- | --- | --- | --- | --- |
| 1860 | 84 | **CAMEL phase 4** | 625d | 2000-04-17 A | 2002-09-06 A |  | 100% | 2000-04-17 | 2002-09-06 | 625d |  | S1 | 41104h | 41104h | CAMEL4 | Nokia | keijo.palviainen@nokia.com | Rel-5 | Alain |  |
| 1861 | 84.1 | Service requirements | 565d | 2000-04-17 A | 2002-06-14 A |  | 100% | 2000-04-17 | 2002-06-14 | 565d | finish no earlier than 2002-06-14 | S1 | 4520h | 4520h |  |  |  | Rel-5 | Alain |  |
| 1862 | 84.2 | Call Party Handling | 500d | 2000-07-10 A | 2002-06-07 A |  | 100% | 2000-07-10 | 2002-06-07 | 500d | finish no earlier than 2002-06-07 | N2 | 4000h | 4000h | CAMEL4-CPH |  |  | Rel-5 | Kimmo |  |
| 1863 | 84.3 | Mid call procedure for MO and MT calls | 495d | 2000-07-17 A | 2002-06-07 A |  | 100% | 2000-07-17 | 2002-06-07 | 495d | finish no earlier than 2002-06-07 | N2 | 3960h | 3960h | CAMEL4-MCP |  |  | Rel-5 | Kimmo |  |
| 1864 | 84.4 | Interactions with Optimal Routing | 430d | 2000-07-17 A | 2002-03-08 A |  | 100% | 2000-07-17 | 2002-03-08 | 430d | finish no earlier than 2002-03-08 | N2 | 3440h | 3440h | CAMEL4-IOR |  |  | Rel-5 | Kimmo |  |
| 1865 | 84.5 | Inclusion of flexible tone injection | 430d | 2000-07-17 A | 2002-03-08 A |  | 100% | 2000-07-17 | 2002-03-08 | 430d | finish no earlier than 2002-03-08 | N2 | 3440h | 3440h | CAMEL4-IFTI |  |  | Rel-5 | Kimmo |  |
| 1866 | 84.6 | CSE control over MT SMS | 430d | 2000-07-17 A | 2002-03-08 A |  | 100% | 2000-07-17 | 2002-03-08 | 430d | finish no earlier than 2002-03-08 | N2 | 3440h | 3440h | CAMEL4-CCSMS |  |  | Rel-5 | Kimmo |  |
| 1867 | 84.7 | Notification of GPRS mobility management to CSE | 331d | 2001-03-02 A | 2002-06-07 A |  | 100% | 2001-03-02 | 2002-06-07 | 331d | finish no earlier than 2002-06-07 | N2 | 2648h | 2648h | CAMEL4-NMM |  |  | Rel-5 | Kimmo |  |
| 1868 | 84.8 | Provision of location information of called subscriber | 266d | 2001-03-02 A | 2002-03-08 A |  | 100% | 2001-03-02 | 2002-03-08 | 266d | finish no earlier than 2002-03-08 | N2 | 2128h | 2128h | CAMEL4-LOCB |  |  | Rel-5 | Kimmo |  |
| 1869 | 84.9 | Inclusion of ODB data in the CSE_HLR interface | 175d | 2001-07-09 A | 2002-03-08 A |  | 100% | 2001-07-09 | 2002-03-08 | 175d | finish no earlier than 2002-03-08 | N2 | 1400h | 1400h | CAMEL4-ODB |  |  | Rel-5 | Kimmo |  |
| 1870 | 84.10 | Location information during an ongoing call (Handover DP) | 280d | 2001-05-14 A | 2002-06-07 A |  | 100% | 2001-05-14 | 2002-06-07 | 280d | finish no earlier than 2002-06-07 | N2 | 2240h | 2240h | CAMEL4-HODP |  |  | Rel-5 | Kimmo |  |
| 1871 | 84.11 | GPRS Any Time Interrogation | 240d | 2001-07-09 A | 2002-06-07 A |  | 100% | 2001-07-09 | 2002-06-07 | 240d | finish no earlier than 2002-06-07 | N2 | 1920h | 1920h | CAMEL4-ATI |  |  | Rel-5 | Kimmo |  |
| 1872 | 84.12 | Transfer of IMEI (with SW version) to CSE | 240d | 2001-07-09 A | 2002-06-07 A |  | 100% | 2001-07-09 | 2002-06-07 | 240d | finish no earlier than 2002-06-07 | N2 | 1920h | 1920h | CAMEL4-ATI |  |  | Rel-5 | Kimmo |  |
| 1873 | 84.13 | Handling of partial implementations of CAMEL4 | 131d | 2002-03-08 A | 2002-09-06 A |  | 100% | 2002-03-08 | 2002-09-06 | 131d | finish no earlier than 2002-06-07 | N2 | 1048h | 1048h | CAMEL4-SUB |  |  | Rel-5 | Kimmo |  |
| 1874 | 85 | **Rel-5 MExE enhancements** | 250d | 2001-03-26 A | 2002-03-08 A |  | 100% | 2001-03-26 | 2002-03-08 | 250d |  | T2 | 2880h | 2880h | MEXE5 |  |  | Rel-5 | Kimmo |  |
| 1875 | 85.1 | MExE Rel-5 Improvements and Investigations | 110d | 2001-03-26 A | 2002-03-08 A |  | 100% | 2001-03-26 | 2002-03-08 | 110d | finish no earlier than 2001-12-17 | T2 | 880h | 880h | MEXE5-ENHANC | Motorola | Mark Cataldo | Rel-5 |  | 22.057, 23.057 |
| 1876 | 86 | **Wideband Telephony Service - AMR** | 1036d | 2000-01-01 A | 2003-12-19 A |  | 100% | 2000-01-01 | 2003-12-19 | 1036d |  | S4 | 81496h | 81496h | AMRWB | Siemens | Imre.Varga@mch.siemens.de | Rel-5 | Paolo |  |
| 1877 | 86.1 | **Specification** | 636d | 2000-01-01 A | 2002-06-07 A |  | 100% | 2000-01-01 | 2002-06-07 | 636d |  | S4 | 19984h | 19984h |  |  |  | Rel-5 | Paolo |  |
| 1878 | 86.1.1 | Stage 1 | 125d | 2001-10-01 A | 2002-03-22 A |  | 100% | 2001-10-01 | 2002-03-22 | 125d | finish no earlier than 2002-03-22 | S1 | 1000h | 1000h |  |  |  | Rel-5 | Alain |  |
| 1879 | 86.1.2 | **Stage 2** | 77d | 2000-01-03 A | 2000-04-17 A |  | 100% | 2000-01-03 | 2000-04-17 | 77d |  | S4 | 1232h | 1232h |  |  |  | Rel-5 | Paolo |  |
| 1880 | 86.1.2.1 | Design Constraints | 27d | 2000-01-03 A | 2000-02-07 A |  | 100% | 2000-01-03 | 2000-02-07 | 27d |  | S4 [96.3%] | 208h | 208h |  |  |  | Rel-5 | Paolo |  |
| 1881 | 86.1.2.2 | General Description | 51d | 2000-02-07 A | 2000-04-17 A | 1880 | 100% | 2000-02-07 | 2000-04-17 | 51d | start no earlier than 2000-09-25 | S4 | 408h | 408h |  |  |  | Rel-5 | Paolo |  |
| 1882 | 86.1.3 | Feasibility Study | 26d | 2000-04-28 A | 2000-06-02 A | 1881 | 100% | 2000-04-28 | 2000-06-02 | 26d | finish no earlier than 2000-06-02 | S4 | 208h | 208h |  |  |  | Rel-5 | Paolo | 26.901 |
| 1883 | 86.1.4 | N1 Aspects | 66d | 2001-09-21 A | 2001-12-21 A |  | 100% | 2001-09-21 | 2001-12-21 | 66d | finish no earlier than 2001-12-21 | N1 | 528h | 528h |  |  |  | Rel-5 | Frederic |  |
| 1884 | 86.1.5 | N4 work | 83d | 2002-02-13 A | 2002-06-07 A |  | 100% | 2002-02-13 | 2002-06-07 | 83d | finish no earlier than 2002-06-07 | N4 | 664h | 664h |  |  |  | Rel-5 | Kimmo |  |

Notes:
- 1860: -
- 1861: -
- 1862: -
- 1863: -
- 1864: -
- 1865: -
- 1866: -
- 1867: -
- 1868: -
- 1869: Added on May 29, 2001
- 1870: -
- 1871: -
- 1872: -
- 1873: stage2 and stage3 CRs for approval at CN#17
- 1874: -
- 1875: -
- 1876: -
- 1877: -
- 1878: -
- 1879: -
- 1880: -
- 1881: -
- 1882: S4,TD SP-000024: TR 26.901 v.4.0.0
- 1883: Some of N1 tasks: Indication of supported codecs by the MS, Bearer cap negociation, codec indication to MS... / One common set of codec negotiation procedures will be specified as in ID1657.
- 1884: CN4#11 30/11/01: No inputs to CN4 at this meeting / 14/02/02 work started 50% reached / 17 May work is done 100%

| ID | WBS | Task | Duration | Start | Finish | Predecessors | Complete | Baseline start | Baseline finish | Baseline duration | Constraint | Resources | Work | Actual work | Text6 | Text8 | Text1 | Text3 | Text12 | Text4 | Text5 |
| --- | --- | --- | --- | --- | --- | --- | --- | --- | --- | --- | --- | --- | --- | --- | --- | --- | --- | --- | --- | --- | --- |
| 1885 | 86.1.6 | **Codec issues** | 636d | 2000-01-03 A | 2002-06-07 A |  | 100% | 2000-01-03 | 2002-06-07 | 636d |  | S4 | 9496h | 9496h | Rel-5 | Paolo |  |  |  |  |  |
| 1886 | 86.1.6.1 | Codec qualification | 86d | 2000-02-02 A | 2000-05-31 A |  | 100% | 2000-02-02 | 2000-05-31 | 86d | finish no earlier than 2000-05-31 | S4 | 688h | 688h | Rel-5 | Paolo |  |  |  |  |  |
| 1887 | 86.1.6.2 | Codec selection tests | 102d | 2000-06-01 A | 2000-10-20 A | 1886 | 100% | 2000-06-01 | 2000-10-20 | 102d | finish no earlier than 2000-10-20 | S4 | 816h | 816h | Rel-5 | Paolo |  |  |  |  |  |
| 1888 | 86.1.6.3 | Codec selection | 5d | 2000-10-23 A | 2000-10-27 A | 1887 | 100% | 2000-10-23 | 2000-10-27 | 5d | finish no earlier than 2000-10-27 | S4 | 40h | 40h | Rel-5 | Paolo |  |  |  |  |  |
| 1889 | 86.1.6.4 | TFO AMR-WB | 63d | 2001-12-18 A | 2002-03-14 A |  | 100% | 2001-12-18 | 2002-03-14 | 63d | finish no earlier than 2002-03-14 | S4 | 504h | 504h | Rel-5 | Paolo | AMRWB-TFO |  |  |  |  |
| 1890 | 86.1.6.5 | Other codec issues (verif., characterization) | 441d | 2000-09-29 A | 2002-06-07 A |  | 100% | 2000-09-29 | 2002-06-07 | 441d | finish no earlier than 2002-06-07 | S4 | 3528h | 3528h | Rel-5 | Paolo |  | 26.976 |  |  |  |
| 1891 | 86.1.6.6 | AMR-WB and narrrowband interworking | 121d | 2001-09-27 A | 2002-03-14 A |  | 100% | 2001-09-27 | 2002-03-14 | 121d | finish no earlier than 2002-03-14 | S4 | 968h | 968h | Rel-5 | Paolo | AMRWB-IWG |  |  |  |  |
| 1892 | 86.1.6.7 | Interworking with fixed broadband networks | 121d | 2001-09-27 A | 2002-03-14 A |  | 100% | 2001-09-27 | 2002-03-14 | 121d | finish no earlier than 2002-03-14 | S4 | 968h | 968h | Rel-5 | Paolo |  |  |  |  |  |
| 1893 | 86.1.6.8 | Tones and announcements | 121d | 2001-09-27 A | 2002-03-14 A |  | 100% | 2001-09-27 | 2002-03-14 | 121d | finish no earlier than 2002-03-14 | S4 | 968h | 968h | Rel-5 | Paolo |  |  |  |  |  |
| 1894 | 86.1.6.9 | Deleted - WB Conferencing and WB Voice Group calls | 1d | 2000-01-03 A | 2000-01-03 A |  | 100% | 2000-01-03 | 2000-01-03 | 1d | finish no earlier than 2000-01-03 | S1 | 8h | 8h | Rel-5 | Alain |  |  | SP-07 |  |  |
| 1895 | 86.1.8 | **Conformance tests (CRs to 34 series)** | 74d | 2000-01-01 A | 2000-04-12 A |  | 100% | 2000-01-01 | 2000-04-12 | 74d |  | T1 | 1768h | 1768h | Rel-5 | Ingbert |  |  |  |  |  |
| 1896 | 86.1.8.1 | **Terminal Acoustic Characteristics** | 74d | 2000-01-01 A | 2000-04-12 A |  | 100% | 2000-01-01 | 2000-04-12 | 74d |  | S4 | 1176h | 1176h | Rel-5 | Paolo |  |  |  |  |  |
| 1897 | 86.1.8.1.1 | Definition | 22d | 2000-01-01 A | 2000-01-31 A |  | 100% | 2000-01-01 | 2000-01-31 | 22d | finish no earlier than 2000-01-28 | S4 [95.5%] | 168h | 168h | Rel-5 | Paolo |  | 26.131 |  |  |  |
| 1898 | 86.1.8.1.2 | Test specification | 52d | 2000-02-01 A | 2000-04-12 A | 1897 | 100% | 2000-02-01 | 2000-04-12 | 52d | finish no earlier than 2000-03-13 | S4 | 416h | 416h | Rel-5 | Paolo |  | 26.132 |  |  |  |
| 1899 | 86.2 | Floating-point ANSI-C code for the AMR-WB speech codec | 123d | 2001-09-25 A | 2002-03-14 A |  | 100% | 2001-09-25 | 2002-03-14 | 123d | finish no earlier than 2002-03-14 | S4 | 984h | 984h | Rel-5 | Paolo | AMRWB-FP | 26.204 |  | Nokia | janne.m.vainio@nokia.com |
| 1900 | 86.3 | **Support of AMR-WB in GERAN: GMSK and 8PSK WB FR / HR** | 651d | 2000-01-03 A | 2002-06-28 A |  | 100% | 2000-01-03 | 2002-06-28 | 651d |  | GP | 23488h | 23488h | Rel-5 | Paolo | GAMRWB |  |  |  |  |
| 1901 | 86.3.1 | Channel coding in 45.003 | 591d | 2000-01-03 A | 2002-04-05 A |  | 100% | 2000-01-03 | 2002-04-05 | 591d |  | GP | 4720h | 4720h | Rel-5 | Paolo |  |  |  |  |  |
| 1902 | 86.3.2 | Signalling for the A interface | 391d | 2000-01-03 A | 2001-06-29 A |  | 100% | 2000-01-03 | 2001-06-29 | 391d | finish no earlier than 2001-06-29 | GP | 3120h | 3120h | Rel-5 | Paolo |  |  |  |  |  |
| 1903 | 86.3.3 | Signalling for Iu | 651d | 2000-01-03 A | 2002-06-28 A |  | 100% | 2000-01-03 | 2002-06-28 | 651d | finish no earlier than 2002-06-28 | GP | 5200h | 5200h | Rel-5 | Paolo |  |  |  |  |  |
| 1904 | 86.3.4 | Receiver performance in TS 45.005 | 325d | 2001-04-02 A | 2002-06-28 A |  | 100% | 2001-04-02 | 2002-06-28 | 325d | finish no earlier than 2002-06-28 | GP | 2600h | 2600h | Rel-5 | Paolo |  |  |  |  |  |
| 1905 | 86.3.5 | Link Adaptation in 45.009 | 330d | 2001-03-26 A | 2002-06-28 A |  | 100% | 2001-03-26 | 2002-06-28 | 330d | finish no earlier than 2002-06-28 | GP | 2640h | 2640h | Rel-5 | Paolo |  |  |  |  |  |
| 1906 | 86.4 | **Deleted - GERAN MS conformance test for AMR-WB** | 1036d | 2000-01-03 A | 2003-12-19 A |  | 100% | 2000-01-03 | 2003-12-19 | 1036d |  | GP | 16568h | 16568h | Rel-5 | Paolo |  |  |  |  |  |
| 1907 | 86.4.1 | Deleted - MS test for AMR-WB | 1036d | 2000-01-03 A | 2003-12-19 A |  | 100% | 2000-01-03 | 2003-12-19 | 1036d | finish no earlier than 2003-12-19 | GP | 8280h | 8280h | Rel-5 | Paolo |  |  | GP-17 |  |  |
| 1908 | 86.5 | **GERAN BTS conformance test for AMR-WB** | 762d | 2000-01-03 A | 2002-12-02 A |  | 100% | 2000-01-03 | 2002-12-02 | 762d |  | GP | 12184h | 12184h | Rel-5 | Paolo |  |  |  |  |  |
| 1909 | 86.5.1 | BTS test | 762d | 2000-01-03 A | 2002-12-02 A |  | 100% | 2000-01-03 | 2002-12-02 | 762d | finish no earlier than 2002-12-02 | GP | 6088h | 6088h | Rel-5 | Paolo |  |  |  |  |  |

Notes:
- 1885: -
- 1886: -
- 1887: -
- 1888: -
- 1889: -
- 1890: ANSI C-Code , Test Sequences, Speech Transcoding Functions, Error Concealment of lost frames, Source Controlled Bit-Rate Operation, Voice Activity Detector, Frame Structure
- 1891: -
- 1892: -
- 1893: -
- 1894: -
- 1895: -
- 1896: -
- 1897: -
- 1898: -
- 1899: -
- 1900: -
- 1901: 50098 -> 50298
- 1902: -
- 1903: -
- 1904: -
- 1905: -
- 1906: Not started 02/2003. Marked as stopped 12/2008
- 1907: Marked as stopped 12/2008
- 1908: -
- 1909: -

| ID | WBS | Task | Duration | Start | Finish | Complete | Baseline start | Baseline finish | Baseline duration | Constraint | Resources | Work | Actual work | Text1 | Text6 | Text8 | Text3 | Text4 | Text5 |
| --- | --- | --- | --- | --- | --- | --- | --- | --- | --- | --- | --- | --- | --- | --- | --- | --- | --- | --- | --- |
| 1910 | 11 | **Terminal interfaces** | 223d | 2001-05-14 A | 2002-03-20 A | 100% | 2001-05-14 | 2002-03-20 | 223d |  | T2 | 3568h | 3568h | TI | Rel-5 | Kimmo |  |  |  |
| 1911 | 87 | Terminal local model enhancements | 223d | 2001-05-14 A | 2002-03-20 A | 100% | 2001-05-14 | 2002-03-20 | 223d | finish no earlier than 2002-03-20 | T2 | 1784h | 1784h | TLM5 | Rel-5 |  | 23.227 |  |  |
| 1912 | 88 | **Rel-5 Location Services enhancements** | 845d | 2000-04-03 A | 2003-06-27 A | 100% | 2000-04-03 | 2003-06-27 | 845d |  | S2,S5 | 86804h | 86804h | LCS1 | Rel-5 | Maurice |  | Nokia | Jan Kall |
| 1913 | 88.1 | **UE positioning** | 315d | 2001-01-15 A | 2002-03-29 A | 100% | 2001-01-15 | 2002-03-29 | 315d |  | RP | 5560h | 5560h | LCS1-UEpos | Rel-5 | Issam |  |  |  |
| 1914 | 88.1.1 | UE positioning enhancements for 1.28 Mcps TDD | 255d | 2001-04-09 A | 2002-03-29 A | 100% | 2001-04-09 | 2002-03-29 | 255d | finish no earlier than 2002-03-29 | R2 | 2040h | 2040h | LCS-128Pos | Rel-5 | Joern |  | CATT | Xiaohua Mei |
| 1915 | 88.1.2 | Open SMLC-SRNC Interface within the UTRAN to support A-GPS Positioning | 195d | 2001-01-15 A | 2001-10-12 A | 100% | 2001-01-15 | 2001-10-12 | 195d |  | R2 | 1560h | 1560h | LCS-INTF | Rel-5 | Joern |  | Qualcomm | Kirk Burroughs |
| 1916 | 88.2 | **Event based and Periodic LCS** | 535d | 2000-05-22 A | 2002-06-07 A | 100% | 2000-05-22 | 2002-06-07 | 535d |  | S1 | 6288h | 6288h | LCS1-EBP | Rel-5 | Alain |  |  |  |
| 1917 | 88.2.1 | Stage 1 | 130d | 2000-05-22 A | 2000-11-17 A | 100% | 2000-05-22 | 2000-11-17 | 130d | finish no earlier than 2000-07-21 | S1 | 1040h | 1040h |  | Rel-5 | Alain | 22.071 | Pacific Bell Wireless | Randolph Wohlert (rwohlert@tri.sbc.com) |
| 1918 | 88.2.2 | Stage 2 specification | 60d | 2000-11-06 A | 2001-01-26 A | 100% | 2000-11-06 | 2001-01-26 | 60d | finish no earlier than 2001-01-26 | S2 | 480h | 480h |  | Rel-5 | Maurice |  |  |  |
| 1919 | 88.2.3 | Impact on MAP | 61d | 2002-03-15 A | 2002-06-07 A | 100% | 2002-03-15 | 2002-06-07 | 61d | finish no earlier than 2002-06-07 | N4 | 488h | 488h |  | Rel-5 | Kimmo |  |  |  |
| 1920 | 88.3 | **Location Services for GERAN in A/Gb Mode** | 485d | 2000-04-03 A | 2002-02-08 A | 100% | 2000-04-03 | 2002-02-08 | 485d |  | GP | 14760h | 14760h | LCS-GERAN | Rel-5 | Paolo |  |  |  |
| 1921 | 88.3.1 | GERAN LCS Stage 2 (first release) | 485d | 2000-04-03 A | 2002-02-08 A | 100% | 2000-04-03 | 2002-02-08 | 485d | finish no earlier than 2002-02-08 | GP,S2,G1,G2 | 3880h | 3880h |  | Rel-5 | Paolo |  |  |  |
| 1922 | 88.3.2 | Gb interface support for LCS | 370d | 2000-04-03 A | 2001-08-31 A | 100% | 2000-04-03 | 2001-08-31 | 370d | finish no earlier than 2001-08-31 | GP | 2960h | 2960h |  | Rel-5 | Paolo |  |  |  |
| 1923 | 88.3.3 | L3 protocol support for LCS | 305d | 2000-04-03 A | 2001-06-01 A | 100% | 2000-04-03 | 2001-06-01 | 305d | finish no earlier than 2001-06-01 | GP | 2440h | 2440h |  | Rel-5 | Paolo |  |  |  |
| 1924 | 88.3.4 | Stage 3 specifications | 305d | 2000-04-03 A | 2001-06-01 A | 100% | 2000-04-03 | 2001-06-01 | 305d | finish no earlier than 2001-06-01 | GP | 2440h | 2440h |  | Rel-5 | Paolo |  |  |  |
| 1925 | 88.4 | **Location Services for GERAN in Iu Mode** | 585d | 2000-04-03 A | 2002-06-28 A | 100% | 2000-04-03 | 2002-06-28 | 585d |  | S2,G1,G2,R2,R3 | 20996h | 20996h |  | Rel-5 | Paolo |  |  |  |
| 1926 | 88.4.1 | GERAN LCS Stage 2 | 585d | 2000-04-03 A | 2002-06-28 A | 100% | 2000-04-03 | 2002-06-28 | 585d | finish no earlier than 2002-06-28 | S2,G1,G2 | 4680h | 4680h |  | Rel-5 | Paolo |  |  |  |
| 1927 | 88.4.2 | Iu-ps interface support for LCS | 585d | 2000-04-03 A | 2002-06-28 A | 100% | 2000-04-03 | 2002-06-28 | 585d | finish no earlier than 2002-06-28 | R2,R3 | 4680h | 4680h |  | Rel-5 | Paolo |  |  |  |
| 1928 | 88.4.3 | Iu-cs interface support for LCS | 585d | 2000-04-03 A | 2002-06-28 A | 100% | 2000-04-03 | 2002-06-28 | 585d | finish no earlier than 2002-06-28 | R2,R3 | 4680h | 4680h |  | Rel-5 | Paolo |  |  |  |
| 1929 | 88.4.4 | Iur-g interface support for LCS | 62.5d | 2002-01-23 A | 2002-04-19 A | 100% | 2002-01-23 | 2002-04-19 | 62.5d | finish no earlier than 2002-04-19 | G1,G2 | 500h | 500h |  | Rel-5 | Paolo |  |  |  |
| 1930 | 88.4.5 | RRC protocol support for LCS | 75d | 2001-08-20 A | 2001-11-30 A | 100% | 2001-08-20 | 2001-11-30 | 75d | finish no earlier than 2001-11-30 | G1,G2,R2,R3 | 600h | 600h |  | Rel-5 | Paolo |  |  |  |
| 1931 | 88.4.6 | Additional impacts on Broadcast of LCS data on packet channels | 77.5d | 2001-08-20 A | 2001-12-05 A | 100% | 2001-08-20 | 2001-12-05 | 77.5d | finish no earlier than 2001-12-05 | G1,G2,R2,R3 | 620h | 620h |  | Rel-5 | Paolo |  |  |  |
| 1932 | 88.4.7 | Stage 3 specifications | 69.5d | 2002-03-25 A | 2002-06-28 A | 100% | 2002-03-25 | 2002-06-28 | 69.5d | finish no earlier than 2002-06-28 | G1,G2,R2,R3 | 556h | 556h |  | Rel-5 | Paolo |  |  |  |
| 1933 | 88.5 | **GERAN MS Conformance test for LCS** | 280d | 2002-06-03 A | 2003-06-27 A | 100% | 2002-06-03 | 2003-06-27 | 280d |  | GP | 6720h | 6720h | LCS-GERAN-MSconf | Rel-5 | Paolo |  |  |  |
| 1934 | 88.5.1 | Develop LCS MS test case work plan (Release 98/99/4) | 280d | 2002-06-03 A | 2003-06-27 A | 100% | 2002-06-03 | 2003-06-27 | 280d | finish no earlier than 2003-06-27 | G4,G5 | 2240h | 2240h |  | Rel-5 | Paolo |  |  |  |
| 1935 | 88.5.2 | Develop LCS MS test cases | 280d | 2002-06-03 A | 2003-06-27 A | 100% | 2002-06-03 | 2003-06-27 | 280d | finish no earlier than 2003-06-27 | G4,G5 | 2240h | 2240h |  | Rel-5 | Paolo |  |  |  |

Notes:
- 1910: -
- 1911: -
- 1912: -
- 1913: -
- 1914: -
- 1915: Finished at RP#13
- 1916: -
- 1917: Evaluate Event based and Periodic LCS to be included in R00, corresponding Stage 1 description
- 1918: Marked as closed 12/2008 (was marked 51% complete)
- 1919: Possible impact on UTRAN of LCS quality level request / 17 May No stage 2 for event-based & periodic LCS. Work 100% completefor current stage 2
- 1920: -
- 1921: -
- 1922: -
- 1923: -
- 1924: -
- 1925: -
- 1926: -
- 1927: -
- 1928: -
- 1929: FFS
- 1930: -
- 1931: -
- 1932: -
- 1933: -
- 1934: Marked as closed 12/2008 (was marked 60% complete)
- 1935: Marked as closed 12/2008 (was marked 60% complete)

| ID | WBS | Task | Duration | Start | Finish | Predecessors | Complete | Baseline start | Baseline finish | Baseline duration | Constraint | Resources | Work | Actual work | Text1 | Text6 | Text8 | Text12 | Text3 | Text4 | Text5 |
| --- | --- | --- | --- | --- | --- | --- | --- | --- | --- | --- | --- | --- | --- | --- | --- | --- | --- | --- | --- | --- | --- |
| 1936 | 88.6 | **Deleted - GERAN BTS Conformance test for LCS** | 280d | 2002-06-03 A | 2003-06-27 A |  | 100% | 2002-06-03 | 2003-06-27 | 280d |  | GP | 6720h | 6720h | LCS-GERAN-BTSconf | Rel-5 | Paolo | GP-15 |  |  |  |
| 1937 | 88.6.1 | Deleted - Develop LCS BTS test case work plan (Release 98/99/4) | 280d | 2002-06-03 A | 2003-06-27 A |  | 100% | 2002-06-03 | 2003-06-27 | 280d | finish no earlier than 2003-06-27 | G4,G5 | 2240h | 2240h |  | Rel-5 | Paolo | GP-15 |  |  |  |
| 1938 | 88.6.2 | Deleted - Develop LCS BTS test cases | 280d | 2002-06-03 A | 2003-06-27 A |  | 100% | 2002-06-03 | 2003-06-27 | 280d | finish no earlier than 2003-06-27 | G4,G5 | 2240h | 2240h |  | Rel-5 | Paolo | GP-15 |  |  |  |
| 1939 | 88.7 | LCS interoperation stage 2 aspects | 480d | 2000-08-28 A | 2002-06-28 A |  | 100% | 2000-08-28 | 2002-06-28 | 480d |  | S2 | 3840h | 3840h |  | Rel-5 | Maurice |  |  |  |  |
| 1940 | 88.8 | **LCS interoperability aspects to GERAN** | 480d | 2000-08-28 A | 2002-06-28 A |  | 100% | 2000-08-28 | 2002-06-28 | 480d |  | GP,S5 | 7680h | 7680h | LCS-GERAN | Rel-5 | Paolo |  |  |  |  |
| 1941 | 88.8.1 | Co-ordinated development of GSM LCS Phase 2 and UMTS LCS, S2 and GERAN | 480d | 2000-08-28 A | 2002-06-28 A |  | 100% | 2000-08-28 | 2002-06-28 | 480d | finish no earlier than 2002-06-28 | GP,S2,S5,R2,R3,G2,G1 | 3840h | 3840h | LCS-GERAN | Rel-5 | Paolo |  |  |  |  |
| 1942 | 88.9 | FS on LCS support in the IMS | 90d | 2001-02-12 A | 2002-01-18 A |  | 100% | 2001-02-12 | 2002-01-18 | 90d | start no earlier than 2001-02-12 | S1 | 720h | 720h |  | Rel-5 | Alain |  |  |  |  |
| 1943 | 88.10 | Charging and OAM&P for LCS enhancements | 201d | 2001-09-21 A | 2002-06-28 A |  | 100% | 2001-09-21 | 2002-06-28 | 201d | finish no earlier than 2002-06-28 | S5 | 1608h | 1608h | LCS1-OAM | Rel-5 | Dionisio |  | 32-series | VoiceStream, Motorola |  |
| 1944 | 88.11 | New security aspects of LCS (not identified) | 446d | 2000-04-14 A | 2001-12-28 A |  | 100% | 2000-04-14 | 2001-12-28 | 446d | finish no earlier than 2001-12-28 | S3 | 3568h | 3568h | LCS1-SEC | Rel-5 | Dionisio |  |  | Nokia | valtteri.niemi@nokia.com |
| 1945 | 88.12 | Specification for the Le Interface | 45d | 2002-01-14 A | 2002-03-15 A |  | 100% | 2002-01-14 | 2002-03-15 | 45d | start no earlier than 2002-01-14 | S2 | 360h | 360h | LCS1-Le | Rel-5 | Maurice |  |  |  |  |
| 1946 | 88.13 | Deleted - CHECK STATUS - Inter-GMLC interface | 153d | 2002-05-30 A | 2002-12-30 A |  | 100% | 2002-05-30 | 2002-12-30 | 153d | finish no earlier than 2002-12-30 | S2 | 1224h | 1224h |  | Rel-5 | Maurice | SP-10 |  |  |  |
| 1947 | 89 | **Rel-5 Security enhancements** | 615d | 2000-02-21 A | 2002-06-28 A |  | 100% | 2000-02-21 | 2002-06-28 | 615d |  | S3 | 29974.9h | 29974.9h |  | Rel-5 | Dionisio |  |  | Vodafone | Peter.Howard@vodafone.com |
| 1948 | 89.1 | **Network domain security** | 615d | 2000-02-21 A | 2002-06-28 A |  | 100% | 2000-02-21 | 2002-06-28 | 615d |  | S3 | 25054.9h | 25054.9h | SEC1-NDS | Rel-5 | Dionisio |  |  | Telenor | Geir-myrdahl.koien@telenor.com |
| 1949 | 89.1.1 | **Deleted -Control plane protection in core network (e.g., GTP, CAP, MAP/IP, provided by IPsec)** | 541d | 2000-05-12 A | 2002-06-07 A |  | 100% | 2000-05-12 | 2002-06-07 | 541d |  | S3 | 7118.9h | 7118.9h |  | Rel-5 | Dionisio | SP-16 |  |  |  |
| 1950 | 89.1.1.1 | Deleted - Main aspects | 290d | 2000-05-12 A | 2001-06-21 A |  | 100% | 2000-05-12 | 2001-06-21 | 290d | finish no earlier than 2001-06-21 | S3 | 2320h | 2320h |  | Rel-5 | Dionisio | SP-12 |  |  |  |
| 1951 | 89.1.1.2 | Deleted -Integration of GTP signalling security architecture | 191d | 2001-09-14 A | 2002-06-07 A |  | 100% | 2001-09-14 | 2002-06-07 | 191d | finish no earlier than 2002-06-07 | N4 | 1528h | 1528h |  | Rel-5 | Kimmo | NP-16 |  |  |  |
| 1952 | 89.1.2 | **Deleted -User plane protection in core network (e.g., provided by IPsec)** | 615d | 2000-02-21 A | 2002-06-28 A |  | 100% | 2000-02-21 | 2002-06-28 | 615d |  | S3 | 9360h | 9360h |  | Rel-5 | Dionisio | SP-16 |  |  |  |
| 1953 | 89.1.2.1 | Deleted -Main aspects | 349d | 2000-02-21 A | 2001-06-21 A |  | 100% | 2000-02-21 | 2001-06-21 | 349d | finish no earlier than 2001-06-21 | S3 | 2792h | 2792h |  | Rel-5 | Dionisio | SP-12 |  |  |  |
| 1954 | 89.1.2.2 | Deleted -Integration of GTP signalling security architecture | 206d | 2001-09-14 A | 2002-06-28 A |  | 100% | 2001-09-14 | 2002-06-28 | 206d | finish no earlier than 2002-06-28 | N4 | 1648h | 1648h |  | Rel-5 | Kimmo | NP-16 |  |  |  |
| 1955 | 89.1.3 | IP network layer security (NDS/IP) | 457d | 2000-06-15 A | 2002-03-15 A |  | 100% | 2000-06-15 | 2002-03-15 | 457d | finish no earlier than 2002-03-15 | S3 | 3656h | 3656h | SEC1-NDS-IP | Rel-5 | Dionisio |  | 33.210 | Telenor | Geir-myrdahl.koien@telenor.com |
| 1956 | 90 | **Intra Domain Connection of RAN Nodes to Multiple CN Nodes** | 455d | 2000-10-02 A | 2002-06-28 A |  | 100% | 2000-10-02 | 2002-06-28 | 455d |  | S2 | 15136h | 15136h | IUFLEX | Rel-5 | Alain |  | 23.236 | Ericsson | stephen.terrill@ericsson.com |
| 1957 | 90.1 | Overall System Architecture | 188d | 2001-01-03 A | 2001-09-21 A |  | 100% | 2001-01-03 | 2001-09-21 | 188d | finish no earlier than 2001-06-01 | S2 | 1504h | 1504h |  | Rel-5 | Maurice |  |  |  |  |
| 1958 | 90.2 | Stage 3: RAN node selecting CN node | 130d | 2001-09-24 A | 2002-03-22 A | 1957 | 100% | 2001-09-24 | 2002-03-22 | 130d | finish no earlier than 2002-03-22 | R3 | 1040h | 1040h |  | Rel-5 | Juha |  |  | Vodafone | Brendan.McWilliams@gb.vodafone.co.uk |
| 1959 | 90.3 | N1 work | 205d | 2001-09-17 A | 2002-06-28 A |  | 100% | 2001-09-17 | 2002-06-28 | 205d | start no earlier than 2001-09-17 | N1 | 1640h | 1640h |  | Rel-5 | Frederic |  | 24.008 and check 29.018 |  |  |
| 1960 | 90.4 | N4 work | 375d | 2000-10-02 A | 2002-03-08 A |  | 100% | 2000-10-02 | 2002-03-08 | 375d | finish no earlier than 2002-03-15 | N4 | 3000h | 3000h |  | Rel-5 | Kimmo |  |  |  |  |

Notes:
- 1936: Not started 02/3003. Marked as stopped 12/2008
- 1937: Marked as stopped 12/2008
- 1938: Marked as stopped 12/2008
- 1939: Marked as closed 12/2008 (was marked 17% complete)
- 1940: -
- 1941: -
- 1942: Marked as closed 12/2008 (was marked 75% complete)
- 1943: -
- 1944: 14/09/00: WI may need to be split to improve on this date. S3#17 15% complete. No progress since S3#17
- 1945: -
- 1946: Marked as stopped 12/2008
- 1947: Added BB UE authentication and rapporteur added. TO BE DELETED
- 1948: S3#17: All due in Rel5. (WI Update at S3#18). Replaced by NDS-IP and NDS-MAP. TO BE DELETED OR MOVED TO HISTORY FILE
- 1949: Marked as stopped 12/2008
- 1950: TO BE DELETED. Marked as stopped 12/2008
- 1951: Waiting for input from SA3!.... Marked as stopped 12/2008
- 1952: TO BE DELETED. Marked as stopped 12/2008
- 1953: -
- 1954: 14/02/2002 requirements are not clear/not received...Marked as closed 12/2008 (was marked 95 complete)
- 1955: 2002/12: All IPsec RFCs are stable STD Track RFCs. WID updated SP#17
- 1956: No clear indication on the end date. Put to Rel5 by AS.
- 1957: -
- 1958: Not identified
- 1959: -
- 1960: DAB 12.12.01 - % complete to 66% / 14/02/02 Work completed

| ID | WBS | Task | Duration | Start | Finish | Complete | Baseline start | Baseline finish | Baseline duration | Constraint | Resources | Work | Actual work | Text1 | Text4 | Text5 | Text6 | Text8 | Text12 | Text3 |
| --- | --- | --- | --- | --- | --- | --- | --- | --- | --- | --- | --- | --- | --- | --- | --- | --- | --- | --- | --- | --- |
| 1961 | 90.5 | **GERAN work for Intra Domain Connection of RAN Nodes to Multiple CN Nodes** | 101d | 2002-02-08 A | 2002-06-28 A | 100% | 2002-02-08 | 2002-06-28 | 101d |  | GP | 4848h | 4848h | IDCRAN-GERAN | Ericsson | ingemar.backlund@era.ericsson.se | Rel-5 | Paolo |  |  |
| 1962 | 90.5.1 | Stage 2 (changes to ) | 101d | 2002-02-08 A | 2002-06-28 A | 100% | 2002-02-08 | 2002-06-28 | 101d | finish no earlier than 2002-06-28 | G1 | 808h | 808h |  |  |  | Rel-5 |  |  |  |
| 1963 | 90.5.2 | 43.051 Introduction of support for IDNNS in GERAN Iu mode | 101d | 2002-02-08 A | 2002-06-28 A | 100% | 2002-02-08 | 2002-06-28 | 101d | finish no earlier than 2002-06-28 | G1 | 808h | 808h |  |  |  | Rel-5 |  |  |  |
| 1964 | 90.5.3 | Stage 3 (changes to ) | 101d | 2002-02-08 A | 2002-06-28 A | 100% | 2002-02-08 | 2002-06-28 | 101d | finish no earlier than 2002-06-28 | G2 | 808h | 808h |  |  |  | Rel-5 | Gert |  |  |
| 1965 | 90.5.4 | 48.016 Use of Gb interface concepts when a network applies IDNNS | 101d | 2002-02-08 A | 2002-06-28 A | 100% | 2002-02-08 | 2002-06-28 | 101d | finish no earlier than 2002-06-28 | G2 | 808h | 808h |  |  |  | Rel-5 | Gert |  |  |
| 1966 | 90.5.5 | 48.018 Include MSC/VLR identity in CS IMSI paging | 101d | 2002-02-08 A | 2002-06-28 A | 100% | 2002-02-08 | 2002-06-28 | 101d | finish no earlier than 2002-06-28 | G2 | 808h | 808h |  |  |  | Rel-5 | Gert |  |  |
| 1967 | 91 | **Deleted - GERAN improvements 3 (new transport layer on interface A)** | 446d | 2001-04-06 A | 2002-12-20 A | 100% | 2001-04-06 | 2002-12-20 | 446d |  | GP | 14272h | 14272h | GEIMP3 |  |  | Rel-5 | Paolo |  |  |
| 1968 | 91.1 | **Deleted - Evolution of the transport for A** | 446d | 2001-04-06 A | 2002-12-20 A | 100% | 2001-04-06 | 2002-12-20 | 446d |  | GP | 10704h | 10704h | GEIMP3-EtA |  |  | Rel-5 | Paolo | GP-12 |  |
| 1969 | 91.1.1 | Deleted - Definition of a new A/Ater interface Transport Layer option based on the Iu Interface Transport Layer | 446d | 2001-04-06 A | 2002-12-20 A | 100% | 2001-04-06 | 2002-12-20 | 446d | finish no earlier than 2002-12-20 | GP | 3568h | 3568h |  |  |  | Rel-5 | Paolo | GP-12 |  |
| 1970 | 91.1.2 | Deleted - Adaptation of the Layer 3 BSSMAP procedures as required | 446d | 2001-04-06 A | 2002-12-20 A | 100% | 2001-04-06 | 2002-12-20 | 446d | finish no earlier than 2002-12-20 | GP | 3568h | 3568h |  |  |  | Rel-5 | Paolo | GP-12 |  |
| 1971 | 92 | **Rel-5 Charging and OAM&P** | 264d | 2001-09-10 A | 2002-09-12 A | 100% | 2001-09-10 | 2002-09-12 | 264d |  | S5 | 9976h | 9976h | OAM | VoiceStream, Motorola |  | Rel-5 | Dionisio |  |  |
| 1972 | 92.1 | Rel5 Principles, high level Requirements and Architecture | 205d | 2001-09-17 A | 2002-06-28 A | 100% | 2001-09-17 | 2002-06-28 | 205d | finish no earlier than 2002-06-28 | S5 | 1640h | 1640h | OAM-AR/PR | Motorola |  | Rel-5 | Dionisio |  | 32.101, 32.102 |
| 1973 | 92.2 | Rel5 Performance Management | 259d | 2001-09-17 A | 2002-09-12 A | 100% | 2001-09-17 | 2002-09-12 | 259d | finish no earlier than 2002-09-12 | S5 | 2072h | 2072h | OAM-PM | Nortel |  | Rel-5 | Dionisio |  | 32.4xy, 52.402 |
| 1974 | 92.3 | Rel5 Charging Management | 264d | 2001-09-10 A | 2002-09-12 A | 100% | 2001-09-10 | 2002-09-12 | 264d | finish no earlier than 2002-09-12 | S5 | 2112h | 2112h | OAM-CH | T-Mobile | Karl-Heinz.Nenner@T-MOBILE.DE | Rel-5 | Dionisio |  | 32.200, 32.205, 32.215, 32.225, 32.235 |
| 1975 | 92.4 | Rel5 Network Infrastructure Management | 255d | 2001-09-21 A | 2002-09-12 A | 100% | 2001-09-21 | 2002-09-12 | 255d | finish no earlier than 2002-09-12 | S5 | 2040h | 2040h | OAM-NIM | Ericsson | thomas.tovinger@ericsson.com | Rel-5 | Dionisio |  | 32.6xy, 32.3xy |
| 1976 | 93 | **GERAN enhancements for streaming services 1 (RLC enhancements)** | 430d | 2000-11-06 A | 2002-06-28 A | 100% | 2000-11-06 | 2002-06-28 | 430d |  | GP | 8944h | 8944h |  |  |  | Rel-5 | Paolo |  |  |
| 1977 | 93.1 | Concept | 258d | 2000-11-06 A | 2001-10-31 A | 100% | 2000-11-06 | 2001-10-31 | 258d | finish no earlier than 2001-10-31 | GP | 2064h | 2064h |  |  |  | Rel-5 | Paolo |  |  |
| 1978 | 93.2 | RLC protocol enhancement (SDU Discard) | 430d | 2000-11-06 A | 2002-06-28 A | 100% | 2000-11-06 | 2002-06-28 | 430d | finish no earlier than 2002-06-28 | GP | 3440h | 3440h |  |  |  | Rel-5 | Paolo |  |  |
| 1979 | 94 | **GERAN enhancements for streaming services 2 (usage of ECSD)** | 430d | 2000-11-06 A | 2002-06-28 A | 100% | 2000-11-06 | 2002-06-28 | 430d |  | GP | 19840h | 19840h |  | Ericsson | Frank Muller | Rel-5 | Paolo |  |  |
| 1980 | 94.1 | Usage of ECSD Concept | 380d | 2000-11-06 A | 2002-04-19 A | 100% | 2000-11-06 | 2002-04-19 | 380d | finish no earlier than 2002-04-19 | GP | 3040h | 3040h |  |  |  | Rel-5 | Paolo |  |  |
| 1981 | 94.2 | Stage 2 | 380d | 2000-11-06 A | 2002-04-19 A | 100% | 2000-11-06 | 2002-04-19 | 380d | finish no earlier than 2002-04-19 | GP | 3040h | 3040h |  |  |  | Rel-5 | Paolo |  |  |
| 1982 | 94.3 | Stage 3 | 430d | 2000-11-06 A | 2002-06-28 A | 100% | 2000-11-06 | 2002-06-28 | 430d | finish no earlier than 2002-06-28 | GP | 3440h | 3440h |  |  |  | Rel-5 | Paolo |  |  |
| 1983 | 94.4 | RLC PDU formats | 430d | 2000-11-06 A | 2002-06-28 A | 100% | 2000-11-06 | 2002-06-28 | 430d | finish no earlier than 2002-06-28 | GP | 3440h | 3440h |  |  |  | Rel-5 | Paolo |  |  |
| 1984 | 94.5 | MAC header | 430d | 2000-11-06 A | 2002-06-28 A | 100% | 2000-11-06 | 2002-06-28 | 430d | finish no earlier than 2002-06-28 | GP | 3440h | 3440h |  |  |  | Rel-5 | Paolo |  |  |

Notes:
- 1961: Accept changes Gb over IP
- 1962: -
- 1963: -
- 1964: -
- 1965: Closed, accept changes for Gb over IP
- 1966: -
- 1967: Terminated - not standardized. Marked as stopped 12/2008
- 1968: TERMINATED - NOT STANDARDIZED. Marked as stopped 12/2008
- 1969: TERMINATED - NOT STANDARDIZED. Marked as stopped 12/2008
- 1970: TERMINATED - NOT STANDARDIZED. Marked as stopped 12/2008
- 1971: -
- 1972: -
- 1973: -
- 1974: -
- 1975: -
- 1976: -
- 1977: -
- 1978: -
- 1979: AWS, Nokia, Ericsson, Nortel, Siemens, Motorola, Vodafone
- 1980: -
- 1981: -
- 1982: -
- 1983: -
- 1984: -

| ID | WBS | Task | Duration | Start | Finish | Predecessors | Complete | Baseline start | Baseline finish | Baseline duration | Constraint | Resources | Work | Actual work | Text1 | Text4 | Text5 | Text6 | Text8 |
| --- | --- | --- | --- | --- | --- | --- | --- | --- | --- | --- | --- | --- | --- | --- | --- | --- | --- | --- | --- |
| 1985 | 95 | **GERAN/UTRAN interface evolution 1 (evolution of Iu PS)** | 476d | 2000-09-01 A | 2002-06-28 A |  | 100% | 2000-09-01 | 2002-06-28 | 476d |  | GP,R3 | 10688h | 10688h | GERUEV1 | SBC | Marc Grant | Rel-5 | Paolo |
| 1986 | 95.1 | **Evolution of Iu ps** | 476d | 2000-09-01 A | 2002-06-28 A |  | 100% | 2000-09-01 | 2002-06-28 | 476d |  | GP,R3 | 7248h | 7248h | GERUEV1-IuPS |  |  | Rel-5 | Paolo |
| 1987 | 95.1.1 | Identification of GERAN requirements on Iu ps | 326d | 2000-09-01 A | 2001-11-30 A |  | 100% | 2000-09-01 | 2001-11-30 | 326d | finish no earlier than 2001-11-30 | GP,R3 | 2608h | 2608h |  |  |  | Rel-5 | Paolo |
| 1988 | 95.1.2 | Update of specifications | 150d | 2001-12-03 A | 2002-06-28 A | 1987 | 100% | 2001-12-03 | 2002-06-28 | 150d | finish no earlier than 2002-06-28 | GP,R3 | 1200h | 1200h |  |  |  | Rel-5 | Paolo |
| 1989 | 96 | **GERAN/UTRAN interface evolution 2 (evolution of Iu CS)** | 476d | 2000-09-01 A | 2002-06-28 A |  | 100% | 2000-09-01 | 2002-06-28 | 476d |  | GP,R3 | 12816h | 12816h | GERUEV2 |  |  | Rel-5 | Paolo |
| 1990 | 96.1 | **Evolution of Iu cs** | 476d | 2000-09-01 A | 2002-06-28 A |  | 100% | 2000-09-01 | 2002-06-28 | 476d |  | GP,R3 | 10016h | 10016h | GERUEV2-IuCS | Lucent | Krishna Balachandran | Rel-5 | Paolo |
| 1991 | 96.1.1 | Identification of GERAN requirements on Iu cs | 426d | 2000-09-01 A | 2002-06-24 A |  | 100% | 2000-09-01 | 2002-06-24 | 426d | finish no earlier than 2002-04-19 | GP,R3 | 3408h | 3408h |  |  |  | Rel-5 | Paolo |
| 1992 | 96.1.2 | Update of specifications | 476d | 2000-09-01 A | 2002-06-28 A |  | 100% | 2000-09-01 | 2002-06-28 | 476d | finish no earlier than 2002-06-28 | GP,R3 | 3808h | 3808h |  |  |  | Rel-5 | Paolo |
| 1993 | 97 | **End to End QoS for PS Domain including IMS** | 480d | 2000-08-28 A | 2002-06-28 A |  | 100% | 2000-08-28 | 2002-06-28 | 480d |  | S2 | 9856h | 9856h | E2EQoS | Ericsson | Johnson.oyama@era.ericcson.se | Rel-5 | Maurice |
| 1994 | 97.1 | E2E QoSConcept and Architecture | 178d | 2001-01-03 A | 2001-09-07 A |  | 100% | 2001-01-03 | 2001-09-07 | 178d | finish no earlier than 2001-09-07 | S2 | 1424h | 1424h |  |  |  | Rel-5 | Maurice |
| 1995 | 97.2 | E2E QoS interworking | 465d | 2000-08-28 A | 2002-06-07 A |  | 100% | 2000-08-28 | 2002-06-07 | 465d | finish no earlier than 2002-06-07 | N3 | 3720h | 3720h | E2EQoS-IW | Lucent | Daisuke Yokota (yokota@lucent.com) | Rel-5 | Gwiho |
| 1996 | 97.3 | QoS Management (Provisioning and Monitoring) | 201d | 2001-09-21 A | 2002-06-28 A |  | 100% | 2001-09-21 | 2002-06-28 | 201d | finish no earlier than 2002-06-28 | S5 | 1608h | 1608h | E2EQoS-OAM | VoiceStream, Motorola |  | Rel-5 | Dionisio |
| 1997 | 98 | **Messaging enhancements Rel-5** | 467d | 2001-06-15 A | 2003-03-31 A |  | 100% | 2001-06-15 | 2003-03-31 | 467d |  | T2 | 19000h | 19000h | MESS5 |  |  | Rel-5 | Kimmo |
| 1998 | 98.1 | **Multimedia Messaging (MMS) enhancements** | 467d | 2001-06-15 A | 2003-03-31 A |  | 100% | 2001-06-15 | 2003-03-31 | 467d |  | T2 | 11688h | 11688h | MESS5-MMS | Siemens | Josef.Laumen@SAL.SIEMENS.DE | Rel-5 | Alain |
| 1999 | 98.1.1 | Definition of service requirements | 196d | 2001-06-15 A | 2002-03-15 A |  | 100% | 2001-06-15 | 2002-03-15 | 196d | finish no earlier than 2002-03-15 | S1 | 1568h | 1568h | MESS5-SR | Siemens | Josef.Laumen@SAL.SIEMENS.DE | Rel-5 |  |
| 2000 | 98.1.2 | Technical realization | 256d | 2001-06-15 A | 2002-06-07 A |  | 100% | 2001-06-15 | 2002-06-07 | 256d | finish no earlier than 2002-06-07 | T2 | 2048h | 2048h |  | Siemens | Josef.Laumen@SAL.SIEMENS.DE | Rel-5 |  |
| 2001 | 98.1.3 | WAP Forum dependency: MM1 stage 3 | 467d | 2001-06-15 A | 2003-03-31 A |  | 100% | 2001-06-15 | 2003-03-31 | 467d | finish no earlier than 2003-03-31 | T2 | 3736h | 3736h |  |  |  | Rel-5 |  |
| 2002 | 98.1.4 | MMS formats and codecs | 75d | 2001-12-03 A | 2002-03-15 A |  | 100% | 2001-12-03 | 2002-03-15 | 75d | finish no earlier than 2002-03-15 | S4 | 600h | 600h |  |  |  | Rel-5 | Paolo |
| 2003 | 98.2 | **Enhanced Messaging Service (EMS) enhancements** | 191d | 2001-06-15 A | 2002-03-08 A |  | 100% | 2001-06-15 | 2002-03-08 | 191d |  | T2 | 3584h | 3584h | MESS5-EMS | Ericsson | Alan.Baldwin@EML.ERICSSON.SE | Rel-5 |  |
| 2004 | 98.2.1 | Definition of service requirements | 66d | 2001-06-15 A | 2001-09-14 A |  | 100% | 2001-06-15 | 2001-09-14 | 66d | finish no earlier than 2001-09-14 | S1 | 528h | 528h |  | Ericsson | Alan.Baldwin@EML.ERICSSON.SE | Rel-5 | Alain |
| 2005 | 98.2.2 | Technical realization | 191d | 2001-06-15 A | 2002-03-08 A |  | 100% | 2001-06-15 | 2002-03-08 | 191d | finish no earlier than 2002-03-08 | T2 | 1528h | 1528h |  | Ericsson | Alan.Baldwin@EML.ERICSSON.SE | Rel-5 |  |
| 2006 | 99 | **GERAN Inter BSC NACC improvements over the Gb Interface** | 215d | 2001-09-03 A | 2002-06-28 A |  | 100% | 2001-09-03 | 2002-06-28 | 215d |  | GP | 8200h | 8200h | GERNACC |  |  | Rel-5 | Paolo |
| 2007 | 99.1 | **Modification of core network protocols for GERAN Inter BSC NACC over Gb Interface** | 165d | 2001-09-03 A | 2002-04-19 A |  | 100% | 2001-09-03 | 2002-04-19 | 165d |  | N4,S2 | 4064h | 4064h | GERNACC-Cnmod |  |  | Rel-5 | Kimmo |
| 2008 | 99.1.1 | Stage 2 - Concept | 43d | 2001-09-03 A | 2001-10-31 A |  | 100% | 2001-09-03 | 2001-10-31 | 43d | finish no earlier than 2001-10-31 | N4,S2 | 344h | 344h |  |  |  | Rel-5 | Kimmo |
| 2009 | 99.1.2 | Stage 2 - 23.060 change - Definition of Inter BSC NACC | 165d | 2001-09-03 A | 2002-04-19 A |  | 100% | 2001-09-03 | 2002-04-19 | 165d | finish no earlier than 2002-04-19 | N4,S2 | 1320h | 1320h |  |  |  | Rel-5 | Kimmo |
| 2010 | 99.1.3 | Stage 3 (changes to TS 29.060) | 135d | 2001-09-03 A | 2002-03-08 A |  | 100% | 2001-09-03 | 2002-03-08 | 135d | finish no earlier than 2002-03-08 | N4 | 1080h | 1080h |  |  |  | Rel-5 | Kimmo |

Notes:
- 1985: SBC, Motorola, Nokia, Ericsson, Nortel
- 1986: -
- 1987: -
- 1988: -
- 1989: -
- 1990: Lucent, Ericsson, AWS, Nortel
- 1991: -
- 1992: -
- 1993: -
- 1994: - / Text3: 23.207
- 1995: [DAB - 30/07/02] - % complete to 95% (if we exclude Diffserv). Marked as closed 12/2008 (was marked 95% complete) / Text3: 29.208, 29.207, 27.060, 29.061, 24.008, 24.228, , 24.229, 29.060, 29.163
- 1996: - / Text3: 32-series
- 1997: support of UAProf, so this in my opinion is 100% complete
- 1998: -
- 1999: - / Text3: 22.140
- 2000: stage 3 MM7 is missing / Text3: 23.140
- 2001: Marked as closed 12/2008 (was marked 80% complete)
- 2002: - / Text3: 26.140
- 2003: - / Text3: 23.040
- 2004: -
- 2005: - / Text3: 23.040
- 2006: -
- 2007: -
- 2008: -
- 2009: -
- 2010: IP 30/11/01: Input awaited from GERAN2 to CN4 / 17 May Work complete 100%

| ID | WBS | Task | Duration | Start | Finish | Complete | Baseline start | Baseline finish | Baseline duration | Constraint | Resources | Work | Actual work | Text1 | Text6 | Text8 | Text12 | Text3 | Text4 | Text5 |
| --- | --- | --- | --- | --- | --- | --- | --- | --- | --- | --- | --- | --- | --- | --- | --- | --- | --- | --- | --- | --- |
| 2011 | 99.2 | **Modification of Gb protocols for GERAN Inter BSC NACC over Gb Interface** | 151d | 2001-11-30 A | 2002-06-28 A | 100% | 2001-11-30 | 2002-06-28 | 151d |  | GP | 2416h | 2416h | GERNACC-Gbmod | Rel-5 | Paolo |  |  |  |  |
| 2012 | 99.2.1 | Stage 3 (changes to TS 48.018) | 151d | 2001-11-30 A | 2002-06-28 A | 100% | 2001-11-30 | 2002-06-28 | 151d | finish no earlier than 2002-06-28 | GP | 1208h | 1208h |  | Rel-5 | Paolo |  |  |  |  |
| 2013 | 100 | **Enhanced Power Control** | 540d | 2001-11-26 A | 2003-12-19 A | 100% | 2001-11-26 | 2003-12-19 | 540d |  | GP | 12840h | 12840h | EPC | Rel-5 | Paolo |  |  |  |  |
| 2014 | 100.1 | Realization of Enhanced power control and signalling support | 5d | 2001-11-26 A | 2001-11-30 A | 100% | 2001-11-26 | 2001-11-30 | 5d | finish no earlier than 2001-11-30 | GP | 40h | 40h |  | Rel-5 | Paolo |  |  |  |  |
| 2015 | 100.2 | Deleted - GERAN MS Conformance test for Enhanced Power Control | 530d | 2001-12-10 A | 2003-12-19 A | 100% | 2001-12-10 | 2003-12-19 | 530d | finish no earlier than 2003-12-19 | GP | 4240h | 4240h |  | Rel-5 | Paolo | GP-17 |  |  |  |
| 2016 | 100.3 | Deleted - GERAN BTS Conformance test for Enhanced Power Control | 530d | 2001-12-10 A | 2003-12-19 A | 100% | 2001-12-10 | 2003-12-19 | 530d | finish no earlier than 2003-12-19 | GP | 4240h | 4240h |  | Rel-5 | Paolo | GP-17 |  |  |  |
| 2017 | 101 | **8PSK AMR HR** | 530d | 2001-12-10 A | 2003-12-19 A | 100% | 2001-12-10 | 2003-12-19 | 530d |  | GP | 21080h | 21080h | 8PSK-AH | Rel-5 | Paolo |  |  |  |  |
| 2018 | 101.1 | **Definition of channel coding, performance requirements and signalling support** | 145d | 2001-12-10 A | 2002-06-28 A | 100% | 2001-12-10 | 2002-06-28 | 145d |  | GP | 10440h | 10440h |  | Rel-5 | Paolo |  |  |  |  |
| 2019 | 101.1.1 | Concept | 145d | 2001-12-10 A | 2002-06-28 A | 100% | 2001-12-10 | 2002-06-28 | 145d | finish no earlier than 2002-06-28 | GP | 1160h | 1160h |  | Rel-5 | Paolo |  |  |  |  |
| 2020 | 101.1.2 | Changes to 44.018 | 145d | 2001-12-10 A | 2002-06-28 A | 100% | 2001-12-10 | 2002-06-28 | 145d | finish no earlier than 2002-06-28 | G2 | 1160h | 1160h |  | Rel-5 | Gert |  |  |  |  |
| 2021 | 101.1.3 | Changes to 45.001 | 145d | 2001-12-10 A | 2002-06-28 A | 100% | 2001-12-10 | 2002-06-28 | 145d | finish no earlier than 2002-06-28 | G1 | 1160h | 1160h |  | Rel-5 |  |  |  |  |  |
| 2022 | 101.1.4 | Changes to 45.002 | 145d | 2001-12-10 A | 2002-06-28 A | 100% | 2001-12-10 | 2002-06-28 | 145d | finish no earlier than 2002-06-28 | G1 | 1160h | 1160h |  | Rel-5 |  |  |  |  |  |
| 2023 | 101.1.5 | Changes to 45.003 | 145d | 2001-12-10 A | 2002-06-28 A | 100% | 2001-12-10 | 2002-06-28 | 145d | finish no earlier than 2002-06-28 | G1 | 1160h | 1160h |  | Rel-5 |  |  |  |  |  |
| 2024 | 101.1.6 | Changes to 45.005 | 145d | 2001-12-10 A | 2002-06-28 A | 100% | 2001-12-10 | 2002-06-28 | 145d | finish no earlier than 2002-06-28 | G1 | 1160h | 1160h |  | Rel-5 |  |  |  |  |  |
| 2025 | 101.1.7 | Changes to 24.008 | 145d | 2001-12-10 A | 2002-06-28 A | 100% | 2001-12-10 | 2002-06-28 | 145d | finish no earlier than 2002-06-28 | G2 | 1160h | 1160h |  | Rel-5 | Gert |  |  |  |  |
| 2026 | 101.1.8 | Changes to 48.058 | 145d | 2001-12-10 A | 2002-06-28 A | 100% | 2001-12-10 | 2002-06-28 | 145d | finish no earlier than 2002-06-28 | G2 | 1160h | 1160h |  | Rel-5 | Gert |  |  |  |  |
| 2027 | 101.2 | Deleted - GERAN MS Conformance test for 8PSK HR | 530d | 2001-12-10 A | 2003-12-19 A | 100% | 2001-12-10 | 2003-12-19 | 530d | finish no earlier than 2003-12-19 | GP | 4240h | 4240h |  | Rel-5 | Paolo | GP-17 |  |  |  |
| 2028 | 101.3 | GERAN BTS Conformance test for 8PSK HR | 270d | 2001-12-10 A | 2002-12-20 A | 100% | 2001-12-10 | 2002-12-20 | 270d | finish no earlier than 2002-12-20 | GP | 2160h | 2160h |  | Rel-5 | Paolo |  |  |  |  |
| 2029 | 102 | Service Change and UDI Fallback | 175d | 2001-10-08 A | 2002-06-07 A | 100% | 2001-10-08 | 2002-06-07 | 175d | finish no earlier than 2002-06-07 | N3 | 1400h | 1400h | SCUDIF | Rel-5 | Gwiho |  | 29.007, 27.001, 24.008 | Ericsson | Rune.Werner.Wiik@ericsson.no |
| 2030 | 103 | **Rel-5 USIM toolkit enhancements** | 865d | 2000-06-05 A | 2003-09-26 A | 100% | 2000-06-05 | 2003-09-26 | 865d |  | T3 | 24352h | 24352h | USAT1-Interpr | Rel-5 | Xavier |  |  | G & D | Michael Meyer |
| 2031 | 103.1 | Deleted - Test specification for USIM toolkit security mechanisms | 349d | 2002-05-28 A | 2003-09-26 A | 100% | 2002-05-28 | 2003-09-26 | 349d | finish no earlier than 2003-09-26 | T3 | 2792h | 2792h |  | Rel-5 |  | TP-21 |  | Gemplus | Sophie Viallet |
| 2032 | 103.2 | **Protocol Standardisation of a SIM Toolkit Interpreter** | 688d | 2000-06-05 A | 2003-01-22 A | 100% | 2000-06-05 | 2003-01-22 | 688d |  | T3 | 12512h | 12512h | USAT1-Interpr | Rel-5 | Xavier |  | 27.103 | G & D | Michael Meyer |
| 2033 | 103.2.1 | Stage 1 | 205d | 2000-06-05 A | 2001-03-16 A | 100% | 2000-06-05 | 2001-03-16 | 205d | finish no earlier than 2001-03-16 | T3 | 1640h | 1640h | USAT1-Interpr | Rel-5 | Xavier |  |  |  |  |
| 2034 | 103.2.2 | Stage 2 and 3 | 308d | 2001-01-03 A | 2002-03-08 A | 100% | 2001-01-03 | 2002-03-08 | 308d | finish no earlier than 2002-03-08 | T3 | 2464h | 2464h | USAT1-Interpr | Rel-5 | Xavier |  |  |  |  |
| 2035 | 103.2.3 | Test specification | 363d | 2001-09-03 A | 2003-01-22 A | 100% | 2001-09-03 | 2003-01-22 | 363d | finish no earlier than 2003-01-22 | T3 | 2904h | 2904h | USAT1-Interpr | Rel-5 | Xavier |  |  | Gemplus | Gérald MAUNIER |

Notes:
- 2011: -
- 2012: -
- 2013: -
- 2014: Completed 11/2001
- 2015: Not started. Marked as stopped 12/2008
- 2016: Not started. Marked as stopped 12/2008
- 2017: Completed for Rel-5
- 2018: -
- 2019: -
- 2020: -
- 2021: -
- 2022: -
- 2023: -
- 2024: -
- 2025: -
- 2026: -
- 2027: Marked as stopped 12/2008
- 2028: -
- 2029: -
- 2030: -
- 2031: Marked as stopped 12/2008
- 2032: 28/5/2001: T3-19 proposed that since the stage 2 and 3 will not be presented to TP-12 for approval as expected, the WI will be moved to rel-5, with completion expected at TP-13.
- 2033: 5/10/2001: Stage one comepeted at TP-12.
- 2034: 5/10/2001: TS 31.112 and 31.113 approved at TP-13. TS 31.114 to be presented to TP-14.
- 2035: 5/10/2001: Work started on test specification. Marked as closed 12/2008 (was marked 12% complete)

| ID | WBS | Task | Duration | Start | Finish | Complete | Baseline start | Baseline finish | Baseline duration | Constraint | Resources | Work | Actual work | Text1 | Text4 | Text5 | Text6 | Text8 | Text12 |
| --- | --- | --- | --- | --- | --- | --- | --- | --- | --- | --- | --- | --- | --- | --- | --- | --- | --- | --- | --- |
| 2036 | 103.4 | **(U)SIM API** | 133d | 2002-03-20 A | 2002-09-20 A | 100% | 2002-03-20 | 2002-09-20 | 133d |  | T3 | 2128h | 2128h | USAT1-API | Microelectrónica Española | Mario Pérez | Rel-5 | Xavier |  |
| 2037 | 103.4.1 | Java API Test specification | 133d | 2002-03-20 A | 2002-09-20 A | 100% | 2002-03-20 | 2002-09-20 | 133d | finish no earlier than 2002-09-20 | T3 | 1064h | 1064h | USAT1-API | Microelectrónica Española | Mario Pérez | Rel-5 | Xavier |  |
| 2038 | 104 | **small Technical Enhancements and Improvements for Rel5** | 2349d? | 2000-01-03 A | 2008-12-31 A | 100% | 2000-01-03 | 2008-12-31 | 2349d? |  | All | 18792h | 18792h | TEI5 |  |  | Rel-5 | all |  |
| 2039 | 538.1 | Small Technical Enhancements and Improvements for Rel-5 Conformance Testing | 2349d? | 2000-01-03 A | 2008-12-31 A | 100% | 2000-01-03 | 2008-12-31 | 2349d? | finish no earlier than 2008-12-31 | R5,T1 | 18792h | 18792h | TEI5_Test |  |  | Rel-5 | Ingbert |  |
| 2040 | 105 | Deleted - Technical Report on UE Functionality Split | 87d | 2000-01-03 A | 2000-05-01 A | 100% | 2000-01-03 | 2000-05-01 | 87d |  | S1 | 688h | 688h | UESPLIT | Motorola | sanjay.gupta@motorola.com | Rel-5 | Alain | SP-08 |
| 2041 | 106 | **User Equipment Management** | 267d | 2001-06-21 A | 2002-06-28 A | 100% | 2001-06-21 | 2002-06-28 | 267d |  | S5 | 3752h | 3752h | UEM | Vodafone | john.mudge@vf.vodafone.co.uk | Rel-5 | Dionisio |  |
| 2042 | 106.1 | FS on User Equipment (UE) Management | 267d | 2001-06-21 A | 2002-06-28 A | 100% | 2001-06-21 | 2002-06-28 | 267d | finish no earlier than 2002-06-28 | S5 | 2136h | 2136h | OAM-UEM | Vodafone | john.mudge@vf.vodafone.co.uk | Rel-5 | Dionisio |  |
| 2043 | 107 | **Flow control supporting an MS with multiple data flows with different QoS over the Gb interface** | 50d | 2002-06-24 A | 2002-08-30 A | 100% | 2002-06-24 | 2002-08-30 | 50d |  | GP | 1288h | 1288h | FlowCon | Ericsson | ingemar.backlund@era.ericsson.se | Rel-5 | Paolo |  |
| 2044 | 107.1 | **Update of stage 2 specifications** | 50d | 2002-06-24 A | 2002-08-30 A | 100% | 2002-06-24 | 2002-08-30 | 50d |  | GP | 808h | 808h |  |  |  | Rel-5 | Paolo |  |
| 2045 | 107.1.1 | Concept document 23.060 (changes to) | 46d | 2002-06-28 A | 2002-08-30 A | 100% | 2002-06-28 | 2002-08-30 | 46d | finish no earlier than 2002-08-30 | S2 | 368h | 368h |  |  |  | Rel-5 | Maurice |  |
| 2046 | 107.1.2 | Flow Control | 5d | 2002-06-24 A | 2002-06-28 A | 100% | 2002-06-24 | 2002-06-28 | 5d | finish no earlier than 2002-06-28 | GP | 40h | 40h |  |  |  | Rel-5 | Paolo |  |
| 2047 | 107.2 | **Modification of BSSGP protocol** | 5d | 2002-06-24 A | 2002-06-28 A | 100% | 2002-06-24 | 2002-06-28 | 5d |  | GP | 80h | 80h |  | Ericsson | ingemar.backlund@era.ericsson.se | Rel-5 | Paolo |  |
| 2048 | 107.2.1 | Stage 3 (changes to 48.018) | 5d | 2002-06-24 A | 2002-06-28 A | 100% | 2002-06-24 | 2002-06-28 | 5d | finish no earlier than 2002-06-28 | G2 | 40h | 40h |  |  |  | Rel-5 | Gert |  |
| 2049 | 108 | **Deleted - Multiple TBF in A/Gb mode - Phase 1** | 421d | 2002-04-19 A | 2003-11-28 A | 100% | 2002-04-19 | 2003-11-28 | 421d |  | GP | 17480h | 17480h | MULTBF | Ericsson | gunnar.mildh@era.ericsson.se | Rel-5 | Paolo | GP-17 |
| 2050 | 108.1 | **Deleted - Multiple TBF in A/Gb mode - Phase 1** | 351d | 2002-04-19 A | 2003-08-22 A | 100% | 2002-04-19 | 2003-08-22 | 351d |  | GP | 8112h | 8112h | MULTBF-Agbmode |  |  | Rel-5 | Paolo | GP-17 |
| 2051 | 108.1.1 | Deleted - Multiple TBF Concept paper | 351d | 2002-04-19 A | 2003-08-22 A | 100% | 2002-04-19 | 2003-08-22 | 351d | finish no earlier than 2003-08-22 | GP | 2808h | 2808h | MULTBF-Agbmode |  |  | Rel-5 | Paolo | GP-17 |
| 2052 | 108.1.2 | Deleted - Multiple TBF Stage 2 (43.064) CRs | 156d | 2002-04-19 A | 2002-11-22 A | 100% | 2002-04-19 | 2002-11-22 | 156d | finish no earlier than 2002-11-22 | G1 | 1248h | 1248h | MULTBF-Agbmode |  |  | Rel-5 | Paolo | GP-12 |
| 2053 | 108.1.3 | Deleted - Multiple TBF Stage 3 (44.060) CRs | 156d | 2002-04-19 A | 2002-11-22 A | 100% | 2002-04-19 | 2002-11-22 | 156d | finish no earlier than 2002-11-22 | G2 | 1248h | 1248h | MULTBF-Agbmode |  |  | Rel-5 | Gert | GP-12 |
| 2054 | 108.2 | **Deleted - Multiple TBF in A/Gb mode – MS testing** | 375d | 2002-06-24 A | 2003-11-28 A | 100% | 2002-06-24 | 2003-11-28 | 375d |  | GP | 6000h | 6000h |  | Ericsson | ingemar.backlund@era.ericsson.se | Rel-5 | Paolo | GP-17 |
| 2055 | 108.2.1 | Deleted - MS conformance tests | 375d | 2002-06-24 A | 2003-11-28 A | 100% | 2002-06-24 | 2003-11-28 | 375d | finish no earlier than 2003-11-28 | G4 | 3000h | 3000h |  |  |  | Rel-5 | Paolo | GP-17 |
| 2056 | 109 | **Alignment of 3G functional split and Iu** | 922d | 2000-06-08 A | 2003-12-19 A | 100% | 2000-06-08 | 2003-12-19 | 922d |  | GP | 126664h | 126664h | GER3GAL | Ericsson | Frank Muller | Rel-5 | Paolo |  |
| 2057 | 109.1 | **GERAN user / control plane** | 540d | 2000-08-07 A | 2002-08-30 A | 100% | 2000-08-07 | 2002-08-30 | 540d |  | GP | 36232h | 36232h | GER3GAL-GUCOPL | Ericsson | Frank Muller | Rel-5 | Paolo |  |
| 2058 | 109.1.1 | **Alignment with UMTS bearer concept** | 540d | 2000-08-07 A | 2002-08-30 A | 100% | 2000-08-07 | 2002-08-30 | 540d |  | GP | 24952h | 24952h |  |  |  | Rel-5 | Paolo |  |
| 2059 | 109.1.1.1 | Enhanced power control | 1d | 2001-08-31 A | 2001-08-31 A | 100% | 2001-08-31 | 2001-08-31 | 1d | finish no earlier than 2001-08-31 | GP | 8h | 8h |  |  |  | Rel-5 | Paolo |  |
| 2060 | 109.1.1.2 | Stage 2 | 235d | 2000-08-07 A | 2001-06-29 A | 100% | 2000-08-07 | 2001-06-29 | 235d | finish no earlier than 2001-06-29 | GP | 1880h | 1880h |  |  |  | Rel-5 | Paolo |  |
| 2061 | 109.1.1.3 | Adoption of the UTRAN PDCP | 295d | 2000-11-06 A | 2001-12-21 A | 100% | 2000-11-06 | 2001-12-21 | 295d | finish no earlier than 2001-12-21 | GP | 2360h | 2360h |  |  |  | Rel-5 | Paolo |  |
| 2062 | 109.1.1.4 | Development of RLC / MAC | 261d | 2001-08-31 A | 2002-08-30 A | 100% | 2001-08-31 | 2002-08-30 | 261d | finish no earlier than 2002-08-30 | GP | 2088h | 2088h |  |  |  | Rel-5 | Paolo |  |
| 2063 | 109.1.1.5 | Development of GERAN RRC | 266d | 2001-06-22 A | 2002-06-28 A | 100% | 2001-06-22 | 2002-06-28 | 266d | finish no earlier than 2002-06-28 | GP | 2128h | 2128h |  |  |  | Rel-5 | Paolo |  |
| 2064 | 109.1.1.6 | Ciphering and integrity protection concept paper | 166d | 2001-08-31 A | 2002-04-19 A | 100% | 2001-08-31 | 2002-04-19 | 166d | finish no earlier than 2002-04-19 | GP | 1328h | 1328h |  |  |  | Rel-5 | Paolo |  |
| 2065 | 109.1.1.7 | Multiple TBF or equivalent Concept paper | 116d | 2001-08-31 A | 2002-02-08 A | 100% | 2001-08-31 | 2002-02-08 | 116d | finish no earlier than 2002-02-08 | GP | 928h | 928h |  |  |  | Rel-5 | Paolo |  |
| 2066 | 109.1.1.8 | Paging concept | 166d | 2001-08-31 A | 2002-04-19 A | 100% | 2001-08-31 | 2002-04-19 | 166d | finish no earlier than 2002-04-19 | GP | 1328h | 1328h |  |  |  | Rel-5 | Paolo |  |
| 2067 | 109.1.1.9 | Dedicated Physical subchannels, includes traffic and control channels | 66d | 2001-08-31 A | 2001-11-30 A | 100% | 2001-08-31 | 2001-11-30 | 66d | finish no earlier than 2001-11-30 | GP | 528h | 528h |  |  |  | Rel-5 | Paolo |  |
| 2068 | 109.1.1.10 | Iu support and broadcast concept | 166d | 2001-08-31 A | 2002-04-19 A | 100% | 2001-08-31 | 2002-04-19 | 166d | finish no earlier than 2002-04-19 | GP | 1328h | 1328h |  |  |  | Rel-5 | Paolo |  |
| 2069 | 109.1.1.11 | Impact of using RLC instead of LAPDm concept | 116d | 2001-08-31 A | 2002-02-08 A | 100% | 2001-08-31 | 2002-02-08 | 116d | finish no earlier than 2002-02-08 | GP | 928h | 928h |  |  |  | Rel-5 | Paolo |  |
| 2070 | 109.1.1.12 | Contention resolution, mobile station identity, and access concept | 66d | 2001-08-31 A | 2001-11-30 A | 100% | 2001-08-31 | 2001-11-30 | 66d | finish no earlier than 2001-11-30 | GP | 528h | 528h |  |  |  | Rel-5 | Paolo |  |
| 2071 | 109.1.1.13 | PDCP concept | 166d | 2001-08-31 A | 2002-04-19 A | 100% | 2001-08-31 | 2002-04-19 | 166d | finish no earlier than 2002-04-19 | GP | 1328h | 1328h |  |  |  | Rel-5 | Paolo |  |
| 2072 | 109.1.1.14 | Downlink delayed TBF release | 261d | 2001-08-31 A | 2002-08-30 A | 100% | 2001-08-31 | 2002-08-30 | 261d | finish no earlier than 2002-08-30 | GP | 2088h | 2088h |  |  |  | Rel-5 | Paolo |  |
| 2073 | 109.1.1.15 | Add transparent RLC Concept | 116d | 2001-08-31 A | 2002-02-08 A | 100% | 2001-08-31 | 2002-02-08 | 116d | finish no earlier than 2002-02-08 | GP | 928h | 928h |  |  |  | Rel-5 | Paolo |  |
| 2074 | 109.1.1.16 | Handover concept | 116d | 2001-08-31 A | 2002-02-08 A | 100% | 2001-08-31 | 2002-02-08 | 116d | finish no earlier than 2002-02-08 | GP | 928h | 928h |  |  |  | Rel-5 | Paolo |  |

Notes:
- 2036: 8/3/2001: test spec is based on R99 core spec, so deleted from Workplan
- 2037: -
- 2038: "Joker" WI, to be used for a Rel 5 CR not related to any feature and with very limited impact on the system
- 2039: "Joker" WI, to be used for small modifications applicable to Rel 5 conformance testing. Moved in from Stoyan/testing WP. / Text3: 34.108, 34.109, 34.121-1, 34.121-2, 34.122, 34.123-1, 34.123-2, 34.123-3, 34.171, 34.229-1, 34.229-2, 34.229-3
- 2040: -
- 2041: - / Text3: 32.802
- 2042: - / Text3: 32.802
- 2043: 50101 -> 50201
- 2044: 50102 -> 50202
- 2045: -
- 2046: 50103 -> 50203
- 2047: -
- 2048: -
- 2049: GP#17 Nov 2003 Moved to Rel-6 as UID_50600 MULTBF (Only Multiple TBF Concept paper produced in Rel-5)
- 2050: Marked as closed 12/2008 (was marked 26% complete)
- 2051: Marked as closed 12/2008 (was marked 50% complete)
- 2052: Marked as stopped 12/2008
- 2053: Marked as stopped 12/2008
- 2054: 08/08: duplicate UID_50106=-> 50206. Marked as stopped 12/2008
- 2055: Not started. Marked as stopped 12/2008
- 2056: AWS, Nokia, Ericsson, Nortel, Siemens, Vodafone
- 2057: AWS, Nokia, Ericsson, Nortel, Siemens, Vodafone
- 2058: -
- 2059: -
- 2060: -
- 2061: Responsible is GERAN; RAN WG2 help may be needed.
- 2062: -
- 2063: -
- 2064: -
- 2065: -
- 2066: -
- 2067: -
- 2068: -
- 2069: -
- 2070: -
- 2071: -
- 2072: -
- 2073: -
- 2074: -

| ID | WBS | Task | Duration | Start | Finish | Complete | Baseline start | Baseline finish | Baseline duration | Constraint | Resources | Work | Actual work | Text6 | Text8 | Text1 | Text4 | Text5 |
| --- | --- | --- | --- | --- | --- | --- | --- | --- | --- | --- | --- | --- | --- | --- | --- | --- | --- | --- |
| 2075 | 109.1.2 | **Physical layer alignment with UMTS bearer concept** | 280d | 2000-11-06 A | 2001-11-30 A | 100% | 2000-11-06 | 2001-11-30 | 280d |  | GP | 6960h | 6960h | Rel-5 | Paolo |  |  |  |
| 2076 | 109.1.2.1 | PDTCH/TCH in 45.003 | 155d | 2000-11-06 A | 2001-06-08 A | 100% | 2000-11-06 | 2001-06-08 | 155d | finish no earlier than 2001-06-08 | GP | 1240h | 1240h | Rel-5 | Paolo |  |  |  |
| 2077 | 109.1.2.2 | Control channels in 45.003 | 155d | 2000-11-06 A | 2001-06-08 A | 100% | 2000-11-06 | 2001-06-08 | 155d | finish no earlier than 2001-06-08 | GP | 1240h | 1240h | Rel-5 | Paolo |  |  |  |
| 2078 | 109.1.2.3 | Receiver performance in 45.005 for PDTCH/TCH and control channels | 280d | 2000-11-06 A | 2001-11-30 A | 100% | 2000-11-06 | 2001-11-30 | 280d | finish no earlier than 2001-11-30 | GP | 2240h | 2240h | Rel-5 | Paolo |  |  |  |
| 2079 | 109.2 | **Iu rg interface** | 430d | 2000-11-06 A | 2002-06-28 A | 100% | 2000-11-06 | 2002-06-28 | 430d |  | GP,RP | 39560h | 39560h | Rel-5 | Paolo | GER3GAL-Iurg | Ericsson | Frank Muller |
| 2080 | 109.2.1 | **Inter BSS interface** | 430d | 2000-11-06 A | 2002-06-28 A | 100% | 2000-11-06 | 2002-06-28 | 430d |  | GP,RP | 20640h | 20640h | Rel-5 | Paolo |  |  |  |
| 2081 | 109.2.1.1 | Identification of requirements | 430d | 2000-11-06 A | 2002-06-28 A | 100% | 2000-11-06 | 2002-06-28 | 430d | finish no earlier than 2002-06-28 | GP | 3440h | 3440h | Rel-5 | Paolo |  |  |  |
| 2082 | 109.2.1.2 | Stage 2 | 430d | 2000-11-06 A | 2002-06-28 A | 100% | 2000-11-06 | 2002-06-28 | 430d | finish no earlier than 2002-06-28 | GP | 3440h | 3440h | Rel-5 | Paolo |  |  |  |
| 2083 | 109.2.1.3 | Adoption of relevant parts from Iur | 430d | 2000-11-06 A | 2002-06-28 A | 100% | 2000-11-06 | 2002-06-28 | 430d | finish no earlier than 2002-06-28 | GP | 3440h | 3440h | Rel-5 | Paolo |  |  |  |
| 2084 | 109.2.1.4 | Complementation with GERAN specifics | 430d | 2000-11-06 A | 2002-06-28 A | 100% | 2000-11-06 | 2002-06-28 | 430d | finish no earlier than 2002-06-28 | GP | 3440h | 3440h | Rel-5 | Paolo |  |  |  |
| 2085 | 109.2.1.5 | Stage 3 | 430d | 2000-11-06 A | 2002-06-28 A | 100% | 2000-11-06 | 2002-06-28 | 430d | finish no earlier than 2002-06-28 | GP | 3440h | 3440h | Rel-5 | Paolo |  |  |  |
| 2086 | 109.2.2 | **Inter BSS-RNS interface** | 430d | 2000-11-06 A | 2002-06-28 A | 100% | 2000-11-06 | 2002-06-28 | 430d |  | GP,RP | 15480h | 15480h | Rel-5 | Paolo |  |  |  |
| 2087 | 109.2.2.1 | Identification of requirements | 430d | 2000-11-06 A | 2002-06-28 A | 100% | 2000-11-06 | 2002-06-28 | 430d | start no earlier than 2000-11-06 | GP,R3 | 3440h | 3440h | Rel-5 | Paolo |  |  |  |
| 2088 | 109.2.2.2 | Stage 2 | 430d | 2000-11-06 A | 2002-06-28 A | 100% | 2000-11-06 | 2002-06-28 | 430d | finish no earlier than 2002-06-28 | GP,R3 | 3440h | 3440h | Rel-5 | Paolo |  |  |  |
| 2089 | 109.2.2.3 | Adoption of relevant parts from Iur | 430d | 2000-11-06 A | 2002-06-28 A | 100% | 2000-11-06 | 2002-06-28 | 430d | finish no earlier than 2002-06-28 | GP,R3 | 3440h | 3440h | Rel-5 | Paolo |  |  |  |
| 2090 | 109.2.2.4 | Complementation with GERAN specifics | 107.5d | 2002-01-30 A | 2002-06-28 A | 100% | 2002-01-30 | 2002-06-28 | 107.5d | finish no earlier than 2002-06-28 | GP,R3 | 860h | 860h | Rel-5 | Paolo |  |  |  |
| 2091 | 109.2.2.5 | Stage 3 | 107.5d | 2002-01-30 A | 2002-06-28 A | 100% | 2002-01-30 | 2002-06-28 | 107.5d | finish no earlier than 2002-06-28 | GP,R3 | 860h | 860h | Rel-5 | Paolo |  |  |  |
| 2092 | 109.3 | **Voice over GERAN PS and CS concept** | 430d | 2000-11-06 A | 2002-06-28 A | 100% | 2000-11-06 | 2002-06-28 | 430d |  | GP,R3 | 18520h | 18520h | Rel-5 | Paolo |  |  |  |
| 2093 | 109.3.1 | Architecture for A, Iu cs and Iu ps | 430d | 2000-11-06 A | 2002-06-28 A | 100% | 2000-11-06 | 2002-06-28 | 430d | finish no earlier than 2002-06-28 | GP,R3 | 3440h | 3440h | Rel-5 | Paolo |  |  |  |
| 2094 | 109.3.2 | Transcoder position/operation | 115d | 2000-11-06 A | 2001-04-13 A | 100% | 2000-11-06 | 2001-04-13 | 115d | finish no earlier than 2001-04-13 | GP | 920h | 920h | Rel-5 | Paolo |  |  |  |
| 2095 | 109.3.3 | Handover | 430d | 2000-11-06 A | 2002-06-28 A | 100% | 2000-11-06 | 2002-06-28 | 430d | finish no earlier than 2002-06-28 | GP,R3 | 3440h | 3440h | Rel-5 | Paolo |  |  |  |
| 2096 | 109.3.4 | RTP payload | 430d | 2000-11-06 A | 2002-06-28 A | 100% | 2000-11-06 | 2002-06-28 | 430d | finish no earlier than 2002-06-28 | GP,R3 | 3440h | 3440h | Rel-5 | Paolo |  |  |  |
| 2097 | 109.3.5 | Codec renegotiation concept | 365d | 2000-11-06 A | 2002-03-29 A | 100% | 2000-11-06 | 2002-03-29 | 365d | finish no earlier than 2002-03-29 | GP,R3 | 2920h | 2920h | Rel-5 | Paolo |  |  |  |
| 2098 | 109.3.6 | LA | 115d | 2000-11-06 A | 2001-04-13 A | 100% | 2000-11-06 | 2001-04-13 | 115d | finish no earlier than 2001-04-13 | GP | 920h | 920h | Rel-5 | Paolo |  |  |  |

Notes:
- 2075: -
- 2076: -
- 2077: -
- 2078: -
- 2079: AWS, Nokia, Ericsson, Nortel, Siemens, Vodafone
- 2080: -
- 2081: -
- 2082: -
- 2083: -
- 2084: -
- 2085: -
- 2086: -
- 2087: -
- 2088: -
- 2089: -
- 2090: -
- 2091: -
- 2092: -
- 2093: -
- 2094: -
- 2095: -
- 2096: -
- 2097: -
- 2098: -

| ID | WBS | Task | Duration | Start | Finish | Complete | Baseline start | Baseline finish | Baseline duration | Total slack | Constraint | Resources | Work | Actual work | Text6 | Text8 | Text12 | Text1 | Text4 | Text5 |
| --- | --- | --- | --- | --- | --- | --- | --- | --- | --- | --- | --- | --- | --- | --- | --- | --- | --- | --- | --- | --- |
| 2099 | 109.4 | **Deleted - GERAN MS Conformance test for GERAN interface evolution** | 660d | 2001-06-11 A | 2003-12-19 A | 100% | 2001-06-11 | 2003-12-19 | 660d |  |  | GP | 10560h | 10560h | Rel-5 | Paolo | GP-17 |  |  |  |
| 2100 | 109.4.1 | Deleted - MS test | 660d | 2001-06-11 A | 2003-12-19 A | 100% | 2001-06-11 | 2003-12-19 | 660d |  | finish no earlier than 2003-12-19 | GP | 5280h | 5280h | Rel-5 | Paolo | GP-17 |  |  |  |
| 2101 | 109.5 | **GERAN BSS Conformance test for GERAN interface evolution** | 922d | 2000-06-08 A | 2003-12-19 A | 100% | 2000-06-08 | 2003-12-19 | 922d |  |  | GP | 14752h | 14752h | Rel-5 | Paolo |  |  |  |  |
| 2102 | 109.5.1 | Deleted - BSS test | 922d | 2000-06-08 A | 2003-12-19 A | 100% | 2000-06-08 | 2003-12-19 | 922d |  | finish no earlier than 2003-12-19 | GP | 7376h | 7376h | Rel-5 | Paolo | GP-17 |  |  |  |
| 2103 | 110 | **GERAN support for IMS** | 690d | 2000-05-01 A | 2002-12-20 A | 100% | 2000-05-01 | 2002-12-20 | 690d |  |  | GP | 39198.4h | 39198.4h | Rel-5 | Paolo |  | GERIMS | Nokia | Shkumbin Hamiti |
| 2104 | 110.1 | **GERAN Header adaptation** | 690d | 2000-05-01 A | 2002-12-20 A | 100% | 2000-05-01 | 2002-12-20 | 690d |  |  | GP,S2,RP | 12302.8h | 12302.8h | Rel-5 | Paolo |  | GERIMS-HEADAPT | Nokia | Shkumbin Hamiti |
| 2105 | 110.1.1 | Definition of compression and removal modes for PDCP protocol | 15.05d | 2000-05-01 A | 2000-06-09 A | 100% | 2000-05-01 | 2000-06-09 | 15.05d |  | finish no earlier than 2000-09-01 | GP,S2,RP | 120.4h | 120.4h | Rel-5 | Paolo |  |  |  |  |
| 2106 | 110.1.2 | Conceptual description in stage 2 | 393d | 2000-05-01 A | 2001-10-31 A | 100% | 2000-05-01 | 2001-10-31 | 393d |  | finish no earlier than 2001-10-31 | GP,S2,RP | 3144h | 3144h | Rel-5 | Paolo |  |  |  |  |
| 2107 | 110.1.3 | Necessary changes on stage 3 regarding header removal | 439.8d | 2000-11-06 A | 2002-12-20 A | 100% | 2000-11-06 | 2002-12-20 | 439.8d |  | finish no earlier than 2002-12-20 | GP,S2,RP | 3518.4h | 3518.4h | Rel-5 | Paolo |  |  |  |  |
| 2108 | 110.2 | **Deleted - GERAN Radio access bearer design for IMS** | 430d | 2000-11-06 A | 2002-06-28 A | 100% | 2000-11-06 | 2002-06-28 | 430d |  |  | GP,S2,RP | 9287.6h | 9287.6h | Rel-5 | Paolo | GP-10 | GERIMS-RABDES | Nokia | Shkumbin Hamiti |
| 2109 | 110.2.1 | **Deleted - MuM control signalling for conversational multimedia services** | 430d | 2000-11-06 A | 2002-06-28 A | 100% | 2000-11-06 | 2002-06-28 | 430d |  |  | GP,S2,RP | 5847.6h | 5847.6h | Rel-5 | Paolo | GP-10 |  |  |  |
| 2110 | 110.2.1.1 | Deleted - Identification of requirements | 330d | 2000-11-06 A | 2002-02-08 A | 100% | 2000-11-06 | 2002-02-08 | 330d |  | finish no earlier than 2002-02-08 | GP,S2,RP | 2640h | 2640h | Rel-5 | Paolo | GP-08 |  |  |  |
| 2111 | 110.2.1.2 | Deleted - Necessary modifications due to SIP | 40d | 2002-05-06 A | 2002-06-28 A | 100% | 2002-05-06 | 2002-06-28 | 40d |  | finish no earlier than 2002-06-28 | GP,S2,RP | 320h | 320h | Rel-5 | Paolo | GP-10 |  |  |  |
| 2112 | 110.3 | **Deleted - GERAN MS Conformance test for support of IMS** | 400d | 2001-06-11 A | 2002-12-20 A | 100% | 2001-06-11 | 2002-12-20 | 400d |  |  | GP | 6400h | 6400h | Rel-5 | Paolo | GP-12 | GERIMS-MSconf | Nokia | Shkumbin Hamiti |
| 2113 | 110.3.1 | Deleted - MS test | 400d | 2001-06-11 A | 2002-12-20 A | 100% | 2001-06-11 | 2002-12-20 | 400d |  | finish no earlier than 2002-12-20 | G4 | 3200h | 3200h | Rel-5 | Paolo | GP-12 |  |  |  |
| 2114 | 110.4 | **Deleted - GERAN BTS Conformance test for support of IMS** | 400d | 2001-06-11 A | 2002-12-20 A | 100% | 2001-06-11 | 2002-12-20 | 400d |  |  | GP | 6400h | 6400h | Rel-5 | Paolo | GP-12 | GERIMS-BTSconf | Nokia | Shkumbin Hamiti |
| 2115 | 110.4.1 | Deleted - BTS test | 400d | 2001-06-11 A | 2002-12-20 A | 100% | 2001-06-11 | 2002-12-20 | 400d |  | finish no earlier than 2002-12-20 | G3new | 3200h | 3200h | Rel-5 | Ingbert | GP-12 |  |  |  |
| 2116 | 545 | MS Conformance Testing of Dual Transfer Mode | 65d? | 2002-11-11 A | 2003-02-07 A | 100% | 2002-11-11 | 2003-02-07 | 65d? |  | finish no earlier than 2003-02-07 | G4,G5 | 520h | 520h | Rel-5 | Paolo |  | MSCTDTM | Vodafone | Dave Fox |
| 2117 | 546 | **Handling of early UEs** | 911d? | 2000-01-03 A | 2003-06-27 A | 100% | 2000-01-03 | 2003-06-27 | 911d? |  |  | S2 | 4488h | 4488h | Rel-5 | Maurice |  | LATE_UE |  |  |
| 2118 | 546.1 | Feasibility Study | 50d? | 2002-10-07 A | 2002-12-13 A | 100% | 2002-10-07 | 2002-12-13 | 50d? |  | finish no earlier than 2002-12-13 | S2 | 400h | 400h | Rel-5 | Maurice |  |  |  |  |
| 2119 | 546.2 | Stage 2 | 125d? | 2003-01-06 A | 2003-06-27 A | 100% | 2003-01-06 | 2003-06-27 | 125d? |  | start no earlier than 2003-01-06 | S2 | 1000h | 1000h | Rel-5 | Maurice |  |  |  |  |
| 2120 | 546.3 | FS for the Early Mobile Handling in UTRAN | 195d | 2002-09-09 A | 2003-06-06 A | 100% | 2002-09-09 | 2003-06-06 | 195d |  | finish no earlier than 2003-06-06 | R2 | 1560h | 1560h | Rel-5 | Joern |  | FSEarlyUE | Vodafone | Alan Law |
| 2121 | 546.4 | Note: Stage 3 RAN part not shown | 1d | 2000-01-03 A | 2000-01-03 A | 100% | 2000-01-03 | 2000-01-03 | 1d |  |  | RP | 8h | 8h | Rel-5 |  |  |  |  |  |
| 2122 | 547 | Release 4 Features | 1d? | 2000-01-03 | 2000-01-03 |  | 2000-01-03 | 2000-01-03 | 1d? | 3056d |  | NP,GP, RP,SP,TP | 8h |  | Rel-4 |  |  |  |  |  |

Notes:
- 2099: Not started. Marked as stopped 12/2008
- 2100: Not started. Marked as stopped 12/2008
- 2101: Not started. Marked as stopped 12/2008
- 2102: Not started. Marked as stopped 12/2008
- 2103: AWS, Nokia, Ericsson, Nortel, Siemens, Motorola
- 2104: AWS, Nokia, Ericsson, Nortel, Siemens, Motorola
- 2105: -
- 2106: -
- 2107: -
- 2108: TERMINATED - NOT STANDARDIZED. Marked as stopped 12/2008
- 2109: TERMINATED - NOT STANDARDIZED. Marked as stopped 12/2008
- 2110: TERMINATED - NOT STANDARDIZED
- 2111: TERMINATED - NOT STANDARDIZED
- 2112: TERMINATED - NOT STANDARDIZED. Marked as stopped 12/2008
- 2113: TERMINATED - NOT STANDARDIZED. Marked as stopped 12/2008
- 2114: TERMINATED - NOT STANDARDIZED. Marked as stopped 12/2008
- 2115: TERMINATED - NOT STANDARDIZED. Marked as stopped 12/2008
- 2116: Needed to complete DTM (R99)
- 2117: -
- 2118: -
- 2119: -
- 2120: -
- 2121: -
- 2122: -

| ID | WBS | Task | Duration | Start | Finish | Predecessors | Complete | Baseline start | Baseline finish | Baseline duration | Constraint | Resources | Work | Actual work | Text1 | Text6 | Text8 | Text3 | Text12 | Text4 | Text5 |
| --- | --- | --- | --- | --- | --- | --- | --- | --- | --- | --- | --- | --- | --- | --- | --- | --- | --- | --- | --- | --- | --- |
| 2123 | 15 | **Miscellaneous UE Conformance Testing Activities** | 958d | 2001-04-02 A | 2004-12-01 A |  | 100% | 2001-04-02 | 2004-12-01 | 958d |  | T1 | 36360h | 36360h | MISTST1 | Rel-4 | Ingbert |  |  |  |  |
| 2124 | 15.1 | Optimization of Test Time, RF Aspects (FDD) | 508d | 2001-09-24 A | 2003-09-03 A |  | 100% | 2001-09-24 | 2003-09-03 | 508d | finish no earlier than 2003-09-03 | T1 | 4064h | 4064h | MISTST1-OpFDD | Rel-4 | Ingbert | 34.121 |  |  |  |
| 2125 | 15.2 | Optimization of Test Time, RF Aspects (TDD) | 508d | 2001-09-24 A | 2003-09-03 A |  | 100% | 2001-09-24 | 2003-09-03 | 508d | finish no earlier than 2003-09-03 | T1 | 4064h | 4064h | MISTST1-OpTDD | Rel-4 | Ingbert | 34.122 |  |  |  |
| 2126 | 15.3 | Extensions to R99 Test cases | 139.4w | 2001-04-02 A | 2003-12-02 A |  | 100% | 2001-04-02 | 2003-12-02 | 139.4w | finish no earlier than 2003-12-02 | T1 | 5576h | 5576h | MISTST1-Ext | Rel-4 | Ingbert | 34.123 p 1,2 |  |  |  |
| 2127 | 15.4 | Extension to R99 Test cases - TTCN | 439d | 2002-06-28 A | 2004-03-03 A |  | 100% | 2002-06-28 | 2004-03-03 | 439d | finish no earlier than 2004-03-03 | T1 | 3512h | 3512h |  | Rel-4 | Ingbert |  |  |  |  |
| 2128 | 15.5 | Creation of R99 TCs for TDD - prose | 719d | 2001-10-01 A | 2004-07-01 A |  | 100% | 2001-10-01 | 2004-07-01 | 719d | finish no earlier than 2004-07-01 | T1 | 5752h | 5752h | MISTST1-TDD | Rel-4 | Ingbert | 34.123-1 |  |  |  |
| 2129 | 15.6 | Deleted - Creation of R99 TCs for TDD - TTCN | 587d | 2002-09-03 A | 2004-12-01 A |  | 100% | 2002-09-03 | 2004-12-01 | 587d | finish no earlier than 2004-12-01 | T1 | 4696h | 4696h |  | Rel-4 | Ingbert |  | TP-26 |  |  |
| 2130 | 15.7 | Deleted - Review all other work items for impact on new or exiting 34 series specs. | 25.8w | 2002-07-02 A | 2002-12-27 A |  | 100% | 2002-07-02 | 2002-12-27 | 25.8w | finish no earlier than 2002-12-27 | T1 | 1032h | 1032h | MISTST1 | Rel-4 | Ingbert | 34.121,122,123,125 | TP-18 |  |  |
| 2131 | 46 | **Facsimile** | 89d | 2000-02-22 A | 2000-06-23 A |  | 100% | 2000-02-22 | 2000-06-23 | 89d |  | S1 | 4376h | 4376h | FAX | Rel-4 | Alain |  |  |  |  |
| 2132 | 46.1 | **Real Time Fax** | 89d | 2000-02-22 A | 2000-06-23 A |  | 100% | 2000-02-22 | 2000-06-23 | 89d |  | S2 | 3664h | 3664h | FAX-RT | Rel-4 | Maurice |  |  |  |  |
| 2133 | 46.1.1 | Terminal capabilities, AT commands | 89d | 2000-02-22 A | 2000-06-23 A |  | 100% | 2000-02-22 | 2000-06-23 | 89d | finish no earlier than 2000-06-23 | T2 | 712h | 712h |  | Rel-4 |  | 21.904, 27.007 |  |  |  |
| 2134 | 46.1.2 | Signalling aspects (e.g. ICM) | 89d | 2000-02-22 A | 2000-06-23 A |  | 100% | 2000-02-22 | 2000-06-23 | 89d | start no earlier than 2000-02-22 | N1 | 712h | 712h |  | Rel-4 | Frederic |  |  |  |  |
| 2135 | 46.1.3 | Service provision | 89d | 2000-02-22 A | 2000-06-23 A |  | 100% | 2000-02-22 | 2000-06-23 | 89d | finish no earlier than 2000-06-23 | N3 | 712h | 712h |  | Rel-4 | Gwiho | 23.146 |  |  |  |
| 2136 | 46.1.4 | Review whether service/stage 1 aspects need to be aligned | 51d | 2000-04-14 A | 2000-06-23 A |  | 100% | 2000-04-14 | 2000-06-23 | 51d | finish no earlier than 2000-12-14 | S1 | 408h | 408h |  | Rel-4 | Alain |  |  |  |  |
| 2137 | 46.1.5 | Review whether architecture/stage 2 aspects need to be aligned | 51d | 2000-04-14 A | 2000-06-23 A |  | 100% | 2000-04-14 | 2000-06-23 | 51d | finish no earlier than 2000-12-14 | S2 | 408h | 408h |  | Rel-4 | Maurice |  |  |  |  |
| 2138 | 47 | Transparent End-to-End PS mobile streaming application | 253d | 2000-04-03 A | 2001-03-21 A |  | 100% | 2000-04-03 | 2001-03-21 | 253d | finish no earlier than 2000-12-29 | S4 | 2024h | 2024h | PSTREAM | Rel-4 | Paolo | 26.233, 26.234 |  |  |  |
| 2139 | 48 | **Multimedia Messaging** | 277d | 2000-02-22 A | 2001-03-14 A |  | 100% | 2000-02-22 | 2001-03-14 | 277d |  | T2,S1 | 9992h | 9992h | MMS | Rel-4 | Kimmo | 22.140, 23.140 |  | Siemens | Josef.Laumen@SAL.SIEMENS.DE |
| 2140 | 48.1 | Definition of service requirements | 72d | 2000-02-22 A | 2000-05-31 A |  | 100% | 2000-02-22 | 2000-05-31 | 72d | start no earlier than 2000-02-22 | S1 | 576h | 576h | MMS | Rel-4 | Alain |  |  |  |  |
| 2141 | 48.2 | Review of definition of service requirements | 205d | 2000-06-01 A | 2001-03-14 A | 2140 | 100% | 2000-06-01 | 2001-03-14 | 205d | finish no earlier than 2000-09-08 | T2 | 1640h | 1640h | MMS | Rel-4 | Kimmo | 22.140, 23.140 |  | Siemens |  |
| 2142 | 48.3 | **Technical Realisation** | 243d | 2000-04-10 A | 2001-03-14 A |  | 100% | 2000-04-10 | 2001-03-14 | 243d |  | T2 | 7776h | 7776h | MMS | Rel-4 | Kimmo | 22.140, 23.140 |  | Siemens | Josef.Laumen@SAL.SIEMENS.DE |
| 2143 | 48.3.1 | Review of definition of reference Achitecture model | 243d | 2000-04-10 A | 2001-03-14 A |  | 100% | 2000-04-10 | 2001-03-14 | 243d | finish no earlier than 2001-03-14 | T2 | 1944h | 1944h | MMS | Rel-4 | Kimmo | 22.140, 23.140 |  | Siemens | Josef.Laumen@SAL.SIEMENS.DE |
| 2144 | 48.3.2 | Fulfill Requirements of Stage 1 | 243d | 2000-04-10 A | 2001-03-14 A |  | 100% | 2000-04-10 | 2001-03-14 | 243d | finish no earlier than 2001-03-14 | T2 | 1944h | 1944h | MMS | Rel-4 | Kimmo | 22.140, 23.140 |  | Siemens | Josef.Laumen@SAL.SIEMENS.DE |
| 2145 | 48.3.3 | Definition of MMS primitives in Stage 2 | 243d | 2000-04-10 A | 2001-03-14 A |  | 100% | 2000-04-10 | 2001-03-14 | 243d | finish no earlier than 2001-03-14 | T2 | 1944h | 1944h | MMS | Rel-4 | Kimmo | 22.140, 23.140 |  | Siemens | Josef.Laumen@SAL.SIEMENS.DE |
| 2146 | 49 | **Transcoder-Free Operation** | 326d | 2000-01-03 A | 2001-03-30 A |  | 100% | 2000-01-03 | 2001-03-30 | 326d |  | N4,S2,N1 | 10448h | 10448h | TrFO | Rel-4 | Kimmo |  |  |  |  |
| 2147 | 49.1 | **Out-of-Band Transcoder Control solution** | 326d | 2000-01-03 A | 2001-03-30 A |  | 100% | 2000-01-03 | 2001-03-30 | 326d |  | N4 | 8448h | 8448h | TrFO-OoBTC | Rel-4 | Kimmo |  |  | NEC | Toshiyuki Tamura (tamurato@aj.jp.nec.com) |
| 2148 | 49.1.1 | implementation in UTRAN | 145d | 2000-09-11 A | 2001-03-30 A |  | 100% | 2000-09-11 | 2001-03-30 | 145d | finish no earlier than 2001-03-30 | R3 | 1160h | 1160h | TrFO-OoBTC-UTRAN | Rel-4 | Juha | 25.401, 25.410, 25.413, 25.415, 23.153 |  | Siemens | Alexander Vesely |
| 2149 | 49.1.2 | Impact on architecture, Principles and Terminology | 211d | 2000-01-03 A | 2000-10-20 A |  | 100% | 2000-01-03 | 2000-10-20 | 211d | finish no earlier than 2000-10-20 | S2 | 1680h | 1680h | TrFO-OoBTC | Rel-4 | Maurice |  |  |  |  |
| 2150 | 49.1.3 | Codec Negotiation between UE and MSC | 125d | 2000-08-14 A | 2001-02-02 A |  | 100% | 2000-08-14 | 2001-02-02 | 125d | finish no earlier than 2001-02-02 | N1 | 1000h | 1000h | TrFO-OoBTC | Rel-4 | Frederic | 24.008, 23.009, 23.108, (29.002) |  | Motorola | Andrew Howell |
| 2151 | 49.1.4 | Codec Negotiation inter MSC | 125d | 2000-07-03 A | 2000-12-22 A |  | 100% | 2000-07-03 | 2000-12-22 | 125d | finish no earlier than 2000-12-22 | N4 | 1000h | 1000h | TrFO-OoBTC | Rel-4 | Kimmo |  |  |  |  |
| 2152 | 49.1.5 | Bearer establishment inter MSC | 125d | 2000-07-03 A | 2000-12-22 A |  | 100% | 2000-07-03 | 2000-12-22 | 125d | finish no earlier than 2000-12-22 | N4 | 1000h | 1000h | TrFO-OoBTC | Rel-4 | Kimmo | 23.153 |  |  |  |

Notes:
- 2123: -
- 2124: It is believed that the current R99 test spec. can be optimised for faster overall test times. Marked as stopped 12/2008 (was 70% complete)
- 2125: It is believed that the current R99 test spec. can be optimised for faster overall test times
- 2126: Further test coverage of the R99 specification to cover supplementry services. Marked as stopped 12/2008 (was 70% complete)
- 2127: Marked as closed 12/2008 (was marked 50% complete)
- 2128: Marked as closed 12/2008 (was marked 50% complete)
- 2129: Marked as stopped 12/2008
- 2130: Marked as stopped 12/2008
- 2131: -
- 2132: postponed from R99 to R00, SP-000169
- 2133: -
- 2134: -
- 2135: -
- 2136: -
- 2137: -
- 2138: -
- 2139: -
- 2140: -
- 2141: -
- 2142: -
- 2143: -
- 2144: e.g. minimum set of media formats, media format conversion, personalization of MMS.
- 2145: -
- 2146: Lead given to CN4 from CN / [DAB 28/11/00]
- 2147: -
- 2148: moved according to NP-000575
- 2149: e.g. study cascading TrFO/TFO/TrFO
- 2150: the link to NP-000085has been deleted because refering to a R99 status sheet / One common set of codec negotiation procedures will be specified as in ID1656.
- 2151: Bearer establishment inter MSC. TS 23.153 R99 part complete. capabilities moved to annex + list of open issues
- 2152: Bearer establishment inter MSC. TS 23.153 R99 part complete. capabilities moved to annex. / See NP-000127 / Open issues: / Handling of Conference Calls; / Handling of Multi Party Supplementary Services; / Handling of Handover UMTS to GSM; / Handling of Sending a ...

| ID | WBS | Task | Duration | Start | Finish | Complete | Baseline start | Baseline finish | Baseline duration | Constraint | Resources | Work | Actual work | Text1 | Text6 | Text8 | Text4 | Text5 |
| --- | --- | --- | --- | --- | --- | --- | --- | --- | --- | --- | --- | --- | --- | --- | --- | --- | --- | --- |
| 2153 | 49.2 | **Speech Transcoder: Location and Control at the UMTS Core Network Border** | 125d | 2000-04-10 A | 2000-09-29 A | 100% | 2000-04-10 | 2000-09-29 | 125d |  | S2 | 2000h | 2000h | TrFO-STLC | Rel-4 | Maurice |  |  |
| 2154 | 49.2.1 | Transcoder at Edge | 125d | 2000-04-10 A | 2000-09-29 A | 100% | 2000-04-10 | 2000-09-29 | 125d | finish no earlier than 2000-09-29 | NP | 1000h | 1000h | TrFO-STLC | Rel-4 |  |  |  |
| 2155 | 50 | **GERAN improvements 1 (Gb over IP)** | 225d | 2000-05-09 A | 2001-03-19 A | 100% | 2000-05-09 | 2001-03-19 | 225d |  | GP | 6472h | 6472h | GEIMP1 | Rel-4 | Paolo |  |  |
| 2156 | 50.1 | **Gb over IP (Ip-fication of Gb)** | 225d | 2000-05-09 A | 2001-03-19 A | 100% | 2000-05-09 | 2001-03-19 | 225d |  | GP | 4672h | 4672h | GbIP | Rel-4 | Paolo |  |  |
| 2157 | 50.1.1 | Concept | 134d | 2000-05-09 A | 2000-11-10 A | 100% | 2000-05-09 | 2000-11-10 | 134d |  | GP | 1072h | 1072h |  | Rel-4 | Paolo |  |  |
| 2158 | 50.1.2 | Changes to 08.16, 08.18 | 225d | 2000-05-09 A | 2001-03-19 A | 100% | 2000-05-09 | 2001-03-19 | 225d |  | GP | 1800h | 1800h |  | Rel-4 | Paolo |  |  |
| 2159 | 51 | **GERAN improvements 2 (NACC)** | 677d | 2000-11-06 A | 2003-06-10 A | 100% | 2000-11-06 | 2003-06-10 | 677d |  | GP | 19224h | 19224h | GEIMP2 | Rel-4 | Paolo |  |  |
| 2160 | 51.1 | **Gb enhancements** | 155d | 2000-11-06 A | 2001-06-08 A | 100% | 2000-11-06 | 2001-06-08 | 155d |  | GP | 7440h | 7440h | Gben | Rel-4 | Paolo |  |  |
| 2161 | 51.1.1 | **Intra BSC NACC (Network Assisted Cell Change)** | 155d | 2000-11-06 A | 2001-06-08 A | 100% | 2000-11-06 | 2001-06-08 | 155d |  | GP | 6200h | 6200h |  | Rel-4 | Paolo |  |  |
| 2162 | 51.1.1.1 | Concept | 155d | 2000-11-06 A | 2001-06-08 A | 100% | 2000-11-06 | 2001-06-08 | 155d | finish no earlier than 2001-06-08 | GP | 1240h | 1240h |  | Rel-4 | Paolo |  |  |
| 2163 | 51.1.1.2 | Changes in 03.64 | 155d | 2000-11-06 A | 2001-06-08 A | 100% | 2000-11-06 | 2001-06-08 | 155d | finish no earlier than 2001-06-08 | GP | 1240h | 1240h |  | Rel-4 | Paolo |  |  |
| 2164 | 51.1.1.3 | Changes in 04.60 | 155d | 2000-11-06 A | 2001-06-08 A | 100% | 2000-11-06 | 2001-06-08 | 155d | finish no earlier than 2001-06-08 | GP | 1240h | 1240h |  | Rel-4 | Paolo |  |  |
| 2165 | 51.1.1.4 | Changes in 44.008 | 155d | 2000-11-06 A | 2001-06-08 A | 100% | 2000-11-06 | 2001-06-08 | 155d | finish no earlier than 2001-06-08 | GP | 1240h | 1240h |  | Rel-4 | Paolo |  |  |
| 2166 | 51.3 | **MS conformance test for Intra BSC NACC** | 398d | 2001-11-30 A | 2003-06-10 A | 100% | 2001-11-30 | 2003-06-10 | 398d |  | GP | 6368h | 6368h | GEIMP2-Msconf | Rel-4 | Paolo |  |  |
| 2167 | 51.3.1 | Changes in 51.010 | 398d | 2001-11-30 A | 2003-06-10 A | 100% | 2001-11-30 | 2003-06-10 | 398d | finish no earlier than 2003-12-19 | G5,G4 | 3184h | 3184h |  | Rel-4 | Paolo |  |  |
| 2168 | 52 | **GERAN improvements 4 (Delayed TBF)** | 105d | 2001-01-15 A | 2001-06-08 A | 100% | 2001-01-15 | 2001-06-08 | 105d |  | GP | 3960h | 3960h | GEIMP4 | Rel-4 | Paolo |  |  |
| 2169 | 52.1 | **Gb enhancements 2** | 105d | 2001-01-15 A | 2001-06-08 A | 100% | 2001-01-15 | 2001-06-08 | 105d |  | GP | 3120h | 3120h | GEIMP4-Gben2 | Rel-4 | Paolo |  |  |
| 2170 | 52.1.1 | stage 2 | 105d | 2001-01-15 A | 2001-06-08 A | 100% | 2001-01-15 | 2001-06-08 | 105d | finish no earlier than 2001-06-08 | GP | 840h | 840h |  | Rel-4 | Paolo |  |  |
| 2171 | 52.1.2 | **Stage 3 (changes in 44.060)** | 60d | 2001-01-15 A | 2001-04-06 A | 100% | 2001-01-15 | 2001-04-06 | 60d |  | G2 | 1440h | 1440h |  | Rel-4 | Gert |  |  |
| 2172 | 52.1.2.1 | Definition of enhanced countdown procedure | 60d | 2001-01-15 A | 2001-04-06 A | 100% | 2001-01-15 | 2001-04-06 | 60d | finish no earlier than 2001-04-06 | G2 | 480h | 480h |  | Rel-4 | Gert |  |  |
| 2173 | 52.1.2.2 | Definition of enhanced TBF release procedure | 60d | 2001-01-15 A | 2001-04-06 A | 100% | 2001-01-15 | 2001-04-06 | 60d | finish no earlier than 2001-04-06 | G2 | 480h | 480h |  | Rel-4 | Gert |  |  |
| 2174 | 52.1.2.3 | Definition of USF=FREE type polling mechanism on PDCH | 60d | 2001-01-15 A | 2001-04-06 A | 100% | 2001-01-15 | 2001-04-06 | 60d | finish no earlier than 2001-04-06 | G2 | 480h | 480h |  | Rel-4 | Gert |  |  |
| 2175 | 53 | **Low Chip Rate TDD option** | 880d | 2000-07-19 A | 2003-12-02 A | 100% | 2000-07-19 | 2003-12-02 | 880d |  | R1 | 27488h | 27488h | LCRTDD | Rel-4 | Patrick | CWTS | G. Yang |
| 2176 | 53.1 | Physical layer | 183d | 2000-07-19 A | 2001-03-30 A | 100% | 2000-07-19 | 2001-03-30 | 183d | finish no earlier than 2001-03-30 | R1 | 1464h | 1464h | LCRTDD-Phys | Rel-4 | Patrick | CWTS | G. Yang |
| 2177 | 53.2 | Layer 2 and layer 3 protocol aspects | 183d | 2000-07-19 A | 2001-03-30 A | 100% | 2000-07-19 | 2001-03-30 | 183d | finish no earlier than 2001-03-30 | R2 | 1464h | 1464h | LCRTDD-L23 | Rel-4 | Joern | CWTS | Y. Liu |
| 2178 | 53.3 | RF radio transmission/reception, system performance requirements and conformance testing | 165d | 2000-08-14 A | 2001-03-30 A | 100% | 2000-08-14 | 2001-03-30 | 165d | finish no earlier than 2001-03-30 | R4 | 1320h | 1320h | LCRTDD-RF | Rel-4 | Issam | CWTS | D. Zhang |
| 2179 | 53.4 | UE radio access capability | 165d | 2000-08-14 A | 2001-03-30 A | 100% | 2000-08-14 | 2001-03-30 | 165d | finish no earlier than 2001-03-30 | R2 | 1320h | 1320h | LCRTDD-UErac | Rel-4 | Joern | CWTS | Y. Liu |
| 2180 | 53.5 | Iub/Iur protocol aspects | 165d | 2000-08-14 A | 2001-03-30 A | 100% | 2000-08-14 | 2001-03-30 | 165d | finish no earlier than 2001-03-30 | R3 | 1320h | 1320h | LCRTDD-IubIur | Rel-4 | Juha | CWTS | Y. Liu |

Notes:
- 2153: WI description and Tdoc S2-99352 / Speech Transcoder: Location and Control at the UMTS Core Network Border
- 2154: WI description and Tdoc S2-99352...
- 2155: -
- 2156: -
- 2157: -
- 2158: -
- 2159: -
- 2160: -
- 2161: -
- 2162: -
- 2163: -
- 2164: -
- 2165: -
- 2166: -
- 2167: az 05/08: duplicated UID_50099 => 50299. Marked as closed 12/2008 (was marked 50% complete)
- 2168: -
- 2169: -
- 2170: -
- 2171: -
- 2172: -
- 2173: -
- 2174: -
- 2175: -
- 2176: -
- 2177: -
- 2178: -
- 2179: -
- 2180: -

| ID | WBS | Task | Duration | Start | Finish | Predecessors | Complete | Baseline start | Baseline finish | Baseline duration | Constraint | Resources | Work | Actual work | Text6 | Text8 | Text3 | Text12 | Text1 | Text4 | Text5 |
| --- | --- | --- | --- | --- | --- | --- | --- | --- | --- | --- | --- | --- | --- | --- | --- | --- | --- | --- | --- | --- | --- |
| 2181 | 53.6 | **Low chiprate TDD interworking with GERAN** | 101d | 2000-09-01 A | 2001-01-19 A | 2180 | 100% | 2000-09-01 | 2001-01-19 | 101d |  | GP | 1616h | 1616h | Rel-4 | Paolo |  |  |  |  |  |
| 2182 | 53.6.1 | Handover and Cell Selection / Reselection to UTRA 1.28 Mcps TDD | 101d | 2000-09-01 A | 2001-01-19 A |  | 100% | 2000-09-01 | 2001-01-19 | 101d | finish no earlier than 2001-01-19 | GP | 808h | 808h | Rel-4 |  |  |  |  |  |  |
| 2183 | 53.8 | **Conformance Test Aspects - Low Chip Rate TDD** | 577d | 2001-09-17 A | 2003-12-02 A | 2181 | 100% | 2001-09-17 | 2003-12-02 | 577d |  | T1 | 12088h | 12088h | Rel-4 | Ingbert |  |  |  |  |  |
| 2184 | 53.8.1 | Testing Layer 2 and layer 3 protocol aspects | 468d | 2001-09-17 A | 2003-07-02 A |  | 100% | 2001-09-17 | 2003-07-02 | 468d | finish no earlier than 2003-07-02 | T1 | 3744h | 3744h | Rel-4 | Ingbert | 34.123-1, 34.123-2 |  |  |  |  |
| 2185 | 53.8.2 | Deleted - Testing Layer 2 and layer 3 protocol aspects - TTCN | 261d | 2002-12-03 A | 2003-12-02 A |  | 100% | 2002-12-03 | 2003-12-02 | 261d | finish no earlier than 2003-12-02 | T1 | 2088h | 2088h | Rel-4 | Ingbert | 34.123-3 | TP-22 |  |  |  |
| 2186 | 53.8.3 | Testing RF Radio Transmission and Reception | 205d | 2001-09-17 A | 2002-06-28 A |  | 100% | 2001-09-17 | 2002-06-28 | 205d | finish no earlier than 2002-06-28 | T1 | 1640h | 1640h | Rel-4 | Ingbert |  |  |  |  |  |
| 2187 | 54 | **Enable bearer independent CS architecture** | 566d | 2000-01-03 A | 2002-03-01 A |  | 100% | 2000-01-03 | 2002-03-01 | 566d |  | S2 | 20192h | 20192h | Rel-4 | Maurice |  |  | CSSPLIT | Siemens | Alexander Milinski |
| 2188 | 54.1 | **Enable bearer-independent call control** | 425d | 2000-01-03 A | 2001-08-16 A |  | 100% | 2000-01-03 | 2001-08-16 | 425d |  | N4 | 12344h | 12344h | Rel-4 | Kimmo |  |  |  | Ericsson | Heinz-Peter.Keutmann@eed.ericsson.se |
| 2189 | 54.1.1 | Architecture and Stage 2 description | 181d | 2000-01-03 A | 2000-09-08 A |  | 100% | 2000-01-03 | 2000-09-08 | 181d | finish no earlier than 2000-09-08 | S2 | 1440h | 1440h | Rel-4 | Maurice | 23.002 |  |  |  |  |
| 2190 | 54.1.2 | Standardisation of protocols (control & user planes) over Nb interface | 64d | 2001-01-02 A | 2001-03-30 A |  | 100% | 2001-01-02 | 2001-03-30 | 64d | finish no earlier than 2001-03-30 | N3 | 512h | 512h | Rel-4 | Gwiho |  |  |  |  |  |
| 2191 | 54.1.3 | Standardisation of protocols over reference points between MSC server and Gateway MSC server | 130d | 2000-09-25 A | 2001-03-23 A |  | 100% | 2000-09-25 | 2001-03-23 | 130d | finish no earlier than 2001-03-23 | N4 | 1040h | 1040h | Rel-4 | Kimmo |  |  |  |  |  |
| 2192 | 54.1.4 | Standardisation of detailed stage 2 description | 180d | 2000-07-17 A | 2001-03-23 A |  | 100% | 2000-07-17 | 2001-03-23 | 180d | finish no earlier than 2001-03-23 | N4 | 1440h | 1440h | Rel-4 | Kimmo |  |  |  |  |  |
| 2193 | 54.1.5 | **Bearer control between MSC server and MGW** | 250d | 2000-09-01 A | 2001-08-16 A |  | 100% | 2000-09-01 | 2001-08-16 | 250d |  | N4 | 4512h | 4512h | Rel-4 | Kimmo |  |  |  |  |  |
| 2194 | 54.1.5.1 | stage 3 - protocol issues | 250d | 2000-09-01 A | 2001-08-16 A |  | 100% | 2000-09-01 | 2001-08-16 | 250d | finish no earlier than 2001-08-16 | N4 | 2000h | 2000h | Rel-4 | Kimmo |  |  |  |  |  |
| 2195 | 54.1.5.2 | stage 3 - parameter value issues | 64d | 2001-01-02 A | 2001-03-30 A |  | 100% | 2001-01-02 | 2001-03-30 | 64d | finish no earlier than 2001-03-30 | N3 | 512h | 512h | Rel-4 | Gwiho |  |  |  |  |  |
| 2196 | 54.2 | Lawful interception | 155d | 2000-08-21 A | 2001-03-23 A |  | 100% | 2000-08-21 | 2001-03-23 | 155d | finish no earlier than 2001-03-23 | S3 | 1240h | 1240h | Rel-4 | Dionisio |  |  |  |  |  |
| 2197 | 54.4 | Deleted - Conformance Test Aspects - Enable bearer independent CS architecture | 260d | 2001-03-05 A | 2002-03-01 A |  | 100% | 2001-03-05 | 2002-03-01 | 260d |  | T1 | 2080h | 2080h | Rel-4 | Ingbert |  | TP-15 | CSSPLIT-TEST |  |  |
| 2198 | 55 | **MExE enhancements Rel-4** | 511d | 2000-01-03 A | 2001-12-14 A |  | 100% | 2000-01-03 | 2001-12-14 | 511d |  | T2 | 19032h | 19032h | Rel-4 | Kimmo |  |  | MEXE |  |  |
| 2199 | 55.1 | **MExE Security Analysis Activity** | 474d | 2000-02-22 A | 2001-12-14 A |  | 100% | 2000-02-22 | 2001-12-14 | 474d |  | S3 | 8464h | 8464h | Rel-4 | Dionisio |  |  | MEXE-SEC | BT | colin.blanchard@bt.com |
| 2200 | 55.1.1 | Stage 3 | 370d | 2000-07-17 A | 2001-12-14 A |  | 100% | 2000-07-17 | 2001-12-14 | 370d | finish no earlier than 2001-12-14 | S3 | 2960h | 2960h | Rel-4 | Dionisio |  |  | MEXE1-SEC |  |  |
| 2201 | 55.1.2 | Terminal aspects | 214d | 2000-02-22 A | 2000-12-15 A |  | 100% | 2000-02-22 | 2000-12-15 | 214d | finish no earlier than 2000-12-15 | T2 | 1712h | 1712h | Rel-4 |  |  |  |  |  |  |
| 2202 | 55.2 | **MExE Rel4 Improvements and Investigations** | 251d | 2000-01-03 A | 2000-12-15 A |  | 100% | 2000-01-03 | 2000-12-15 | 251d |  | T2 | 6480h | 6480h | Rel-4 |  | 22.057, 23.057 |  | MEXE-ENHANC | Motorola | Mark Cataldo |
| 2203 | 55.2.1 | 3rd MExE classmark | 251d | 2000-01-03 A | 2000-12-15 A |  | 100% | 2000-01-03 | 2000-12-15 | 251d | finish no earlier than 2000-12-15 | T2 | 2000h | 2000h | Rel-4 |  | 22.057, 23.057 |  |  | Motorola | Mark Cataldo |
| 2204 | 55.2.2 | FS on Secure download mechanism and capabilities to support SDR concepts | 225d | 2000-02-07 A | 2000-12-15 A |  | 100% | 2000-02-07 | 2000-12-15 | 225d | finish no earlier than 2000-12-15 | T2 | 1800h | 1800h | Rel-4 |  | 22.057, 23.057 |  |  | Motorola | Mark Cataldo |
| 2205 | 55.2.3 | FS on Support of MP3/MPEG4 content | 225d | 2000-02-07 A | 2000-12-15 A |  | 100% | 2000-02-07 | 2000-12-15 | 225d | finish no earlier than 2000-12-15 | T2 | 1800h | 1800h | Rel-4 |  | 22.057, 23.057 |  |  | Motorola | Mark Cataldo |

Notes:
- 2181: -
- 2182: -
- 2183: -
- 2184: Marked as closed 12/2008 (was marked 60% complete)
- 2185: Marked as stopped 12/2008
- 2186: duration set to 6 months (was 0), finish date set
- 2187: -
- 2188: DAB 12.12.01 should be 100% hence closed
- 2189: R00 stage 2 at least 80 % complete in TSGS #8 21.-23.6.2000
- 2190: -
- 2191: -
- 2192: -
- 2193: -
- 2194: -
- 2195: -
- 2196: Requirements capture: S3#14 (Aug 00), Feature specification: S3#15 (Sep 00), Definition of architecture. Should be included in general LI work mentioned above.
- 2197: Marked as stopped 12/2008
- 2198: -
- 2199: Presentation to S3 of threats and countermeasures analysis: S3#15, Feature specification: S3#16. S3#18: WID updated
- 2200: Analysis undertaken by T2. No additional analysis needed for Rel-4
- 2201: -
- 2202: -
- 2203: Additional features for MExE R2000
- 2204: -
- 2205: -

| ID | WBS | Task | Duration | Start | Finish | Complete | Baseline start | Baseline finish | Baseline duration | Constraint | Resources | Work | Actual work | Text1 | Text6 | Text8 | Text3 | Text4 | Text5 |
| --- | --- | --- | --- | --- | --- | --- | --- | --- | --- | --- | --- | --- | --- | --- | --- | --- | --- | --- | --- |
| 2206 | 56 | **Tandem Free aspects for 3G and between 2G and 3G systems** | 344d | 2000-02-22 A | 2001-06-15 A | 100% | 2000-02-22 | 2001-06-15 | 344d |  | S4 | 9696h | 9696h | TFO | Rel-4 | Paolo |  |  |  |
| 2207 | 56.1 | **Tandem Free AMR** | 344d | 2000-02-22 A | 2001-06-15 A | 100% | 2000-02-22 | 2001-06-15 | 344d |  | S4 | 6944h | 6944h | TFO-AMR | Rel-4 | Paolo |  |  |  |
| 2208 | 56.1.1 | Specification | 284d | 2000-02-22 A | 2001-03-23 A | 100% | 2000-02-22 | 2001-03-23 | 284d | start no earlier than 2000-02-22 | S4 | 2272h | 2272h |  | Rel-4 | Paolo | 28.062 |  |  |
| 2209 | 56.1.2 | **Impact on:** | 115d | 2001-01-08 A | 2001-06-15 A | 100% | 2001-01-08 | 2001-06-15 | 115d |  | NP | 1920h | 1920h |  | Rel-4 | Kimmo |  |  |  |
| 2210 | 56.1.2.1 | CN | 60d | 2001-03-26 A | 2001-06-15 A | 100% | 2001-03-26 | 2001-06-15 | 60d | finish no earlier than 2001-06-15 | NP | 480h | 480h |  | Rel-4 | Kimmo |  |  |  |
| 2211 | 56.1.2.2 | GERAN | 65d | 2001-01-08 A | 2001-04-06 A | 100% | 2001-01-08 | 2001-04-06 | 65d | finish no earlier than 2001-04-06 | GP | 520h | 520h |  | Rel-4 | Paolo |  |  |  |
| 2212 | 57 | **Advanced Speech Call Items enhancements_REL-4** | 334d | 2000-12-03 A | 2002-03-14 A | 100% | 2000-12-03 | 2002-03-14 | 334d |  | N1 | 5925.6h | 5925.6h | ASCI | Rel-4 | Frederic |  | Nortel | sonia.garapaty@nortelnetworks.com |
| 2213 | 57.1 | Stage 2 | 326.7d | 2000-12-03 A | 2002-03-14 A | 100% | 2000-12-03 | 2002-03-14 | 326.7d | finish no earlier than 2002-03-14 | N4 | 2613.6h | 2613.6h |  | Rel-4 | Kimmo | 23.067, 24.067 | Sagem | Vivien Perlic |
| 2214 | 57.2 | Stages 2 and 3 on A interface | 80d | 2000-12-03 A | 2001-03-23 A | 100% | 2000-12-03 | 2001-03-23 | 80d | finish no earlier than 2001-03-23 | N1 | 640h | 640h |  | Rel-4 | Frederic | 44.068, 44.069, 24.008 | Nortel | sonia.garapaty@nortelnetworks.com |
| 2215 | 58 | **700 MHz spectrum support** | 776d | 2000-01-03 A | 2002-12-20 A | 100% | 2000-01-03 | 2002-12-20 | 776d |  | GP | 25016h | 25016h | 700SS | Rel-4 | Paolo |  |  |  |
| 2216 | 58.1 | **GERAN support for the 700 MHz band** | 276d | 2000-01-03 A | 2001-01-19 A | 100% | 2000-01-03 | 2001-01-19 | 276d |  | GP | 8808h | 8808h |  | Rel-4 | Paolo |  |  |  |
| 2217 | 58.1.1 | Signalling support | 276d | 2000-01-03 A | 2001-01-19 A | 100% | 2000-01-03 | 2001-01-19 | 276d | finish no earlier than 2001-01-19 | GP | 2200h | 2200h |  | Rel-4 | Paolo |  |  |  |
| 2218 | 58.1.2 | Physical layer definitions | 276d | 2000-01-03 A | 2001-01-19 A | 100% | 2000-01-03 | 2001-01-19 | 276d | finish no earlier than 2001-01-19 | GP | 2200h | 2200h |  | Rel-4 | Paolo |  |  |  |
| 2219 | 58.1.3 | Receiver performance and RF budget | 276d | 2000-01-03 A | 2001-01-19 A | 100% | 2000-01-03 | 2001-01-19 | 276d | finish no earlier than 2001-01-19 | GP | 2200h | 2200h |  | Rel-4 | Paolo |  |  |  |
| 2220 | 58.2 | **GERAN MS Conformance test for 700 MHz band** | 175d | 2001-04-02 A | 2001-11-30 A | 100% | 2001-04-02 | 2001-11-30 | 175d |  | GP | 2800h | 2800h |  | Rel-4 | Paolo |  |  |  |
| 2221 | 58.2.1 | MS test | 175d | 2001-04-02 A | 2001-11-30 A | 100% | 2001-04-02 | 2001-11-30 | 175d | finish no earlier than 2001-11-30 | GP | 1400h | 1400h |  | Rel-4 | Paolo |  |  |  |
| 2222 | 58.3 | **GERAN BTS Conformance test for 700 MHz band** | 450d | 2001-04-02 A | 2002-12-20 A | 100% | 2001-04-02 | 2002-12-20 | 450d |  | GP | 7200h | 7200h |  | Rel-4 | Paolo |  |  |  |
| 2223 | 58.3.1 | BTS test | 450d | 2001-04-02 A | 2002-12-20 A | 100% | 2001-04-02 | 2002-12-20 | 450d | finish no earlier than 2002-12-20 | GP | 3600h | 3600h |  | Rel-4 | Paolo |  |  |  |
| 2224 | 59 | Operator Determined Barring for Packet Oriented Services | 208d | 2000-06-01 A | 2001-03-19 A | 100% | 2000-06-01 | 2001-03-19 | 208d | finish no earlier than 2001-03-19 | NP | 1664h | 1664h | ODB | Rel-4 |  |  | NEC | Toshiyuki Tamura (tamurato@aj.jp.nec.com) |
| 2225 | 60 | **UMTS QoS Architecture for PS Domain** | 759d | 2000-01-03 A | 2002-11-27 A | 100% | 2000-01-03 | 2002-11-27 | 759d |  | S2 | 41312h | 41312h | QoSPS | Rel-4 | Maurice |  | Ericsson | Ina.widegren@era.ericsson.se |
| 2226 | 60.1 | Architecture | 153d | 2000-06-05 A | 2001-01-03 A | 100% | 2000-06-05 | 2001-01-03 | 153d | finish no earlier than 2001-01-03 | S2 | 1224h | 1224h |  | Rel-4 | Maurice | 23.107 |  |  |
| 2227 | 60.2 | Charging and OAM&P for QoS Management | 201d | 2001-09-21 A | 2002-06-28 A | 100% | 2001-09-21 | 2002-06-28 | 201d | finish no earlier than 2002-06-28 | S5 | 1608h | 1608h | QoSPS-OAM | Rel-4 | Dionisio | 32-series | VoiceStream, Motorola |  |
| 2228 | 60.3 | **RAB Quality of Service (re)Negotiation over Iu** | 155d | 2000-08-21 A | 2001-03-23 A | 100% | 2000-08-21 | 2001-03-23 | 155d |  | R3 | 3648h | 3648h | QoSPS-MAPEND-RABQoS | Rel-4 | Juha | 25.413 | Ericsson | A. Molander |
| 2229 | 60.3.1 | RAB Quality of Service Negotiation over Iu | 155d | 2000-08-21 A | 2001-03-23 A | 100% | 2000-08-21 | 2001-03-23 | 155d | finish no earlier than 2001-03-23 | R3 | 1240h | 1240h | QoSPS-MAPEND-RABQoS-Negot | Rel-4 | Juha |  | Ericsson | A. Molander |
| 2230 | 60.3.2 | RAB Quality of Service Negotiation over Iu during relocation | 16d | 2001-03-02 A | 2001-03-23 A | 100% | 2001-03-02 | 2001-03-23 | 16d | start no earlier than 2001-03-02 | R3 | 128h | 128h | QoSPS-MAPEND-RABQoS-NegotReloc | Rel-4 | Juha |  |  |  |
| 2231 | 60.3.3 | RAB Quality of Service Re-Negotiation over Iu | 130d | 2000-09-25 A | 2001-03-23 A | 100% | 2000-09-25 | 2001-03-23 | 130d | finish no earlier than 2001-03-23 | R3 | 1040h | 1040h | QoSPS-MAPEND-RABQoS-ReNegot | Rel-4 | Juha |  | Motorola | S. Irwin |

Notes:
- 2206: RAN and CN to verify no problems for GSM terminals roaming in 3G R99
- 2207: RAN and CN to verify UMTS_AMR_2 support
- 2208: -
- 2209: "Implementation" changed to "Impact on:" by A. Sultan (for better wording)
- 2210: RAN and CN to verify UMTS_AMR_2 support
- 2211: End date Modified from June to March to have it in Rel4
- 2212: Approved at CN#10
- 2213: CN4#11 30/11/02: no inputs received in CN4
- 2214: -
- 2215: -
- 2216: -
- 2217: -
- 2218: -
- 2219: -
- 2220: -
- 2221: -
- 2222: -
- 2223: -
- 2224: Completed WI missing from the P-plan Added for tracking
- 2225: -
- 2226: -
- 2227: -
- 2228: -
- 2229: -
- 2230: -
- 2231: -

| ID | WBS | Task | Duration | Start | Finish | Complete | Baseline start | Baseline finish | Baseline duration | Constraint | Resources | Work | Actual work | Text1 | Text6 | Text8 | Text12 | Text4 | Text5 | Text3 |
| --- | --- | --- | --- | --- | --- | --- | --- | --- | --- | --- | --- | --- | --- | --- | --- | --- | --- | --- | --- | --- |
| 2232 | 60.4 | **GERAN QoS Aspects - Handovers: maintenance of real-time QoS while moving between cells in the PLMN including inter-SGSN and SRNS relocation or possibly other mechanisms** | 501d | 2000-01-03 A | 2001-11-30 A | 100% | 2000-01-03 | 2001-11-30 | 501d |  | GP | 14456h | 14456h | GERQoS | Rel-4 | Paolo |  |  |  |  |
| 2233 | 60.4.1 | **Handover Concept for the PS domain** | 501d | 2000-01-03 A | 2001-11-30 A | 100% | 2000-01-03 | 2001-11-30 | 501d |  | GP | 10448h | 10448h |  | Rel-4 | Paolo |  |  |  |  |
| 2234 | 60.4.1.1 | Stable RT handover report 25.936 including header removal | 14d | 2000-01-03 A | 2000-01-19 A | 100% | 2000-01-03 | 2000-01-19 | 14d | start no earlier than 2000-01-03 | GP [92.9%] | 104h | 104h |  | Rel-4 | Paolo |  |  |  |  |
| 2235 | 60.4.1.2 | Update of stage 2 | 293d | 2000-01-03 A | 2001-02-13 A | 100% | 2000-01-03 | 2001-02-13 | 293d | finish no earlier than 2001-02-13 | GP | 2336h | 2336h |  | Rel-4 | Paolo |  |  |  |  |
| 2236 | 60.4.1.3 | Update of relevant stage 3 specs -> RRC | 501d | 2000-01-03 A | 2001-11-30 A | 100% | 2000-01-03 | 2001-11-30 | 501d | finish no earlier than 2001-11-30 | G2 | 4000h | 4000h |  | Rel-4 | Gert |  |  |  |  |
| 2237 | 60.5 | **Deleted - GERAN MS Conformance test for inter-system and intra-system Packet data real-time Handover** | 324d | 2001-08-31 A | 2002-11-27 A | 100% | 2001-08-31 | 2002-11-27 | 324d |  | G4,R3 | 12960h | 12960h | GERQoS-Mstest | Rel-4 | Paolo | GP-12 |  |  |  |
| 2238 | 60.5.1 | **Deleted - Handover for the PS domain** | 324d | 2001-08-31 A | 2002-11-27 A | 100% | 2001-08-31 | 2002-11-27 | 324d |  | G4,R3 | 10368h | 10368h |  | Rel-4 | Paolo | GP-12 |  |  |  |
| 2239 | 60.5.1.1 | Deleted - Stable RT handover report 25.936 including header removal | 324d | 2001-08-31 A | 2002-11-27 A | 100% | 2001-08-31 | 2002-11-27 | 324d | finish no earlier than 2002-11-27 | G4,R3 | 2592h | 2592h |  | Rel-4 | Paolo | GP-12 |  |  |  |
| 2240 | 60.5.1.2 | Deleted - Update of stage 2 | 324d | 2001-08-31 A | 2002-11-27 A | 100% | 2001-08-31 | 2002-11-27 | 324d | finish no earlier than 2002-11-27 | G4,R3 | 2592h | 2592h |  | Rel-4 | Paolo | GP-12 |  |  |  |
| 2241 | 60.5.1.3 | Deleted - Update of relevant stage 3 specs | 324d | 2001-08-31 A | 2002-11-27 A | 100% | 2001-08-31 | 2002-11-27 | 324d | finish no earlier than 2002-11-27 | G4,R3 | 2592h | 2592h |  | Rel-4 | Paolo | GP-12 |  |  |  |
| 2242 | 60.6 | PS-domain handover for real-time services | 155d | 2000-08-28 A | 2001-03-30 A | 100% | 2000-08-28 | 2001-03-30 | 155d | finish no earlier than 2001-03-30 | R3 | 1240h | 1240h | QoSPS-PSdoRTS | Rel-4 | Juha |  | Nokia | A. Lansisalmi |  |
| 2243 | 60.7 | Deleted - RAB QoS Renegotiation at Relocation | 58d | 2001-01-03 A | 2001-03-23 A | 100% | 2001-01-03 | 2001-03-23 | 58d | finish no earlier than 2001-03-23 | R3 | 464h | 464h |  | Rel-4 | Juha | RP-11 |  |  | 25.851, 25.946 |
| 2244 | 61 | **small Technical Enhancements and Improvements for Rel4** | 2178d? | 2000-01-03 A | 2008-05-06 A | 100% | 2000-01-03 | 2008-05-06 | 2178d? |  | All | 17424h | 17424h | TEI4 | Rel-4 | all |  |  |  |  |
| 2245 | 564.1 | Small Technical Enhancements and Improvements for Rel-4 Conformance Testing | 2178d? | 2000-01-03 A | 2008-05-06 A | 100% | 2000-01-03 | 2008-05-06 | 2178d? | finish no earlier than 2008-12-31 | R5,T1 | 17424h | 17424h | TEI4_Test | Rel-4 | Ingbert |  |  |  |  |
| 2246 | 62 | **Rel-4 Evolutions of the transport in the UTRAN** | 525d | 2000-08-21 A | 2002-08-23 A | 100% | 2000-08-21 | 2002-08-23 | 525d |  | RP | 8600h | 8600h | ETRAN | Rel-4 | Issam |  | Alcatel | Francois Courau |  |
| 2247 | 62.1 | QoS optimization for AAL2 connections over Iub and Iur interfaces | 160d | 2000-08-21 A | 2001-03-30 A | 100% | 2000-08-21 | 2001-03-30 | 160d | finish no earlier than 2001-03-30 | R3 | 1280h | 1280h | ETRAN-QoSAAL2 | Rel-4 | Juha |  | Japan Telecom | T. Yoshimura |  |
| 2248 | 62.2 | Transport bearer modification procedure on Iub, Iur, and Iu | 130d | 2000-10-02 A | 2001-03-30 A | 100% | 2000-10-02 | 2001-03-30 | 130d | finish no earlier than 2001-03-30 | R3 | 1040h | 1040h | ETRAN-MigrMod | Rel-4 | Juha |  | Japan Telecom | T. Yoshimura |  |
| 2249 | 62.3 | **Deleted - Conformance Test Aspects of Rel-4 evolutions of the transport in UTRAN** | 130d | 2002-02-25 A | 2002-08-23 A | 100% | 2002-02-25 | 2002-08-23 | 130d |  | T1 | 2080h | 2080h |  | Rel-4 | Ingbert | TP-17 |  |  |  |
| 2250 | 62.3.1 | Deleted - Testing RAB support enhancements | 130d | 2002-02-25 A | 2002-08-23 A | 100% | 2002-02-25 | 2002-08-23 | 130d | finish no earlier than 2002-08-23 | T1 | 1040h | 1040h | CT-RABS? | Rel-4 | Ingbert | TP-17 |  |  | 34.108, 34. 121, 34.122, 34.123 p 1,2, 34.123 pt 3 |
| 2251 | 63 | **Rel-4 Evolutions of the transport in the CN** | 215d | 2000-05-29 A | 2001-03-23 A | 100% | 2000-05-29 | 2001-03-23 | 215d |  | N4,N1,N2,S2 | 7968h | 7968h | CNTRSP | Rel-4 | Kimmo |  |  |  |  |
| 2252 | 63.1 | **IP Transport of CN protocols (e.g., CAP, MAP)** | 77d | 2000-12-07 A | 2001-03-23 A | 100% | 2000-12-07 | 2001-03-23 | 77d |  | N4 | 2808h | 2808h | SS7IP | Rel-4 | Kimmo |  |  |  |  |
| 2253 | 63.1.1 | **Stage 3** | 77d | 2000-12-07 A | 2001-03-23 A | 100% | 2000-12-07 | 2001-03-23 | 77d |  | N4 | 2192h | 2192h |  | Rel-4 | Kimmo |  |  |  |  |
| 2254 | 63.1.1.1 | CAP | 77d | 2000-12-07 A | 2001-03-23 A | 100% | 2000-12-07 | 2001-03-23 | 77d | finish no earlier than 2001-03-23 | N2 | 616h | 616h |  | Rel-4 | Kimmo |  |  |  |  |
| 2255 | 63.1.1.2 | MAP | 77d | 2000-12-07 A | 2001-03-23 A | 100% | 2000-12-07 | 2001-03-23 | 77d | finish no earlier than 2001-03-23 | N4 | 616h | 616h |  | Rel-4 | Kimmo |  |  |  |  |
| 2256 | 63.1.1.3 | BSSAP+ | 43d | 2001-01-15 A | 2001-03-14 A | 100% | 2001-01-15 | 2001-03-14 | 43d | finish no earlier than 2001-03-14 | N1 | 344h | 344h | SS7IP-BSSAP+ | Rel-4 | Frederic |  |  |  |  |

Notes:
- 2232: -
- 2233: -
- 2234: -
- 2235: -
- 2236: -
- 2237: Still exist? To be clarified by GERAN4/5. Marked as stopped 12/2008
- 2238: Marked as stopped 12/2008
- 2239: Marked as stopped 12/2008
- 2240: Marked as stopped 12/2008
- 2241: Marked as stopped 12/2008
- 2242: -
- 2243: Marked as stopped 12/2008
- 2244: "Joker" WI, to be used for a Rel 4 CR not related to any feature and with very limited impact on the system
- 2245: "Joker" WI, to be used for small modifications applicable to Rel 4 conformance testing. Moved in from the Stoyan/Testing WP
- 2246: -
- 2247: -
- 2248: -
- 2249: Marked as stopped 12/2008
- 2250: Marked as stopped 12/2008
- 2251: -
- 2252: -
- 2253: -
- 2254: -
- 2255: -
- 2256: -

| ID | WBS | Task | Duration | Start | Finish | Complete | Baseline start | Baseline finish | Baseline duration | Constraint | Resources | Work | Actual work | Text4 | Text5 | Text6 | Text8 | Text1 | Text3 | Text12 |
| --- | --- | --- | --- | --- | --- | --- | --- | --- | --- | --- | --- | --- | --- | --- | --- | --- | --- | --- | --- | --- |
| 2257 | 63.2 | **FS on Transport and control separation in the PS CN domain** | 215d | 2000-05-29 A | 2001-03-23 A | 100% | 2000-05-29 | 2001-03-23 | 215d |  | S2 | 3440h | 3440h | Ericsson | Juan-Antonio.Ibanez@eed.ericsson.se | Rel-4 | Maurice |  |  |  |
| 2258 | 63.2.1 | Architectural impacts | 215d | 2000-05-29 A | 2001-03-23 A | 100% | 2000-05-29 | 2001-03-23 | 215d | finish no earlier than 2001-03-23 | S2 | 1720h | 1720h |  |  | Rel-4 | Maurice |  |  |  |
| 2259 | 64 | **Rel-4 Improvements of Radio Interface** | 700d | 2000-07-10 A | 2003-03-14 A | 100% | 2000-07-10 | 2003-03-14 | 700d |  | RP | 28624h | 28624h |  |  | Rel-4 |  | RInImp |  |  |
| 2260 | 64.1 | UTRA repeater specification (master) | 183d | 2000-07-10 A | 2001-03-21 A | 100% | 2000-07-10 | 2001-03-21 | 183d | finish no earlier than 2001-03-21 | R4 | 1464h | 1464h | Mikom, Allgon | T. Kummetz, Mikom; Alf Ahlström, Allgon | Rel-4 | Issam | RInImp-REP |  |  |
| 2261 | 64.2 | DSCH power control improvement in soft handover | 140d | 2000-09-11 A | 2001-03-23 A | 100% | 2000-09-11 | 2001-03-23 | 140d | finish no earlier than 2001-03-23 | R1 | 1120h | 1120h | Nokia | antti.toskala@nokia.com | Rel-4 | Patrick | RInImp-DSCHsho |  |  |
| 2262 | 64.3 | UMTS 1800 | 320d | 2000-09-25 A | 2001-12-14 A | 100% | 2000-09-25 | 2001-12-14 | 320d | finish no earlier than 2001-12-14 | R4 | 2560h | 2560h | Motorola | Howard Benn | Rel-4 | Issam | RInImp-UMTS18 |  |  |
| 2263 | 64.4 | UMTS 1900 | 195d | 2001-03-19 A | 2001-12-14 A | 100% | 2001-03-19 | 2001-12-14 | 195d | finish no earlier than 2001-12-14 | R4 | 1560h | 1560h | Motorola | Howard Benn | Rel-4 | Issam | RInImp-UMTS19 | 25.101 |  |
| 2264 | 64.5 | FS on High Speed downlink packet access | 155d | 2000-08-21 A | 2001-03-23 A | 100% | 2000-08-21 | 2001-03-23 | 155d | finish no earlier than 2001-03-23 | R2 | 1240h | 1240h | Motorola | A. Ghosh | Rel-4 | Joern | RInImp-HSDPA |  |  |
| 2265 | 64.6 | Deleted - FS on improved common DL channel for Cell-FACH state | 340d | 2000-09-11 A | 2001-12-28 A | 100% | 2000-09-11 | 2001-12-28 | 340d | finish no earlier than 2001-12-28 | R2 | 2720h | 2720h | GBT | J. Kwak | Rel-4 | Joern | RInImp-DLCFACH |  | RP-14 |
| 2266 | 64.7 | **Conformance Test Spec. Rel-4 improvements in Radio Interface** | 375d | 2001-10-08 A | 2003-03-14 A | 100% | 2001-10-08 | 2003-03-14 | 375d |  | T1 | 12360h | 12360h |  |  | Rel-4 | Ingbert |  |  |  |
| 2267 | 64.7.1 | Deleted - Testing Improved usage of downlink resource in FDD for CCTrCHs of dedicated type | 140d | 2002-02-18 A | 2002-08-30 A | 100% | 2002-02-18 | 2002-08-30 | 140d | finish no earlier than 2002-08-30 | T1 | 1120h | 1120h |  |  | Rel-4 | Ingbert |  |  | TP-17 |
| 2268 | 64.7.2 | Deleted - Testing Terminal Power saving features | 140d | 2002-02-18 A | 2002-08-30 A | 100% | 2002-02-18 | 2002-08-30 | 140d | finish no earlier than 2002-08-30 | T1 | 1120h | 1120h |  |  | Rel-4 | Ingbert |  |  | TP-17 |
| 2269 | 64.7.3 | Deleted - Testing DSCH power control improvement in soft handover | 140d | 2002-02-18 A | 2002-08-30 A | 100% | 2002-02-18 | 2002-08-30 | 140d | finish no earlier than 2002-08-30 | T1 | 1120h | 1120h |  |  | Rel-4 | Ingbert |  |  | TP-17 |
| 2270 | 64.7.4 | Testing UMTS 1800 | 180d | 2001-10-08 A | 2002-06-14 A | 100% | 2001-10-08 | 2002-06-14 | 180d | finish no earlier than 2002-06-14 | T1 | 1440h | 1440h |  |  | Rel-4 | Ingbert |  | 34.108, 34,121, 34.122, 34.123-1 |  |
| 2271 | 64.7.5 | Testing UMTS 1900 | 180d | 2001-10-08 A | 2002-06-14 A | 100% | 2001-10-08 | 2002-06-14 | 180d | finish no earlier than 2002-06-14 | T1 | 1440h | 1440h |  |  | Rel-4 | Ingbert |  | 34.108, 34,121, 34.122, 34.123-1 |  |
| 2272 | 64.7.6 | Testing UMTS 1800 - TTCN | 195d | 2002-06-17 A | 2003-03-14 A | 100% | 2002-06-17 | 2003-03-14 | 195d | finish no earlier than 2003-03-14 | T1 | 1560h | 1560h |  |  | Rel-4 | Ingbert |  | 34.123-3 |  |
| 2273 | 64.7.7 | Testing UMTS 1900 - TTCN | 195d | 2002-06-17 A | 2003-03-14 A | 100% | 2002-06-17 | 2003-03-14 | 195d | finish no earlier than 2003-03-14 | T1 | 1560h | 1560h |  |  | Rel-4 | Ingbert |  | 34.123-3 |  |
| 2274 | 65 | **Rel-4 RAN improvements** | 938d? | 2000-08-14 A | 2004-03-17 A | 100% | 2000-08-14 | 2004-03-17 | 938d? |  | RP | 29336h | 29336h |  |  | Rel-4 |  | RANimp |  |  |
| 2275 | 65.1 | Node B synchronization for TDD | 160d | 2000-08-14 A | 2001-03-23 A | 100% | 2000-08-14 | 2001-03-23 | 160d | finish no earlier than 2001-03-23 | R1 | 1280h | 1280h | Siemens | S. Oestreich | Rel-4 | Patrick | RANimp-NBsync |  |  |
| 2276 | 65.2 | RAB support enhancement for Rel-4 | 155d | 2000-08-21 A | 2001-03-23 A | 100% | 2000-08-21 | 2001-03-23 | 155d | finish no earlier than 2001-03-23 | R2 | 1240h | 1240h | Ericsson | M. Israelsson, A. Krishnarajah | Rel-4 | Joern | RANimp-RABSE |  |  |
| 2277 | 65.4 | **Deleted - Conformance Test Aspects - Rel-4 RAN Improvements** | 577d? | 2002-01-01 A | 2004-03-17 A | 100% | 2002-01-01 | 2004-03-17 | 577d? |  | T1 | 19312h | 19312h |  |  | Rel-4 | Ingbert |  |  | TP-23 |
| 2278 | 65.4.1 | Deleted - Testing Radio access bearer support enhancments | 175d | 2002-01-01 A | 2002-09-02 A | 100% | 2002-01-01 | 2002-09-02 | 175d | finish no earlier than 2002-09-02 | T1 | 1400h | 1400h |  |  | Rel-4 | Ingbert |  |  | TP-17 |
| 2279 | 65.4.2 | Deleted - Testing RAB support enhancements-Robust Header Compression | 332d | 2002-05-28 A | 2003-09-03 A | 100% | 2002-05-28 | 2003-09-03 | 332d | finish no earlier than 2003-09-03 | T1 | 2656h | 2656h |  |  | Rel-4 | Ingbert | RABimp-RoCH | 34.123-1, -2 | TP-21 |
| 2280 | 65.4.3 | Deleted - Testing RAB support enhancements-Robust Header Compression - TTCN | 472d | 2002-05-28 A | 2004-03-17 A | 100% | 2002-05-28 | 2004-03-17 | 472d | finish no earlier than 2004-03-17 | T1 | 3776h | 3776h |  |  | Rel-4 | Ingbert |  | 34.123-3 | TP-23 |
| 2281 | 65.4.4 | Testing of Extended Robut Header Compression | 270d | 2002-09-18 A | 2003-09-30 A | 100% | 2002-09-18 | 2003-09-30 | 270d | finish no earlier than 2003-09-30 | T1 | 2160h | 2160h |  |  | Rel-4 | Ingbert | Ext-RoHC | 34.123-1, -2 |  |
| 2282 | 65.4.5 | Deleted - Testing of Extended Robut Header Compression - TTCN | 325d | 2002-09-18 A | 2003-12-16 A | 100% | 2002-09-18 | 2003-12-16 | 325d | finish no earlier than 2003-12-16 | T1 | 2600h | 2600h |  |  | Rel-4 | Ingbert |  | 34.123-3 | TP-22 |
| 2283 | 568.3.6 | Deleted - General changes to TS34.121 corresponding to release 4 | 263d? | 2003-03-03 A | 2004-03-03 A | 100% | 2003-03-03 | 2004-03-03 | 263d? | finish no earlier than 2004-03-03 | T1 | 2104h | 2104h |  |  | Rel-4 | Ingbert | RANimp-test | 34.108, 34.121 | TP-23 |

Notes:
- 2257: -
- 2258: -
- 2259: -
- 2260: -
- 2261: -
- 2262: -
- 2263: -
- 2264: -
- 2265: Stopped at RP#14
- 2266: -
- 2267: Marked as stopped 12/2008
- 2268: Marked as stopped 12/2008
- 2269: Marked as stopped 12/2008
- 2270: -
- 2271: -
- 2272: -
- 2273: -
- 2274: -
- 2275: -
- 2276: 29 Nov 2000: split into ROHC and non-ROHC part; 5 Mar 2001: splitting off of ROHC for Rel-4 agreed by R2
- 2277: Marked as stopped 12/2008
- 2278: Marked as stopped 12/2008
- 2279: UID changed. Marked as stopped 12/2008
- 2280: UID changed. Marked as stopped 12/2008
- 2281: Marked as closed 12/2008 (was marked 15% complete)
- 2282: Marked as stopped 12/2008
- 2283: Marked as stopped 12/2008

| ID | WBS | Task | Duration | Start | Finish | Complete | Baseline start | Baseline finish | Baseline duration | Constraint | Resources | Work | Actual work | Text1 | Text4 | Text6 | Text8 | Text12 | Text3 | Text5 |
| --- | --- | --- | --- | --- | --- | --- | --- | --- | --- | --- | --- | --- | --- | --- | --- | --- | --- | --- | --- | --- |
| 2284 | 66 | **Rel-4 Emergency call enhancements** | 628d | 2000-01-03 A | 2002-05-28 A | 100% | 2000-01-03 | 2002-05-28 | 628d |  | N1,S1,T1 | 3600h | 3600h | EMC1 | Ericsson | Rel-4 | Frederic |  |  |  |
| 2285 | 66.1 | **For CS based calls** | 628d | 2000-01-03 A | 2002-05-28 A | 100% | 2000-01-03 | 2002-05-28 | 628d |  | N1 | 3600h | 3600h | EMC1-CS | Ericsson | Rel-4 | Frederic |  |  |  |
| 2286 | 66.1.1 | Distinction in CS domain of emergency call types to different emergency services | 40d | 2000-05-01 A | 2000-06-23 A | 100% | 2000-05-01 | 2000-06-23 | 40d | finish no earlier than 2000-06-23 | S1 | 320h | 320h | EMC1-CS |  | Rel-4 | Alain |  |  |  |
| 2287 | 66.1.2 | Distinction in CS domain of emergency calls to different emergency types | 22d | 2000-08-24 A | 2000-09-22 A | 100% | 2000-08-24 | 2000-09-22 | 22d | finish no earlier than 2000-09-22 | N1 | 176h | 176h | EMC1-CS |  | Rel-4 | Frederic |  |  |  |
| 2288 | 66.1.3 | Deleted - Conformance Test Aspects - Emergency call enhancements | 151d | 2000-01-03 A | 2000-07-28 A | 100% | 2000-01-03 | 2000-07-28 | 151d |  | T1 | 1200h | 1200h | EMC1-CS |  | Rel-4 | Ingbert | TP-08 |  |  |
| 2289 | 66.1.4 | Testing CS based emergency calls | 67d | 2002-02-25 A | 2002-05-28 A | 100% | 2002-02-25 | 2002-05-28 | 67d | finish no earlier than 2002-05-28 | T1 | 536h | 536h | EMC1-CS |  | Rel-4 | Ingbert |  | 34.123-1 |  |
| 2290 | 66.1.5 | Testing CS based emergency calls - TTCN | 134d | 2001-11-22 A | 2002-05-28 A | 100% | 2001-11-22 | 2002-05-28 | 134d | finish no earlier than 2002-05-28 | T1 | 1072h | 1072h | EMC1-CS |  | Rel-4 | Ingbert |  | 34.123-3 |  |
| 2291 | 67 | **Rel-4 Terminal interfaces** | 315d | 2000-01-03 A | 2001-03-15 A | 100% | 2000-01-03 | 2001-03-15 | 315d |  | T2 | 14296h | 14296h | TI |  | Rel-4 | Kimmo |  |  |  |
| 2292 | 67.1 | **AT commands enhancements** | 314d | 2000-01-03 A | 2001-03-14 A | 100% | 2000-01-03 | 2001-03-14 | 314d |  | T2 | 5016h | 5016h | TI-ATC |  | Rel-4 |  |  | 27.007 |  |
| 2293 | 67.1.1 | Specification of AT commands for new services | 314d | 2000-01-03 A | 2001-03-14 A | 100% | 2000-01-03 | 2001-03-14 | 314d | finish no earlier than 2001-03-14 | T2 | 2504h | 2504h |  |  | Rel-4 |  |  | 27.007 |  |
| 2294 | 67.2 | **Wide Area Data Synchronization** | 314d | 2000-01-03 A | 2001-03-14 A | 100% | 2000-01-03 | 2001-03-14 | 314d |  | T2 | 5016h | 5016h | TI-WADS |  | Rel-4 |  |  |  |  |
| 2295 | 67.2.1 | Continues evolution of Synchronization protocol | 314d | 2000-01-03 A | 2001-03-14 A | 100% | 2000-01-03 | 2001-03-14 | 314d | finish no earlier than 2001-03-14 | T2 | 2504h | 2504h | TI-SYNC-EVOL |  | Rel-4 |  |  | 27.903, 27.103 |  |
| 2296 | 67.3 | Terminal local model | 218d | 2000-05-16 A | 2001-03-15 A | 100% | 2000-05-16 | 2001-03-15 | 218d | finish no earlier than 2001-03-15 | T2 | 1744h | 1744h | TLM | Ericsson | Rel-4 |  |  | 23.227 | Olga.Tome@ECS.ERICSSON.SE |
| 2297 | 68 | **Rel-4 Location Services enhancements** | 455d | 2000-04-03 A | 2001-12-28 A | 100% | 2000-04-03 | 2001-12-28 | 455d |  | S2 | 26799.2h | 26799.2h | LCS1 | Nokia | Rel-4 | Maurice |  |  | Jan Kall |
| 2298 | 68.1 | CBS interactions | 455d | 2000-04-03 A | 2001-12-28 A | 100% | 2000-04-03 | 2001-12-28 | 455d | finish no earlier than 2001-12-28 | T2 | 3640h | 3640h | LCS1-CBS |  | Rel-4 |  |  | 23.041 |  |
| 2299 | 68.2 | LCS support in the CS domain | 180d | 2000-05-15 A | 2001-01-19 A | 100% | 2000-05-15 | 2001-01-19 | 180d | finish no earlier than 2001-01-19 | S2 | 1440h | 1440h | LCS1-CS |  | Rel-4 | Maurice |  |  |  |
| 2300 | 68.3 | **LCS support in the PS domain** | 435d | 2000-05-01 A | 2001-12-28 A | 100% | 2000-05-01 | 2001-12-28 | 435d |  | S2 | 13560h | 13560h | LCS1-PS |  | Rel-4 | Maurice |  |  |  |
| 2301 | 68.3.1 | Stage 1 | 40d | 2000-07-03 A | 2000-08-25 A | 100% | 2000-07-03 | 2000-08-25 | 40d | start no earlier than 2000-07-03 | S1 | 320h | 320h |  | Pacific Bell Wireless | Rel-4 | Alain |  | 22.071 | Randolph Wohlert (rwohlert@tri.sbc.com) |
| 2302 | 68.3.2 | Stage 2 | 190d | 2000-05-01 A | 2001-01-19 A | 100% | 2000-05-01 | 2001-01-19 | 190d | finish no earlier than 2001-01-19 | S2 | 1520h | 1520h |  |  | Rel-4 | Maurice |  | 23.271 |  |
| 2303 | 68.3.3 | **Stage 3** | 355d | 2000-08-21 A | 2001-12-28 A | 100% | 2000-08-21 | 2001-12-28 | 355d |  | N1 | 8240h | 8240h |  |  | Rel-4 | Frederic |  |  |  |
| 2304 | 68.3.3.1 | Layer 3 LCS signalling UE (MS) -SGSN (UMTS PS and and GSM-GPRS) | 355d | 2000-08-21 A | 2001-12-28 A | 100% | 2000-08-21 | 2001-12-28 | 355d | finish no earlier than 2001-12-28 | N1 | 2840h | 2840h |  | Nokia | Rel-4 | Frederic |  |  | Janne Muhonen |
| 2305 | 68.3.3.2 | MAP impacts of LCS | 160d | 2000-08-21 A | 2001-03-30 A | 100% | 2000-08-21 | 2001-03-30 | 160d | finish no earlier than 2001-03-30 | N4 | 1280h | 1280h |  |  | Rel-4 | Kimmo |  |  |  |
| 2306 | 68.3.3.3 | GTP signalling for LCS | 160d | 2000-08-21 A | 2001-03-30 A | 100% | 2000-08-21 | 2001-03-30 | 160d | finish no earlier than 2001-03-30 | N4 | 1280h | 1280h |  |  | Rel-4 | Kimmo |  |  |  |
| 2307 | 68.4 | **UE positioning Rel-4** | 260d | 2000-04-03 A | 2001-03-30 A | 100% | 2000-04-03 | 2001-03-30 | 260d |  | RP | 4591.2h | 4591.2h | LCS1-UEpos |  | Rel-4 | Issam |  |  |  |
| 2308 | 68.4.1 | Iub/Iur interfaces for methods Rel 99 | 233.9d | 2000-04-03 A | 2001-03-30 A | 100% | 2000-04-03 | 2001-03-30 | 233.9d | finish no earlier than 2001-03-30 | R3 | 1871.2h | 1871.2h | LCS1-UEpos-IubIur | Ericsson | Rel-4 | Juha |  |  | Yun-Chao Hu |
| 2309 | 68.4.2 | UE positioning enhancements - IPDL for TDD | 150d | 2000-08-28 A | 2001-03-23 A | 100% | 2000-08-28 | 2001-03-23 | 150d | finish no earlier than 2001-03-23 | R2 | 1200h | 1200h | LCS1-UEpos-enh | Siemens | Rel-4 | Joern |  |  | M. Beckmann |

Notes:
- 2284: -
- 2285: WI approved in TSG_10
- 2286: -
- 2287: Calls to different emergency services such as ambulance, fire brigade, police, etc. can be routed to respective different emergency centres. / NP-000447 is the stage 3 changes for CS call control protocol.
- 2288: UID changed. Marked as stopped 12/2008
- 2289: -
- 2290: -
- 2291: -
- 2292: -
- 2293: goal not completely achieved because of missing input
- 2294: AS: Rel5 changed to Rel4 according to SP#10 decision, milestone on testing added
- 2295: -
- 2296: -
- 2297: -
- 2298: -
- 2299: Only MAP impact foreseen so far. To be further split if needed.
- 2300: -
- 2301: To be also considered: External LCS client identity, and Privacy options when PDP-context and when no PDP-context is established
- 2302: AS: 23.271 completed at SP#10
- 2303: -
- 2304: -
- 2305: Missing work task
- 2306: -
- 2307: UID changed
- 2308: 27/11: WG corrected; rapporteur corrected
- 2309: 5 Mar 2001: splitting off of IPDL for TDD for Rel-4 agreed by R2

| ID | WBS | Task | Duration | Start | Finish | Complete | Baseline start | Baseline finish | Baseline duration | Constraint | Resources | Work | Actual work | Text1 | Text6 | Text8 | Text3 | Text4 | Text5 | Text12 |
| --- | --- | --- | --- | --- | --- | --- | --- | --- | --- | --- | --- | --- | --- | --- | --- | --- | --- | --- | --- | --- |
| 2310 | 69 | **Rel-4 UICC/(U)SIM enhancements and interworking** | 175d | 2000-07-24 A | 2001-03-23 A | 100% | 2000-07-24 | 2001-03-23 | 175d |  | T3 | 2800h | 2800h | UICC1 | Rel-4 | Xavier |  |  |  |  |
| 2311 | 69.1 | Common PCN Handset Specification (CPHS) | 175d | 2000-07-24 A | 2001-03-23 A | 100% | 2000-07-24 | 2001-03-23 | 175d | finish no earlier than 2001-03-23 | T3 | 1400h | 1400h | UICC1-CPHS | Rel-4 |  | 27.103 | One2One |  |  |
| 2312 | 70 | **Rel-4 (U)SIM toolkit enhancements** | 210d | 2000-06-05 A | 2001-03-23 A | 100% | 2000-06-05 | 2001-03-23 | 210d |  | T3 | 3360h | 3360h | USAT1-LocLnk | Rel-4 | Xavier |  | Gemplus | Jean-Francois Rubon |  |
| 2313 | 70.1 | USAT local link | 210d | 2000-06-05 A | 2001-03-23 A | 100% | 2000-06-05 | 2001-03-23 | 210d | finish no earlier than 2001-03-23 | T3 | 1680h | 1680h | USAT1-LocLnk | Rel-4 | Xavier |  | Gemplus | Jean-Francois Rubon |  |
| 2314 | 71 | **Rel-4 Security enhancements** | 576d | 2000-01-03 A | 2002-03-15 A | 100% | 2000-01-03 | 2002-03-15 | 576d |  | S3 | 24152h | 24152h |  | Rel-4 | Dionisio |  | Vodafone | Peter.Howard@vodafone.com |  |
| 2315 | 71.1 | Evolution of GSM CS algorithms (e.g. A5/3 development and deployment) | 272d | 2000-01-03 A | 2001-01-15 A | 100% | 2000-01-03 | 2001-01-15 | 272d | finish no earlier than 2001-01-15 | S3 | 2168h | 2168h | SEC1-CSALGO1 | Rel-4 | Dionisio |  |  |  |  |
| 2316 | 71.2 | **Evolution of GSM PS algorithms (e.g. GEA 2 deployment)** | 219d | 2000-02-22 A | 2000-12-22 A | 100% | 2000-02-22 | 2000-12-22 | 219d |  | S3 | 6024h | 6024h | SEC1-PSALGO1 | Rel-4 | Dionisio |  |  |  |  |
| 2317 | 71.2.1 | Main aspects | 199d | 2000-02-22 A | 2000-11-24 A | 100% | 2000-02-22 | 2000-11-24 | 199d | finish no earlier than 2000-11-24 | S3 | 1592h | 1592h | SEC1-PSALGO1 | Rel-4 | Dionisio |  |  |  |  |
| 2318 | 71.2.2 | Impact on GTP | 200d | 2000-03-20 A | 2000-12-22 A | 100% | 2000-03-20 | 2000-12-22 | 200d | finish no earlier than 2000-12-22 | N4 | 1600h | 1600h | SEC1-PSALGO1 | Rel-4 | Kimmo |  |  |  |  |
| 2319 | 71.2.3 | GEA capability indication in MS CM | 135d | 2000-06-19 A | 2000-12-22 A | 100% | 2000-06-19 | 2000-12-22 | 135d | finish no earlier than 2000-12-22 | N1 | 1080h | 1080h | SEC1-PSALGO1-GEACAP | Rel-4 | Frederic |  | Vodafone Airtouch | Duncan Mills |  |
| 2320 | 71.3 | **Deleted - MAP application layer security** | 576d | 2000-01-03 A | 2002-03-15 A | 100% | 2000-01-03 | 2002-03-15 | 576d |  | S3 | 11352h | 11352h | SEC1-MAPAL | Rel-4 | Dionisio |  |  |  | SP-15 |
| 2321 | 71.3.1 | Deleted - Main aspects | 199d | 2000-02-21 A | 2001-03-29 A | 100% | 2000-02-21 | 2001-03-29 | 199d | start no earlier than 2000-02-21 | S3 | 1592h | 1592h |  | Rel-4 | Dionisio |  |  |  | SP-11 |
| 2322 | 71.3.2 | Deleted - Other stage 3 aspects | 199d | 2000-02-22 A | 2000-11-24 A | 100% | 2000-02-22 | 2000-11-24 | 199d | finish no earlier than 2000-11-24 | N4 | 1592h | 1592h |  | Rel-4 | Kimmo |  |  |  | CP-10 |
| 2323 | 71.3.3 | Deleted - Visibility and Configurability of security | 576d | 2000-01-03 A | 2002-03-15 A | 100% | 2000-01-03 | 2002-03-15 | 576d | finish no earlier than 2002-03-15 | S3 | 4600h | 4600h | SEC1-VCS | Rel-4 | Dionisio |  | France Telecom | Sebastien.nguyenngoc@rd.francetelecom.com | SP-15 |
| 2324 | 72 | **Rel-4 Charging and OAM&P** | 221d | 2000-12-01 A | 2001-10-05 A | 100% | 2000-12-01 | 2001-10-05 | 221d |  | S5 | 10472h | 10472h | OAM | Rel-4 | Dionisio |  | VoiceStream, Motorola |  |  |
| 2325 | 72.1 | Rel4 Principles, high level Requirements and Architecture | 145d | 2000-12-01 A | 2001-06-21 A | 100% | 2000-12-01 | 2001-06-21 | 145d | finish no earlier than 2001-06-21 | S5 | 1160h | 1160h | OAM-AR/PR | Rel-4 | Dionisio | 32.101, 32.102 | Motorola, Telia | Michael.Truss@MOTOROLA.COM; Tommy.R.Berggren@TELIA.SE |  |
| 2326 | 72.2 | Rel4 Performance Management | 216d | 2000-12-01 A | 2001-09-28 A | 100% | 2000-12-01 | 2001-09-28 | 216d | finish no earlier than 2001-06-21 | S5 | 1728h | 1728h |  | Rel-4 | Dionisio | 32.4xy, 52.402 | T-Mobile | karl-heinz.nenner@t-mobile.de |  |
| 2327 | 72.3 | Fault Management | 221d | 2000-12-01 A | 2001-10-05 A | 100% | 2000-12-01 | 2001-10-05 | 221d | finish no earlier than 2001-06-21 | S5 | 1768h | 1768h |  | Rel-4 | Dionisio | 32.111-1/4 | Lucent |  |  |
| 2328 | 72.4 | Configuration Management | 145d | 2000-12-01 A | 2001-06-21 A | 100% | 2000-12-01 | 2001-06-21 | 145d | finish no earlier than 2001-06-21 | S5 | 1160h | 1160h | OAM-CM | Rel-4 | Dionisio | 32.106-1/8 | Ericsson | thomas.tovinger@ericsson.com |  |
| 2329 | 72.5 | Rel4 Charging Management | 216d | 2000-12-01 A | 2001-09-28 A | 100% | 2000-12-01 | 2001-09-28 | 216d | finish no earlier than 2001-06-21 | S5 | 1728h | 1728h | OAM-CH | Rel-4 | Dionisio | 32.200, 32.205, 32.215, 32.235 | T-Mobile | karl-heinz.nenner@t-mobile.de |  |
| 2330 | 72.6 | UTRAN Operations and Maintenance procedures | 145d | 2000-12-01 A | 2001-06-21 A | 100% | 2000-12-01 | 2001-06-21 | 145d | finish no earlier than 2001-06-21 | S5 | 1160h | 1160h | UOAM | Rel-4 | Dionisio | 32.800 | Mannesmann Mobilfunk | bert.boden@d2mannesmann.de |  |
| 2331 | 73 | **Global Text Telephony** | 2537d? | 2000-01-03 A | 2009-09-18 A | 100% | 2000-01-03 | 2009-09-18 | 2537d? |  | S1,S2,S4,T1,R5 | 44928h | 44928h | GTT | Rel-4 | Maurice |  | Ericsson | gunnar.hellstrom@omnitor.se |  |
| 2332 | 73.1 | Stage 1 | 188d | 2000-04-05 A | 2000-12-22 A | 100% | 2000-04-05 | 2000-12-22 | 188d | finish no earlier than 2000-12-22 | S1 | 1504h | 1504h | GTT | Rel-4 | Alain | 22.976, 22.226 |  |  |  |
| 2333 | 73.2 | Stage 2 | 206d | 2000-01-03 A | 2000-10-13 A | 100% | 2000-01-03 | 2000-10-13 | 206d |  | S2 | 1640h | 1640h | GTT | Rel-4 | Maurice | 23.226 |  |  |  |

Notes:
- 2310: -
- 2311: 28/5/2001: CRs approved at TP-11. WI complete.
- 2312: -
- 2313: 25/5/2001:CR was approved at TP-11. WI is complete
- 2314: Added BB UE authentication and rapporteur added. TO BE DELETED
- 2315: Approved SP#17
- 2316: A5/3 development will consider new GEA algorithm based on Kasumi
- 2317: Complete TSG#09 (09/2000). S3#17: Proposed for deletion. TO BE DELETED
- 2318: -
- 2319: -
- 2320: REPLACED BY NDS-MAP and NDS-IP. Completed Auto Key Management -> Rel-6. Marked as stopped 12/2008
- 2321: UID changed. Marked as stopped 12/2008
- 2322: UID changed. Marked as stopped 12/2008
- 2323: CR approved at SA3#21 awaiting comments from CN1. Marked as stopped 12/2008
- 2324: SP#13 approved WID
- 2325: -
- 2326: -
- 2327: -
- 2328: -
- 2329: -
- 2330: -
- 2331: SP#12 updated WID SP-000162=>SP-010340
- 2332: -
- 2333: -

| ID | WBS | Task | Type | Duration | Start | Finish | Complete | Baseline start | Baseline finish | Baseline duration | Total slack | Constraint | Resources | Work | Actual work | Text1 | Text6 | Text8 | Text9 | Text12 |
| --- | --- | --- | --- | --- | --- | --- | --- | --- | --- | --- | --- | --- | --- | --- | --- | --- | --- | --- | --- | --- |
| 2334 | 73.3 | **Specification of Cellular Text telephone Modem** |  | 136d | 2000-09-11 A | 2001-03-19 A | 100% | 2000-09-11 | 2001-03-19 | 136d |  |  | S4 | 2704h | 2704h | GTT-CTM | Rel-4 | Paolo |  |  |
| 2335 | 73.3.1 | General description and C-code |  | 66d | 2000-09-11 A | 2000-12-11 A | 100% | 2000-09-11 | 2000-12-11 | 66d |  | finish no earlier than 2000-12-11 | S4 | 528h | 528h | GTT-CTM | Rel-4 | Paolo |  |  |
| 2336 | 73.3.2 | Minimum Performance requirements |  | 136d | 2000-09-11 A | 2001-03-19 A | 100% | 2000-09-11 | 2001-03-19 | 136d |  | finish no earlier than 2001-03-19 | S4 | 1088h | 1088h | GTT-CTM | Rel-4 | Paolo |  |  |
| 2337 | 73.5 | Deleted - Conformance Test Aspects - Global Text Telephony |  | 2348d? | 2000-09-21 A | 2009-09-18 A | 100% | 2000-09-21 | 2009-09-18 | 2348d? |  | finish no earlier than 2009-09-18 | R5,T1 | 18784h | 18784h | GTT_Test | Rel-4 | Ingbert | PCG-23 | RP-45 |
| 2338 | 577 | Release 1999 Features | milestone | 0d? | 2000-01-01 | 2000-01-01 |  | 2000-01-01 | 2000-01-01 | 0d? | 3057d |  | NP,SP,TP,SMG |  |  |  | R99 |  |  |  |
| 2339 | 578 | **UMTS Features** |  | 261d? | 1999-01-01 A | 1999-12-31 A | 100% | 1999-01-01 | 1999-12-31 | 261d? |  |  | S1,S2,S4,SMG,N3,N4,RP | 25056h | 25056h |  | R99 |  |  |  |
| 2340 | 578.1 | UMTS_SERVICES |  | 261d? | 1999-01-01 A | 1999-12-31 A | 100% | 1999-01-01 | 1999-12-31 | 261d? |  | start no earlier than 1999-01-01 | S1 | 2088h | 2088h | UMTS_SERVICES | R99 |  |  |  |
| 2341 | 578.2 | UMTS phase 1 |  | 261d? | 1999-01-01 A | 1999-12-31 A | 100% | 1999-01-01 | 1999-12-31 | 261d? |  | start no earlier than 1999-01-01 | S1 | 2088h | 2088h | UMTS1 | R99 |  |  |  |
| 2342 | 578.3 | UMTS Capabilities |  | 261d? | 1999-01-01 A | 1999-12-31 A | 100% | 1999-01-01 | 1999-12-31 | 261d? |  | start no earlier than 1999-01-01 | S1 | 2088h | 2088h | UMTS_Capabil | R99 |  |  |  |
| 2343 | 578.4 | Architecture of the GSM-UMTS platform |  | 261d? | 1999-01-01 A | 1999-12-31 A | 100% | 1999-01-01 | 1999-12-31 | 261d? |  | start no earlier than 1999-01-01 | S2,N4 | 2088h | 2088h |  | R99 |  |  |  |
| 2344 | 578.5 | UMTS Terrestrial Radio Access Network |  | 261d? | 1999-01-01 A | 1999-12-31 A | 100% | 1999-01-01 | 1999-12-31 | 261d? |  | start no earlier than 1999-01-01 | RP | 2088h | 2088h | UTRAN | R99 |  |  |  |
| 2345 | 578.6 | UMTS 1800, UMTS 1900 |  | 261d? | 1999-01-01 A | 1999-12-31 A | 100% | 1999-01-01 | 1999-12-31 | 261d? |  | start no earlier than 1999-01-01 | R2 | 2088h | 2088h | Rlnlmp19, Rlnlmp18 | R99 |  |  |  |
| 2346 | 578.7 | Mandatory speech codec for narrowband telephony service |  | 261d? | 1999-01-01 A | 1999-12-31 A | 100% | 1999-01-01 | 1999-12-31 | 261d? |  | start no earlier than 1999-01-01 | S4 | 2088h | 2088h | Mandatory_Speech_Codec, AMR-NB, AMR | R99 | Paolo |  |  |
| 2347 | 578.8 | Codec for low bitrate multimedia telephony service |  | 261d? | 1999-01-01 A | 1999-12-31 A | 100% | 1999-01-01 | 1999-12-31 | 261d? |  | start no earlier than 1999-01-01 | S4 | 2088h | 2088h | Low_bit_rate_codec_for_MM_Tel., H.324M | R99 | Paolo |  |  |
| 2348 | 578.9 | 3G Audio-Visual Terminal characteristics |  | 261d? | 1999-01-01 A | 1999-12-31 A | 100% | 1999-01-01 | 1999-12-31 | 261d? |  | start no earlier than 1999-01-01 | S4 | 2088h | 2088h | WI5TAC, 3G-AVT, Terminal_Acoustic_Characteristics | R99 |  |  |  |
| 2349 | 578.10 | Updates_for_UMTS |  | 261d? | 1999-01-01 A | 1999-12-31 A | 100% | 1999-01-01 | 1999-12-31 | 261d? |  | start no earlier than 1999-01-01 | N3 | 2088h | 2088h | Updates_for_UMTS | R99 |  |  |  |
| 2350 | 578.11 | UMTS |  | 261d? | 1999-01-01 A | 1999-12-31 A | 100% | 1999-01-01 | 1999-12-31 | 261d? |  | start no earlier than 1999-01-01 | N3 | 2088h | 2088h | UMTS | R99 |  |  |  |
| 2351 | 579 | **UMTS and GSM Features** |  | 261d? | 1999-01-01 A | 1999-12-31 A | 100% | 1999-01-01 | 1999-12-31 | 261d? |  |  | S1,S2,SMG,T2,N1,N2,N3,N4,R2,R3 | 114840h | 114840h |  | R99 |  |  |  |
| 2352 | 579.1 | Multimedia Messaging Service |  | 261d? | 1999-01-01 A | 1999-12-31 A | 100% | 1999-01-01 | 1999-12-31 | 261d? |  | start no earlier than 1999-01-01 | T2 | 2088h | 2088h | MMS | R99 |  |  |  |
| 2353 | 579.2 | Location Services |  | 261d? | 1999-01-01 A | 1999-12-31 A | 100% | 1999-01-01 | 1999-12-31 | 261d? |  | start no earlier than 1999-01-01 | S1,S2,S3,SMG1,SMG2,SMG12,N1,N2,N4,R2,R3 | 2088h | 2088h | LCS | R99 |  |  |  |
| 2354 | 579.3 | **Customised Application for Mobile network Enhanced Logic Phase 3** |  | 261d? | 1999-01-01 A | 1999-12-31 A | 100% | 1999-01-01 | 1999-12-31 | 261d? |  |  | S1,S2,N2,N4 | 6264h | 6264h | CAMEL3 | R99 |  |  |  |
| 2355 | 579.3.1 | Global view |  | 261d? | 1999-01-01 A | 1999-12-31 A | 100% | 1999-01-01 | 1999-12-31 | 261d? |  | start no earlier than 1999-01-01 | S1,S2,N2,N4 | 2088h | 2088h | CAMEL3 | R99 |  |  |  |
| 2356 | 579.3.2 | Multiple Subscriber Profile (MSP) based on CAMEL phase 3 |  | 261d? | 1999-01-01 A | 1999-12-31 A | 100% | 1999-01-01 | 1999-12-31 | 261d? |  | start no earlier than 1999-01-01 | S1 | 2088h | 2088h | CAMEL3 | R99 |  |  |  |
| 2357 | 579.4 | Short Message Service enhancements / Enhanced Messaging Service (EMS) |  | 261d? | 1999-01-01 A | 1999-12-31 A | 100% | 1999-01-01 | 1999-12-31 | 261d? |  | start no earlier than 1999-01-01 | T2 | 2088h | 2088h | EMS | R99 |  |  |  |
| 2358 | 579.5 | Mobile Station Execution Environment |  | 261d? | 1999-01-01 A | 1999-12-31 A | 100% | 1999-01-01 | 1999-12-31 | 261d? |  | start no earlier than 1999-01-01 | S1,SMG1,T2 | 2088h | 2088h | MExE | R99 |  |  |  |
| 2359 | 579.6 | MS_Classmark |  | 261d? | 1999-01-01 A | 1999-12-31 A | 100% | 1999-01-01 | 1999-12-31 | 261d? |  | start no earlier than 1999-01-01 | N1 | 2088h | 2088h | MS_Classmark | R99 |  |  |  |

Notes:
- 2334: -
- 2335: - / Text3: 26.226, 26.230
- 2336: - / Text3: 26.231
- 2337: RP#45 work item abandoned/closed (it was never really started)
- 2338: -
- 2339: -
- 2340: - / Text3: 22.101
- 2341: - / Text3: 22.100
- 2342: Requirement for high quality speech in UMTS Phase 1 but not in R99 / Text3: 22.105
- 2343: wid Architecture overview of the GSM-UMTS System, Architecture the GSM-UMTS Platform and New Access Network to Core Network (BSS-NSS) interface / Text3: 23.002, 23.008, 23.060, 23.101, 23.110
- 2344: - / Text3: 22.011, 22.038, 22.060, 22.078, 22.100, 22.101, 22.105, 22.115, 22.129, 23.002, 23.060, 24.007, 24.008, 25.101, 25.102, 25.104, 25.105, 25.113, 25.123, 25.133, 25.141, 25.142, 25.201, 25.211, 25.212, 25.213, 25.214, 25.215, 25.221, 25.222, 25.223, 25.224,
- 2345: - / Text3: 25.307 CR#0002, 0003 Inclusion of release independent RF related information
- 2346: Define the default speech codec for UMTS (both for FDD and TDD). Definition limited to selection of one codec among several existing ones/proposed codecs: GSM AMR, IS127 EVRC, ITU G.729 and MPEG-4 speech codec. / Text3: 04.08, 05.01, 05.02, 05.03, 05.05, 05.08, 05.09, 05.09, 05.50, 08.60, 08.61, 11.21, 26.071, 26.073, 26.074, 26.090, 26.091, 26.092, 26.093, 26.094, 26.101, 26.102, 26.103, 26.104, 26.975
- 2347: - / Text3: 26.104, 26.110, 26.111, 26.911, 26.912, 26.915
- 2348: - / Text3: 26.131, 26.132
- 2349: - / Text3: 24.022, 27.001, 29.007
- 2350: - / Text3: 27.060, 29.061
- 2351: -
- 2352: MMS allows users to send/receive messages e.g. almost unlimited text length, images, audio and video clips and new content types. R99 only includes the concept. MMS stage 3 is not included in 23.140. Rel-4 adds detailed architecture and protocols. / Text3: 22.140, 23.040, 23.140
- 2353: LCS provide ability to localize a terminal. Location data is used to provide services to end-user (e.g. local map indicating closest restaurants), for emergency services or for a UMTS network entity (RNC to direct beam when space diversity is used) / Text3: 02.07, 03.71, 04.31, 04.35, 04.71, 05.05, 08.08, 08.31, 08.71, 09.31, 22.071, 23.002, 23.003, 23.007, 23.008, 23.016, 23.018, 23.032, 23.171, 24.007, 24.008, 24.030, 24.080, 25.305, 25.306, 25.331, 25.413, 25.423, 29.002, 29.010
- 2354: CAMEL is a network feature providing mechanisms to support services of operators which are not covered by standardised services, even when roaming outside the HPLMN. / Text3: 22.101, 23.008, 23.012, 23.016, 23.018, 23.060, 23.072, 23.078, 23.079, 23.082, 23.093, 29.002, 29.078
- 2355: - / Text3: 22.078, 23.078, 29.078
- 2356: MSP is an optional service enabling mobile subscribers to have several profiles associated with a single IMSI, with each profile being a subscription option. Each profile may be used for mobile originated and mobile terminated calls. / Text3: 22.097 (Advanced Addressing)
- 2357: SMS for 3G terminals compatible with GSM SMS. Added Enhanced Messaging Service (EMS) allowing small pictures, sounds, animations to be transferred via SMS. / Text3: 23.038, 23.039, 23.040, 23.042
- 2358: MExE provides a standardized MS execution environment and ability to negotiate its supported capabilities with a MExE SP. R99 enhances SIM MExE certificate management, security clarifications, QoS and defines two MExE classmarks WAP/Personal-Java based. / Text3: 02.57, 22.057, 22.101, 23.057
- 2359: MExE classmark identifies a category of MExE UE supporting MExE functionality with a minimum level of processing, memory, display, and interactive capabilities. Several MExE classmarks may be defined. / Text3: 24.008

| ID | WBS | Task | Duration | Start | Finish | Complete | Baseline start | Baseline finish | Baseline duration | Constraint | Resources | Work | Actual work | Text1 | Text6 | Text12 |
| --- | --- | --- | --- | --- | --- | --- | --- | --- | --- | --- | --- | --- | --- | --- | --- | --- |
| 2360 | 579.7 | **MultiCall** | 261d? | 1999-01-01 A | 1999-12-31 A | 100% | 1999-01-01 | 1999-12-31 | 261d? |  | S1,N1,N2,N4 | 4176h | 4176h | Multicall | R99 |  |
| 2361 | 579.7.1 | Multicall | 261d? | 1999-01-01 A | 1999-12-31 A | 100% | 1999-01-01 | 1999-12-31 | 261d? | start no earlier than 1999-01-01 | S1 | 2088h | 2088h | Multicall | R99 |  |
| 2362 | 579.8 | Virtual Home Environment | 261d? | 1999-01-01 A | 1999-12-31 A | 100% | 1999-01-01 | 1999-12-31 | 261d? | start no earlier than 1999-01-01 | S1,SMG1,S2 | 2088h | 2088h | VHE | R99 |  |
| 2363 | 579.9 | Open Service Access | 261d? | 1999-01-01 A | 1999-12-31 A | 100% | 1999-01-01 | 1999-12-31 | 261d? | start no earlier than 1999-01-01 | S1,S2,N5 | 2088h | 2088h | OSA | R99 |  |
| 2364 | 579.10 | Super Charger mechanism for signalling traffic associated with mobility | 261d? | 1999-01-01 A | 1999-12-31 A | 100% | 1999-01-01 | 1999-12-31 | 261d? | start no earlier than 1999-01-01 | N2,N4 | 2088h | 2088h | Super_Charger | R99 |  |
| 2365 | 579.11 | Follow_Me service | 261d? | 1999-01-01 A | 1999-12-31 A | 100% | 1999-01-01 | 1999-12-31 | 261d? | start no earlier than 1999-01-01 | S1,N2,N4 | 2088h | 2088h | Follow_Me | R99 |  |
| 2366 | 579.12 | Wide area network Synchronization and object exchange | 261d? | 1999-01-01 A | 1999-12-31 A | 100% | 1999-01-01 | 1999-12-31 | 261d? | start no earlier than 1999-01-01 | T2 | 2088h | 2088h | SYNC | R99 |  |
| 2367 | 579.13 | **Terminal Interfaces** | 261d? | 1999-01-01 A | 1999-12-31 A | 100% | 1999-01-01 | 1999-12-31 | 261d? |  | T2 | 8352h | 8352h |  | R99 |  |
| 2368 | 579.13.1 | AT commands for 3GPP | 261d? | 1999-01-01 A | 1999-12-31 A | 100% | 1999-01-01 | 1999-12-31 | 261d? | start no earlier than 1999-01-01 | T2 | 2088h | 2088h |  | R99 |  |
| 2369 | 579.13.2 | Physical interfaces | 261d? | 1999-01-01 A | 1999-12-31 A | 100% | 1999-01-01 | 1999-12-31 | 261d? | start no earlier than 1999-01-01 | T2 | 2088h | 2088h |  | R99 |  |
| 2370 | 579.13.3 | Multiplexer | 261d? | 1999-01-01 A | 1999-12-31 A | 100% | 1999-01-01 | 1999-12-31 | 261d? | start no earlier than 1999-01-01 | T2 | 2088h | 2088h | MUX MS-TE | R99 |  |
| 2371 | 579.14 | **Bearer Services** | 261d? | 1999-01-01 A | 1999-12-31 A | 100% | 1999-01-01 | 1999-12-31 | 261d? |  | S1,T2,N1,N3 | 27144h | 27144h |  | R99 |  |
| 2372 | 579.14.1 | **Circuit Switched Bearer Services** | 261d? | 1999-01-01 A | 1999-12-31 A | 100% | 1999-01-01 | 1999-12-31 | 261d? |  | S1,N3 | 14616h | 14616h | Circuit_switched_Bearer_Services | R99 |  |
| 2373 | 579.14.1.1 | Circuit Switched Bearer Services | 261d? | 1999-01-01 A | 1999-12-31 A | 100% | 1999-01-01 | 1999-12-31 | 261d? | start no earlier than 1999-01-01 | S1,N3 | 2088h | 2088h | CS_Bearerss_in_UMTS | R99 |  |
| 2374 | 579.14.1.2 | CS_Bearers | 261d? | 1999-01-01 A | 1999-12-31 A | 100% | 1999-01-01 | 1999-12-31 | 261d? | start no earlier than 1999-01-01 | N3 | 2088h | 2088h | CS_Bearers | R99 |  |
| 2375 | 579.14.1.3 | CS_Bearerss | 261d? | 1999-01-01 A | 1999-12-31 A | 100% | 1999-01-01 | 1999-12-31 | 261d? | start no earlier than 1999-01-01 | N3 | 2088h | 2088h | CS_Bearerss | R99 |  |
| 2376 | 579.14.1.4 | CS_Data | 261d? | 1999-01-01 A | 1999-12-31 A | 100% | 1999-01-01 | 1999-12-31 | 261d? | start no earlier than 1999-01-01 | N3 | 2088h | 2088h | CS_Data | R99 |  |
| 2377 | 579.14.1.5 | CS_Data_Bearers | 261d? | 1999-01-01 A | 1999-12-31 A | 100% | 1999-01-01 | 1999-12-31 | 261d? | start no earlier than 1999-01-01 | N3 | 2088h | 2088h | CS_Data_Bearers | R99 |  |
| 2378 | 579.14.1.6 | Deleted - Circuit Switched Bearer Services | 261d? | 1999-01-01 A | 1999-12-31 A | 100% | 1999-01-01 | 1999-12-31 | 261d? | start no earlier than 1999-01-01 | N3 | 2088h | 2088h | CSBS | R99 | NP-06 |
| 2379 | 579.14.2 | Frame Tunnelling Mode | 261d? | 1999-01-01 A | 1999-12-31 A | 100% | 1999-01-01 | 1999-12-31 | 261d? | start no earlier than 1999-01-01 | T2,N1,N3 | 2088h | 2088h | FTM | R99 |  |
| 2380 | 579.14.3 | Access to ISPs and Intranets – Wireless/Remote access to LANs | 261d? | 1999-01-01 A | 1999-12-31 A | 100% | 1999-01-01 | 1999-12-31 | 261d? | start no earlier than 1999-01-01 | N3 | 2088h | 2088h | Interworking with PDN (DHCP) | R99 |  |
| 2381 | 579.14.4 | **PHS Internet Access Forum Specification** | 261d? | 1999-01-01 A | 1999-12-31 A | 100% | 1999-01-01 | 1999-12-31 | 261d? |  | S1,N3 | 6264h | 6264h | PIAFS | R99 |  |
| 2382 | 579.14.4.1 | Personal Handyphone System Internet Access Forum Standard (PIAFS) | 261d? | 1999-01-01 A | 1999-12-31 A | 100% | 1999-01-01 | 1999-12-31 | 261d? | start no earlier than 1999-01-01 | S1 | 2088h | 2088h | PIAFS | R99 |  |
| 2383 | 579.14.4.2 | Support_of_PIAFS_in_UMTS | 261d? | 1999-01-01 A | 1999-12-31 A | 100% | 1999-01-01 | 1999-12-31 | 261d? | start no earlier than 1999-01-01 | N3 | 2088h | 2088h | Support_of_PIAFS_in_UMTS | R99 |  |

Notes:
- 2360: Multicall allows several simultaneous CS calls with dedicated bearers of independent traffic and performance characteristics. R99 Multicall was defined as a supplementary service limited to one CS bearer to be used for speech at any time. / Text3: 22.030, 22.083, 22.087, 23.008, 23.009, 23.016, 23.018, 23.108, 23.135, 24.008, 24.080, 24.135, 29.002, 29.010
- 2361: - / Text3: 22.030, 22.083, 22.087
- 2362: Information exists in SP#5-8 reports & in SP-99416,SP-000095,SP 000155. OSA allows service development by operators and 3rd parties by making use of network functionality through open, standardised, secure, extensible and scalable interfaces. / Text3: 02.01, 22.105, 22.121,23.127
- 2363: Open Service Architecture became in later Releases Open Service Access. Produced by Parlay, ETSI SPAN (TISPAN), 3GPP SA1 (Stage 1), SA2 (Stage 2) and CN5 (Stage 3), resulting in a single set of standard OSA APIs for the whole development community. / Text3: 22.121, 23.127, 29.198, 29.998
- 2364: Super Charger reduces mobility management cost by reducing the volume of location update signalling. It changes subscriber data management associated with inter-VLR and SGSN location updates. It also applies to packet services (SGSN replaces VLR and … / Text3: 21.905, 23.007, 23.008, 23.012, 23.016, 23.018, 23.040, 23.060, 23.116, 23.912, 29.002
- 2365: Follow Me enables a mobile subscriber A to manipulate the Follow Me data of a party B in such a way that - under certain conditions - subsequent calls directed to party B will be forwarded to subscriber A. It is PLMN-specific and control based on USSD / Text3: 21.905, 22.004, 22.030, 22.082, 22.090, 22.094, 23.090, 24.090, 22.094, 23.011, 23.015, 23.082, 29.002
- 2366: Allows data stored in ME/USIM to be synchronized with the outside world. TS 27.103 defines protocols based upon IrMC level 4 and will evaluate new technologies (XML) for inclusion. From Rel-4 IrMC was replaced by SyncML in 27.103. / Text3: 27.103, 27.903
- 2367: -
- 2368: AT commands to control a 3G ME via an external Terminal Equipment (TE), fully compatible with GSM AT commands. R99 adds new AT commands e.g. to control Advanced Speech Call Items (ASCI) services. / Text3: 27.005, 27.007
- 2369: Conclusion: 3GPP should not produce any technical specification for terminal interfaces other than radio interface and USIM interface. SDOs could develop own optional physical connector specification based on market requirements / Text3: 27.901
- 2370: Multiplexing protocol allowing a number of simultaneous sessions between a MS and a terminal; used to send any data (voice, SMS, USSD, fax etc.). 27.010 describes the protocol, but not the commands or data transported with it. / Text3: 27.010
- 2371: -
- 2372: CS and real-time data services provided for interworking with PSTN/ISDN so that user is unaware of access network used (UMTS, GSM or handover between ANs). Transparent(constant delay) & non-transparent(zero error with flow control) services are supported / Text3: 22.002, 23.910, 27.001, 29.007
- 2373: CS and real-time data services provided for interworking with PSTN/ISDN so that user is unaware of access network used (UMTS, GSM or handover between ANs). Transparent(constant delay) & non-transparent(zero error with flow control) services are supported / Text3: 22.002, 23.910, 27.001, 29.007
- 2374: - / Text3: 29.007
- 2375: - / Text3: 04.21, 23.910, 27.001, 29.007
- 2376: - / Text3: 27.001, 27.002, 27.003, 29.007
- 2377: - / Text3: 23.910, 27.001, 29.007
- 2378: No CR or new TS/TR approved under this WI / Text3: 29.007
- 2379: FTM is a type of async non-transparent CS bearer service (22.002). Generic term for HDLC and HDLC-related transmission protocols. Converts async non-transp data stream towards mobile side & sync data stream using X.31 flag stuffing on fixed network side. / Text3: 22.002, 27.001, 27.007, 29.007
- 2380: Access to an Intranet or ISP by running DHCP between the TE and a server in the Intranet/ISP domain. / Text3: 29.061
- 2381: PIAFS is one type of CS bearer data service (22.002). It refers to async CS tx protocol over ISDN 64 kbit/s unrestricted digital line. Facilitates interworking between PHS-MS and UMTS-UE & UMTS-UE and existing PIAFS TA (Terminal Adapter). / Text3: 22.002, 27.001, 27.007, 29.007
- 2382: PIAFS was originally standardised by the PHS Internet Access Forum in Japan. More information can be found at: http://www.infopro.or.jp/piaf / Text3: 22.002
- 2383: - / Text3: 27.001, 27.007, 29.007

| ID | WBS | Task | Duration | Start | Finish | Complete | Baseline start | Baseline finish | Baseline duration | Constraint | Resources | Work | Actual work | Text1 | Text6 | Text12 |
| --- | --- | --- | --- | --- | --- | --- | --- | --- | --- | --- | --- | --- | --- | --- | --- | --- |
| 2384 | 579.15 | **Universal Integrated Circuit Card (UICC) and Universal Subscriber Identity Module (USIM)** | 261d? | 1999-01-01 A | 1999-12-31 A | 100% | 1999-01-01 | 1999-12-31 | 261d? |  | T3 | 27144h | 27144h | UICC, USIM | R99 |  |
| 2385 | 579.15.1 | UICC / Terminal interface; Physical and logical characteristics | 261d? | 1999-01-01 A | 1999-12-31 A | 100% | 1999-01-01 | 1999-12-31 | 261d? | start no earlier than 1999-01-01 | T3 | 2088h | 2088h | UICC | R99 |  |
| 2386 | 579.15.2 | UICC/(U)SIM enhancements and interworking | 261d? | 1999-01-01 A | 1999-12-31 A | 100% | 1999-01-01 | 1999-12-31 | 261d? | start no earlier than 1999-01-01 | T3 | 2088h | 2088h | UICC1 | R99 |  |
| 2387 | 579.15.3 | Characteristics of the USIM application | 261d? | 1999-01-01 A | 1999-12-31 A | 100% | 1999-01-01 | 1999-12-31 | 261d? | start no earlier than 1999-01-01 | T3 | 2088h | 2088h | USIM | R99 |  |
| 2388 | 579.15.4 | UICC Application Identifiers | 261d? | 1999-01-01 A | 1999-12-31 A | 100% | 1999-01-01 | 1999-12-31 | 261d? | start no earlier than 1999-01-01 | T3 | 2088h | 2088h | AID, Application_Identifiers | R99 |  |
| 2389 | 579.15.5 | SIM Application Toolkit | 261d? | 1999-01-01 A | 1999-12-31 A | 100% | 1999-01-01 | 1999-12-31 | 261d? | start no earlier than 1999-01-01 | S1,T3 | 2088h | 2088h | SAT | R99 |  |
| 2390 | 579.15.6 | USIM Application Toolkit | 261d? | 1999-01-01 A | 1999-12-31 A | 100% | 1999-01-01 | 1999-12-31 | 261d? | start no earlier than 1999-01-01 | T3 | 2088h | 2088h | USAT | R99 |  |
| 2391 | 579.15.7 | Bearer Independent Protocol for SAT applications to exchange data over the GSM network | 261d? | 1999-01-01 A | 1999-12-31 A | 100% | 1999-01-01 | 1999-12-31 | 261d? | start no earlier than 1999-01-01 | T3 | 2088h | 2088h | BIP | R99 |  |
| 2392 | 579.15.8 | Administrative commands and functions for IC cards | 261d? | 1999-01-01 A | 1999-12-31 A | 100% | 1999-01-01 | 1999-12-31 | 261d? | start no earlier than 1999-01-01 | T3 | 2088h | 2088h |  | R99 |  |
| 2393 | 579.15.9 | USIM and UICC requirements | 261d? | 1999-01-01 A | 1999-12-31 A | 100% | 1999-01-01 | 1999-12-31 | 261d? | start no earlier than 1999-01-01 | T3 | 2088h | 2088h |  | R99 |  |
| 2394 | 579.15.10 | SIM_API | 261d? | 1999-01-01 A | 1999-12-31 A | 100% | 1999-01-01 | 1999-12-31 | 261d? | start no earlier than 1999-01-01 | T3 | 2088h | 2088h | SIM_API | R99 |  |
| 2395 | 579.15.11 | SIM_toolkit_API | 261d? | 1999-01-01 A | 1999-12-31 A | 100% | 1999-01-01 | 1999-12-31 | 261d? | start no earlier than 1999-01-01 | SMG9,T3 | 2088h | 2088h | SIM_toolkit | R99 |  |
| 2396 | 579.15.12 | Deleted - 1.8 Volt SIM ME interface | 261d? | 1999-01-01 A | 1999-12-31 A | 100% | 1999-01-01 | 1999-12-31 | 261d? | start no earlier than 1999-01-01 | SMG9 | 2088h | 2088h | SMIME_1.8V | R99 | TP-06 |
| 2397 | 579.16 | **USIM/UICC Testing** | 261d? | 1999-01-01 A | 1999-12-31 A | 100% | 1999-01-01 | 1999-12-31 | 261d? |  | T3 | 10440h | 10440h |  | R99 |  |
| 2398 | 579.16.1 | Terminal tests for the UICC Interface | 261d? | 1999-01-01 A | 1999-12-31 A | 100% | 1999-01-01 | 1999-12-31 | 261d? | start no earlier than 1999-01-01 | T3 | 2088h | 2088h |  | R99 |  |
| 2399 | 579.16.2 | USIM application test specification | 261d? | 1999-01-01 A | 1999-12-31 A | 100% | 1999-01-01 | 1999-12-31 | 261d? | start no earlier than 1999-01-01 | T3 | 2088h | 2088h |  | R99 |  |
| 2400 | 579.16.3 | USIM conformance test specification | 261d? | 1999-01-01 A | 1999-12-31 A | 100% | 1999-01-01 | 1999-12-31 | 261d? | start no earlier than 1999-01-01 | T3 | 2088h | 2088h |  | R99 |  |
| 2401 | 579.16.4 | SIM toolkit test specification | 261d? | 1999-01-01 A | 1999-12-31 A | 100% | 1999-01-01 | 1999-12-31 | 261d? | start no earlier than 1999-01-01 | T3 | 2088h | 2088h |  | R99 |  |
| 2402 | 579.17 | **Security** | 261d? | 1999-01-01 A | 1999-12-31 A | 100% | 1999-01-01 | 1999-12-31 | 261d? |  | S3,N2,N4 | 8352h | 8352h | Security | R99 |  |
| 2403 | 579.17.1 | Fraud Information Gathering Service (for connection-orientated services) | 261d? | 1999-01-01 A | 1999-12-31 A | 100% | 1999-01-01 | 1999-12-31 | 261d? | start no earlier than 1999-01-01 | S3 | 2088h | 2088h | FIGS | R99 |  |
| 2404 | 579.17.2 | Immediate Service Termination / SECurity Immediate Service Termination | 261d? | 1999-01-01 A | 1999-12-31 A | 100% | 1999-01-01 | 1999-12-31 | 261d? | start no earlier than 1999-01-01 | S3,N2,N4 | 2088h | 2088h | IST, SECIST | R99 |  |
| 2405 | 579.17.3 | Core_Network_Security | 261d? | 1999-01-01 A | 1999-12-31 A | 100% | 1999-01-01 | 1999-12-31 | 261d? | start no earlier than 1999-01-01 | N4 | 2088h | 2088h | Core_Network_Security | R99 |  |
| 2406 | 580 | **GSM Features** | 261d? | 1999-01-01 A | 1999-12-31 A | 100% | 1999-01-01 | 1999-12-31 | 261d? |  | S1,S2,SMG,T2,N1,N2,N3,N4 | 50112h | 50112h |  | R99 |  |
| 2407 | 580.1 | **Dual Transfer Mode within GSM and GPRS** | 261d? | 1999-01-01 A | 1999-12-31 A | 100% | 1999-01-01 | 1999-12-31 | 261d? |  | SMG,N1 | 6264h | 6264h | DTM | R99 |  |
| 2408 | 580.1.1 | Class A Dual Transfer Mode | 261d? | 1999-01-01 A | 1999-12-31 A | 100% | 1999-01-01 | 1999-12-31 | 261d? | start no earlier than 1999-01-01 | SMG | 2088h | 2088h | Class_A_Dual_Transfer_Mode_(DTM) | R99 |  |
| 2409 | 580.1.2 | Dual Transfer Mode | 261d? | 1999-01-01 A | 1999-12-31 A | 100% | 1999-01-01 | 1999-12-31 | 261d? | start no earlier than 1999-01-01 | SMG,N1 | 2088h | 2088h | DTM | R99 |  |

Notes:
- 2384: For 3G, GSM 11.11 was divided into two parts: a platform comprised of basic physical, electrical and logical specification (31.101) and an application specification (31.102)
- 2385: Defines a generic Terminal/Integrated Circuit Card (ICC) interface. Is independent of 3G USIM application => platform for any IC card application. Ensures interoperability between ICC and terminal independently of manufacturer, card issuer or operator. / Text3: 31.101 (Since 10/2000, ETSI EP SCP is responsible for the generic Terminal/Integrated Circuit Card (ICC) interface TS 102 221)
- 2386: - / Text3: 31.102, 31.900
- 2387: Defines Universal Subscriber Identity Module (USIM) application for 3G telecom network operation & resides on UICC, an IC card specified in 31.101. UICC can be used as a multi-application card: several USIMs and/or other applications can co-exist / Text3: 31.102
- 2388: Defines and administers Application IDentifiers (AID) for UICC. AID is used to address an application in the card. Consists of Registered application provider ID (RID) & Proprietary application ID exception (PIX - according to ISO/IEC 7816-5). / Text3: 21.111, 31.110
- 2389: - / Text3: 11.14, 22.030, 22.100, 22.101
- 2390: Defines UICC - ME interface, and mandatory ME procedures for USAT. Based on GSM 11.14 (SIM Application Toolkit). Commands and procedures defined in USIM and 3G Terminal for using USAT. Service and security requirements defined in 22.100 and 22.101. / Text3: 31.111
- 2391: Defines at SIM-ME interface a basic protocol allowing SIM Toolkit applications to determine available bearers and to exchange data by selecting using the most appropriate bearer available (CS data, GPRS, SMS, Unstructured Supplementary Service Data (USSD) / Text3: 03.48, 11.10, 11.14
- 2392: Defines function and syntax of administrative commands for telecommunication IC Card used during installation, activation and de-activation of applications. Compliant to ISO/IEC 7816 series. Handed over to ETSI Project Smart Card Platform (SCP) in 2000. / Text3: ETSI TS 102 222
- 2393: High level requirements for 3GPP IC card and its interface to 3GPP terminal (USIM&UICC reqs). Service&security reqs in 322.01,22.00. USIM is a 3GPP application on an IC card. Inter-operates with 3GPP terminals and provides access to 3GPP services / Text3: 21.111
- 2394: - / Text3: 03.19
- 2395: - / Text3: 03.48, 11.11, 11.14
- 2396: No CR or new TS/TR approved under this WI / Text3: 11.18
- 2397: -
- 2398: Test spec for the interface between UICC and terminal (originally based GSM 11.10-1 clause 27). Ensures UICC - terminal interoperability independently of manufacturer, card issuer or operator. Tests for applications residing on UICC are in 31.121 / Text3: 31.120
- 2399: Application test spec originally based on GSM 11.17. Aspects related to UICC administrative management phase are not defined. Any internal technical realisation of either UICC or terminal is only specified where these are reflected over the interface. / Text3: 31.121
- 2400: Conformance Test specification for UICC defined in 31.101 with USIM defined in 31.102. / Text3: 31.122
- 2401: SIM Application Toolkit (SAT) has major impact on ME design and enhances SIM/ME interface. Contains tests for SIM/ME interface optional features (no network related signalling issues involved). Doesn't form basis for any type approval or regulatory tests. / Text3: 11.10-4
- 2402: - / Text3: 02.09, 03.20, 21.133, 22.022, 23.003, 23.007, 23.008, 23.012, 23.018, 24.007, 24.008, 24.010, 24.011, 29.002, 29.060, 33.102, 33.103, 33.105, 33.107, 35.201
- 2403: HPLMN can monitor its subscribers in VPLMN, which collects info on a defined set of monitored subscribers activities & sends it to HPLMN, which can perform service limitation control eg Operator Determined Barring (ODB) and IST to limit financial exposure / Text3: 22.031, 23.031
- 2404: HPLMN can terminate all activities of its subscriber in VPLMN, if decides (based on info via eg FIGS) that a roaming subscriber is behaving in fraudulent/suspicious way. HPLMN can terminate all subscriber activities including calls in progress. / Text3: 03.35, 22.032, 23.008, 23.016, 23.035, 29.002
- 2405: - / Text3: 29.002
- 2406: -
- 2407: WID on BSS co-ordination of Radio Resource allocation for class A GPRS services - GSM Radio Access (R99) / Text3: 03.55, 03.64, 04.18, 04.60, 05.01, 05.02, 05.08, 08.08, 23.060, 24.007, 24.008
- 2408: - / Text3: 05.10
- 2409: - / Text3: 03.55, 03.64, 04.18, 05.01, 05.02, 05.08, 24.008

| ID | WBS | Task | Duration | Start | Finish | Complete | Baseline start | Baseline finish | Baseline duration | Constraint | Resources | Work | Actual work | Text1 | Text6 | Text12 |
| --- | --- | --- | --- | --- | --- | --- | --- | --- | --- | --- | --- | --- | --- | --- | --- | --- |
| 2410 | 580.2 | **General Packet Radio Service enahancements** | 261d? | 1999-01-01 A | 1999-12-31 A | 100% | 1999-01-01 | 1999-12-31 | 261d? |  | S1,S2,SMG1,SMG2,SMG7,N1,N2,N3,N4,T2 | 8352h | 8352h | GPRS enhancements | R99 |  |
| 2411 | 580.2.1 | General Packet Radio Service | 261d? | 1999-01-01 A | 1999-12-31 A | 100% | 1999-01-01 | 1999-12-31 | 261d? | start no earlier than 1999-01-01 | S1,S2,SMG1,SMG2,SMG7,N1,N2,N3,N4,T2 | 2088h | 2088h | GPRS | R99 |  |
| 2412 | 580.2.2 | GPRS2 | 261d? | 1999-01-01 A | 1999-12-31 A | 100% | 1999-01-01 | 1999-12-31 | 261d? | start no earlier than 1999-01-01 | SMG1,N2 | 2088h | 2088h | GPRS2 | R99 |  |
| 2413 | 580.2.3 | GPRS Tunnelling Protocol enhancement | 261d? | 1999-01-01 A | 1999-12-31 A | 100% | 1999-01-01 | 1999-12-31 | 261d? | start no earlier than 1999-01-01 | N4,N2 | 2088h | 2088h | GTP_enhancement | R99 |  |
| 2414 | 580.3 | **Enhanced Data rates for GSM Evolution - Phase 1** | 261d? | 1999-01-01 A | 1999-12-31 A | 100% | 1999-01-01 | 1999-12-31 | 261d? |  | SMG2,SMG1,SMG3,SMG4,SMG7,SMG9,SMG10,N1,N3,T2 | 25056h | 25056h | EDGE - Phase 1 | R99 |  |
| 2415 | 580.3.1 | Enhanced Data rates for GSM Evolution | 261d? | 1999-01-01 A | 1999-12-31 A | 100% | 1999-01-01 | 1999-12-31 | 261d? | start no earlier than 1999-01-01 | SMG2,SMG1,SMG3,SMG4,SMG7,SMG9,SMG10,N1,N3,T2 | 2088h | 2088h | EDGE | R99 |  |
| 2416 | 580.3.2 | EDGE-Layer1 | 261d? | 1999-01-01 A | 1999-12-31 A | 100% | 1999-01-01 | 1999-12-31 | 261d? | start no earlier than 1999-01-01 | SMG2 | 2088h | 2088h | EDGE-Layer1 | R99 |  |
| 2417 | 580.3.3 | High Speed Circuit Switched Data | 261d? | 1999-01-01 A | 1999-12-31 A | 100% | 1999-01-01 | 1999-12-31 | 261d? | start no earlier than 1999-01-01 | SMG1,SMG2,SMG7 | 2088h | 2088h | HSCSD | R99 |  |
| 2418 | 580.3.4 | Enhanced Circuit Switched Data - Phase 1 | 261d? | 1999-01-01 A | 1999-12-31 A | 100% | 1999-01-01 | 1999-12-31 | 261d? | start no earlier than 1999-01-01 | S1,SMG | 2088h | 2088h | ECSD | R99 |  |
| 2419 | 580.3.5 | EDGE-Enhanced Circuit Switched Data | 261d? | 1999-01-01 A | 1999-12-31 A | 100% | 1999-01-01 | 1999-12-31 | 261d? | start no earlier than 1999-01-01 | SMG2 | 2088h | 2088h | EDGE-ECSD | R99 |  |
| 2420 | 580.3.6 | Enhanced GPRS - Phase 1 | 261d? | 1999-01-01 A | 1999-12-31 A | 100% | 1999-01-01 | 1999-12-31 | 261d? | start no earlier than 1999-01-01 | SMG,N1 | 2088h | 2088h | EGPRS | R99 |  |
| 2421 | 580.3.7 | EDGE-EGPRS | 261d? | 1999-01-01 A | 1999-12-31 A | 100% | 1999-01-01 | 1999-12-31 | 261d? | start no earlier than 1999-01-01 | SMG2 | 2088h | 2088h | EDGE-EGPRS | R99 |  |
| 2422 | 580.3.8 | Packet Flow Context (PFC) | 261d? | 1999-01-01 A | 1999-12-31 A | 100% | 1999-01-01 | 1999-12-31 | 261d? | start no earlier than 1999-01-01 | SMG2 | 2088h | 2088h | PFC | R99 |  |
| 2423 | 580.3.9 | Support for EGPRS in ANSI-136 networks and EDGE COMPACT | 261d? | 1999-01-01 A | 1999-12-31 A | 100% | 1999-01-01 | 1999-12-31 | 261d? | start no earlier than 1999-01-01 | SMG | 2088h | 2088h | EDGE-Compact | R99 |  |
| 2424 | 580.3.10 | EGPRS COMPACT | 261d? | 1999-01-01 A | 1999-12-31 A | 100% | 1999-01-01 | 1999-12-31 | 261d? | start no earlier than 1999-01-01 | SMG | 2088h | 2088h | EGPRS-Compact | R99 |  |
| 2425 | 580.3.11 | COMPACT | 261d? | 1999-01-01 A | 1999-12-31 A | 100% | 1999-01-01 | 1999-12-31 | 261d? | start no earlier than 1999-01-01 | SMG,N1 | 2088h | 2088h | COMPACT | R99 |  |
| 2426 | 580.4 | GSM_400 | 261d? | 1999-01-01 A | 1999-12-31 A | 100% | 1999-01-01 | 1999-12-31 | 261d? | start no earlier than 1999-01-01 | SMG2,SMG7,T2 | 2088h | 2088h | GSM_400 | R99 |  |
| 2427 | 580.5 | GSM_450 | 261d? | 1999-01-01 A | 1999-12-31 A | 100% | 1999-01-01 | 1999-12-31 | 261d? | start no earlier than 1999-01-01 | SMG2 | 2088h | 2088h | GSM_450 | R99 |  |
| 2428 | 580.6 | GSM_700 | 261d? | 1999-01-01 A | 1999-12-31 A | 100% | 1999-01-01 | 1999-12-31 | 261d? | start no earlier than 1999-01-01 | SMG2 | 2088h | 2088h | GSM_700 | R99 |  |
| 2429 | 580.7 | Deleted - GERAN | 261d? | 1999-01-01 A | 1999-12-31 A | 100% | 1999-01-01 | 1999-12-31 | 261d? | start no earlier than 1999-01-01 | SMG2,S2 | 2088h | 2088h | GERAN | R99 | SP-06 |
| 2430 | 581 | **GSM Features transposed to UMTS** | 261d? | 1999-01-01 A | 1999-12-31 A | 100% | 1999-01-01 | 1999-12-31 | 261d? |  | S1,S3,T2,N2,N4 | 16704h | 16704h |  | R99 |  |
| 2431 | 581.1 | Cell Broadcast Service | 261d? | 1999-01-01 A | 1999-12-31 A | 100% | 1999-01-01 | 1999-12-31 | 261d? | start no earlier than 1999-01-01 | T2 | 2088h | 2088h | CBS | R99 |  |
| 2432 | 581.2 | **GSM mobile number portability euro MNP / North American MNP** | 261d? | 1999-01-01 A | 1999-12-31 A | 100% | 1999-01-01 | 1999-12-31 | 261d? |  | S1,N2,N4 | 4176h | 4176h | MNP | R99 |  |
| 2433 | 581.2.1 | Mobile Number Portability | 261d? | 1999-01-01 A | 1999-12-31 A | 100% | 1999-01-01 | 1999-12-31 | 261d? | start no earlier than 1999-01-01 | N2,N4 | 2088h | 2088h | MNP | R99 |  |
| 2434 | 581.3 | Automatic establishment of roaming relations | 261d? | 1999-01-01 A | 1999-12-31 A | 100% | 1999-01-01 | 1999-12-31 | 261d? | start no earlier than 1999-01-01 | S1 | 2088h | 2088h |  | R99 |  |
| 2435 | 581.4 | Advanced addressing | 261d? | 1999-01-01 A | 1999-12-31 A | 100% | 1999-01-01 | 1999-12-31 | 261d? | start no earlier than 1999-01-01 | S1 | 2088h | 2088h |  | R99 |  |
| 2436 | 581.5 | UMTS numbering, addressing and identities | 261d? | 1999-01-01 A | 1999-12-31 A | 100% | 1999-01-01 | 1999-12-31 | 261d? | start no earlier than 1999-01-01 | S1 | 2088h | 2088h |  | R99 |  |
| 2437 | 581.6 | Lawful Interception | 261d? | 1999-01-01 A | 1999-12-31 A | 100% | 1999-01-01 | 1999-12-31 | 261d? | start no earlier than 1999-01-01 | S3 | 2088h | 2088h | LI | R99 |  |

Notes:
- 2410: GPRS was introduced in Release 97. Release 99 brings a number of essential corrections e.g. on Downlink Power Control, Timing Advance procedure, Cell reselection delay time, PBCCH scheduling, PTCCH mapping, etc. / Text3: 05.02, 05.05, 05.08, 05.10, 05.50, 11.21, 23.064, 24.008, 24.060
- 2411: - / Text3: 02.60, 03.22, 03.64, 04.18, 04.60, 04.64, 04.65, 05.01, 05.02, 05.05, 05.08, 05.10, 08.08, 08.18, 11.10-1, 11.21, 22.041, 22.060, 23.003, 23.007, 23.060, 23.107, 23.122, 24.007, 24.008, 27.007, 27.060, 29.002, 29.016, 29.018, 29.060, 29.061
- 2412: Introduction of EGPRS (S1) + Introduction of Reserved Service Labels in the APN (N2) / Text3: 02.60, 23.003
- 2413: - / Text3: 23.003, 23.008, 29.060
- 2414: EDGE is independent of the frequency bands, so it can be deployed e.g. in 900 and 1900 MHz bands. The new physical layer based on 8-PSK modulation is introduced and EGPRS and ECSD facilitate the new modulation in single and multi slot constellation. / Text3: 10.59, 02.34, 02.60, 03.30, 05.10, 05.50, 11.26
- 2415: - / Text3: 02.34, 03.10, 03.20, 03.64, 04.03, 04.04, 04.06, 04.08, 04.18, 04.21, 04.22, 04.60, 04.64, 05.01, 05.02, 05.03, 05.04, 05.05, 05.08, 05.10, 05.50, 07.01, 07.02, 07.03, 08.08, 08.20, 08.58, 08.60, 09.07, 09.18, 11.10-1, 11.11, 11.21, 11.26, 23.034, 24.008,
- 2416: - / Text3: 05.05, 05.10, 05.50
- 2417: No additional features for R99. / Text3: 02.34, 04.18, 11.10-1
- 2418: ECSD supports both transparent and non-transparent services, up to 64 kbit/s and 57.6 kbit/s respectively. See Tdoc SMG2 670/99 ECSD Concept Evaluation for more info / Text3: 05.02, 08.58, 22.034
- 2419: - / Text3: 05.03
- 2420: - / Text3: 02.07, 03.64, 04.14, 04.18, 04.60, 05.05, 05.08, 24.008
- 2421: - / Text3: 05.03, 05.05, 05.08
- 2422: - / Text3: 04.18
- 2423: Support for EGPRS in ANSI-136 networks and EDGE Compact (for ANSI-136 networks only). COMPACT = Deployment of services in spectrum below 1 MHz / Text3: 03.22, 03.30, 03.64, 05.01, 05.02, 05.03, 05.05, 05.08, 05.10
- 2424: COMPACT = Deployment of services in spectrum below 1 MHz / Text3: 04.18, 05.02
- 2425: COMPACT = Deployment of services in spectrum below 1 MHz / Text3: 03.22, 04.18, 04.60, 05.08, 23.122, 24.008
- 2426: - / Text3: 02.17, 03.22, 03.30, 04.04, 04.18, 04.60, 05.01, 05.02, 05.05, 05.08, 05.10, 05.50, 08.18, 08.58, 11.21, 24.008, 27.007 / Text8: GSM in the 400 MHz bands allows to deploy GSM within frequency bands in the range 450 to 500 MHz, previously used for analogue cellular systems. See Tdoc SMG2 190/99 and 595/99 for further info.
- 2427: - / Text3: 03.22, 03.30, 05.01, 05.05, 05.08
- 2428: - / Text3: 05.05
- 2429: No CR or new TS/TR approved under this WI / Text3: G2: 04.18 CR#A248 , 04.60 CR#B090
- 2430: -
- 2431: Moved to CT1 at TSG-T closure. Applicability of the Cell Broadcast Service (as defined for GSM network) to 3G networks / Text3: 23.041
- 2432: R98 MNP: mobile subscriber ability to change PLMN operator within the same country whilst retaining its original MS ISDN number (MSISDN). IMSI is changed, only MSISDN is kept. R99 adds requirements for North American Service Provider Number Portability. / Text3: 22.066
- 2433: - / Text3: 23.018, 23.066, 29.002
- 2434: framework for commercial and technical interworking between UMTS Home Environments and Serving Networks who have no direct prior commercial agreements with each other. / Text3: 22.101, 22.971
- 2435: - / Text3: 22.101, 22.75U, 22.975
- 2436: Also new requirements for Single and Multiple Numbering scheme was added (CR#20 and 21). Deleted the term International Mobile User Identifier (IMUI) and changed IMSI (International Mobile Station Identifier=>International Mobile Subscriber Identity. / Text3: 22.101
- 2437: Defines an interception system in UMTS that supports a number of regional interception regulations. Regional interception requirements shall be met in using specific (regional) mediation functions allowing only required information to be transported. / Text3: 33.106, 33.107

| ID | WBS | Task | Duration | Start | Finish | Complete | Baseline start | Baseline finish | Baseline duration | Constraint | Resources | Work | Actual work | Text1 | Text6 |
| --- | --- | --- | --- | --- | --- | --- | --- | --- | --- | --- | --- | --- | --- | --- | --- |
| 2438 | 582 | **Charging** | 261d? | 1999-01-01 A | 1999-12-31 A | 100% | 1999-01-01 | 1999-12-31 | 261d? |  | S1,S5 | 6264h | 6264h | CH | R99 |
| 2439 | 582.1 | Charging | 261d? | 1999-01-01 A | 1999-12-31 A | 100% | 1999-01-01 | 1999-12-31 | 261d? | start no earlier than 1999-01-01 | S1 | 2088h | 2088h | Charging | R99 |
| 2440 | 582.2 | OAM Charging Management | 261d? | 1999-01-01 A | 1999-12-31 A | 100% | 1999-01-01 | 1999-12-31 | 261d? | start no earlier than 1999-01-01 | S5 | 2088h | 2088h | OAMCH, CH | R99 |
| 2441 | 583 | **Operations, Administration, Maintenance and Provisioning (OAM&P)** | 261d? | 1999-01-01 A | 1999-12-31 A | 100% | 1999-01-01 | 1999-12-31 | 261d? |  | S5 | 12528h | 12528h | OAM | R99 |
| 2442 | 583.1 | OAM Principles and High-level Requirements | 261d? | 1999-01-01 A | 1999-12-31 A | 100% | 1999-01-01 | 1999-12-31 | 261d? | start no earlier than 1999-01-01 | S5 | 2088h | 2088h | PR, Princs_&_Reqs_(PR) | R99 |
| 2443 | 583.2 | OAM Architecture | 261d? | 1999-01-01 A | 1999-12-31 A | 100% | 1999-01-01 | 1999-12-31 | 261d? | start no earlier than 1999-01-01 | S5 | 2088h | 2088h | OAMAR, AR, Telecom_Management_Arch_(AR) | R99 |
| 2444 | 583.3 | OAM Configuration Management | 261d? | 1999-01-01 A | 1999-12-31 A | 100% | 1999-01-01 | 1999-12-31 | 261d? | start no earlier than 1999-01-01 | S5 | 2088h | 2088h | OAMCM, CM | R99 |
| 2445 | 583.4 | OAM Fault Management | 261d? | 1999-01-01 A | 1999-12-31 A | 100% | 1999-01-01 | 1999-12-31 | 261d? | start no earlier than 1999-01-01 | S5 | 2088h | 2088h | OAMFM | R99 |
| 2446 | 583.5 | OAM Performance Management | 261d? | 1999-01-01 A | 1999-12-31 A | 100% | 1999-01-01 | 1999-12-31 | 261d? | start no earlier than 1999-01-01 | S5 | 2088h | 2088h | OAMPM, PM | R99 |
| 2447 | 584 | Vocabulary | 261d? | 1999-01-01 A | 1999-12-31 A | 100% | 1999-01-01 | 1999-12-31 | 261d? | start no earlier than 1999-01-01 | S1 | 2088h | 2088h | Vocabulary | R99 |
| 2448 | 585 | Emergency | 261d? | 1999-01-01 A | 1999-12-31 A | 100% | 1999-01-01 | 1999-12-31 | 261d? | start no earlier than 1999-01-01 | S1 | 2088h | 2088h | Emergency | R99 |
| 2449 | 586 | GSM General Bearer Services (GBS) and interworking scenarios support in UMTS | 261d? | 1999-01-01 A | 1999-12-31 A | 100% | 1999-01-01 | 1999-12-31 | 261d? | start no earlier than 1999-01-01 | S1 | 2088h | 2088h | GSM_to_UMTS_Evol | R99 |
| 2450 | 587 | GPRS_Mobile_IP_interworking | 261d? | 1999-01-01 A | 1999-12-31 A | 100% | 1999-01-01 | 1999-12-31 | 261d? | start no earlier than 1999-01-01 | N3 | 2088h | 2088h | GPRS_Mobile_IP_interworking | R99 |
| 2451 | 588 | GSM/UMTS interworking | 261d? | 1999-01-01 A | 1999-12-31 A | 100% | 1999-01-01 | 1999-12-31 | 261d? | start no earlier than 1999-01-01 | N1,N2,N4,R3,S1,SMG | 2088h | 2088h | 2G3Ginterworking | R99 |
| 2452 | 589 | Handover | 261d? | 1999-01-01 A | 1999-12-31 A | 100% | 1999-01-01 | 1999-12-31 | 261d? | start no earlier than 1999-01-01 | S1,SMG2,N1,N2,N4 | 2088h | 2088h | Handover | R99 |
| 2453 | 590 | 2G3Ghandover | 261d? | 1999-01-01 A | 1999-12-31 A | 100% | 1999-01-01 | 1999-12-31 | 261d? | start no earlier than 1999-01-01 | SMG2 | 2088h | 2088h | 2G3Ghandover | R99 |
| 2454 | 591 | Service Provider Name Indication | 261d? | 1999-01-01 A | 1999-12-31 A | 100% | 1999-01-01 | 1999-12-31 | 261d? | start no earlier than 1999-01-01 | S1 | 2088h | 2088h | SPANME | R99 |
| 2455 | 592 | Data & Data_CleanUp | 261d? | 1999-01-01 A | 1999-12-31 A | 100% | 1999-01-01 | 1999-12-31 | 261d? | start no earlier than 1999-01-01 | SMG1 | 2088h | 2088h | Data, Data_CleanUp | R99 |
| 2456 | 593 | Unstructured Supplementary Service Data | 261d? | 1999-01-01 A | 1999-12-31 A | 100% | 1999-01-01 | 1999-12-31 | 261d? | start no earlier than 1999-01-01 | SMG1,N4 | 2088h | 2088h | USSD | R99 |
| 2457 | 594 | Man-Machine Interface (MMI) of the User Equipment (UE) | 261d? | 1999-01-01 A | 1999-12-31 A | 100% | 1999-01-01 | 1999-12-31 | 261d? | start no earlier than 1999-01-01 | S1 | 2088h | 2088h | MMI | R99 |
| 2458 | 595 | Network Identity and Timezone (NITZ) | 261d? | 1999-01-01 A | 1999-12-31 A | 100% | 1999-01-01 | 1999-12-31 | 261d? | start no earlier than 1999-01-01 | SMG1,SMG3 | 2088h | 2088h | NITZ | R99 |
| 2459 | 596 | Operator Determined Barring for Packet Oriented Services | 261d? | 1999-01-01 A | 1999-12-31 A | 100% | 1999-01-01 | 1999-12-31 | 261d? | start no earlier than 1999-01-01 | S1 | 2088h | 2088h | ODB_Enh. | R99 |
| 2460 | 597 | Packet Flow Management | 261d? | 1999-01-01 A | 1999-12-31 A | 100% | 1999-01-01 | 1999-12-31 | 261d? | start no earlier than 1999-01-01 | SMG2 | 2088h | 2088h | Packet_Flow_Management | R99 |
| 2461 | 598 | GPRS_Point-To-Multipoint Group call | 261d? | 1999-01-01 A | 1999-12-31 A | 100% | 1999-01-01 | 1999-12-31 | 261d? | start no earlier than 1999-01-01 | SMG1 | 2088h | 2088h | GPRS_PTMG | R99 |

Notes:
- 2438: -
- 2439: WID SP-99271 Charging and accounting / Text3: 22.115, 23.121
- 2440: WID SP-99581 SA5 Year 2000 Work plan / Text3: 32.005, 32.015
- 2441: WID SP-99581 SA5 Year 2000 Work plan
- 2442: WID SP-99581 SA5 Year 2000 Work plan / Text3: 32.101
- 2443: WID SP-99581 SA5 Year 2000 Work plan / Text3: 32.101, 32.102
- 2444: WID SP-99273 Configuration management / Text3: 32.106, 32.106-1, 32.106-2, 32.106-3, 32.106-4, 32.106-5, 32.106-6, 32.106-7, 32.106-8
- 2445: WID SP-99272 Fault management / Text3: 32.111, 32.111-1, 32.111-2, 32.111-3, 32.111-4
- 2446: WID SP-99274 Performance management / Text3: 12.04, 32.104
- 2447: - / Text3: 21.905
- 2448: - / Text3: 22.101
- 2449: UMTS shall support GSM General Bearer Services (GBS) and interworking scenarios as specified in 02.02 / Text3: 22.105
- 2450: - / Text3: 29.061
- 2451: - / Text3: 03.22, 04.18, 04.60, 05.02, 05.08, 05.10, 08.08, 08.18, 08.58, 09.08, 22.011, 23.003, 23.009, 23.014, 23.034, 23.122, 24.007, 24.008, 24.011, 24.080, 29.108
- 2452: - / Text3: 04.18, 08.08, 08.58, 22.129, 23.009, 29.002, 29.010
- 2453: - / Text3: 04.18, 04.60, 05.02, 05.08, 05.10, 08.08, 29.010
- 2454: Service Provider Name Indication included in R98 (02.07) was not carried into R99 (22.101), but is in the SIM/USIM specification for R99 / Text3: 22.101
- 2455: - / Text3: 02.01, 02.02, 02.04, 02.34
- 2456: No additional features for R99. / Text3: 02.04, 02.90, 23.090, 29.002
- 2457: Data services streamlining + Support for Anonymous Call Rejection / Text3: 22.030
- 2458: - / Text3: 02.42, 04.08
- 2459: Remove ODB for Packet Oriented Services from R99 / Text3: 22.041
- 2460: - / Text3: 08.18
- 2461: - / Text3: 02.60

| ID | WBS | Task | Duration | Start | Finish | Complete | Baseline start | Baseline finish | Baseline duration | Constraint | Resources | Work | Actual work | Text6 | Text8 |
| --- | --- | --- | --- | --- | --- | --- | --- | --- | --- | --- | --- | --- | --- | --- | --- |
| 2462 | 599 | **Call Forwarding** | 261d? | 1999-01-01 A | 1999-12-31 A | 100% | 1999-01-01 | 1999-12-31 | 261d? |  | SMG1,N2,N4 | 8352h | 8352h | R99 |  |
| 2463 | 599.1 | Call Forwarding enhancements | 261d? | 1999-01-01 A | 1999-12-31 A | 100% | 1999-01-01 | 1999-12-31 | 261d? | start no earlier than 1999-01-01 | N4,N2 | 2088h | 2088h | R99 |  |
| 2464 | 599.2 | Call_Forwarding | 261d? | 1999-01-01 A | 1999-12-31 A | 100% | 1999-01-01 | 1999-12-31 | 261d? | start no earlier than 1999-01-01 | SMG1,N2 | 2088h | 2088h | R99 |  |
| 2465 | 599.3 | Call_Forwarding_Enhancements | 261d? | 1999-01-01 A | 1999-12-31 A | 100% | 1999-01-01 | 1999-12-31 | 261d? | start no earlier than 1999-01-01 | N4 | 2088h | 2088h | R99 |  |
| 2466 | 600 | **Quality of Service** | 261d? | 1999-01-01 A | 1999-12-31 A | 100% | 1999-01-01 | 1999-12-31 | 261d? |  | S2,T2,N1,N2,N4 | 10440h | 10440h | R99 |  |
| 2467 | 600.1 | End-to-end UMTS Quality of Service management | 261d? | 1999-01-01 A | 1999-12-31 A | 100% | 1999-01-01 | 1999-12-31 | 261d? | start no earlier than 1999-01-01 | S2,T2,N1,N2,N4 | 2088h | 2088h | R99 |  |
| 2468 | 600.2 | End-to-end QoS for PS Domain including IMS | 261d? | 1999-01-01 A | 1999-12-31 A | 100% | 1999-01-01 | 1999-12-31 | 261d? | start no earlier than 1999-01-01 | S2 | 2088h | 2088h | R99 |  |
| 2469 | 600.3 | GPRS-enhanced_QoS | 261d? | 1999-01-01 A | 1999-12-31 A | 100% | 1999-01-01 | 1999-12-31 | 261d? | start no earlier than 1999-01-01 | T2 | 2088h | 2088h | R99 |  |
| 2470 | 600.4 | QoS_enhancements | 261d? | 1999-01-01 A | 1999-12-31 A | 100% | 1999-01-01 | 1999-12-31 | 261d? | start no earlier than 1999-01-01 | N2,N1,N4 | 2088h | 2088h | R99 |  |
| 2471 | 601 | Support of Localised Service Area | 261d? | 1999-01-01 A | 1999-12-31 A | 100% | 1999-01-01 | 1999-12-31 | 261d? | start no earlier than 1999-01-01 | SMG2,SMG3,SMG7,N2 | 2088h | 2088h | R99 |  |
| 2472 | 602 | Transcoder_location | 261d? | 1999-01-01 A | 1999-12-31 A | 100% | 1999-01-01 | 1999-12-31 | 261d? | start no earlier than 1999-01-01 | S2 | 2088h | 2088h | R99 |  |
| 2473 | 603 | Antenna_test_methods | 261d? | 1999-01-01 A | 1999-12-31 A | 100% | 1999-01-01 | 1999-12-31 | 261d? | start no earlier than 1999-01-01 | SMG2 | 2088h | 2088h | R99 |  |
| 2474 | 604 | WBAMR / high quality speech in UMTS Phase 1 but not in R99 | 261d? | 1999-01-01 A | 1999-12-31 A | 100% | 1999-01-01 | 1999-12-31 | 261d? | start no earlier than 1999-01-01 | S1 | 2088h | 2088h | R99 |  |
| 2475 | 605 | **Codec** | 261d? | 1999-01-01 A | 1999-12-31 A | 100% | 1999-01-01 | 1999-12-31 | 261d? |  | S4 | 14616h | 14616h | R99 | Paolo |
| 2476 | 605.1 | Codec(s)_for_Multimedia_Telephony_Service | 261d? | 1999-01-01 A | 1999-12-31 A | 100% | 1999-01-01 | 1999-12-31 | 261d? | start no earlier than 1999-01-01 | S4 | 2088h | 2088h | R99 | Paolo |
| 2477 | 605.2 | QoS for Speech and Multimedia Codec | 261d? | 1999-01-01 A | 1999-12-31 A | 100% | 1999-01-01 | 1999-12-31 | 261d? | start no earlier than 1999-01-01 | S4 | 2088h | 2088h | R99 | Paolo |
| 2478 | 605.3 | Tandem Free Operation - Adaptive Multi-Rate codec types | 261d? | 1999-01-01 A | 1999-12-31 A | 100% | 1999-01-01 | 1999-12-31 | 261d? | start no earlier than 1999-01-01 | S4 | 2088h | 2088h | R99 | Paolo |
| 2479 | 605.4 | Noise Suppression for AMR | 261d? | 1999-01-01 A | 1999-12-31 A | 100% | 1999-01-01 | 1999-12-31 | 261d? | start no earlier than 1999-01-01 | S4 | 2088h | 2088h | R99 | Paolo |
| 2480 | 605.5 | Out-of-Band Transcoder | 261d? | 1999-01-01 A | 1999-12-31 A | 100% | 1999-01-01 | 1999-12-31 | 261d? | start no earlier than 1999-01-01 | N1 | 2088h | 2088h | R99 |  |
| 2481 | 605.6 | Out-of-Band Transcoder Control | 261d? | 1999-01-01 A | 1999-12-31 A | 100% | 1999-01-01 | 1999-12-31 | 261d? | start no earlier than 1999-01-01 | N1 | 2088h | 2088h | R99 |  |
| 2482 | 606 | Advanced Speech Call Items enhancements | 261d? | 1999-01-01 A | 1999-12-31 A | 100% | 1999-01-01 | 1999-12-31 | 261d? | start no earlier than 1999-01-01 | SMG1,SMG2,SMG3,SMG7,SMG9,N1,C1,N4,S1,T2 | 2088h | 2088h | R99 |  |
| 2483 | 607 | Call Control improvements | 261d? | 1999-01-01 A | 1999-12-31 A | 100% | 1999-01-01 | 1999-12-31 | 261d? | start no earlier than 1999-01-01 | N1 | 2088h | 2088h | R99 |  |
| 2484 | 608 | Multimedia | 261d? | 1999-01-01 A | 1999-12-31 A | 100% | 1999-01-01 | 1999-12-31 | 261d? | start no earlier than 1999-01-01 | N1,N3 | 2088h | 2088h | R99 |  |
| 2485 | 609 | Sub-System Number allocation for RANAP, RNSAP | 261d? | 1999-01-01 A | 1999-12-31 A | 100% | 1999-01-01 | 1999-12-31 | 261d? | start no earlier than 1999-01-01 | N2 | 2088h | 2088h | R99 |  |
| 2486 | 610 | Intranet / ISP access with DHCP end-to-end | 261d? | 1999-01-01 A | 1999-12-31 A | 100% | 1999-01-01 | 1999-12-31 | 261d? | start no earlier than 1999-01-01 | N3 | 2088h | 2088h | R99 |  |
| 2487 | 611 | Point_to_Multipoint_Services | 261d? | 1999-01-01 A | 1999-12-31 A | 100% | 1999-01-01 | 1999-12-31 | 261d? | start no earlier than 1999-01-01 | N3 | 2088h | 2088h | R99 |  |
| 2488 | 612 | Facsimile | 261d? | 1999-01-01 A | 1999-12-31 A | 100% | 1999-01-01 | 1999-12-31 | 261d? | start no earlier than 1999-01-01 | S1 | 2088h | 2088h | R99 |  |
| 2489 | 613 | Realtime_NT_FAX_in_UMTS | 261d? | 1999-01-01 A | 1999-12-31 A | 100% | 1999-01-01 | 1999-12-31 | 261d? | start no earlier than 1999-01-01 | N3 | 2088h | 2088h | R99 |  |
| 2490 | 614 | Gateway Location Register (GLR) - Mobile Application Part (MAP) specification | 261d? | 1999-01-01 A | 1999-12-31 A | 100% | 1999-01-01 | 1999-12-31 | 261d? | start no earlier than 1999-01-01 | N4 | 2088h | 2088h | R99 |  |
| 2491 | 615 | Multiple Subscriber Profile phase 2 | 261d? | 1999-01-01 A | 1999-12-31 A | 100% | 1999-01-01 | 1999-12-31 | 261d? | start no earlier than 1999-01-01 | S1,N4 | 2088h | 2088h | R99 |  |
| 2492 | 616 | Prepaging | 261d? | 1999-01-01 A | 1999-12-31 A | 100% | 1999-01-01 | 1999-12-31 | 261d? | start no earlier than 1999-01-01 | N2,N4 | 2088h | 2088h | R99 |  |
| 2493 | 617 | Downlink Advanced Receiver Performance | 261d? | 1999-01-01 A | 1999-12-31 A | 100% | 1999-01-01 | 1999-12-31 | 261d? | start no earlier than 1999-01-01 | SMG | 2088h | 2088h | R99 |  |
| 2494 | 618 | Harmonized Standard | 261d? | 1999-01-01 A | 1999-12-31 A | 100% | 1999-01-01 | 1999-12-31 | 261d? | start no earlier than 1999-01-01 | SMG2 | 2088h | 2088h | R99 |  |
| 2495 | 619 | Streamlining of specifications | 261d? | 1999-01-01 A | 1999-12-31 A | 100% | 1999-01-01 | 1999-12-31 | 261d? | start no earlier than 1999-01-01 | N3 | 2088h | 2088h | R99 |  |
| 2496 | 620 | R99_Service_Clean_up | 261d? | 1999-01-01 A | 1999-12-31 A | 100% | 1999-01-01 | 1999-12-31 | 261d? | start no earlier than 1999-01-01 | N3 | 2088h | 2088h | R99 |  |

Notes:
- 2462: -
- 2463: No additional features for R99. / Text1: CF_enhancements / Text3: 23.078, 23.079, 23.082, 29.002, 29.078
- 2464: - / Text1: Call_Forwarding / Text3: 02.82, 29.002
- 2465: - / Text1: Call_Forwarding_Enhancements / Text3: 23.082
- 2466: WID SMG 98-0781 End To End UMTS QoS Management
- 2467: WID SMG 98-0781 End To End UMTS QoS Management / Text1: QoS / Text3: 23.107, 23.907, 24.008
- 2468: - / Text1: E2EQoS / Text3: 23.060, 23.170
- 2469: AT-commands for Enhanced QoS Support management / Text1: GPRS-enhanced_QoS / Text3: 27.007
- 2470: - / Text1: QoS_enhancements / Text3: 23.008, 23.016, 24.008, 29.002, 29.060
- 2471: Mechanism which can be used as a platform for providing special tariffs and/or special set of service features for certain subscribers within a regionally restricted area or areas. No additional features for R99. / Text1: SoLSA / Text3: 04.08, 04.18, 08.08, 11.10-1, 29.002
- 2472: UE location identification: background information and associated primitives 2. Transcoder location at the core network and source depending coding belonging to the non-access stratum. / Text1: Transcoder_location / Text3: 23.110
- 2473: - / Text1: Antenna_test_methods / Text3: 03.30
- 2474: Add requirement for high quality speech in UMTS Phase 1 but not in R99 / Text1: WBAMR / Text3: 22.105
- 2475: -
- 2476: - / Text1: Multimedia_Codec, CSM, WI2MMC, Codec(s)_for_CS_MM_Tel._Serv, Codec(s)_for_MM_Tel_Service, Codec_for_Multimedia_Telephony / Text3: 26.911, 26.104, 26.111
- 2477: - / Text1: QoS_for_Speech_&_MM_Codecs_/_AMR / Text3: 26.102, 26.912
- 2478: UMTS_AMR2 is default Codec Type in R99 dual_mode terminals / Text1: TFOAMR / Text3: 26.103
- 2479: Combination of the AMR speech codec and the Noise Suppression function. TS 06.77 and TR 06.78 only apply to GSM. They apply to UMTS from Rel-4 onwards, when they were converted to TS 26.077 and TR 26.078. / Text1: AMRNS / Text3: 06.77, 06.78
- 2480: Transcoder handling in the CN at inter-system handover and relocation + Introduction of UMTS AMR / Text1: OoBT / Text3: 23.009, 24.008
- 2481: 24.008 CR#0572 in NP-020220 was approved under this WI / Text1: OoBTC / Text3: 24.008 CR#0572 in NP-020220
- 2482: - / Text1: ASCI / Text3: 02.30, 02.68, 03.68, 03.69, 04.18, 08.08, 11.10-1, 11.11, 23.067, 23.094, 24.008, 24.067, 27.007, 29.002
- 2483: Minor improvements to 24.007 and 24.008 to increase the number of simultaneous calls/sessions from the present 7: the TI value is increased (NP-99441). / Text1: CC_Related_items / Text3: 24.007, 24.008
- 2484: - / Text1: Multimedia / Text3: 24.008, 27.001, 29.007
- 2485: Sub-System Number allocation for Radio Access Network Application Part, Radio Network Subsystem Application Part / Text1: SSN_allocation / Text3: 23.003
- 2486: Access to an Intranet/ISP with DHCP end to end / Text1: ISPaccess / Text3: 29.061
- 2487: Support for the IP-Multicast protocol / Text1: Point_to_Multipoint_Services / Text3: 29.061
- 2488: - / Text1: FAX / Text3: 22.003, 22.100
- 2489: Asynchronous Interface for real-time NT Fax + Introduction of Asynchronous interface for Real-time non-transparent FAX / Text1: Realtime_NT_FAX_in_UMTS / Text3: 27.001, 27.003
- 2490: - / Text1: GLR / Text3: 29.120
- 2491: - / Text1: MSP2 / Text3: 22.097, 23.072, 23.083, 23.084, 23.091, 23.093, 23.097
- 2492: - / Text1: Prepaging / Text3: 23.018, 23.082, 29.002
- 2493: Re-definition of channel quality measure used for AMR link adaptation for DARP MS / Text3: 05.09
- 2494: - / Text1: HS / Text3: 13.21
- 2495: - / Text1: Streamlining / Text3: 27.060, 29.061
- 2496: - / Text1: R99_Service_Clean_up / Text3: 03.10, 27.001, 27.002, 27.003, 27.060, 29.007, 29.061

| ID | WBS | Task | Type | Duration | Start | Finish | Complete | Baseline start | Baseline finish | Baseline duration | Total slack | Constraint | Resources | Work | Actual work | Text1 | Text6 | Text3 | Text8 | Text12 |
| --- | --- | --- | --- | --- | --- | --- | --- | --- | --- | --- | --- | --- | --- | --- | --- | --- | --- | --- | --- | --- |
| 2497 | 621 | **small Technical Enhancements and Improvements for R99** |  | 261d? | 1999-01-01 A | 1999-12-31 A | 100% | 1999-01-01 | 1999-12-31 | 261d? |  |  | N3 | 6264h | 6264h | TEI | R99 |  |  |  |
| 2498 | 621.1 | TEI_[CS_Data] |  | 261d? | 1999-01-01 A | 1999-12-31 A | 100% | 1999-01-01 | 1999-12-31 | 261d? |  | start no earlier than 1999-01-01 | N3 | 2088h | 2088h | TEI_[CS_Data] | R99 |  |  |  |
| 2499 | 621.2 | TEI_[GPRS] |  | 261d? | 1999-01-01 A | 1999-12-31 A | 100% | 1999-01-01 | 1999-12-31 | 261d? |  | start no earlier than 1999-01-01 | N3 | 2088h | 2088h | TEI_[GPRS] | R99 |  |  |  |
| 2500 | 622 | **R99 UE Conformance Testing** |  | 261d? | 1999-01-01 A | 1999-12-31 A | 100% | 1999-01-01 | 1999-12-31 | 261d? |  |  | R5,T1 | 4176h | 4176h | TEI_Test | R99 | 34.108, 34.121, 34.122, 34.123-1, 34.123-2, 34.123-3 | Ingbert |  |
| 2501 | 622.1 | Deleted - RTEI |  | 261d? | 1999-01-01 A | 1999-12-31 A | 100% | 1999-01-01 | 1999-12-31 | 261d? |  | start no earlier than 1999-01-01 | T1 | 2088h | 2088h | RTEI | R99 | 34.123-1 CR#0650, 0651, 34.123-3 CR#0148, 0149, 0150 |  | TP-06 |
| 2502 | 622.2 | Common test environments for User Equipment (UE); Conformance testing | milestone | 0d? | 1999-01-01 A | 1999-01-01 A | 100% | 1999-01-01 | 1999-01-01 | 0d? |  | start no earlier than 1999-01-01 | R5,T1 |  |  | TEI_Test | R99 | 34.108 | Ingbert |  |
| 2503 | 622.3 | Terminal conformance specification, Radio transmission and reception (FDD) | milestone | 0d? | 1999-01-01 A | 1999-01-01 A | 100% | 1999-01-01 | 1999-01-01 | 0d? |  | start no earlier than 1999-01-01 | R5,T1 |  |  | TEI_Test | R99 | 34.121 | Ingbert |  |
| 2504 | 622.4 | Terminal conformance specification, Radio transmission and reception (TDD) | milestone | 0d? | 1999-01-01 A | 1999-01-01 A | 100% | 1999-01-01 | 1999-01-01 | 0d? |  | start no earlier than 1999-01-01 | R5,T1 |  |  | TEI_Test | R99 | 34.122 | Ingbert |  |
| 2505 | 622.5 | UE conformance specification; Part 1: Protocol conformance specification | milestone | 0d? | 1999-01-01 A | 1999-01-01 A | 100% | 1999-01-01 | 1999-01-01 | 0d? |  | start no earlier than 1999-01-01 | R5,T1 |  |  | TEI_Test | R99 | 34.123-1 | Ingbert |  |
| 2506 | 622.6 | UE conformance specification; Part 2: Implementation Conformance Statement (ICS) specification | milestone | 0d? | 1999-01-01 A | 1999-01-01 A | 100% | 1999-01-01 | 1999-01-01 | 0d? |  | start no earlier than 1999-01-01 | R5,T1 |  |  | TEI_Test | R99 | 34.123-2 | Ingbert |  |
| 2507 | 622.7 | UE conformance specification; Part 3: Abstract test suites (ATSs) | milestone | 0d? | 1999-01-01 A | 1999-01-01 A | 100% | 1999-01-01 | 1999-01-01 | 0d? |  | start no earlier than 1999-01-01 | R5,T1 |  |  | TEI_Test | R99 | 34.123-3 | Ingbert |  |
| 2508 | 623 | Deleted - Dual Tone Multi-Frequency signalling : Support in the whole 3GPP system |  | 261d? | 1999-01-01 A | 1999-12-31 A | 100% | 1999-01-01 | 1999-12-31 | 261d? |  | start no earlier than 1999-01-01 | N1 | 2088h | 2088h | DTMF | R99 | 23.014 CR#0004 |  | NP-06 |
| 2509 | 624 | Deleted - Intersystem_Change |  | 261d? | 1999-01-01 A | 1999-12-31 A | 100% | 1999-01-01 | 1999-12-31 | 261d? |  | start no earlier than 1999-01-01 | SMG | 2088h | 2088h | Intersystem_Change | R99 | 04.18 CR#A243 |  | SMG |
| 2510 | 625 | Deleted - Long_Forwardedto_Numbers |  | 261d? | 1999-01-01 A | 1999-12-31 A | 100% | 1999-01-01 | 1999-12-31 | 261d? |  | start no earlier than 1999-01-01 | N2 | 2088h | 2088h | Long_Forwardedto_Numbers | R99 | 29.002 |  | NP-06 |
| 2511 | 626 | Deleted - RANimp-FSEarlyUE |  | 261d? | 1999-01-01 A | 1999-12-31 A | 100% | 1999-01-01 | 1999-12-31 | 261d? |  | start no earlier than 1999-01-01 | R3 | 2088h | 2088h | RANimp-FSEarlyUE | R99 | 25.413 CR#0520, 0538, 0565, 0563, 0541, 0540, 0539, 0547 |  | RP-06 |
| 2512 | 627 | Release 1999 Studies |  | 1d? | 2000-01-03 | 2000-01-03 |  | 2000-01-03 | 2000-01-03 | 1d? | 3056d |  | S1,T2 | 8h |  |  | R99 |  |  |  |
| 2513 | 628 | Advanced Addressing/Numbering |  | 261d? | 1999-01-01 A | 1999-12-31 A | 100% | 1999-01-01 | 1999-12-31 | 261d? |  | start no earlier than 1999-01-01 | S1 | 2088h | 2088h | Numbering | R99 | 22.975 |  |  |
| 2514 | 629 | Combined GSM and Mobile IP mobility handling in UMTS IP CN |  | 261d? | 1999-01-01 A | 1999-12-31 A | 100% | 1999-01-01 | 1999-12-31 | 261d? |  | start no earlier than 1999-01-01 | S2 | 2088h | 2088h |  | R99 | 23.923 |  |  |
| 2515 | 630 | UE Capabilities Requirements |  | 261d? | 1999-01-01 A | 1999-12-31 A | 100% | 1999-01-01 | 1999-12-31 | 261d? |  | start no earlier than 1999-01-01 | T2 | 2088h | 2088h | UCR | R99 | 21.904 |  |  |
| 2516 | 631 | Electrical safety requirements and regulations |  | 261d? | 1999-01-01 A | 1999-12-31 A | 100% | 1999-01-01 | 1999-12-31 | 261d? |  | start no earlier than 1999-01-01 | T2 | 2088h | 2088h |  | R99 | 34.907 |  |  |
| 2517 | 632 | Specific Absorbtion Rate (SAR) requirements and regulations in different regions |  | 261d? | 1999-01-01 A | 1999-12-31 A | 100% | 1999-01-01 | 1999-12-31 | 261d? |  | start no earlier than 1999-01-01 | T2 | 2088h | 2088h |  | R99 | 34.925 |  |  |
| 2518 | 633 | Multi-mode UE issues |  | 261d? | 1999-01-01 A | 1999-12-31 A | 100% | 1999-01-01 | 1999-12-31 | 261d? |  | start no earlier than 1999-01-01 | T2 | 2088h | 2088h |  | R99 | 21.810, 21.910 |  |  |
| 2519 | 634 | Provision of fax service in GSM and UMTS |  | 261d? | 1999-01-01 A | 1999-12-31 A | 100% | 1999-01-01 | 1999-12-31 | 261d? |  | start no earlier than 1999-01-01 | T2 | 2088h | 2088h |  | R99 | 22.945 |  |  |
| 2520 | 635 | Separating Radio Resources and Mobility Management specific parts of the MS Classmark |  | 261d? | 1999-01-01 A | 1999-12-31 A | 100% | 1999-01-01 | 1999-12-31 | 261d? |  | start no earlier than 1999-01-01 | T2 | 2088h | 2088h |  | R99 | 23.814 |  |  |

Notes:
- 2497: -
- 2498: -
- 2499: -
- 2500: Specifies Conformance Tests for a 3G UE to be recognised as 3GPP-standard compliant. A 3GPP-external body, GCF (Global Certification Forum), delivers certificates to prove that a UE has correctly passed tests and is then conform to the 3GPP standard.
- 2501: No CR or new TS/TR approved under this WI
- 2502: -
- 2503: measurement procedures for the conformance test of the UE that contain transmitting characteristics, receiving characteristics and performance requirements in addition to requirements for support of RRM (Radio Resource Management) in FDD mode.
- 2504: measurement procedures for the conformance test of the UE that contain transmitting characteristics, receiving characteristics and performance requirements in addition to requirements for support of RRM (Radio Resource Management) in TDD mode.
- 2505: TS 34.123, composed of three parts, actually specifies the protocol conformance testing for the 3G UE. Part 1 describes the overall test structure.
- 2506: Part 2 contains the applicability of each test case defined as the Implementation Conformance Statement (ICS) proforma, in compliance with the relevant requirements, and in accordance with the relevant guidance given in ISO/IEC 9646-7 and ETS 300 406.
- 2507: Part 3 specifies the protocol conformance testing in TTCN for the 3G UE at the Uu interface. It defines the TTCN test specification and design considerations in Abstract Test Suites based on the test cases specified in prose in part 1.
- 2508: No CR or new TS/TR approved under this WI
- 2509: No CR or new TS/TR approved under this WI
- 2510: -
- 2511: No CR or new TS/TR approved under this WI
- 2512: -
- 2513: Study on requirements for numbering and addressing for UMTS
- 2514: -
- 2515: Moved to CT1 at TSG-T closure
- 2516: Moved to RAN4 at TSG-T closure. TR summarizes differences between international and national standards relevant to IEC60950 and refers to regulations for conformity assessment due to different regulatory environments in different countries / regions.
- 2517: Moved to RAN4 at TSG-T closure.
- 2518: Moved to CT1 at TSG-T closure. Consequences on roaming capabilities and service availability (e.g. handover) of multi-mode UEs while roaming in various regions with various network configurations. Case studies for each of the possible scenarios in specs
- 2519: CP#27: Moved to C1 on closure of T2; see TP-050062. CP#28: C1->C3
- 2520: CP#27: change of WG as a result of closure of CN and T.
